# PG031 Coleta e Tratamento de Esgoto e Destinação de Resíduos Sólidos

Schedule from MS Project, 2016-12-28 to 2026-02-11, status date 2019-04-30, A marks actual dates.

## Calendars

- Padrão_FR: Mon-Fri 09:00-12:00, 13:00-18:00; Sat-Sun off. Exceptions (off unless hours are given): 2019-01-01 (Ano-novo), 2019-03-04 to 2019-03-06 (Carnaval), 2019-04-18 (Quinta-feira santa (recesso)), 2019-04-19 (Sexta-feira Santa), 2019-04-21 (Tiradentes), 2019-05-01 (Trabalho), 2019-06-20 (Corpus Christi), 2019-08-15 (Assunção de Nossa Senhora), 2019-09-07 (Independência), 2019-10-12 (Nossa Senhora Aparecida), 2019-11-02 (Finados), 2019-11-15 (Proclamação da República), 2019-12-12 (Aniversário BH), 2019-12-24 (Véspera de Natal), 2019-12-25 (Natal), 2020-01-01 (Ano-novo), 2020-02-24 to 2020-02-26 (Carnaval), 2020-04-10 (Sexta-feira Santa), 2020-04-21 (Tiradentes), 2020-05-01 (Trabalho), 2020-06-11 (Corpus Christi), 2020-08-15 (Assunção de Nossa Senhora), 2020-09-07 (Independência), 2020-10-12 (Nossa Senhora Aparecida), 2020-11-02 (Finados), 2020-11-15 (Proclamação da República), 2020-12-12 (Aniversário BH), 2020-12-24 (Véspera de Natal), 2020-12-25 (Natal), 2021-01-01 (Ano-novo), 2021-02-15 to 2021-02-17 (Carnaval), 2021-04-02 (Sexta-feira Santa), 2021-04-21 (Tiradentes), 2021-05-01 (Trabalho), 2021-06-03 (Corpus Christi), 2021-08-15 (Assunção de Nossa Senhora), 2021-09-07 (Independência), 2021-10-12 (Nossa Senhora Aparecida), 2021-11-02 (Finados), 2021-11-15 (Programação da República), 2021-12-12 (Aniversário BH), 2021-12-24 (Véspera de Natal), 2021-12-25 (Natal), 2022-01-01 (Ano-novo), 2022-02-28 to 2022-03-02 (Carnaval), 2022-04-15 (Sexta-feira Santa), 2022-04-21 (Tiradentes), 2022-05-01 (Trabalho), 2022-06-16 (Corpus Christi), 2022-08-15 (Assunção de Nossa Senhora), 2022-09-07 (Independência), 2022-10-12 (Nossa Senhora Aparecida), 2022-11-02 (Finados), 2022-11-15 (Proclamação da República), 2022-12-12 (Aniversário BH), 2022-12-24 (Véspera de Natal), 2022-12-25 (Natal), 2023-01-01 (Ano-novo), 2023-02-20 to 2023-02-22 (Carnaval), 2023-04-07 (Sexta-feira Santa), 2023-04-21 (Tiradentes), 2023-05-01 (Trabalho), 2023-06-08 (Corpus Christ), 2023-08-15 (Assunção de Nossa Senhora), 2023-09-07 (Independência), 2023-10-12 (Nossa Senhora Aparecida), 2023-11-02 (Finados), 2023-11-15 (Proclamação da República), 2023-12-12 (Aniversário BH), 2023-12-24 (Véspera de Natal), 2023-12-25 (Natal), 2024-01-01 (Ano-novo), 2024-02-12 to 2024-02-14 (Carnaval), 2024-03-29 (Sexta-feira Santa), 2024-04-21 (Tiradentes), 2024-05-01 (Trabalho), 2024-05-30 (Corpus Christi), 2024-08-15 (Assunção de Nossa Senhora), 2024-09-07 (Independência), 2024-10-12 (Nossa Senhora Aparecida), 2024-11-02 (Finados), 2024-11-15 (Proclamação da República), 2024-12-12 (Aniversário BH), 2024-12-24 (Véspera Natal), 2024-12-25 (Natal), 2025-01-01 (Ano-novo), 2025-03-03 to 2025-03-05 (Carnaval), 2025-04-18 (Sexta-feira Santa), 2025-04-21 (Tiradentes), 2025-05-01 (Trabalho), 2025-06-19 (Corpus Christi), 2025-08-15 (Assunção de Nossa Senhora), 2025-09-07 (Independência), 2025-10-12 (Nossa Senhora Aparecida), 2025-11-02 (Finados), 2025-11-15 (Proclamação da República), 2025-12-12 (Aniversário BH), 2025-12-24 (Véspera de Natal), 2025-12-25 (Natal), 2026-01-01 (Ano-novo).

## Resources

| Resource |
| --- |
| 03 - Rio Doce2 |
| 41 - Linhares2 |
| 32 - Galiléia2 |
| 26 - Periquito2 |

## Schedule

| ID | WBS | Task | Type | Duration | Start | Finish | Predecessors | Complete | Remaining | Baseline start | Baseline finish | Baseline duration | Baseline 1 start | Baseline 1 finish | Total slack | Free slack | Constraint | Farol de Atraso | Farol Marcos | % Previsto Tempo | % Concluída Numérico | % Previsto Tempo Numérico | Índice de Desempenho Físico (IDF) | IDF Numérico | Farol IDF | % Previsto Ponderado | % Previsto Ponderado Numérico | % Concluído Ponderado | % Concluído Ponderado Numérico | Farol de Início | Código do Contrato | Responsável |
| --- | --- | --- | --- | --- | --- | --- | --- | --- | --- | --- | --- | --- | --- | --- | --- | --- | --- | --- | --- | --- | --- | --- | --- | --- | --- | --- | --- | --- | --- | --- | --- | --- |
| 1 | 1 | **Definição** |  | 2052d | 2016-12-28 A | 2025-02-24 |  | 99% | 0d | 2016-12-28 | 2025-02-24 | 2052d | 2017-03-20 | 2019-04-16 | 0d |  |  | Verde | Verde | 29% | 99 | 29 | 100% | 100 | Verde | 100% | 100 | 100% | 100 |  |  |  |
| 2 | 1.1 | **Atividade Interna Renova** |  | 2052d | 2016-12-28 A | 2025-02-24 |  |  | 2052d | 2016-12-28 | 2025-02-24 | 2052d |  |  | 0d |  |  | Verde | Verde | 29% |  | 29 | 0% |  | Vermelho | 0% |  | 0% |  |  |  |  |
| 3 | 1.1.1 | Atividade Interna Renova | milestone | 0d | 2025-02-24 | 2025-02-24 | 2965 |  |  | 2025-02-24 | 2025-02-24 | 0d | 2023-01-19 | 2023-01-19 | 0d |  |  | Verde | Verde | 0% |  |  | 0% |  | Verde | 0% |  | 0% |  | Verde |  |  |
| 4 | 1.1.2 | **Atividade Interna Renova** |  | 771d | 2016-12-28 A | 2019-12-30 |  |  | 771d | 2016-12-28 | 2019-12-30 | 771d | 2016-12-28 | 2019-12-30 | 1281d |  |  | Verde | Verde | 78% |  | 78 | 0% |  | Vermelho | 0% |  | 0% |  |  |  |  |
| 5 | 1.1.2.1 | Atividade Interna Renova | milestone | 0d | 2016-12-28 A | 2016-12-28 A |  | 100% |  | 2016-12-28 | 2016-12-28 | 0d | 2016-12-28 | 2017-02-02 |  |  | start no earlier than 2016-12-28 | Verde | Verde | 100% | 100 | 100 | 0% |  | Vermelho | 100% | 100 | 0% |  | Verde | PG 031 |  |
| 6 | 1.1.2.2 | Atividade Interna Renova | milestone | 0d | 2017-06-12 A | 2017-06-12 A | 5FS+85d | 100% |  | 2017-06-12 | 2017-06-12 | 0d | 2017-06-12 | 2017-06-12 |  |  | start no earlier than 2017-06-12 | Verde | Verde | 100% | 100 | 100 | 0% |  | Vermelho | 100% | 100 | 0% |  | Verde | PG 031 |  |
| 7 | 1.1.2.3 | Atividade Interna Renova | milestone | 0d | 2017-12-18 A | 2017-12-18 A | 6FS+136ed | 100% |  | 2017-12-18 | 2017-12-18 | 0d | 2017-12-18 | 2017-12-18 |  |  | start no earlier than 2017-12-18 | Verde | Verde | 100% | 100 | 100 | 0% |  | Vermelho | 100% | 100 | 0% |  | Verde | PG 031 |  |
| 8 | 1.1.2.4 | Atividade Interna Renova | milestone | 0d | 2019-06-28 | 2019-06-28 | 7FS+392d |  |  | 2019-06-28 | 2019-06-28 | 0d | 2019-06-28 | 2019-06-28 | 1281d | 0d |  | Verde | Verde | 0% |  |  | 0% |  | Verde | 0% |  | 0% |  | Verde | PG 031 |  |
| 9 | 1.1.2.5 | Atividade Interna Renova | milestone | 0d | 2019-12-30 | 2019-12-30 | 8FS+126d |  |  | 2019-12-30 | 2019-12-30 | 0d | 2019-12-30 | 2019-12-30 | 1281d | 0d |  | Verde | Verde | 0% |  |  | 0% |  | Verde | 0% |  | 0% |  | Verde |  |  |
| 10 | 1.1.2.6 | Atividade Interna Renova | milestone | 0d | 2019-12-30 | 2019-12-30 | 9 |  |  | 2019-12-30 | 2019-12-30 | 0d |  |  | 1281d |  |  | Verde | Verde | 0% |  |  | 0% |  | Verde | 0% |  | 0% |  | Verde |  |  |
| 11 | 1.1.3 | Atividade Interna Renova | milestone | 0d | 2025-02-24 | 2025-02-24 | 2965 |  |  | 2025-02-24 | 2025-02-24 | 0d |  |  | 0d |  |  | Verde | Verde | 0% |  |  | 0% |  | Verde | 0% |  | 0% |  | Verde |  |  |
| 12 | 1.2 | **Atividade Interna Renova** |  | 1223d | 2020-03-25 | 2025-02-24 |  |  |  | 2020-03-25 | 2025-02-24 | 1223d |  |  | 0d |  |  | Verde | Verde | 0% |  |  | 0% |  | Verde | 0% |  | 0% |  |  |  |  |
| 13 | 1.2.1 | Atividade Interna Renova | milestone | 0d | 2025-02-24 | 2025-02-24 | 288, 344, 365, 381, 391, 421, 424, 427, 531, 541, 619, 625, 631, 647, 663, 687, 697, 721, 731, 755, 1094, 1114, 1156, 1201, 1235, 1245, 1211, 1297, 1320, 1307, 1317, 1510, 1520, 1581, 1765, 1700, 1716, 1752, 1768, 1771, 1774, 1732, 1777, 1762, 1955, 1981, 1991, 2035, 2038, 2041, 2051, 2081, 2102, 2133, 2154, 2236, 2314, 2323, 2297, 2307, 2317, 2320, 2341, 2357, 2373, 2405, 2415, 2447, 2570, 2616, 2626, 2636, 2658, 2674, 2679, 2689, 2699, 2728, 2749, 2848, 2858, 2868, 594, 583, 789, 823, 857, 891, 975, 925, 943, 951, 765, 799, 833, 867, 901, 935, 985, 995, 1005, 1015, 1025, 1035, 1045, 1055, 1065, 83, 208, 2964 |  |  | 2025-02-24 | 2025-02-24 | 0d | 2023-01-20 | 2023-01-20 | 0d |  |  | Verde | Verde | 0% |  |  | 0% |  | Verde | 0% |  | 0% |  | Verde | PG 031 | 02 - Execução |
| 14 | 1.2.2 | Atividade Interna Renova | milestone | 0d | 2025-02-24 | 2025-02-24 | 1098, 1118, 1130, 1145, 1271, 1335, 1596, 2006, 2485, 2528, 2764, 2781, 2784 |  |  | 2025-02-24 | 2025-02-24 | 0d |  |  | 0d |  |  | Verde | Verde | 0% |  |  | 0% |  | Verde | 0% |  | 0% |  | Verde |  |  |
| 15 | 1.2.3 | Atividade Interna Renova | milestone | 0d | 2021-05-17 | 2021-05-17 | 1439, 1455, 1530, 1546 |  |  | 2021-05-17 | 2021-05-17 | 0d |  |  | 940d |  |  | Verde | Verde | 0% |  |  | 0% |  | Verde | 0% |  | 0% |  | Verde |  |  |
| 16 | 1.2.4 | Atividade Interna Renova | milestone | 0d | 2022-05-30 | 2022-05-30 | 438, 2581, 2812 |  |  | 2022-05-30 | 2022-05-30 | 0d |  |  | 681d |  |  | Verde | Verde | 0% |  |  | 0% |  | Verde | 0% |  | 0% |  | Verde |  |  |
| 17 | 1.2.5 | Atividade Interna Renova | milestone | 0d | 2021-11-16 | 2021-11-16 | 2504, 2515 |  |  | 2021-11-16 | 2021-11-16 | 0d |  |  | 814d |  |  | Verde | Verde | 0% |  |  | 0% |  | Verde | 0% |  | 0% |  | Verde |  |  |
| 18 | 1.2.6 | Atividade Interna Renova | milestone | 0d | 2021-12-28 | 2021-12-28 | 506, 610 |  |  | 2021-12-28 | 2021-12-28 | 0d |  |  | 785d |  |  | Verde | Verde | 0% |  |  | 0% |  | Verde | 0% |  | 0% |  | Verde |  |  |
| 19 | 1.2.7 | Atividade Interna Renova | milestone | 0d | 2024-04-08 | 2024-04-08 | 2909 |  |  | 2024-04-08 | 2024-04-08 | 0d |  |  | 222d |  |  | Verde | Verde | 0% |  |  | 0% |  | Verde | 0% |  | 0% |  | Verde |  |  |
| 20 | 1.2.8 | Atividade Interna Renova | milestone | 0d | 2020-03-25 | 2020-03-25 | 1934 |  |  | 2020-03-25 | 2020-03-25 | 0d |  |  | 1223d |  |  | Verde | Verde | 0% |  |  | 0% |  | Verde | 0% |  | 0% |  | Verde |  |  |
| 21 | 1.2.9 | Atividade Interna Renova | milestone | 0d | 2022-04-29 | 2022-04-29 | 1473, 1628, 1084, 1638, 1655, 1671, 1804, 1821, 1869, 1889, 1899, 1909, 1879, 1852, 1842, 2262, 2246, 2561, 1484, 1832 |  |  | 2022-04-29 | 2022-04-29 | 0d |  |  | 702d |  |  | Verde | Verde | 0% |  |  | 0% |  | Verde | 0% |  | 0% |  | Verde |  |  |
| 22 | 1.2.10 | Atividade Interna Renova | milestone | 0d | 2020-12-28 | 2020-12-28 | 247, 236, 2447 |  |  | 2020-12-28 | 2020-12-28 | 0d |  |  | 1034d |  |  | Verde | Verde | 0% |  |  | 0% |  | Verde | 0% |  | 0% |  | Verde |  |  |
| 23 | 1.3 | **Atividade Interna Renova** |  | 647d | 2017-03-20 A | 2019-09-23 |  | 99% | 0d | 2017-03-20 | 2019-09-23 | 647d |  |  | 1347d |  |  | Verde | Verde | 84% | 99 | 84 | 100% | 100 | Verde | 100% | 100 | 100% | 100 |  |  |  |
| 24 | 1.3.1 | **Atividade Interna Renova** |  | 65d | 2017-03-20 A | 2017-06-16 A |  | 100% |  | 2017-03-20 | 2017-06-16 | 65d | 2017-03-20 | 2017-06-16 |  |  |  | Verde | Verde | 100% | 100 | 100 | 100% | 100 | Verde | 100% | 100 | 100% | 100 |  |  |  |
| 25 | 1.3.1.1 | Atividade Interna Renova |  | 51d | 2017-03-20 A | 2017-05-29 A | 5FS+83ed | 100% |  | 2017-03-20 | 2017-05-29 | 51d | 2017-03-20 | 2017-05-29 |  |  | start no earlier than 2017-03-20 | Verde | Verde | 100% | 100 | 100 | 100% | 100 | Verde | 100% | 100 | 100% | 100 | Verde | PG 031 | 01 - Definição |
| 26 | 1.3.1.2 | Atividade Interna Renova |  | 55d | 2017-04-02 A | 2017-06-16 A | 25SS+13ed | 100% |  | 2017-04-02 | 2017-06-16 | 55d | 2017-04-02 | 2017-06-16 |  |  |  | Verde | Verde | 100% | 100 | 100 | 100% | 100 | Verde | 100% | 100 | 100% | 100 | Verde | PG 031 | 01 - Definição |
| 27 | 1.3.1.3 | Atividade Interna Renova |  | 43d | 2017-04-03 A | 2017-05-31 A | 26SS+1ed | 100% |  | 2017-04-03 | 2017-05-31 | 43d | 2017-04-03 | 2017-05-31 |  |  |  | Verde | Verde | 100% | 100 | 100 | 100% | 100 | Verde | 100% | 100 | 100% | 100 | Verde | PG 031 | 01 - Definição |
| 28 | 1.3.1.4 | Atividade Interna Renova |  | 39d | 2017-04-03 A | 2017-05-25 A | 26SS+1ed | 100% |  | 2017-04-03 | 2017-05-25 | 39d | 2017-04-03 | 2017-05-25 |  |  |  | Verde | Verde | 100% | 100 | 100 | 100% | 100 | Verde | 100% | 100 | 100% | 100 | Verde | PG 031 | 01 - Definição |
| 29 | 1.3.1.5 | Atividade Interna Renova |  | 17d | 2017-05-05 A | 2017-05-29 A | 28SS+32ed | 100% |  | 2017-05-05 | 2017-05-29 | 17d | 2017-05-05 | 2017-05-29 |  |  |  | Verde | Verde | 100% | 100 | 100 | 100% | 100 | Verde | 100% | 100 | 100% | 100 | Verde | PG 031 | 01 - Definição |
| 30 | 1.3.1.6 | Atividade Interna Renova | milestone | 0d | 2017-05-10 A | 2017-05-10 A | 25SS+51ed | 100% |  | 2017-05-10 | 2017-05-10 | 0d | 2017-05-10 | 2017-05-10 |  |  |  | Verde | Verde | 100% | 100 | 100 | 0% |  | Vermelho | 100% | 100 | 0% |  | Verde | PG 031 | 01 - Definição |
| 31 | 1.3.1.7 | Atividade Interna Renova | milestone | 0d | 2017-05-12 A | 2017-05-12 A | 25SS+53ed | 100% |  | 2017-05-12 | 2017-05-12 | 0d | 2017-05-12 | 2017-05-12 |  |  |  | Verde | Verde | 100% | 100 | 100 | 0% |  | Vermelho | 100% | 100 | 0% |  | Verde | PG 031 | 01 - Definição |
| 32 | 1.3.1.8 | Atividade Interna Renova |  | 6d | 2017-05-22 A | 2017-05-29 A | 25SS+63ed | 100% |  | 2017-05-22 | 2017-05-29 | 6d | 2017-05-22 | 2017-05-29 |  |  |  | Verde | Verde | 100% | 100 | 100 | 100% | 100 | Verde | 100% | 100 | 100% | 100 | Verde | PG 031 | 01 - Definição |
| 33 | 1.3.1.9 | Atividade Interna Renova |  | 3d | 2017-05-25 A | 2017-05-29 A | 32SS+3ed | 100% |  | 2017-05-25 | 2017-05-29 | 3d | 2017-05-25 | 2017-05-29 |  |  |  | Verde | Verde | 100% | 100 | 100 | 100% | 100 | Verde | 100% | 100 | 100% | 100 | Verde | PG 031 | 01 - Definição |
| 34 | 1.3.1.10 | Atividade Interna Renova |  | 3d | 2017-05-25 A | 2017-05-29 A | 25SS+66ed | 100% |  | 2017-05-25 | 2017-05-29 | 3d | 2017-05-25 | 2017-05-29 |  |  |  | Verde | Verde | 100% | 100 | 100 | 100% | 100 | Verde | 100% | 100 | 100% | 100 | Verde | PG 031 | 01 - Definição |
| 35 | 1.3.1.11 | Atividade Interna Renova | milestone | 0d | 2017-05-29 A | 2017-05-29 A | 29, 30, 31, 33, 34 | 100% |  | 2017-05-29 | 2017-05-29 | 0d | 2017-05-29 | 2017-05-29 |  |  |  | Verde | Verde | 100% | 100 | 100 | 0% |  | Vermelho | 100% | 100 | 0% |  | Verde | PG 031 | 01 - Definição |
| 36 | 1.3.1.12 | Atividade Interna Renova | milestone | 0d | 2017-05-31 A | 2017-05-31 A | 27SS+58ed, 35 | 100% |  | 2017-05-31 | 2017-05-31 | 0d | 2017-05-31 | 2017-05-31 |  |  |  | Verde | Verde | 100% | 100 | 100 | 0% |  | Vermelho | 100% | 100 | 0% |  | Verde | PG 031 | 01 - Definição |

| ID | WBS | Task | Type | Duration | Start | Finish | Predecessors | Complete | Baseline start | Baseline finish | Baseline duration | Baseline 1 start | Baseline 1 finish | Farol de Atraso | Farol Marcos | % Previsto Tempo | % Concluída Numérico | % Previsto Tempo Numérico | Índice de Desempenho Físico (IDF) | IDF Numérico | Farol IDF | % Previsto Ponderado | % Previsto Ponderado Numérico | % Concluído Ponderado | % Concluído Ponderado Numérico | Responsável | Código do Contrato | Farol de Início |
| --- | --- | --- | --- | --- | --- | --- | --- | --- | --- | --- | --- | --- | --- | --- | --- | --- | --- | --- | --- | --- | --- | --- | --- | --- | --- | --- | --- | --- |
| 37 | 1.3.2 | **Atividade Interna Renova** |  | 139d | 2017-06-15 A | 2017-12-26 A |  | 100% | 2017-06-15 | 2017-12-26 | 139d | 2017-06-15 | 2017-12-26 | Verde | Verde | 100% | 100 | 100 | 100% | 100 | Verde | 100% | 100 | 100% | 100 |  |  |  |
| 38 | 1.3.2.1 | Atividade Interna Renova |  | 8d | 2017-06-15 A | 2017-06-26 A | 26SS+74ed | 100% | 2017-06-15 | 2017-06-26 | 8d | 2017-06-15 | 2017-06-26 | Verde | Verde | 100% | 100 | 100 | 100% | 100 | Verde | 100% | 100 | 100% | 100 | 01 - Definição | PG 031 | Verde |
| 39 | 1.3.2.2 | Atividade Interna Renova |  | 7d | 2017-06-19 A | 2017-06-27 A | 32SS+28ed | 100% | 2017-06-19 | 2017-06-27 | 7d | 2017-06-19 | 2017-06-27 | Verde | Verde | 100% | 100 | 100 | 100% | 100 | Verde | 100% | 100 | 100% | 100 | 01 - Definição | PG 031 | Verde |
| 40 | 1.3.2.3 | Atividade Interna Renova | milestone | 0d | 2017-06-27 A | 2017-06-27 A | 38 | 100% | 2017-06-27 | 2017-06-27 | 0d | 2017-06-27 | 2017-06-27 | Verde | Verde | 100% | 100 | 100 | 0% |  | Vermelho | 100% | 100 | 0% |  | 01 - Definição | PG 031 | Verde |
| 41 | 1.3.2.4 | Atividade Interna Renova |  | 20d | 2017-06-27 A | 2017-07-24 A | 40SS | 100% | 2017-06-27 | 2017-07-24 | 20d | 2017-06-27 | 2017-07-24 | Verde | Verde | 100% | 100 | 100 | 100% | 100 | Verde | 100% | 100 | 100% | 100 | 01 - Definição | PG 031 | Verde |
| 42 | 1.3.2.5 | Atividade Interna Renova |  | 39d | 2017-06-27 A | 2017-08-18 A | 40SS | 100% | 2017-06-27 | 2017-08-18 | 39d | 2017-06-27 | 2017-08-18 | Verde | Verde | 100% | 100 | 100 | 100% | 100 | Verde | 100% | 100 | 100% | 100 | 01 - Definição | PG 031 | Verde |
| 43 | 1.3.2.6 | Atividade Interna Renova | milestone | 0d | 2017-07-24 A | 2017-07-24 A | 39, 41 | 100% | 2017-07-24 | 2017-07-24 | 0d | 2017-07-24 | 2017-07-24 | Verde | Verde | 100% | 100 | 100 | 0% |  | Vermelho | 100% | 100 | 0% |  | 01 - Definição | PG 031 | Verde |
| 44 | 1.3.2.7 | Atividade Interna Renova | milestone | 0d | 2017-07-26 A | 2017-07-26 A | 43FS+2ed | 100% | 2017-07-26 | 2017-07-26 | 0d | 2017-07-26 | 2017-07-26 | Verde | Verde | 100% | 100 | 100 | 0% |  | Vermelho | 100% | 100 | 0% |  | 01 - Definição | PG 031 | Verde |
| 45 | 1.3.2.8 | Atividade Interna Renova |  | 3d | 2017-08-17 A | 2017-08-21 A | 44FS+22ed | 100% | 2017-08-17 | 2017-08-21 | 3d | 2017-08-17 | 2017-08-21 | Verde | Verde | 100% | 100 | 100 | 100% | 100 | Verde | 100% | 100 | 100% | 100 | 01 - Definição | PG 031 | Verde |
| 46 | 1.3.2.9 | Atividade Interna Renova |  | 5d | 2017-08-18 A | 2017-08-24 A | 42 | 100% | 2017-08-18 | 2017-08-24 | 5d | 2017-08-18 | 2017-08-24 | Verde | Verde | 100% | 100 | 100 | 100% | 100 | Verde | 100% | 100 | 100% | 100 | 01 - Definição | PG 031 | Verde |
| 47 | 1.3.2.10 | Atividade Interna Renova |  | 2d | 2017-08-21 A | 2017-08-22 A | 45 | 100% | 2017-08-21 | 2017-08-22 | 2d | 2017-08-21 | 2017-08-22 | Verde | Verde | 100% | 100 | 100 | 100% | 100 | Verde | 100% | 100 | 100% | 100 | 01 - Definição | PG 031 | Verde |
| 48 | 1.3.2.11 | Atividade Interna Renova |  | 5d | 2017-08-18 A | 2017-08-24 A | 42 | 100% | 2017-08-18 | 2017-08-24 | 5d | 2017-08-18 | 2017-08-24 | Verde | Verde | 100% | 100 | 100 | 100% | 100 | Verde | 100% | 100 | 100% | 100 | 01 - Definição | PG 031 | Verde |
| 49 | 1.3.2.12 | Atividade Interna Renova |  | 45d | 2017-08-22 A | 2017-10-23 A | 47 | 100% | 2017-08-22 | 2017-10-23 | 45d | 2017-08-22 | 2017-10-21 | Verde | Verde | 100% | 100 | 100 | 100% | 100 | Verde | 100% | 100 | 100% | 100 | 01 - Definição | PG 031 | Verde |
| 50 | 1.3.2.13 | Atividade Interna Renova | milestone | 0d | 2017-08-25 A | 2017-08-25 A | 46FS+1ed, 48FS+1ed | 100% | 2017-08-25 | 2017-08-25 | 0d | 2017-08-25 | 2017-08-25 | Verde | Verde | 100% | 100 | 100 | 0% |  | Vermelho | 100% | 100 | 0% |  | 01 - Definição | PG 031 | Verde |
| 51 | 1.3.2.14 | Atividade Interna Renova |  | 83d | 2017-09-01 A | 2017-12-26 A | 50FS+7ed | 100% | 2017-09-01 | 2017-12-26 | 83d | 2017-09-01 | 2017-12-26 | Verde | Verde | 100% | 100 | 100 | 100% | 100 | Verde | 100% | 100 | 100% | 100 | 01 - Definição | PG 031 | Verde |
| 52 | 1.3.2.15 | Atividade Interna Renova | milestone | 0d | 2017-09-21 A | 2017-09-21 A | 51SS+20ed | 100% | 2017-09-21 | 2017-09-21 | 0d | 2017-09-21 | 2017-09-21 | Verde | Verde | 100% | 100 | 100 | 0% |  | Vermelho | 100% | 100 | 0% |  | 01 - Definição | PG 031 | Verde |
| 53 | 1.3.2.16 | Atividade Interna Renova |  | 6d | 2017-09-29 A | 2017-10-06 A | 50FS+35ed | 100% | 2017-09-29 | 2017-10-06 | 6d | 2017-09-29 | 2017-10-06 | Verde | Verde | 100% | 100 | 100 | 100% | 100 | Verde | 100% | 100 | 100% | 100 | 01 - Definição | PG 031 | Verde |
| 54 | 1.3.2.17 | Atividade Interna Renova | milestone | 0d | 2017-10-06 A | 2017-10-06 A | 53 | 100% | 2017-10-06 | 2017-10-06 | 0d | 2017-10-06 | 2017-10-06 | Verde | Verde | 100% | 100 | 100 | 0% |  | Vermelho | 100% | 100 | 0% |  | 01 - Definição | PG 031 | Verde |
| 55 | 1.3.3 | **Atividade Interna Renova** |  | 57d | 2017-10-01 A | 2017-12-19 A |  | 100% | 2017-10-01 | 2017-12-19 | 57d | 2017-10-01 | 2017-12-19 | Verde | Verde | 100% | 100 | 100 | 100% | 100 | Verde | 100% | 100 | 100% | 100 |  |  |  |
| 56 | 1.3.3.1 | Atividade Interna Renova |  | 35d | 2017-10-01 A | 2017-11-17 A | 53SS+1ed | 100% | 2017-10-01 | 2017-11-17 | 35d | 2017-10-01 | 2017-11-17 | Verde | Verde | 100% | 100 | 100 | 100% | 100 | Verde | 100% | 100 | 100% | 100 | 01 - Definição | PG 031 | Verde |
| 57 | 1.3.3.2 | Atividade Interna Renova |  | 35d | 2017-10-01 A | 2017-11-17 A | 56SS | 100% | 2017-10-01 | 2017-11-17 | 35d | 2017-10-01 | 2017-11-17 | Verde | Verde | 100% | 100 | 100 | 100% | 100 | Verde | 100% | 100 | 100% | 100 | 01 - Definição | PG 031 | Verde |
| 58 | 1.3.3.3 | Atividade Interna Renova |  | 35d | 2017-10-01 A | 2017-11-17 A | 36, 56SS, 57SS | 100% | 2017-10-01 | 2017-11-17 | 35d | 2017-10-01 | 2017-11-17 | Verde | Verde | 100% | 100 | 100 | 100% | 100 | Verde | 100% | 100 | 100% | 100 | 01 - Definição | PG 031 | Verde |
| 59 | 1.3.3.4 | Atividade Interna Renova |  | 7d | 2017-10-06 A | 2017-10-16 A | 53 | 100% | 2017-10-06 | 2017-10-16 | 7d | 2017-10-06 | 2017-10-16 | Verde | Verde | 100% | 100 | 100 | 100% | 100 | Verde | 100% | 100 | 100% | 100 | 01 - Definição | PG 031 | Verde |
| 60 | 1.3.3.5 | Atividade Interna Renova |  | 7d | 2017-10-06 A | 2017-10-16 A | 53, 54 | 100% | 2017-10-06 | 2017-10-16 | 7d | 2017-10-06 | 2017-10-16 | Verde | Verde | 100% | 100 | 100 | 100% | 100 | Verde | 100% | 100 | 100% | 100 | 01 - Definição | PG 031 | Verde |
| 61 | 1.3.3.6 | Atividade Interna Renova |  | 6d | 2017-10-16 A | 2017-10-23 A | 60 | 100% | 2017-10-16 | 2017-10-23 | 6d | 2017-10-16 | 2017-10-21 | Verde | Verde | 100% | 100 | 100 | 100% | 100 | Verde | 100% | 100 | 100% | 100 | 01 - Definição | PG 031 | Verde |
| 62 | 1.3.3.7 | Atividade Interna Renova |  | 5d | 2017-10-21 A | 2017-10-27 A | 52FS+8d, 59, 61 | 100% | 2017-10-21 | 2017-10-27 | 5d | 2017-10-21 | 2017-10-27 | Verde | Verde | 100% | 100 | 100 | 100% | 100 | Verde | 100% | 100 | 100% | 100 | 01 - Definição | PG 031 | Verde |
| 63 | 1.3.3.8 | Atividade Interna Renova | milestone | 0d | 2017-10-27 A | 2017-10-27 A | 49, 62 | 100% | 2017-10-27 | 2017-10-27 | 0d | 2017-10-27 | 2017-10-27 | Verde | Verde | 100% | 100 | 100 | 0% |  | Vermelho | 100% | 100 | 0% |  | 01 - Definição | PG 031 | Verde |
| 64 | 1.3.3.9 | Atividade Interna Renova | milestone | 0d | 2017-11-20 A | 2017-11-20 A | 63FS+24ed | 100% | 2017-11-20 | 2017-11-20 | 0d | 2017-11-20 | 2017-11-20 | Verde | Verde | 100% | 100 | 100 | 0% |  | Vermelho | 100% | 100 | 0% |  | 01 - Definição | PG 031 | Verde |
| 65 | 1.3.3.10 | Atividade Interna Renova |  | 6d | 2017-11-17 A | 2017-11-24 A | 58 | 100% | 2017-11-17 | 2017-11-24 | 6d | 2017-11-17 | 2017-11-24 | Verde | Verde | 100% | 100 | 100 | 100% | 100 | Verde | 100% | 100 | 100% | 100 | 01 - Definição | PG 031 | Verde |
| 66 | 1.3.3.11 | Atividade Interna Renova |  | 18d | 2017-11-24 A | 2017-12-19 A | 64, 65 | 100% | 2017-11-24 | 2017-12-19 | 18d | 2017-11-24 | 2017-12-19 | Verde | Verde | 100% | 100 | 100 | 100% | 100 | Verde | 100% | 100 | 100% | 100 | 01 - Definição | PG 031 | Verde |

| ID | WBS | Task | Type | Duration | Start | Finish | Predecessors | Complete | Remaining | Baseline start | Baseline finish | Baseline duration | Baseline 1 start | Baseline 1 finish | Total slack | Farol de Atraso | Farol Marcos | % Previsto Tempo | % Concluída Numérico | % Previsto Tempo Numérico | Índice de Desempenho Físico (IDF) | IDF Numérico | Farol IDF | % Previsto Ponderado | % Previsto Ponderado Numérico | % Concluído Ponderado | % Concluído Ponderado Numérico | Responsável | Código do Contrato | Farol de Início | Áreas de Suporte |
| --- | --- | --- | --- | --- | --- | --- | --- | --- | --- | --- | --- | --- | --- | --- | --- | --- | --- | --- | --- | --- | --- | --- | --- | --- | --- | --- | --- | --- | --- | --- | --- |
| 67 | 1.3.4 | **Atividade Interna Renova** |  | 181d | 2019-01-02 A | 2019-09-23 |  | 99% | 0d | 2019-01-02 | 2019-09-23 | 181d | 2017-12-22 | 2019-04-16 | 1347d | Verde | Verde | 44% | 99 | 44 | 100% | 100 | Verde | 100% | 100 | 100% | 100 |  |  |  |  |
| 68 | 1.3.4.1 | Atividade Interna Renova |  | 1d | 2019-01-02 A | 2019-01-02 A | 66FS+3ed | 100% |  | 2019-01-02 | 2019-01-02 | 1d | 2017-12-22 | 2017-12-22 |  | Verde | Verde | 100% | 100 | 100 | 100% | 100 | Verde | 100% | 100 | 100% | 100 | 01 - Definição | PG 031 | Verde |  |
| 69 | 1.3.4.2 | Atividade Interna Renova | milestone | 0d | 2019-09-23 | 2019-09-23 | 68FS+180d |  |  | 2019-09-23 | 2019-09-23 | 0d | 2019-04-16 | 2019-04-16 | 1347d | Verde | Verde | 0% |  |  | 0% |  | Verde | 0% |  | 0% |  | 01 - Definição | PG 031 | Verde |  |
| 70 | 2 | **Execução** |  | 1885d | 2017-08-18 A | 2025-02-24 |  | 16% | 1586.44d | 2017-08-18 | 2025-02-24 | 1885d | 2017-08-18 | 2023-01-20 | 240d | Verde | Verde | 23% | 16 | 23 | 97% | 97 | Vermelho | 30% | 30 | 29% | 29 |  |  |  |  |
| 71 | 2.1 | **Atividade Interna Renova** |  | 1885d | 2017-08-18 A | 2025-02-24 |  | 99% | 0d | 2017-08-18 | 2025-02-24 | 1885d | 2017-08-18 | 2023-01-19 | 0d | Verde | Verde | 23% | 99 | 23 | 100% | 100 | Verde | 100% | 100 | 100% | 100 |  |  |  |  |
| 72 | 2.1.1 | **Atividade Interna Renova** |  | 104d | 2017-08-18 A | 2018-01-10 A |  | 100% |  | 2017-08-18 | 2018-01-10 | 104d | 2017-08-18 | 2018-01-10 |  | Verde | Verde | 100% | 100 | 100 | 100% | 100 | Verde | 100% | 100 | 100% | 100 |  |  |  |  |
| 73 | 2.1.1.1 | Atividade Interna Renova |  | 2d | 2017-08-18 A | 2017-08-21 A | 42 | 100% |  | 2017-08-18 | 2017-08-21 | 2d | 2017-08-18 | 2017-08-21 |  | Verde | Verde | 100% | 100 | 100 | 100% | 100 | Verde | 100% | 100 | 100% | 100 | 02 - Execução | PG 031 | Verde | ܁3 |
| 74 | 2.1.1.2 | Atividade Interna Renova |  | 1d | 2017-09-11 A | 2017-09-11 A | 50FS+17ed, 73FS+21ed | 100% |  | 2017-09-11 | 2017-09-11 | 1d | 2017-09-11 | 2017-09-11 |  | Verde | Verde | 100% | 100 | 100 | 100% | 100 | Verde | 100% | 100 | 100% | 100 | 02 - Execução | PG 031 | Verde | ܁3 |
| 75 | 2.1.1.3 | Atividade Interna Renova |  | 35d | 2017-09-11 A | 2017-10-30 A | 74 | 100% |  | 2017-09-11 | 2017-10-30 | 35d | 2017-09-11 | 2017-10-30 |  | Verde | Verde | 100% | 100 | 100 | 100% | 100 | Verde | 100% | 100 | 100% | 100 | 02 - Execução | PG 031 | Verde | ܁3 |
| 76 | 2.1.1.4 | Atividade Interna Renova |  | 52d | 2017-10-30 A | 2018-01-10 A | 75 | 100% |  | 2017-10-30 | 2018-01-10 | 52d | 2017-10-30 | 2018-01-10 |  | Verde | Verde | 100% | 100 | 100 | 100% | 100 | Verde | 100% | 100 | 100% | 100 | 02 - Execução | PG 031 | Verde | ܁3 |
| 77 | 2.1.1.5 | Atividade Interna Renova | milestone | 0d | 2018-01-10 A | 2018-01-10 A | 76 | 100% |  | 2018-01-10 | 2018-01-10 | 0d | 2018-01-10 | 2018-01-10 |  | Verde | Verde | 100% | 100 | 100 | 0% |  | Vermelho | 100% | 100 | 0% |  | 02 - Execução | PG 031 | Verde | ܁3 |
| 78 | 2.1.2 | **Atividade Interna Renova** |  | 251d | 2018-02-20 A | 2019-02-06 A |  | 100% |  | 2018-02-20 | 2019-02-06 | 251d | 2018-02-20 | 2019-02-19 |  | Verde | Verde | 100% | 100 | 100 | 100% | 100 | Verde | 100% | 100 | 100% | 100 |  |  |  |  |
| 79 | 2.1.2.1 | Atividade Interna Renova | milestone | 0d | 2018-02-20 A | 2018-02-20 A | 76FS+41ed, 77FS+40ed | 100% |  | 2018-02-20 | 2018-02-20 | 0d | 2018-02-20 | 2018-02-20 |  | Verde | Verde | 100% | 100 | 100 | 0% |  | Vermelho | 100% | 100 | 0% |  | 02 - Execução | PG 031 | Verde |  |
| 80 | 2.1.2.2 | Atividade Interna Renova |  | 14d | 2018-02-20 A | 2018-03-09 A | 79 | 100% |  | 2018-02-20 | 2018-03-09 | 14d | 2018-02-20 | 2018-03-09 |  | Verde | Verde | 100% | 100 | 100 | 100% | 100 | Verde | 100% | 100 | 100% | 100 | 02 - Execução | PG 031 | Verde |  |
| 81 | 2.1.2.3 | Atividade Interna Renova |  | 204d | 2018-04-05 A | 2019-02-06 A | 80FS+27ed | 100% |  | 2018-04-05 | 2019-02-06 | 204d | 2018-04-05 | 2019-02-19 |  | Verde | Verde | 100% | 100 | 100 | 100% | 100 | Verde | 100% | 100 | 100% | 100 | 02 - Execução | PG 031 | Verde |  |
| 82 | 2.1.2.4 | Atividade Interna Renova | milestone | 0d | 2019-02-06 A | 2019-02-06 A | 81 | 100% |  | 2019-02-06 | 2019-02-06 | 0d |  |  |  | Verde | Verde | 100% | 100 | 100 | 0% |  | Vermelho | 100% | 100 | 0% |  |  |  | Verde |  |
| 83 | 2.1.3 | Atividade Interna Renova | milestone | 0d | 2025-02-24 | 2025-02-24 | 82, 2910 |  |  | 2025-02-24 | 2025-02-24 | 0d |  |  | 0d | Verde | Verde | 0% |  |  | 0% |  | Verde | 0% |  | 0% |  |  |  | Verde |  |
| 84 | 2.2 | **Atividade Interna Renova** |  | 1870d | 2017-09-08 A | 2025-02-24 |  | 90% | 192.59d | 2017-09-08 | 2025-02-24 | 1870d | 2017-09-08 | 2023-01-20 | 240d | Verde | Verde | 22% | 90 | 22 | 100% | 100 | Verde | 95% | 95 | 95% | 95 |  |  |  |  |
| 85 | 2.2.1 | **Atividade Interna Renova** |  | 74d | 2017-09-08 A | 2017-12-20 A |  | 100% |  | 2017-09-08 | 2017-12-20 | 74d | 2017-09-08 | 2017-12-20 |  | Verde | Verde | 100% | 100 | 100 | 100% | 100 | Verde | 100% | 100 | 100% | 100 |  |  |  |  |
| 86 | 2.2.1.1 | Atividade Interna Renova |  | 65d | 2017-09-08 A | 2017-12-07 A | 51SS+7ed | 100% |  | 2017-09-08 | 2017-12-07 | 65d | 2017-09-08 | 2017-12-07 |  | Verde | Verde | 100% | 100 | 100 | 100% | 100 | Verde | 100% | 100 | 100% | 100 | 02 - Execução | PG 031 | Verde |  |
| 87 | 2.2.1.2 | Atividade Interna Renova | milestone | 0d | 2017-12-15 A | 2017-12-15 A | 86FS+8ed | 100% |  | 2017-12-15 | 2017-12-15 | 0d | 2017-12-15 | 2017-12-15 |  | Verde | Verde | 100% | 100 | 100 | 0% |  | Vermelho | 100% | 100 | 0% |  | 02 - Execução | PG 031 | Verde |  |
| 88 | 2.2.1.3 | **Atividade Interna Renova** |  | 61d | 2017-09-27 A | 2017-12-20 A |  | 100% |  | 2017-09-27 | 2017-12-20 | 61d | 2017-09-27 | 2017-12-20 |  | Verde | Verde | 100% | 100 | 100 | 100% | 100 | Verde | 100% | 100 | 100% | 100 |  |  |  |  |
| 89 | 2.2.1.3.1 | **Atividade Interna Renova** |  | 61d | 2017-09-27 A | 2017-12-20 A |  | 100% |  | 2017-09-27 | 2017-12-20 | 61d | 2017-09-27 | 2017-12-20 |  | Verde | Verde | 100% | 100 | 100 | 100% | 100 | Verde | 100% | 100 | 100% | 100 |  |  |  |  |
| 90 | 2.2.1.3.1.1 | Atividade Interna Renova |  | 1d | 2017-09-27 A | 2017-09-27 A | 86SS+19ed | 100% |  | 2017-09-27 | 2017-09-27 | 1d | 2017-09-27 | 2017-09-27 |  | Verde | Verde | 100% | 100 | 100 | 100% | 100 | Verde | 100% | 100 | 100% | 100 | 02 - Execução | PG 031 | Verde |  |
| 91 | 2.2.1.3.1.2 | Atividade Interna Renova |  | 1d | 2017-10-02 A | 2017-10-02 A | 86SS+23ed | 100% |  | 2017-10-02 | 2017-10-02 | 1d | 2017-10-02 | 2017-10-02 |  | Verde | Verde | 100% | 100 | 100 | 100% | 100 | Verde | 100% | 100 | 100% | 100 | 02 - Execução | PG 031 | Verde |  |
| 92 | 2.2.1.3.1.3 | Atividade Interna Renova |  | 1d | 2017-10-03 A | 2017-10-03 A | 86SS+25ed | 100% |  | 2017-10-03 | 2017-10-03 | 1d | 2017-10-03 | 2017-10-03 |  | Verde | Verde | 100% | 100 | 100 | 100% | 100 | Verde | 100% | 100 | 100% | 100 | 02 - Execução | PG 031 | Verde |  |
| 93 | 2.2.1.3.1.4 | Atividade Interna Renova |  | 1d | 2017-10-03 A | 2017-10-03 A | 86SS+25ed | 100% |  | 2017-10-03 | 2017-10-03 | 1d | 2017-10-03 | 2017-10-03 |  | Verde | Verde | 100% | 100 | 100 | 100% | 100 | Verde | 100% | 100 | 100% | 100 | 02 - Execução | PG 031 | Verde |  |
| 94 | 2.2.1.3.1.5 | Atividade Interna Renova |  | 1d | 2017-10-04 A | 2017-10-04 A | 86SS+26ed | 100% |  | 2017-10-04 | 2017-10-04 | 1d | 2017-10-04 | 2017-10-04 |  | Verde | Verde | 100% | 100 | 100 | 100% | 100 | Verde | 100% | 100 | 100% | 100 | 02 - Execução | PG 031 | Verde |  |
| 95 | 2.2.1.3.1.6 | Atividade Interna Renova |  | 1d | 2017-10-04 A | 2017-10-04 A | 86SS+26ed | 100% |  | 2017-10-04 | 2017-10-04 | 1d | 2017-10-04 | 2017-10-04 |  | Verde | Verde | 100% | 100 | 100 | 100% | 100 | Verde | 100% | 100 | 100% | 100 | 02 - Execução | PG 031 | Verde |  |
| 96 | 2.2.1.3.1.7 | Atividade Interna Renova |  | 1d | 2017-10-05 A | 2017-10-05 A | 86SS+27ed | 100% |  | 2017-10-05 | 2017-10-05 | 1d | 2017-10-05 | 2017-10-05 |  | Verde | Verde | 100% | 100 | 100 | 100% | 100 | Verde | 100% | 100 | 100% | 100 | 02 - Execução | PG 031 | Verde |  |
| 97 | 2.2.1.3.1.8 | Atividade Interna Renova |  | 1d | 2017-10-05 A | 2017-10-05 A | 86SS+27ed | 100% |  | 2017-10-05 | 2017-10-05 | 1d | 2017-10-05 | 2017-10-05 |  | Verde | Verde | 100% | 100 | 100 | 100% | 100 | Verde | 100% | 100 | 100% | 100 | 02 - Execução | PG 031 | Verde |  |
| 98 | 2.2.1.3.1.9 | Atividade Interna Renova |  | 1d | 2017-10-09 A | 2017-10-09 A | 86SS+31ed | 100% |  | 2017-10-09 | 2017-10-09 | 1d | 2017-10-09 | 2017-10-09 |  | Verde | Verde | 100% | 100 | 100 | 100% | 100 | Verde | 100% | 100 | 100% | 100 | 02 - Execução | PG 031 | Verde |  |
| 99 | 2.2.1.3.1.10 | Atividade Interna Renova |  | 1d | 2017-10-10 A | 2017-10-10 A | 86SS+32ed | 100% |  | 2017-10-10 | 2017-10-10 | 1d | 2017-10-10 | 2017-10-10 |  | Verde | Verde | 100% | 100 | 100 | 100% | 100 | Verde | 100% | 100 | 100% | 100 | 02 - Execução | PG 031 | Verde |  |
| 100 | 2.2.1.3.1.11 | Atividade Interna Renova |  | 1d | 2017-10-11 A | 2017-10-11 A | 86SS+33ed | 100% |  | 2017-10-11 | 2017-10-11 | 1d | 2017-10-11 | 2017-10-11 |  | Verde | Verde | 100% | 100 | 100 | 100% | 100 | Verde | 100% | 100 | 100% | 100 | 02 - Execução | PG 031 | Verde |  |
| 101 | 2.2.1.3.1.12 | Atividade Interna Renova |  | 1d | 2017-10-16 A | 2017-10-16 A | 86SS+38ed | 100% |  | 2017-10-16 | 2017-10-16 | 1d | 2017-10-16 | 2017-10-16 |  | Verde | Verde | 100% | 100 | 100 | 100% | 100 | Verde | 100% | 100 | 100% | 100 | 02 - Execução | PG 031 | Verde |  |
| 102 | 2.2.1.3.1.13 | Atividade Interna Renova |  | 1d | 2017-10-17 A | 2017-10-17 A | 86SS+39ed | 100% |  | 2017-10-17 | 2017-10-17 | 1d | 2017-10-17 | 2017-10-17 |  | Verde | Verde | 100% | 100 | 100 | 100% | 100 | Verde | 100% | 100 | 100% | 100 | 02 - Execução | PG 031 | Verde |  |
| 103 | 2.2.1.3.1.14 | Atividade Interna Renova |  | 1d | 2017-10-17 A | 2017-10-17 A | 86SS+39ed | 100% |  | 2017-10-17 | 2017-10-17 | 1d | 2017-10-17 | 2017-10-17 |  | Verde | Verde | 100% | 100 | 100 | 100% | 100 | Verde | 100% | 100 | 100% | 100 | 02 - Execução | PG 031 | Verde |  |
| 104 | 2.2.1.3.1.15 | Atividade Interna Renova |  | 1d | 2017-10-18 A | 2017-10-18 A | 86SS+40ed | 100% |  | 2017-10-18 | 2017-10-18 | 1d | 2017-10-18 | 2017-10-18 |  | Verde | Verde | 100% | 100 | 100 | 100% | 100 | Verde | 100% | 100 | 100% | 100 | 02 - Execução | PG 031 | Verde |  |
| 105 | 2.2.1.3.1.16 | Atividade Interna Renova |  | 1d | 2017-10-18 A | 2017-10-18 A | 86SS+40ed | 100% |  | 2017-10-18 | 2017-10-18 | 1d | 2017-10-18 | 2017-10-18 |  | Verde | Verde | 100% | 100 | 100 | 100% | 100 | Verde | 100% | 100 | 100% | 100 | 02 - Execução | PG 031 | Verde |  |
| 106 | 2.2.1.3.1.17 | Atividade Interna Renova |  | 1d | 2017-10-19 A | 2017-10-19 A | 86SS+41ed | 100% |  | 2017-10-19 | 2017-10-19 | 1d | 2017-10-19 | 2017-10-19 |  | Verde | Verde | 100% | 100 | 100 | 100% | 100 | Verde | 100% | 100 | 100% | 100 | 02 - Execução | PG 031 | Verde |  |
| 107 | 2.2.1.3.1.18 | Atividade Interna Renova |  | 1d | 2017-10-20 A | 2017-10-20 A | 86SS+42ed | 100% |  | 2017-10-20 | 2017-10-20 | 1d | 2017-10-20 | 2017-10-20 |  | Verde | Verde | 100% | 100 | 100 | 100% | 100 | Verde | 100% | 100 | 100% | 100 | 02 - Execução | PG 031 | Verde |  |
| 108 | 2.2.1.3.1.19 | Atividade Interna Renova |  | 1d | 2017-10-20 A | 2017-10-20 A | 86SS+42ed | 100% |  | 2017-10-20 | 2017-10-20 | 1d | 2017-10-20 | 2017-10-20 |  | Verde | Verde | 100% | 100 | 100 | 100% | 100 | Verde | 100% | 100 | 100% | 100 | 02 - Execução | PG 031 | Verde |  |
| 109 | 2.2.1.3.1.20 | Atividade Interna Renova |  | 1d | 2017-10-20 A | 2017-10-20 A | 86SS+42ed | 100% |  | 2017-10-20 | 2017-10-20 | 1d | 2017-10-20 | 2017-10-20 |  | Verde | Verde | 100% | 100 | 100 | 100% | 100 | Verde | 100% | 100 | 100% | 100 | 02 - Execução | PG 031 | Verde |  |
| 110 | 2.2.1.3.1.21 | Atividade Interna Renova |  | 1d | 2017-10-20 A | 2017-10-20 A | 86SS+42ed | 100% |  | 2017-10-20 | 2017-10-20 | 1d | 2017-10-20 | 2017-10-20 |  | Verde | Verde | 100% | 100 | 100 | 100% | 100 | Verde | 100% | 100 | 100% | 100 | 02 - Execução | PG 031 | Verde |  |
| 111 | 2.2.1.3.1.22 | Atividade Interna Renova |  | 1d | 2017-10-24 A | 2017-10-24 A | 86SS+46ed | 100% |  | 2017-10-24 | 2017-10-24 | 1d | 2017-10-24 | 2017-10-24 |  | Verde | Verde | 100% | 100 | 100 | 100% | 100 | Verde | 100% | 100 | 100% | 100 | 02 - Execução | PG 031 | Verde |  |
| 112 | 2.2.1.3.1.23 | Atividade Interna Renova |  | 1d | 2017-10-24 A | 2017-10-24 A | 86SS+46ed | 100% |  | 2017-10-24 | 2017-10-24 | 1d | 2017-10-24 | 2017-10-24 |  | Verde | Verde | 100% | 100 | 100 | 100% | 100 | Verde | 100% | 100 | 100% | 100 | 02 - Execução | PG 031 | Verde |  |
| 113 | 2.2.1.3.1.24 | Atividade Interna Renova |  | 1d | 2017-10-25 A | 2017-10-25 A | 86SS+47ed | 100% |  | 2017-10-25 | 2017-10-25 | 1d | 2017-10-25 | 2017-10-25 |  | Verde | Verde | 100% | 100 | 100 | 100% | 100 | Verde | 100% | 100 | 100% | 100 | 02 - Execução | PG 031 | Verde |  |
| 114 | 2.2.1.3.1.25 | Atividade Interna Renova |  | 1d | 2017-10-25 A | 2017-10-25 A | 86SS+47ed | 100% |  | 2017-10-25 | 2017-10-25 | 1d | 2017-10-25 | 2017-10-25 |  | Verde | Verde | 100% | 100 | 100 | 100% | 100 | Verde | 100% | 100 | 100% | 100 | 02 - Execução | PG 031 | Verde |  |
| 115 | 2.2.1.3.1.26 | Atividade Interna Renova |  | 1d | 2017-10-27 A | 2017-10-27 A | 86SS+49ed | 100% |  | 2017-10-27 | 2017-10-27 | 1d | 2017-10-27 | 2017-10-27 |  | Verde | Verde | 100% | 100 | 100 | 100% | 100 | Verde | 100% | 100 | 100% | 100 | 02 - Execução | PG 031 | Verde |  |
| 116 | 2.2.1.3.1.27 | Atividade Interna Renova |  | 1d | 2017-11-14 A | 2017-11-14 A | 86SS+67ed | 100% |  | 2017-11-14 | 2017-11-14 | 1d | 2017-11-14 | 2017-11-14 |  | Verde | Verde | 100% | 100 | 100 | 100% | 100 | Verde | 100% | 100 | 100% | 100 | 02 - Execução | PG 031 | Verde |  |
| 117 | 2.2.1.3.1.28 | Atividade Interna Renova |  | 1d | 2017-11-14 A | 2017-11-14 A | 86SS+67ed | 100% |  | 2017-11-14 | 2017-11-14 | 1d | 2017-11-14 | 2017-11-14 |  | Verde | Verde | 100% | 100 | 100 | 100% | 100 | Verde | 100% | 100 | 100% | 100 | 02 - Execução | PG 031 | Verde |  |
| 118 | 2.2.1.3.1.29 | Atividade Interna Renova |  | 1d | 2017-11-23 A | 2017-11-23 A | 86SS+76ed | 100% |  | 2017-11-23 | 2017-11-23 | 1d | 2017-11-23 | 2017-11-23 |  | Verde | Verde | 100% | 100 | 100 | 100% | 100 | Verde | 100% | 100 | 100% | 100 | 02 - Execução | PG 031 | Verde |  |
| 119 | 2.2.1.3.1.30 | Atividade Interna Renova |  | 1d | 2017-11-28 A | 2017-11-28 A | 86SS+81ed | 100% |  | 2017-11-28 | 2017-11-28 | 1d | 2017-11-28 | 2017-11-28 |  | Verde | Verde | 100% | 100 | 100 | 100% | 100 | Verde | 100% | 100 | 100% | 100 | 02 - Execução | PG 031 | Verde |  |
| 120 | 2.2.1.3.1.31 | Atividade Interna Renova |  | 1d | 2017-11-28 A | 2017-11-28 A | 86SS+81ed | 100% |  | 2017-11-28 | 2017-11-28 | 1d | 2017-11-28 | 2017-11-28 |  | Verde | Verde | 100% | 100 | 100 | 100% | 100 | Verde | 100% | 100 | 100% | 100 | 02 - Execução | PG 031 | Verde |  |
| 121 | 2.2.1.3.1.32 | Atividade Interna Renova |  | 1d | 2017-11-28 A | 2017-11-28 A | 86SS+81ed | 100% |  | 2017-11-28 | 2017-11-28 | 1d | 2017-11-28 | 2017-11-28 |  | Verde | Verde | 100% | 100 | 100 | 100% | 100 | Verde | 100% | 100 | 100% | 100 | 02 - Execução | PG 031 | Verde |  |
| 122 | 2.2.1.3.1.33 | Atividade Interna Renova |  | 1d | 2017-11-29 A | 2017-11-29 A | 86SS+82ed | 100% |  | 2017-11-29 | 2017-11-29 | 1d | 2017-11-29 | 2017-11-29 |  | Verde | Verde | 100% | 100 | 100 | 100% | 100 | Verde | 100% | 100 | 100% | 100 | 02 - Execução | PG 031 | Verde |  |
| 123 | 2.2.1.3.1.34 | Atividade Interna Renova |  | 1d | 2017-11-29 A | 2017-11-29 A | 86SS+82ed | 100% |  | 2017-11-29 | 2017-11-29 | 1d | 2017-11-29 | 2017-11-29 |  | Verde | Verde | 100% | 100 | 100 | 100% | 100 | Verde | 100% | 100 | 100% | 100 | 02 - Execução | PG 031 | Verde |  |
| 124 | 2.2.1.3.1.35 | Atividade Interna Renova |  | 1d | 2017-11-30 A | 2017-11-30 A | 86SS+83ed | 100% |  | 2017-11-30 | 2017-11-30 | 1d | 2017-11-30 | 2017-11-30 |  | Verde | Verde | 100% | 100 | 100 | 100% | 100 | Verde | 100% | 100 | 100% | 100 | 02 - Execução | PG 031 | Verde |  |
| 125 | 2.2.1.3.1.36 | Atividade Interna Renova |  | 1d | 2017-12-18 A | 2017-12-18 A | 86SS+101ed | 100% |  | 2017-12-18 | 2017-12-18 | 1d | 2017-12-18 | 2017-12-18 |  | Verde | Verde | 100% | 100 | 100 | 100% | 100 | Verde | 100% | 100 | 100% | 100 | 02 - Execução | PG 031 | Verde |  |
| 126 | 2.2.1.3.1.37 | Atividade Interna Renova |  | 1d | 2017-12-15 A | 2017-12-15 A | 86SS+98ed | 100% |  | 2017-12-15 | 2017-12-15 | 1d | 2017-12-15 | 2017-12-15 |  | Verde | Verde | 100% | 100 | 100 | 100% | 100 | Verde | 100% | 100 | 100% | 100 | 02 - Execução | PG 031 | Verde |  |
| 127 | 2.2.1.3.1.38 | Atividade Interna Renova |  | 1d | 2017-12-19 A | 2017-12-19 A | 86SS+102ed | 100% |  | 2017-12-19 | 2017-12-19 | 1d | 2017-12-19 | 2017-12-19 |  | Verde | Verde | 100% | 100 | 100 | 100% | 100 | Verde | 100% | 100 | 100% | 100 | 02 - Execução | PG 031 | Verde |  |
| 128 | 2.2.1.3.1.39 | Atividade Interna Renova |  | 1d | 2017-12-20 A | 2017-12-20 A | 86SS+103ed | 100% |  | 2017-12-20 | 2017-12-20 | 1d | 2017-12-20 | 2017-12-20 |  | Verde | Verde | 100% | 100 | 100 | 100% | 100 | Verde | 100% | 100 | 100% | 100 | 02 - Execução | PG 031 | Verde |  |
| 129 | 2.2.1.3.1.40 | Atividade Interna Renova | milestone | 0d | 2017-12-20 A | 2017-12-20 A | 86SS+103ed | 100% |  | 2017-12-20 | 2017-12-20 | 0d | 2017-12-20 | 2017-12-20 |  | Verde | Verde | 100% | 100 | 100 | 0% |  | Vermelho | 100% | 100 | 0% |  | 02 - Execução | PG 031 | Verde |  |

Notes:
- 69: Em 19/03/19: por solicitação da A&M foi modificada a latência da atividade Aprovação da Definição do Programa pelo CIF de 480 dias para 104 dias para atendimento à demanda do MP e igualar as datas de término tendência às da definição do programa.
- 81: - Falta apenas o munícipio de Rio Doce para assinatura de contrato de repasse com o BDMG, porque o mesmo está com pendência no CND. / - O múnicípio de Rio Doce não está mais com pendência
- 90: Reunião de partida para apresentação e alinhamento do programa. / Nesta visita foi solicitado ao município o preenchimento de uma ficha técnica com identificação dos pontos focais, detalhamento de pleitos e requerimento das atividades de apoio técnico e capacitação que o município gostaria de receber
- 91: Reunião de partida para apresentação e alinhamento do programa. / Nesta visita foi solicitado ao município o preenchimento de uma ficha técnica com identificação dos pontos focais, detalhamento de pleitos e requerimento das atividades de apoio técnico e capacitação que o município gostaria de receber
- 92: Reunião de partida para apresentação e alinhamento do programa. / Nesta visita foi solicitado ao município o preenchimento de uma ficha técnica com identificação dos pontos focais, detalhamento de pleitos e requerimento das atividades de apoio técnico e capacitação que o município gostaria de receber
- 93: Reunião de partida para apresentação e alinhamento do programa. / Nesta visita foi solicitado ao município o preenchimento de uma ficha técnica com identificação dos pontos focais, detalhamento de pleitos e requerimento das atividades de apoio técnico e capacitação que o município gostaria de receber
- 94: Reunião de partida para apresentação e alinhamento do programa. / Nesta visita foi solicitado ao município o preenchimento de uma ficha técnica com identificação dos pontos focais, detalhamento de pleitos e requerimento das atividades de apoio técnico e capacitação que o município gostaria de receber
- 95: Reunião de partida para apresentação e alinhamento do programa. / Nesta visita foi solicitado ao município o preenchimento de uma ficha técnica com identificação dos pontos focais, detalhamento de pleitos e requerimento das atividades de apoio técnico e capacitação que o município gostaria de receber
- 96: Reunião de partida para apresentação e alinhamento do programa. / Nesta visita foi solicitado ao município o preenchimento de uma ficha técnica com identificação dos pontos focais, detalhamento de pleitos e requerimento das atividades de apoio técnico e capacitação que o município gostaria de receber
- 97: Reunião de partida para apresentação e alinhamento do programa. / Nesta visita foi solicitado ao município o preenchimento de uma ficha técnica com identificação dos pontos focais, detalhamento de pleitos e requerimento das atividades de apoio técnico e capacitação que o município gostaria de receber
- 98: Reunião de partida para apresentação e alinhamento do programa. / Nesta visita foi solicitado ao município o preenchimento de uma ficha técnica com identificação dos pontos focais, detalhamento de pleitos e requerimento das atividades de apoio técnico e capacitação que o município gostaria de receber
- 99: Reunião de partida para apresentação e alinhamento do programa. / Nesta visita foi solicitado ao município o preenchimento de uma ficha técnica com identificação dos pontos focais, detalhamento de pleitos e requerimento das atividades de apoio técnico e capacitação que o município gostaria de receber
- 100: Reunião de partida para apresentação e alinhamento do programa. / Nesta visita foi solicitado ao município o preenchimento de uma ficha técnica com identificação dos pontos focais, detalhamento de pleitos e requerimento das atividades de apoio técnico e capacitação que o município gostaria de receber
- 101: Reunião de partida para apresentação e alinhamento do programa. / Nesta visita foi solicitado ao município o preenchimento de uma ficha técnica com identificação dos pontos focais, detalhamento de pleitos e requerimento das atividades de apoio técnico e capacitação que o município gostaria de receber
- 102: Reunião de partida para apresentação e alinhamento do programa. / Nesta visita foi solicitado ao município o preenchimento de uma ficha técnica com identificação dos pontos focais, detalhamento de pleitos e requerimento das atividades de apoio técnico e capacitação que o município gostaria de receber
- 103: Reunião de partida para apresentação e alinhamento do programa. / Nesta visita foi solicitado ao município o preenchimento de uma ficha técnica com identificação dos pontos focais, detalhamento de pleitos e requerimento das atividades de apoio técnico e capacitação que o município gostaria de receber
- 104: Reunião de partida para apresentação e alinhamento do programa. / Nesta visita foi solicitado ao município o preenchimento de uma ficha técnica com identificação dos pontos focais, detalhamento de pleitos e requerimento das atividades de apoio técnico e capacitação que o município gostaria de receber
- 105: Reunião de partida para apresentação e alinhamento do programa. / Nesta visita foi solicitado ao município o preenchimento de uma ficha técnica com identificação dos pontos focais, detalhamento de pleitos e requerimento das atividades de apoio técnico e capacitação que o município gostaria de receber
- 106: Reunião de partida para apresentação e alinhamento do programa. / Nesta visita foi solicitado ao município o preenchimento de uma ficha técnica com identificação dos pontos focais, detalhamento de pleitos e requerimento das atividades de apoio técnico e capacitação que o município gostaria de receber
- 107: Reunião de partida para apresentação e alinhamento do programa. / Nesta visita foi solicitado ao município o preenchimento de uma ficha técnica com identificação dos pontos focais, detalhamento de pleitos e requerimento das atividades de apoio técnico e capacitação que o município gostaria de receber
- 108: Reunião de partida para apresentação e alinhamento do programa. / Nesta visita foi solicitado ao município o preenchimento de uma ficha técnica com identificação dos pontos focais, detalhamento de pleitos e requerimento das atividades de apoio técnico e capacitação que o município gostaria de receber.
- 109: Reunião de partida para apresentação e alinhamento do programa. / Nesta visita foi solicitado ao município o preenchimento de uma ficha técnica com identificação dos pontos focais, detalhamento de pleitos e requerimento das atividades de apoio técnico e capacitação que o município gostaria de receber
- 110: Reunião de partida para apresentação e alinhamento do programa. / Nesta visita foi solicitado ao município o preenchimento de uma ficha técnica com identificação dos pontos focais, detalhamento de pleitos e requerimento das atividades de apoio técnico e capacitação que o município gostaria de receber
- 111: Reunião de partida para apresentação e alinhamento do programa. / Nesta visita foi solicitado ao município o preenchimento de uma ficha técnica com identificação dos pontos focais, detalhamento de pleitos e requerimento das atividades de apoio técnico e capacitação que o município gostaria de receber
- 112: Reunião de partida para apresentação e alinhamento do programa. / Nesta visita foi solicitado ao município o preenchimento de uma ficha técnica com identificação dos pontos focais, detalhamento de pleitos e requerimento das atividades de apoio técnico e capacitação que o município gostaria de receber
- 113: Reunião de partida para apresentação e alinhamento do programa. / Nesta visita foi solicitado ao município o preenchimento de uma ficha técnica com identificação dos pontos focais, detalhamento de pleitos e requerimento das atividades de apoio técnico e capacitação que o município gostaria de receber
- 114: Reunião de partida para apresentação e alinhamento do programa. / Nesta visita foi solicitado ao município o preenchimento de uma ficha técnica com identificação dos pontos focais, detalhamento de pleitos e requerimento das atividades de apoio técnico e capacitação que o município gostaria de receber
- 115: Reunião de partida para apresentação e alinhamento do programa. / Nesta visita foi solicitado ao município o preenchimento de uma ficha técnica com identificação dos pontos focais, detalhamento de pleitos e requerimento das atividades de apoio técnico e capacitação que o município gostaria de receber
- 116: Reunião de partida para apresentação e alinhamento do programa. / Nesta visita foi solicitado ao município o preenchimento de uma ficha técnica com identificação dos pontos focais, detalhamento de pleitos e requerimento das atividades de apoio técnico e capacitação que o município gostaria de receber
- 117: Reunião de partida para apresentação e alinhamento do programa. / Nesta visita foi solicitado ao município o preenchimento de uma ficha técnica com identificação dos pontos focais, detalhamento de pleitos e requerimento das atividades de apoio técnico e capacitação que o município gostaria de receber
- 118: Reunião de partida para apresentação e alinhamento do programa. / Nesta visita foi solicitado ao município o preenchimento de uma ficha técnica com identificação dos pontos focais, detalhamento de pleitos e requerimento das atividades de apoio técnico e capacitação que o município gostaria de receber
- 119: Reunião de partida para apresentação e alinhamento do programa. / Nesta visita foi solicitado ao município o preenchimento de uma ficha técnica com identificação dos pontos focais, detalhamento de pleitos e requerimento das atividades de apoio técnico e capacitação que o município gostaria de receber
- 120: Reunião de partida para apresentação e alinhamento do programa. / Nesta visita foi solicitado ao município o preenchimento de uma ficha técnica com identificação dos pontos focais, detalhamento de pleitos e requerimento das atividades de apoio técnico e capacitação que o município gostaria de receber
- 121: Reunião de partida para apresentação e alinhamento do programa. / Nesta visita foi solicitado ao município o preenchimento de uma ficha técnica com identificação dos pontos focais, detalhamento de pleitos e requerimento das atividades de apoio técnico e capacitação que o município gostaria de receber
- 122: Reunião de partida para apresentação e alinhamento do programa. / Nesta visita foi solicitado ao município o preenchimento de uma ficha técnica com identificação dos pontos focais, detalhamento de pleitos e requerimento das atividades de apoio técnico e capacitação que o município gostaria de receber
- 123: Reunião de partida para apresentação e alinhamento do programa. / Nesta visita foi solicitado ao município o preenchimento de uma ficha técnica com identificação dos pontos focais, detalhamento de pleitos e requerimento das atividades de apoio técnico e capacitação que o município gostaria de receber
- 124: Reunião de partida para apresentação e alinhamento do programa. / Nesta visita foi solicitado ao município o preenchimento de uma ficha técnica com identificação dos pontos focais, detalhamento de pleitos e requerimento das atividades de apoio técnico e capacitação que o município gostaria de receber
- 125: Reunião de partida para apresentação e alinhamento do programa. / Nesta visita foi solicitado ao município o preenchimento de uma ficha técnica com identificação dos pontos focais, detalhamento de pleitos e requerimento das atividades de apoio técnico e capacitação que o município gostaria de receber
- 126: Reunião de partida para apresentação e alinhamento do programa. / Nesta visita foi solicitado ao município o preenchimento de uma ficha técnica com identificação dos pontos focais, detalhamento de pleitos e requerimento das atividades de apoio técnico e capacitação que o município gostaria de receber
- 127: Reunião de partida para apresentação e alinhamento do programa. / Nesta visita foi solicitado ao município o preenchimento de uma ficha técnica com identificação dos pontos focais, detalhamento de pleitos e requerimento das atividades de apoio técnico e capacitação que o município gostaria de receber
- 128: Reunião de partida para apresentação e alinhamento do programa. / Nesta visita foi solicitado ao município o preenchimento de uma ficha técnica com identificação dos pontos focais, detalhamento de pleitos e requerimento das atividades de apoio técnico e capacitação que o município gostaria de receber

| ID | WBS | Task | Type | Duration | Start | Finish | Predecessors | Complete | Remaining | Baseline start | Baseline finish | Baseline duration | Baseline 1 start | Baseline 1 finish | Total slack | Free slack | Constraint | Farol de Atraso | Farol Marcos | % Previsto Tempo | % Concluída Numérico | % Previsto Tempo Numérico | Índice de Desempenho Físico (IDF) | IDF Numérico | Farol IDF | % Previsto Ponderado | % Concluído Ponderado | Áreas de Suporte | % Previsto Ponderado Numérico | Farol de Início | % Concluído Ponderado Numérico | Responsável | Código do Contrato |
| --- | --- | --- | --- | --- | --- | --- | --- | --- | --- | --- | --- | --- | --- | --- | --- | --- | --- | --- | --- | --- | --- | --- | --- | --- | --- | --- | --- | --- | --- | --- | --- | --- | --- |
| 130 | 2.2.2 | **Atividade Interna Renova** |  | 143d | 2019-04-02 A | 2019-10-24 |  | 16% | 120.17d | 2019-04-02 | 2019-10-24 | 143d |  |  | 1324d |  |  | Verde | Verde | 13% | 16 | 13 | 100% | 100 | Verde | 3% | 3% |  |  |  |  |  |  |
| 131 | 2.2.2.1 | Atividade Interna Renova | milestone | 0d | 2019-04-02 A | 2019-04-02 A |  | 100% |  | 2019-04-02 | 2019-04-02 | 0d |  |  |  |  | start no earlier than 2019-04-02 | Verde | Verde | 100% | 100 | 100 | 0% |  | Vermelho | 100% | 0% | ܁3 | 100 | Verde |  |  |  |
| 132 | 2.2.2.2 | Atividade Interna Renova |  | 62d | 2019-04-02 A | 2019-07-02 | 131 | 31% | 43d | 2019-04-02 | 2019-07-02 | 62d |  |  | 1324d | 0d |  | Verde | Verde | 30% | 31 | 30 | 103% | 103 | Verde | 30% | 31% | ܁3 | 30 | Verde | 31 |  |  |
| 133 | 2.2.2.3 | Atividade Interna Renova |  | 2d | 2019-07-03 | 2019-07-04 | 132 |  |  | 2019-07-03 | 2019-07-04 | 2d |  |  | 1324d | 0d |  | Verde | Verde | 0% |  |  | 0% |  | Verde | 0% | 0% | ܁3 |  | Verde |  |  |  |
| 134 | 2.2.2.4 | Atividade Interna Renova |  | 5d | 2019-07-05 | 2019-07-11 | 133 |  |  | 2019-07-05 | 2019-07-11 | 5d |  |  | 1324d | 0d |  | Verde | Verde | 0% |  |  | 0% |  | Verde | 0% | 0% | ܁3 |  | Verde |  |  |  |
| 135 | 2.2.2.5 | Atividade Interna Renova |  | 2d | 2019-07-12 | 2019-07-15 | 134 |  |  | 2019-07-12 | 2019-07-15 | 2d |  |  | 1324d | 0d |  | Verde | Verde | 0% |  |  | 0% |  | Verde | 0% | 0% | ܁3 |  | Verde |  |  |  |
| 136 | 2.2.2.6 | Atividade Interna Renova |  | 1d | 2019-07-16 | 2019-07-16 | 135 |  |  | 2019-07-16 | 2019-07-16 | 1d |  |  | 1324d | 0d |  | Verde | Verde | 0% |  |  | 0% |  | Verde | 0% | 0% | ܁3 |  | Verde |  |  |  |
| 137 | 2.2.2.7 | Atividade Interna Renova |  | 1d | 2019-08-14 | 2019-08-14 | 136FS+20d |  |  | 2019-08-14 | 2019-08-14 | 1d |  |  | 1324d | 0d |  | Verde | Verde | 0% |  |  | 0% |  | Verde | 0% | 0% | ܁3 |  | Verde |  |  |  |
| 138 | 2.2.2.8 | Atividade Interna Renova |  | 1d | 2019-08-22 | 2019-08-22 | 137FS+4d |  |  | 2019-08-22 | 2019-08-22 | 1d |  |  | 1324d | 0d |  | Verde | Verde | 0% |  |  | 0% |  | Verde | 0% | 0% | ܁3 |  | Verde |  |  |  |
| 139 | 2.2.2.9 | Atividade Interna Renova |  | 22d | 2019-08-23 | 2019-09-23 | 138 |  |  | 2019-08-23 | 2019-09-23 | 22d |  |  | 1324d | 0d |  | Verde | Verde | 0% |  |  | 0% |  | Verde | 0% | 0% | ܁3 |  | Verde |  |  |  |
| 140 | 2.2.2.10 | Atividade Interna Renova |  | 23d | 2019-09-24 | 2019-10-24 | 139 |  |  | 2019-09-24 | 2019-10-24 | 23d |  |  | 1324d | 0d |  | Verde | Verde | 0% |  |  | 0% |  | Verde | 0% | 0% | ܁3 |  | Verde |  |  |  |
| 141 | 2.2.2.11 | Atividade Interna Renova | milestone | 0d | 2019-10-24 | 2019-10-24 | 140 |  |  | 2019-10-24 | 2019-10-24 | 0d |  |  | 1324d |  |  | Verde | Verde | 0% |  |  | 0% |  | Verde | 0% | 0% | ܁3 |  | Verde |  |  |  |
| 142 | 2.2.3 | **Atividade Interna Renova** |  | 347d | 2017-11-20 A | 2019-03-25 A |  | 100% |  | 2017-11-20 | 2019-03-25 | 347d | 2017-11-20 | 2019-01-30 |  |  |  | Verde | Verde | 100% | 100 | 100 | 100% | 100 | Verde | 100% | 100% |  | 100 |  | 100 |  |  |
| 143 | 2.2.3.1 | Atividade Interna Renova |  | 83d | 2017-11-20 A | 2018-03-14 A | 63FS+24ed | 100% |  | 2017-11-20 | 2018-03-14 | 83d | 2017-11-20 | 2018-03-13 |  |  |  | Verde | Verde | 100% | 100 | 100 | 100% | 100 | Verde | 100% | 100% |  | 100 | Verde | 100 | 02 - Execução | PG 031 |
| 144 | 2.2.3.2 | Atividade Interna Renova | milestone | 0d | 2018-03-13 A | 2018-03-13 A | 143 | 100% |  | 2018-03-13 | 2018-03-13 | 0d | 2018-03-13 | 2018-03-13 |  |  |  | Verde | Verde | 100% | 100 | 100 | 0% |  | Vermelho | 100% | 0% |  | 100 | Verde |  | 02 - Execução | PG 031 |
| 145 | 2.2.3.3 | **Atividade Interna Renova** |  | 266d | 2018-03-13 A | 2019-03-25 A |  | 100% |  | 2018-03-13 | 2019-03-25 | 266d |  |  |  |  |  | Verde | Verde | 100% | 100 | 100 | 100% | 100 | Verde | 100% | 100% | ܁3 | 100 |  | 100 |  |  |
| 146 | 2.2.3.3.1 | Atividade Interna Renova |  | 37d | 2018-03-13 A | 2018-05-02 A | 144 | 100% |  | 2018-03-13 | 2018-05-02 | 37d | 2018-03-13 | 2018-05-02 |  |  |  | Verde | Verde | 100% | 100 | 100 | 100% | 100 | Verde | 100% | 100% | ܁3 | 100 | Verde | 100 | 02 - Execução | PG 031 |
| 147 | 2.2.3.3.2 | Atividade Interna Renova |  | 6d | 2018-05-02 A | 2018-05-09 A | 146 | 100% |  | 2018-05-02 | 2018-05-09 | 6d | 2018-05-02 | 2018-05-09 |  |  |  | Verde | Verde | 100% | 100 | 100 | 100% | 100 | Verde | 100% | 100% | ܁3 | 100 | Verde | 100 | 02 - Execução | PG 031 |
| 148 | 2.2.3.3.3 | Atividade Interna Renova |  | 56d | 2018-05-09 A | 2018-07-26 A | 147, 2924 | 100% |  | 2018-05-09 | 2018-07-26 | 56d | 2018-05-09 | 2018-07-25 |  |  |  | Verde | Verde | 100% | 100 | 100 | 100% | 100 | Verde | 100% | 100% | ܁3 | 100 | Verde | 100 |  |  |
| 149 | 2.2.3.3.4 | Atividade Interna Renova |  | 80d | 2018-07-23 A | 2018-11-14 A | 148 | 100% |  | 2018-07-23 | 2018-11-14 | 80d | 2018-07-23 | 2018-11-10 |  |  |  | Verde | Verde | 100% | 100 | 100 | 100% | 100 | Verde | 100% | 100% | ܁3 | 100 | Verde | 100 |  |  |
| 150 | 2.2.3.3.5 | Atividade Interna Renova |  | 2d | 2018-11-12 A | 2018-11-13 A | 149 | 100% |  | 2018-11-12 | 2018-11-13 | 2d | 2018-11-12 | 2018-11-13 |  |  |  | Verde | Verde | 100% | 100 | 100 | 100% | 100 | Verde | 100% | 100% | ܁3 | 100 | Verde | 100 | 02 - Execução | PG 031 |
| 151 | 2.2.3.3.6 | Atividade Interna Renova |  | 10d | 2018-11-14 A | 2018-11-29 A | 150 | 100% |  | 2018-11-14 | 2018-11-29 | 10d | 2018-11-14 | 2018-11-27 |  |  |  | Verde | Verde | 100% | 100 | 100 | 100% | 100 | Verde | 100% | 100% | ܁3 | 100 | Verde | 100 | 02 - Execução | PG 031 |
| 152 | 2.2.3.3.7 | Atividade Interna Renova |  | 14d | 2018-11-28 A | 2018-12-17 A | 151 | 100% |  | 2018-11-28 | 2018-12-17 | 14d | 2018-11-28 | 2018-12-17 |  |  |  | Verde | Verde | 100% | 100 | 100 | 100% | 100 | Verde | 100% | 100% | ܁3 | 100 | Verde | 100 | 02 - Execução | PG 031 |
| 153 | 2.2.3.3.8 | Atividade Interna Renova |  | 12d | 2019-01-24 A | 2019-02-08 A | 152FS+37ed | 100% |  | 2019-01-24 | 2019-02-08 | 12d | 2018-12-18 | 2019-01-02 |  |  |  | Verde | Verde | 100% | 100 | 100 | 100% | 100 | Verde | 100% | 100% | ܁3 | 100 | Verde | 100 | 02 - Execução | PG 031 |
| 154 | 2.2.3.3.9 | Atividade Interna Renova |  | 22d | 2019-02-08 A | 2019-03-15 A | 153 | 100% |  | 2019-02-08 | 2019-03-15 | 22d | 2018-11-12 | 2018-11-30 |  |  |  | Verde | Verde | 100% | 100 | 100 | 100% | 100 | Verde | 100% | 100% | ܁3 | 100 | Verde | 100 | 02 - Execução | PG 031 |
| 155 | 2.2.3.3.10 | Atividade Interna Renova |  | 4d | 2019-03-18 A | 2019-03-21 A | 154 | 100% |  | 2019-03-18 | 2019-03-21 | 4d | 2018-12-03 | 2018-12-14 |  |  |  | Verde | Verde | 100% | 100 | 100 | 100% | 100 | Verde | 100% | 100% | ܁3 | 100 | Verde | 100 | 02 - Execução | PG 031 |
| 156 | 2.2.3.3.11 | Atividade Interna Renova |  | 2d | 2019-03-22 A | 2019-03-25 A | 155 | 100% |  | 2019-03-22 | 2019-03-25 | 2d | 2019-01-03 | 2019-01-30 |  |  |  | Verde | Verde | 100% | 100 | 100 | 100% | 100 | Verde | 100% | 100% | ܁3 | 100 | Verde | 100 | 02 - Execução | PG 031 |
| 157 | 2.2.3.3.12 | Atividade Interna Renova | milestone | 0d | 2019-03-25 A | 2019-03-25 A | 156 | 100% |  | 2019-03-25 | 2019-03-25 | 0d | 2019-01-30 | 2019-01-30 |  |  |  | Verde | Verde | 100% | 100 | 100 | 0% |  | Vermelho | 100% | 0% | ܁3 | 100 | Verde |  | 02 - Execução | PG 031 |

Notes:
- 132: Em 29/04/2019: atualizado como agendado
- 153: - Foi solicitado esclarecimento pelo Comitê Interno de Programas socioambientais. O email com esclarecimento foi enviado dia 08/01/2019. / O Programa está aguardando a resposta do Comitê após o dia 24/01/2019.

| ID | WBS | Task | Type | Duration | Start | Finish | Predecessors | Complete | Remaining | Baseline start | Baseline finish | Baseline duration | Baseline 1 start | Baseline 1 finish | Total slack | Farol de Atraso | Farol Marcos | % Previsto Tempo | % Concluída Numérico | % Previsto Tempo Numérico | Índice de Desempenho Físico (IDF) | IDF Numérico | Farol IDF | Áreas de Suporte | % Previsto Ponderado | % Previsto Ponderado Numérico | % Concluído Ponderado | % Concluído Ponderado Numérico | Responsável | Código do Contrato | Farol de Início |
| --- | --- | --- | --- | --- | --- | --- | --- | --- | --- | --- | --- | --- | --- | --- | --- | --- | --- | --- | --- | --- | --- | --- | --- | --- | --- | --- | --- | --- | --- | --- | --- |
| 158 | 2.2.4 | **Atividade Interna Renova** |  | 213d | 2018-06-28 A | 2019-04-30 A |  | 100% |  | 2018-06-28 | 2019-04-30 | 213d | 2018-06-28 | 2019-05-04 |  | Verde | Verde | 100% | 100 | 100 | 100% | 100 | Verde | ܁3 | 100% | 100 | 100% | 100 |  |  |  |
| 159 | 2.2.4.1 | Atividade Interna Renova |  | 144d | 2018-07-01 A | 2019-02-08 A | 146FS+60ed | 100% |  | 2018-07-01 | 2019-02-08 | 144d | 2018-07-01 | 2019-01-17 |  | Verde | Verde | 100% | 100 | 100 | 100% | 100 | Verde | ܁3 | 100% | 100 | 100% | 100 | 02 - Execução | PG 031 | Verde |
| 160 | 2.2.4.2 | Atividade Interna Renova |  | 198d | 2018-06-28 A | 2019-04-30 A | 159SS+3ed | 100% |  | 2018-06-28 | 2019-04-30 | 198d | 2018-06-28 | 2019-05-04 |  | Verde | Verde | 100% | 100 | 100 | 100% | 100 | Verde | ܁3 | 100% | 100 | 100% | 100 |  |  | Verde |
| 161 | 2.2.4.3 | Atividade Interna Renova | milestone | 0d | 2019-04-30 A | 2019-04-30 A | 160 | 100% |  | 2019-04-30 | 2019-04-30 | 0d |  |  |  | Verde | Verde | 0% | 100 |  | 0% |  | Verde | ܁3 | 0% |  | 0% |  |  |  | Verde |
| 162 | 2.2.5 | **Atividade Interna Renova** |  | 1744d | 2018-03-05 A | 2025-02-24 |  | 99% | 0d | 2018-03-05 | 2025-02-24 | 1744d | 2018-03-05 | 2023-01-19 | 240d | Verde | Verde | 16% | 99 | 16 | 100% | 100 | Verde |  | 100% | 100 | 100% | 100 |  |  |  |
| 163 | 2.2.5.1 | Atividade Interna Renova |  | 23d | 2018-03-05 A | 2018-04-04 A | 87FS+80ed, 90, 91, 92, 93, 94, 95, 96, 97, 98, 99, 100, 101, 102, 103, 104, 105, 106, 107, 108, 109, 110, 111, 112, 113, 114, 115, 116, 117, 118, 119, 120, 121, 122, 123, 124, 125, 126, 127, 128, 129 | 100% |  | 2018-03-05 | 2018-04-04 | 23d | 2018-03-05 | 2018-04-04 |  | Verde | Verde | 100% | 100 | 100 | 100% | 100 | Verde | ܁3 | 100% | 100 | 100% | 100 | 02 - Execução | PG 031 | Verde |
| 164 | 2.2.5.2 | Atividade Interna Renova |  | 15d | 2018-04-04 A | 2018-04-24 A | 163 | 100% |  | 2018-04-04 | 2018-04-24 | 15d | 2018-04-04 | 2018-04-24 |  | Verde | Verde | 100% | 100 | 100 | 100% | 100 | Verde | ܁3 | 100% | 100 | 100% | 100 | 02 - Execução | PG 031 | Verde |
| 165 | 2.2.5.3 | Atividade Interna Renova |  | 1d | 2018-05-15 A | 2018-05-16 A | 164FS+16d | 100% |  | 2018-05-15 | 2018-05-16 | 1d | 2018-05-15 | 2018-05-16 |  | Verde | Verde | 100% | 100 | 100 | 100% | 100 | Verde | ܁3 | 100% | 100 | 100% | 100 | 02 - Execução | PG 031 | Verde |
| 166 | 2.2.5.4 | **Atividade Interna Renova** |  | 124d | 2018-06-22 A | 2018-12-12 A |  | 100% |  | 2018-06-22 | 2018-12-12 | 124d | 2018-06-22 | 2019-01-07 |  | Verde | Verde | 100% | 100 | 100 | 100% | 100 | Verde |  | 100% | 100 | 100% | 100 |  |  |  |
| 167 | 2.2.5.4.1 | Atividade Interna Renova |  | 1d | 2018-08-15 A | 2018-08-15 A | 165FS+90ed | 100% |  | 2018-08-15 | 2018-08-15 | 1d | 2018-08-15 | 2018-08-15 |  | Verde | Verde | 100% | 100 | 100 | 100% | 100 | Verde |  | 100% | 100 | 100% | 100 |  |  | Verde |
| 168 | 2.2.5.4.2 | Atividade Interna Renova |  | 1d | 2018-07-09 A | 2018-07-10 A | 165FS+52ed | 100% |  | 2018-07-09 | 2018-07-10 | 1d | 2018-07-09 | 2018-07-09 |  | Verde | Verde | 100% | 100 | 100 | 100% | 100 | Verde |  | 100% | 100 | 100% | 100 |  |  | Verde |
| 169 | 2.2.5.4.3 | Atividade Interna Renova |  | 1d | 2018-08-10 A | 2018-08-10 A | 165FS+85ed | 100% |  | 2018-08-10 | 2018-08-10 | 1d | 2018-08-10 | 2018-08-10 |  | Verde | Verde | 100% | 100 | 100 | 100% | 100 | Verde |  | 100% | 100 | 100% | 100 |  |  | Verde |
| 170 | 2.2.5.4.4 | Atividade Interna Renova |  | 1d | 2018-08-09 A | 2018-08-09 A | 165FS+84ed | 100% |  | 2018-08-09 | 2018-08-09 | 1d | 2018-08-09 | 2018-08-09 |  | Verde | Verde | 100% | 100 | 100 | 100% | 100 | Verde |  | 100% | 100 | 100% | 100 |  |  | Verde |
| 171 | 2.2.5.4.5 | Atividade Interna Renova |  | 1d | 2018-08-10 A | 2018-08-10 A | 165FS+85ed | 100% |  | 2018-08-10 | 2018-08-10 | 1d | 2018-08-10 | 2018-08-10 |  | Verde | Verde | 100% | 100 | 100 | 100% | 100 | Verde |  | 100% | 100 | 100% | 100 |  |  | Verde |
| 172 | 2.2.5.4.6 | Atividade Interna Renova |  | 1d | 2018-07-18 A | 2018-07-18 A | 165FS+62ed | 100% |  | 2018-07-18 | 2018-07-18 | 1d | 2018-07-18 | 2018-07-18 |  | Verde | Verde | 100% | 100 | 100 | 100% | 100 | Verde |  | 100% | 100 | 100% | 100 |  |  | Verde |
| 173 | 2.2.5.4.7 | Atividade Interna Renova |  | 1d | 2018-08-13 A | 2018-08-13 A | 165FS+88ed | 100% |  | 2018-08-13 | 2018-08-13 | 1d | 2018-08-13 | 2018-08-13 |  | Verde | Verde | 100% | 100 | 100 | 100% | 100 | Verde |  | 100% | 100 | 100% | 100 |  |  | Verde |
| 174 | 2.2.5.4.8 | Atividade Interna Renova |  | 1d | 2018-07-18 A | 2018-07-18 A | 165FS+62ed | 100% |  | 2018-07-18 | 2018-07-18 | 1d | 2018-07-18 | 2018-07-18 |  | Verde | Verde | 100% | 100 | 100 | 100% | 100 | Verde |  | 100% | 100 | 100% | 100 |  |  | Verde |
| 175 | 2.2.5.4.9 | Atividade Interna Renova |  | 1d | 2018-12-12 A | 2018-12-12 A | 165FS+209ed | 100% |  | 2018-12-12 | 2018-12-12 | 1d | 2019-01-07 | 2019-01-07 |  | Verde | Verde | 100% | 100 | 100 | 100% | 100 | Verde |  | 100% | 100 | 100% | 100 |  |  | Verde |
| 176 | 2.2.5.4.10 | Atividade Interna Renova |  | 1d | 2018-08-16 A | 2018-08-16 A | 165FS+91ed | 100% |  | 2018-08-16 | 2018-08-16 | 1d | 2018-08-16 | 2018-08-16 |  | Verde | Verde | 100% | 100 | 100 | 100% | 100 | Verde |  | 100% | 100 | 100% | 100 |  |  | Verde |
| 177 | 2.2.5.4.11 | Atividade Interna Renova |  | 1d | 2018-07-19 A | 2018-07-19 A | 165FS+63ed | 100% |  | 2018-07-19 | 2018-07-19 | 1d | 2018-07-19 | 2018-07-19 |  | Verde | Verde | 100% | 100 | 100 | 100% | 100 | Verde |  | 100% | 100 | 100% | 100 |  |  | Verde |
| 178 | 2.2.5.4.12 | Atividade Interna Renova |  | 1d | 2018-09-13 A | 2018-09-13 A | 165FS+119ed | 100% |  | 2018-09-13 | 2018-09-13 | 1d | 2018-09-13 | 2018-09-13 |  | Verde | Verde | 100% | 100 | 100 | 100% | 100 | Verde |  | 100% | 100 | 100% | 100 |  |  | Verde |
| 179 | 2.2.5.4.13 | Atividade Interna Renova |  | 1d | 2018-07-18 A | 2018-07-18 A | 165FS+62ed | 100% |  | 2018-07-18 | 2018-07-18 | 1d | 2018-07-18 | 2018-07-18 |  | Verde | Verde | 100% | 100 | 100 | 100% | 100 | Verde |  | 100% | 100 | 100% | 100 |  |  | Verde |
| 180 | 2.2.5.4.14 | Atividade Interna Renova |  | 1d | 2018-06-27 A | 2018-06-27 A | 165FS+41ed | 100% |  | 2018-06-27 | 2018-06-27 | 1d | 2018-06-27 | 2018-06-27 |  | Verde | Verde | 100% | 100 | 100 | 100% | 100 | Verde |  | 100% | 100 | 100% | 100 |  |  | Verde |
| 181 | 2.2.5.4.15 | Atividade Interna Renova |  | 1d | 2018-08-31 A | 2018-08-31 A | 165FS+106ed | 100% |  | 2018-08-31 | 2018-08-31 | 1d | 2018-08-31 | 2018-08-31 |  | Verde | Verde | 100% | 100 | 100 | 100% | 100 | Verde |  | 100% | 100 | 100% | 100 |  |  | Verde |
| 182 | 2.2.5.4.16 | Atividade Interna Renova |  | 1d | 2018-07-12 A | 2018-07-12 A | 165FS+56ed | 100% |  | 2018-07-12 | 2018-07-12 | 1d | 2018-07-12 | 2018-07-12 |  | Verde | Verde | 100% | 100 | 100 | 100% | 100 | Verde |  | 100% | 100 | 100% | 100 |  |  | Verde |
| 183 | 2.2.5.4.17 | Atividade Interna Renova |  | 1d | 2018-07-19 A | 2018-07-19 A | 165FS+63ed | 100% |  | 2018-07-19 | 2018-07-19 | 1d | 2018-07-19 | 2018-07-19 |  | Verde | Verde | 100% | 100 | 100 | 100% | 100 | Verde |  | 100% | 100 | 100% | 100 |  |  | Verde |
| 184 | 2.2.5.4.18 | Atividade Interna Renova |  | 1d | 2018-07-19 A | 2018-07-19 A | 165FS+63ed | 100% |  | 2018-07-19 | 2018-07-19 | 1d | 2018-07-19 | 2018-07-19 |  | Verde | Verde | 100% | 100 | 100 | 100% | 100 | Verde |  | 100% | 100 | 100% | 100 |  |  | Verde |
| 185 | 2.2.5.4.19 | Atividade Interna Renova |  | 1d | 2018-10-03 A | 2018-10-03 A | 165FS+139ed | 100% |  | 2018-10-03 | 2018-10-03 | 1d | 2018-10-03 | 2018-10-03 |  | Verde | Verde | 100% | 100 | 100 | 100% | 100 | Verde |  | 100% | 100 | 100% | 100 |  |  | Verde |
| 186 | 2.2.5.4.20 | Atividade Interna Renova |  | 1d | 2018-10-10 A | 2018-10-10 A | 165FS+146ed | 100% |  | 2018-10-10 | 2018-10-10 | 1d | 2018-10-10 | 2018-10-10 |  | Verde | Verde | 100% | 100 | 100 | 100% | 100 | Verde |  | 100% | 100 | 100% | 100 |  |  | Verde |
| 187 | 2.2.5.4.21 | Atividade Interna Renova |  | 1d | 2018-08-31 A | 2018-08-31 A | 165FS+106ed | 100% |  | 2018-08-31 | 2018-08-31 | 1d | 2018-08-31 | 2018-08-31 |  | Verde | Verde | 100% | 100 | 100 | 100% | 100 | Verde |  | 100% | 100 | 100% | 100 |  |  | Verde |
| 188 | 2.2.5.4.22 | Atividade Interna Renova |  | 1d | 2018-07-12 A | 2018-07-12 A | 165FS+56ed | 100% |  | 2018-07-12 | 2018-07-12 | 1d | 2018-07-12 | 2018-07-12 |  | Verde | Verde | 100% | 100 | 100 | 100% | 100 | Verde |  | 100% | 100 | 100% | 100 |  |  | Verde |
| 189 | 2.2.5.4.23 | Atividade Interna Renova |  | 1d | 2018-06-22 A | 2018-06-22 A | 165FS+36ed | 100% |  | 2018-06-22 | 2018-06-22 | 1d | 2018-06-22 | 2018-06-22 |  | Verde | Verde | 100% | 100 | 100 | 100% | 100 | Verde |  | 100% | 100 | 100% | 100 |  |  | Verde |
| 190 | 2.2.5.4.24 | Atividade Interna Renova |  | 1d | 2018-06-25 A | 2018-06-25 A | 165FS+39ed | 100% |  | 2018-06-25 | 2018-06-25 | 1d | 2018-06-25 | 2018-06-25 |  | Verde | Verde | 100% | 100 | 100 | 100% | 100 | Verde |  | 100% | 100 | 100% | 100 |  |  | Verde |
| 191 | 2.2.5.4.25 | Atividade Interna Renova |  | 1d | 2018-07-18 A | 2018-07-18 A | 165FS+62ed | 100% |  | 2018-07-18 | 2018-07-18 | 1d | 2018-07-18 | 2018-07-18 |  | Verde | Verde | 100% | 100 | 100 | 100% | 100 | Verde |  | 100% | 100 | 100% | 100 |  |  | Verde |
| 192 | 2.2.5.4.26 | Atividade Interna Renova |  | 1d | 2018-07-19 A | 2018-07-19 A | 165FS+63ed | 100% |  | 2018-07-19 | 2018-07-19 | 1d | 2018-07-19 | 2018-07-19 |  | Verde | Verde | 100% | 100 | 100 | 100% | 100 | Verde |  | 100% | 100 | 100% | 100 |  |  | Verde |
| 193 | 2.2.5.4.27 | Atividade Interna Renova |  | 1d | 2018-07-18 A | 2018-07-18 A | 165FS+62ed | 100% |  | 2018-07-18 | 2018-07-18 | 1d | 2018-07-18 | 2018-07-18 |  | Verde | Verde | 100% | 100 | 100 | 100% | 100 | Verde |  | 100% | 100 | 100% | 100 |  |  | Verde |
| 194 | 2.2.5.4.28 | Atividade Interna Renova |  | 1d | 2018-06-25 A | 2018-06-25 A | 165FS+39ed | 100% |  | 2018-06-25 | 2018-06-25 | 1d | 2018-06-25 | 2018-06-25 |  | Verde | Verde | 100% | 100 | 100 | 100% | 100 | Verde |  | 100% | 100 | 100% | 100 |  |  | Verde |
| 195 | 2.2.5.4.29 | Atividade Interna Renova |  | 1d | 2018-07-12 A | 2018-07-12 A | 165FS+56ed | 100% |  | 2018-07-12 | 2018-07-12 | 1d | 2018-07-12 | 2018-07-12 |  | Verde | Verde | 100% | 100 | 100 | 100% | 100 | Verde |  | 100% | 100 | 100% | 100 |  |  | Verde |
| 196 | 2.2.5.4.30 | Atividade Interna Renova |  | 1d | 2018-07-18 A | 2018-07-18 A | 165FS+62ed | 100% |  | 2018-07-18 | 2018-07-18 | 1d | 2018-07-18 | 2018-07-18 |  | Verde | Verde | 100% | 100 | 100 | 100% | 100 | Verde |  | 100% | 100 | 100% | 100 |  |  | Verde |
| 197 | 2.2.5.4.31 | Atividade Interna Renova |  | 1d | 2018-08-31 A | 2018-08-31 A | 165FS+106ed | 100% |  | 2018-08-31 | 2018-08-31 | 1d | 2018-08-31 | 2018-08-31 |  | Verde | Verde | 100% | 100 | 100 | 100% | 100 | Verde |  | 100% | 100 | 100% | 100 |  |  | Verde |
| 198 | 2.2.5.4.32 | Atividade Interna Renova |  | 1d | 2018-07-03 A | 2018-07-03 A | 165FS+47ed | 100% |  | 2018-07-03 | 2018-07-03 | 1d | 2018-07-03 | 2018-07-03 |  | Verde | Verde | 100% | 100 | 100 | 100% | 100 | Verde |  | 100% | 100 | 100% | 100 |  |  | Verde |
| 199 | 2.2.5.4.33 | Atividade Interna Renova |  | 1d | 2018-07-17 A | 2018-07-17 A | 165FS+61ed | 100% |  | 2018-07-17 | 2018-07-17 | 1d | 2018-07-17 | 2018-07-17 |  | Verde | Verde | 100% | 100 | 100 | 100% | 100 | Verde |  | 100% | 100 | 100% | 100 |  |  | Verde |
| 200 | 2.2.5.4.34 | Atividade Interna Renova |  | 1d | 2018-08-10 A | 2018-08-10 A | 165FS+85ed | 100% |  | 2018-08-10 | 2018-08-10 | 1d | 2018-08-10 | 2018-08-10 |  | Verde | Verde | 100% | 100 | 100 | 100% | 100 | Verde |  | 100% | 100 | 100% | 100 |  |  | Verde |
| 201 | 2.2.5.4.35 | Atividade Interna Renova |  | 1d | 2018-08-10 A | 2018-08-10 A | 165FS+85ed | 100% |  | 2018-08-10 | 2018-08-10 | 1d | 2018-08-10 | 2018-08-10 |  | Verde | Verde | 100% | 100 | 100 | 100% | 100 | Verde |  | 100% | 100 | 100% | 100 |  |  | Verde |
| 202 | 2.2.5.4.36 | Atividade Interna Renova |  | 1d | 2018-08-16 A | 2018-08-16 A | 165FS+91ed | 100% |  | 2018-08-16 | 2018-08-16 | 1d | 2018-08-16 | 2018-08-16 |  | Verde | Verde | 100% | 100 | 100 | 100% | 100 | Verde |  | 100% | 100 | 100% | 100 |  |  | Verde |
| 203 | 2.2.5.4.37 | Atividade Interna Renova |  | 1d | 2018-07-18 A | 2018-07-18 A | 165FS+62ed | 100% |  | 2018-07-18 | 2018-07-18 | 1d | 2018-07-18 | 2018-07-18 |  | Verde | Verde | 100% | 100 | 100 | 100% | 100 | Verde |  | 100% | 100 | 100% | 100 |  |  | Verde |
| 204 | 2.2.5.4.38 | Atividade Interna Renova |  | 1d | 2018-08-16 A | 2018-08-16 A | 165FS+91ed | 100% |  | 2018-08-16 | 2018-08-16 | 1d | 2018-08-16 | 2018-08-16 |  | Verde | Verde | 100% | 100 | 100 | 100% | 100 | Verde |  | 100% | 100 | 100% | 100 |  |  | Verde |
| 205 | 2.2.5.4.39 | Atividade Interna Renova |  | 1d | 2018-07-18 A | 2018-07-18 A | 165FS+62ed | 100% |  | 2018-07-18 | 2018-07-18 | 1d | 2018-07-18 | 2018-07-18 |  | Verde | Verde | 100% | 100 | 100 | 100% | 100 | Verde |  | 100% | 100 | 100% | 100 |  |  | Verde |
| 206 | 2.2.5.4.40 | Atividade Interna Renova | milestone | 0d | 2018-12-12 A | 2018-12-12 A | 175, 190, 205, 176, 193, 177, 189, 191, 195, 201, 202, 171, 183, 182, 174, 169, 204, 198, 185, 194, 167, 179, 203, 173, 184, 186, 200, 199, 168, 187, 197, 196, 180, 181, 192, 178, 172, 170, 188 | 100% |  | 2018-12-12 | 2018-12-12 | 0d |  |  |  | Verde | Verde | 100% | 100 | 100 | 0% |  | Vermelho |  | 100% | 100 | 0% |  |  |  | Verde |
| 207 | 2.2.5.5 | Atividade Interna Renova | milestone | 0d | 2025-02-24 | 2025-02-24 | 2910 |  |  | 2025-02-24 | 2025-02-24 | 0d | 2023-01-19 | 2023-01-19 | 240d | Verde | Verde | 0% |  |  | 0% |  | Verde |  | 0% |  | 0% |  | 02 - Execução | PG031 | Verde |
| 208 | 2.2.6 | Atividade Interna Renova | milestone | 0d | 2025-02-24 | 2025-02-24 | 141, 2910 |  |  | 2025-02-24 | 2025-02-24 | 0d |  |  | 0d | Verde | Verde | 0% |  |  | 0% |  | Verde |  | 0% |  | 0% |  |  |  | Verde |

| ID | WBS | Task | Type | Duration | Start | Finish | Predecessors | Complete | Remaining | Baseline start | Baseline finish | Baseline duration | Baseline 1 start | Baseline 1 finish | Total slack | Free slack | Farol de Atraso | Farol Marcos | % Previsto Tempo | % Previsto Tempo Numérico | Índice de Desempenho Físico (IDF) | IDF Numérico | Farol IDF | % Previsto Ponderado | % Concluído Ponderado | % Concluída Numérico | % Previsto Ponderado Numérico | Farol de Início | Responsável | Código do Contrato |
| --- | --- | --- | --- | --- | --- | --- | --- | --- | --- | --- | --- | --- | --- | --- | --- | --- | --- | --- | --- | --- | --- | --- | --- | --- | --- | --- | --- | --- | --- | --- |
| 209 | 2.3 | **PF 8136-3: Processo de Repasse de Recursos aos Municípios** |  | 1670d | 2018-06-15 A | 2025-02-24 |  | 6% | 1565.57d | 2018-06-15 | 2025-02-24 | 1670d | 2018-08-28 | 2023-01-19 | 240d |  | Verde | Verde | 13% | 13 | 100% | 100 | Verde | 1% | 1% |  |  |  |  |  |
| 210 | 2.3.1 | **Aimorés** |  | 973d | 2019-04-23 A | 2023-03-21 |  |  | 973d | 2019-04-23 | 2023-03-21 | 973d | 2019-02-04 | 2022-05-19 | 480d |  | Verde | Verde | 0% |  | 0% |  | Verde | 0% | 0% |  |  |  |  |  |
| 211 | 2.3.1.1 | **Pleito AIMESPJ03 - Elaboração de projeto, incluindo levantamento topográfico e licenciamento para tratamento dos esgotos sanitários gerados somente na sede** |  | 313d | 2019-04-23 A | 2020-07-24 |  |  | 313d | 2019-04-23 | 2020-07-24 | 313d |  |  | 1140d |  | Verde | Verde | 1% |  | 0% |  | Vermelho | 0% | 0% |  |  |  |  |  |
| 212 | 2.3.1.1.1 | Pleito aprovado | milestone | 0d | 2019-04-23 A | 2019-04-23 A | 206FS+88d | 100% |  | 2019-04-23 | 2019-04-23 | 0d |  |  |  |  | Verde | Verde | 100% | 100 | 0% |  | Vermelho | 100% | 0% | 100 | 100 | Verde |  |  |
| 213 | 2.3.1.1.2 | **Licitação do projeto** |  | 61d | 2019-05-08 | 2019-08-02 |  |  |  | 2019-05-08 | 2019-08-02 | 61d |  |  | 1140d |  | Verde | Verde | 0% |  | 0% |  | Verde | 0% | 0% |  |  |  |  |  |
| 214 | 2.3.1.1.2.1 | Licitação do projeto autorizada pelo banco | milestone | 0d | 2019-05-08 | 2019-05-08 | 212FS+10d |  |  | 2019-05-08 | 2019-05-08 | 0d |  |  | 1140d | 0d | Verde | Verde | 0% |  | 0% |  | Verde | 0% | 0% |  |  | Verde |  |  |
| 215 | 2.3.1.1.2.2 | Licitar projeto |  | 41d | 2019-05-09 | 2019-07-05 | 214 |  |  | 2019-05-09 | 2019-07-05 | 41d |  |  | 1140d | 0d | Verde | Verde | 0% |  | 0% |  | Verde | 0% | 0% |  |  | Verde |  |  |
| 216 | 2.3.1.1.2.3 | Documentação de licitação apresentada ao banco | milestone | 0d | 2019-07-12 | 2019-07-12 | 215FS+5d |  |  | 2019-07-12 | 2019-07-12 | 0d |  |  | 1140d | 0d | Verde | Verde | 0% |  | 0% |  | Verde | 0% | 0% |  |  | Verde |  |  |
| 217 | 2.3.1.1.2.4 | Analisar e emitir resultado da licitação do projeto |  | 15d | 2019-07-15 | 2019-08-02 | 216 |  |  | 2019-07-15 | 2019-08-02 | 15d |  |  | 1140d | 0d | Verde | Verde | 0% |  | 0% |  | Verde | 0% | 0% |  |  | Verde |  |  |
| 218 | 2.3.1.1.2.5 | Licitação do projeto concluída | milestone | 0d | 2019-08-02 | 2019-08-02 | 217 |  |  | 2019-08-02 | 2019-08-02 | 0d |  |  | 1140d | 0d | Verde | Verde | 0% |  | 0% |  | Verde | 0% | 0% |  |  | Verde |  |  |
| 219 | 2.3.1.1.3 | **Elaboração do Projeto Básico** |  | 141d | 2019-08-05 | 2020-02-28 |  |  |  | 2019-08-05 | 2020-02-28 | 141d |  |  | 1140d |  | Verde | Verde | 0% |  | 0% |  | Verde | 0% | 0% |  |  |  |  |  |
| 220 | 2.3.1.1.3.1 | Elaborar Projeto Básico |  | 67d | 2019-08-05 | 2019-11-06 | 218 |  |  | 2019-08-05 | 2019-11-06 | 67d | 2019-05-05 | 2019-08-03 | 1140d | 0d | Verde | Verde | 0% |  | 0% |  | Verde | 0% | 0% |  |  | Verde | 02 - Execução | PG 031 |
| 221 | 2.3.1.1.3.2 | Projeto Básico apresentado ao banco | milestone | 0d | 2019-11-06 | 2019-11-06 | 220 |  |  | 2019-11-06 | 2019-11-06 | 0d |  |  | 1140d | 0d | Verde | Verde | 0% |  | 0% |  | Verde | 0% | 0% |  |  | Verde |  |  |
| 222 | 2.3.1.1.3.3 | Analisar Projeto Básico |  | 22d | 2019-11-07 | 2019-12-09 | 221 |  |  | 2019-11-07 | 2019-12-09 | 22d |  |  | 1140d | 0d | Verde | Verde | 0% |  | 0% |  | Verde | 0% | 0% |  |  | Verde |  |  |
| 223 | 2.3.1.1.3.4 | Adequar/revisar Projeto Básico |  | 23d | 2019-12-10 | 2020-01-15 | 222 |  |  | 2019-12-10 | 2020-01-15 | 23d |  |  | 1236d | 0d | Verde | Verde | 0% |  | 0% |  | Verde | 0% | 0% |  |  | Verde |  |  |
| 224 | 2.3.1.1.3.5 | Analisar Projeto Básico - final |  | 24d | 2020-01-16 | 2020-02-18 | 223 |  |  | 2020-01-16 | 2020-02-18 | 24d |  |  | 1236d | 0d | Verde | Verde | 0% |  | 0% |  | Verde | 0% | 0% |  |  | Verde |  |  |
| 225 | 2.3.1.1.3.6 | Projeto Básico concluído | milestone | 0d | 2020-02-18 | 2020-02-18 | 224 |  |  | 2020-02-18 | 2020-02-18 | 0d |  |  | 1236d | 0d | Verde | Verde | 0% |  | 0% |  | Verde | 0% | 0% |  |  | Verde |  |  |
| 226 | 2.3.1.1.3.7 | Recurso do Projeto Básico do pleito AIMESPJ03 repassado | milestone | 0d | 2020-02-28 | 2020-02-28 | 225FS+5d |  |  | 2020-02-28 | 2020-02-28 | 0d |  |  | 1236d | 96d | Verde | Verde | 0% |  | 0% |  | Verde | 0% | 0% |  |  | Verde |  |  |
| 227 | 2.3.1.1.4 | Realizar Licenciamento Ambiental |  | 133d | 2019-11-07 | 2020-05-26 | 220 |  |  | 2019-11-07 | 2020-05-26 | 133d | 2019-08-03 | 2020-01-30 | 1177d | 37d | Verde | Verde | 0% |  | 0% |  | Verde | 0% | 0% |  |  | Verde | 02 - Execução | PG 031 |
| 228 | 2.3.1.1.5 | **Elaboração do Projeto Executivo** |  | 175d | 2019-11-07 | 2020-07-24 |  |  |  | 2019-11-07 | 2020-07-24 | 175d |  |  | 1140d |  | Verde | Verde | 0% |  | 0% |  | Verde | 0% | 0% |  |  |  |  |  |
| 229 | 2.3.1.1.5.1 | Elaborar Projeto Executivo |  | 66d | 2019-11-07 | 2020-02-13 | 221 |  |  | 2019-11-07 | 2020-02-13 | 66d | 2019-08-03 | 2019-12-01 | 1177d | 0d | Verde | Verde | 0% |  | 0% |  | Verde | 0% | 0% |  |  | Verde | 02 - Execução | PG 031 |
| 230 | 2.3.1.1.5.2 | Projeto Executivo apresentado ao banco | milestone | 0d | 2020-02-13 | 2020-02-13 | 229 |  |  | 2020-02-13 | 2020-02-13 | 0d |  |  | 1177d | 0d | Verde | Verde | 0% |  | 0% |  | Verde | 0% | 0% |  |  | Verde |  |  |
| 231 | 2.3.1.1.5.3 | Analisar Projeto Executivo |  | 22d | 2020-02-14 | 2020-03-19 | 230 |  |  | 2020-02-14 | 2020-03-19 | 22d |  |  | 1177d | 0d | Verde | Verde | 0% |  | 0% |  | Verde | 0% | 0% |  |  | Verde |  |  |
| 232 | 2.3.1.1.5.4 | Adequar/revisar Projeto Executivo |  | 22d | 2020-03-20 | 2020-04-22 | 231 |  |  | 2020-03-20 | 2020-04-22 | 22d |  |  | 1177d | 0d | Verde | Verde | 0% |  | 0% |  | Verde | 0% | 0% |  |  | Verde |  |  |
| 233 | 2.3.1.1.5.5 | Analisar Projeto Executivo - final |  | 23d | 2020-04-23 | 2020-05-26 | 232 |  |  | 2020-04-23 | 2020-05-26 | 23d |  |  | 1177d | 37d | Verde | Verde | 0% |  | 0% |  | Verde | 0% | 0% |  |  | Verde |  |  |
| 234 | 2.3.1.1.5.6 | Projeto Executivo concluído | milestone | 0d | 2020-07-17 | 2020-07-17 | 233, 246, 227, 226 |  |  | 2020-07-17 | 2020-07-17 | 0d |  |  | 1140d | 0d | Verde | Verde | 0% |  | 0% |  | Verde | 0% | 0% |  |  | Verde |  |  |
| 235 | 2.3.1.1.5.7 | Recurso do Projeto Executivo do pleito AIMESPJ03 repassado | milestone | 0d | 2020-07-24 | 2020-07-24 | 234FS+5d |  |  | 2020-07-24 | 2020-07-24 | 0d |  |  | 1140d | 0d | Verde | Verde | 0% |  | 0% |  | Verde | 0% | 0% |  |  | Verde |  |  |
| 236 | 2.3.1.1.6 | Pleito AIMESPJ03 concluído | milestone | 0d | 2020-07-24 | 2020-07-24 | 235 |  |  | 2020-07-24 | 2020-07-24 | 0d |  |  | 1140d | 106d | Verde | Verde | 0% |  | 0% |  | Verde | 0% | 0% |  |  | Verde |  |  |

Notes:
- 209: Premissas: / Como não temos dados suficientes das ações a serem implantadas pelos municípios, devido aos pleitos incompletos e mesmo pelo tempo de execução destas ações que não cabem à Renova, é importante considerar: / ·Os municípios ainda não definiram todas as ações a serem executadas / ·Os municípios irão contratar diretamente os projetos e obras a serem executados e não temos ainda o cronograma destas atividades / ·Não sabemos ainda o impacto do prazo para o licenciamento das áreas necessárias para a implantação do programa nos municípios / ·Diante destes fatos, adotamos como premissa para o cronograma de obra, o valor financeiro destinado às mesmas de acordo com o pleito dos munícipios: / Até 1.000.000 - 6 meses / De 1.000.001 a 3.000.000 - 8 meses / De 3.000.001 a 5.000.000 - 12 meses / De 5.000.001 a 7.000.000 - 15 meses / De 7.000.001 a 9.000.000 - 18 meses / De 9.000.001 a 11.000.000 - 20 meses / De 11.000.001 a 14.000.000 - 24 meses / Acima de 14.000.000 - 30 meses / ·Na parte de licenciamento usamos como premissa dois prazos / 6 meses - Até 30.000 hab./ Até 50l/s / 9 meses - Maior que 30.000hab./ maior que 50l/s / ·Licitação de Projetos/Obras / 2/3/4 meses / ·Elaboração de projetos - Prazo depende do porte da obra e do prazo de licenciamento / Projeto Básico - 2 meses/3 meses / Projeto Executivo - 2meses/4 meses/ 6 meses/ 9 meses / ·Gestão das ações implementadas / 6 meses / Ainda deverá ser detalhado por munícipio as ações de Resíduos Sólidos. Como a maioria dos munícipios ainda não têm os pleitos aprovados e os consórcios ainda estão em fase de planejamento, deve-se esperar uma maturidade maior para fazer eata programação.
- 210: Aimorés teve 33,2% dos pleitos de Esgotamento Sanitário aprovado (R$3.664.703,00), conforme Deliberação 75. / O município teve o pleito de resíduos sólidos negado (R$1.102.965,05), equivalente a 10% do total do recurso,). / Aimorés solicitou mudança de pleito, conforme abaixo, mas ainda não foi autorizado pelo CIF. / Solicitação: Substituição dos distritos de São Sebastião da Vala e Mundo Novo pela sede para implantação de SES (R$ 9.326.685,45) e Aquisição de terreno (R$ 200.000,00).
- 212: Em 12/04/19: o pleito foi aprovado na CT (NT36) e pode ser aprovado no próximo CIF (26/04) / Em 26/04/19: pleito aprovado no CIF dia 23/04/2019 na deliberação 276.

| ID | WBS | Task | Type | Duration | Start | Finish | Predecessors | Complete | Remaining | Baseline start | Baseline finish | Baseline duration | Baseline 1 start | Baseline 1 finish | Total slack | Free slack | Farol de Atraso | Farol Marcos | % Previsto Tempo | Índice de Desempenho Físico (IDF) | Farol IDF | % Previsto Ponderado | % Concluído Ponderado | % Concluída Numérico | % Previsto Tempo Numérico | % Previsto Ponderado Numérico | Farol de Início | Responsável | Código do Contrato |
| --- | --- | --- | --- | --- | --- | --- | --- | --- | --- | --- | --- | --- | --- | --- | --- | --- | --- | --- | --- | --- | --- | --- | --- | --- | --- | --- | --- | --- | --- |
| 237 | 2.3.1.2 | **Pleito AIMESCT02 - Aquisição de terreno** |  | 308d | 2019-04-23 A | 2020-07-17 |  |  | 308d | 2019-04-23 | 2020-07-17 | 308d |  |  | 1145d |  | Verde | Verde | 1% | 0% | Vermelho | 0% | 0% |  |  |  |  |  |  |
| 238 | 2.3.1.2.1 | Pleito aprovado | milestone | 0d | 2019-04-23 A | 2019-04-23 A | 212 | 100% |  | 2019-04-23 | 2019-04-23 | 0d |  |  |  |  | Verde | Verde | 100% | 0% | Vermelho | 100% | 0% | 100 | 100 | 100 | Verde |  |  |
| 239 | 2.3.1.2.2 | **Aquisição de terreno** |  | 148d | 2019-12-10 | 2020-07-17 |  |  |  | 2019-12-10 | 2020-07-17 | 148d |  |  | 1140d |  | Verde | Verde | 0% | 0% | Verde | 0% | 0% |  |  |  |  |  |  |
| 240 | 2.3.1.2.2.1 | Regularizar terreno e apresentar escritura ao banco |  | 88d | 2019-12-10 | 2020-04-22 | 222 |  |  | 2019-12-10 | 2020-04-22 | 88d |  |  | 1140d | 0d | Verde | Verde | 0% | 0% | Verde | 0% | 0% |  |  |  | Verde |  |  |
| 241 | 2.3.1.2.2.2 | Analisar documentação do terreno |  | 10d | 2020-04-23 | 2020-05-07 | 240 |  |  | 2020-04-23 | 2020-05-07 | 10d |  |  | 1185d | 0d | Verde | Verde | 0% | 0% | Verde | 0% | 0% |  |  |  | Verde |  |  |
| 242 | 2.3.1.2.2.3 | 50% do valor do imóvel repassado (1) | milestone | 0d | 2020-05-14 | 2020-05-14 | 241FS+5d |  |  | 2020-05-14 | 2020-05-14 | 0d |  |  | 1185d | 45d | Verde | Verde | 0% | 0% | Verde | 0% | 0% |  |  |  | Verde |  |  |
| 243 | 2.3.1.2.2.4 | Registrar imóvel e apresentar documentação ao banco |  | 45d | 2020-04-23 | 2020-06-26 | 240 |  |  | 2020-04-23 | 2020-06-26 | 45d |  |  | 1140d | 0d | Verde | Verde | 0% | 0% | Verde | 0% | 0% |  |  |  | Verde |  |  |
| 244 | 2.3.1.2.2.5 | Analisar documentação do terreno |  | 10d | 2020-06-29 | 2020-07-10 | 243 |  |  | 2020-06-29 | 2020-07-10 | 10d |  |  | 1140d | 0d | Verde | Verde | 0% | 0% | Verde | 0% | 0% |  |  |  | Verde |  |  |
| 245 | 2.3.1.2.2.6 | 50% do valor do imóvel repassado (2) | milestone | 0d | 2020-07-17 | 2020-07-17 | 244FS+5d |  |  | 2020-07-17 | 2020-07-17 | 0d |  |  | 1140d | 0d | Verde | Verde | 0% | 0% | Verde | 0% | 0% |  |  |  | Verde |  |  |
| 246 | 2.3.1.2.2.7 | Aquisição de terreno concluída | milestone | 0d | 2020-07-17 | 2020-07-17 | 242, 245 |  |  | 2020-07-17 | 2020-07-17 | 0d |  |  | 1140d | 0d | Verde | Verde | 0% | 0% | Verde | 0% | 0% |  |  |  | Verde |  |  |
| 247 | 2.3.1.2.3 | Pleito AIMESCT02 concluído | milestone | 0d | 2020-07-17 | 2020-07-17 | 246 |  |  | 2020-07-17 | 2020-07-17 | 0d |  |  | 1145d | 111d | Verde | Verde | 0% | 0% | Verde | 0% | 0% |  |  |  | Verde |  |  |
| 248 | 2.3.1.3 | **Pleito de Aimorés a definir - Implantação de SES na sede do município (R$ 9.326.685,45)** |  | 651d | 2020-05-29 | 2023-01-09 |  |  |  | 2020-05-29 | 2023-01-09 | 651d |  |  | 528d |  | Verde | Verde | 0% | 0% | Verde | 0% | 0% |  |  |  |  |  |  |
| 249 | 2.3.1.3.1 | Pleito aprovado | milestone | 0d | 2020-05-29 | 2020-05-29 | 206FS+362d |  |  | 2020-05-29 | 2020-05-29 | 0d |  |  | 528d | 0d | Verde | Verde | 0% | 0% | Verde | 0% | 0% |  |  |  | Verde |  |  |
| 250 | 2.3.1.3.2 | **Licitação da obra** |  | 82d | 2020-06-15 | 2020-10-08 |  |  |  | 2020-06-15 | 2020-10-08 | 82d |  |  | 528d |  | Verde | Verde | 0% | 0% | Verde | 0% | 0% |  |  |  |  |  |  |
| 251 | 2.3.1.3.2.1 | Licitação da obra autorizada pelo banco | milestone | 0d | 2020-06-15 | 2020-06-15 | 249FS+10d |  |  | 2020-06-15 | 2020-06-15 | 0d |  |  | 528d | 0d | Verde | Verde | 0% | 0% | Verde | 0% | 0% |  |  |  | Verde |  |  |
| 252 | 2.3.1.3.2.2 | Licitar obra |  | 67d | 2020-06-16 | 2020-09-17 | 251 |  |  | 2020-06-16 | 2020-09-17 | 67d | 2019-12-01 | 2020-03-30 | 528d | 0d | Verde | Verde | 0% | 0% | Verde | 0% | 0% |  |  |  | Verde | 02 - Execução | PG 031 |
| 253 | 2.3.1.3.2.3 | Analisar e emitir resultado da licitação da obra |  | 15d | 2020-09-18 | 2020-10-08 | 252 |  |  | 2020-09-18 | 2020-10-08 | 15d |  |  | 528d | 0d | Verde | Verde | 0% | 0% | Verde | 0% | 0% |  |  |  | Verde |  |  |
| 254 | 2.3.1.3.2.4 | Licitação da obra concluída | milestone | 0d | 2020-10-08 | 2020-10-08 | 253 |  |  | 2020-10-08 | 2020-10-08 | 0d |  |  | 528d | 0d | Verde | Verde | 0% | 0% | Verde | 0% | 0% |  |  |  | Verde |  |  |
| 255 | 2.3.1.3.3 | Executar obra |  | 400d | 2020-11-12 | 2022-06-22 | 254FS+22d |  |  | 2020-11-12 | 2022-06-22 | 400d |  |  | 528d | 0d | Verde | Verde | 0% | 0% | Verde | 0% | 0% |  |  |  | Verde |  |  |
| 256 | 2.3.1.3.4 | Realizar processo de pré-operação |  | 132d | 2022-06-23 | 2023-01-02 | 255 |  |  | 2022-06-23 | 2023-01-02 | 132d | 2021-11-20 | 2022-05-19 | 528d | 0d | Verde | Verde | 0% | 0% | Verde | 0% | 0% |  |  |  | Verde | 02 - Execução | PG 031 |
| 257 | 2.3.1.3.5 | Recurso da obra parcelado repassado | milestone | 0d | 2023-01-09 | 2023-01-09 | 256FS+5d |  |  | 2023-01-09 | 2023-01-09 | 0d |  |  | 528d | 0d | Verde | Verde | 0% | 0% | Verde | 0% | 0% |  |  |  | Verde |  |  |
| 258 | 2.3.1.3.6 | Pleito de Aimorés a definir concluído | milestone | 0d | 2023-01-09 | 2023-01-09 | 257 |  |  | 2023-01-09 | 2023-01-09 | 0d |  |  | 528d | 48d | Verde | Verde | 0% | 0% | Verde | 0% | 0% |  |  |  | Verde |  |  |
| 259 | 2.3.1.4 | **Pleito de Aimorés de Resíduos Sólidos a definir** |  | 883d | 2019-08-30 | 2023-03-21 |  |  |  | 2019-08-30 | 2023-03-21 | 883d |  |  | 480d |  | Verde | Verde | 0% | 0% | Verde | 0% | 0% |  |  |  |  |  |  |
| 260 | 2.3.1.4.1 | Pleito aprovado | milestone | 0d | 2019-08-30 | 2019-08-30 | 206FS+178d |  |  | 2019-08-30 | 2019-08-30 | 0d |  |  | 480d | 0d | Verde | Verde | 0% | 0% | Verde | 0% | 0% |  |  |  | Verde |  |  |
| 261 | 2.3.1.4.2 | Iniciar pleito |  | 1d | 2019-09-02 | 2019-09-02 | 260 |  |  | 2019-09-02 | 2019-09-02 | 1d |  |  | 480d | 0d | Verde | Verde | 0% | 0% | Verde | 0% | 0% |  |  |  | Verde |  |  |
| 262 | 2.3.1.4.3 | Pleito de Aimorés de Resíduos Sólidos concluído | milestone | 0d | 2023-03-21 | 2023-03-21 | 261FS+882d |  |  | 2023-03-21 | 2023-03-21 | 0d |  |  | 480d | 0d | Verde | Verde | 0% | 0% | Verde | 0% | 0% |  |  |  | Verde |  |  |
| 263 | 2.3.1.5 | Recursos de Aimorés repassados | milestone | 0d | 2023-03-21 | 2023-03-21 | 236, 258, 262, 247 |  |  | 2023-03-21 | 2023-03-21 | 0d |  |  | 480d |  | Verde | Verde | 0% | 0% | Verde | 0% | 0% |  |  |  | Verde |  |  |

Notes:
- 249: Em 12/04/19: Usando o cronograma da NT 33 o pleito será analisado e aprovado pelo CT/CIF até o dia 31/05/2020
- 260: Em 24/04/2019: considerado que pleito será elaborado até julho e aprovado no CT/CIF de agosto 2019

| ID | WBS | Task | Type | Duration | Start | Finish | Predecessors | Complete | Remaining | Baseline start | Baseline finish | Baseline duration | Baseline 1 start | Baseline 1 finish | Total slack | Free slack | Farol de Atraso | Farol Marcos | % Previsto Tempo | % Concluída Numérico | % Previsto Tempo Numérico | Índice de Desempenho Físico (IDF) | IDF Numérico | Farol IDF | % Previsto Ponderado | % Concluído Ponderado | % Previsto Ponderado Numérico | % Concluído Ponderado Numérico | Responsável | Código do Contrato | Farol de Início |
| --- | --- | --- | --- | --- | --- | --- | --- | --- | --- | --- | --- | --- | --- | --- | --- | --- | --- | --- | --- | --- | --- | --- | --- | --- | --- | --- | --- | --- | --- | --- | --- |
| 264 | 2.3.2 | **Alpercata** |  | 945d | 2018-06-15 A | 2022-03-25 |  | 19% | 768.34d | 2018-06-15 | 2022-03-25 | 945d | 2018-10-09 | 2021-05-26 | 725d |  | Verde | Verde | 23% | 19 | 23 | 100% | 100 | Verde | 2% | 2% |  |  |  |  |  |
| 265 | 2.3.2.1 | **Pleito ALPESPJ01 - Elaboração de projeto de sistema de esgotamento sanitário da sede do município e distrito de Era Nova** |  | 389d | 2018-10-09 A | 2020-05-04 |  | 22% | 303.45d | 2018-10-09 | 2020-05-04 | 389d |  |  | 1198d |  | Verde | Verde | 35% | 22 | 35 | 100% | 100 | Verde | 15% | 15% | 15 | 15 |  |  |  |
| 266 | 2.3.2.1.1 | **Licitação do projeto** |  | 129d | 2018-10-09 A | 2019-04-12 A |  | 100% |  | 2018-10-09 | 2019-04-12 | 129d |  |  |  |  | Verde | Verde | 100% | 100 | 100 | 100% | 100 | Verde | 100% | 100% | 100 | 100 |  |  |  |
| 267 | 2.3.2.1.1.1 | Licitar projeto |  | 85d | 2018-10-09 A | 2019-02-12 A | 168FS+92ed | 100% |  | 2018-10-09 | 2019-02-12 | 85d | 2018-10-09 | 2019-01-07 |  |  | Verde | Verde | 100% | 100 | 100 | 100% | 100 | Verde | 100% | 100% | 100 | 100 | 02 - Execução | PG 031 | Verde |
| 268 | 2.3.2.1.1.2 | Documentação de licitação apresentada ao banco | milestone | 0d | 2019-03-28 A | 2019-03-28 A | 267FS+29d | 100% |  | 2019-03-28 | 2019-03-28 | 0d |  |  |  |  | Verde | Verde | 100% | 100 | 100 | 0% |  | Vermelho | 100% | 0% | 100 |  |  |  | Verde |
| 269 | 2.3.2.1.1.3 | Analisar e emitir resultado da análise de licitação do projeto |  | 11d | 2019-03-29 A | 2019-04-12 A | 268 | 100% |  | 2019-03-29 | 2019-04-12 | 11d |  |  |  |  | Verde | Verde | 100% | 100 | 100 | 100% | 100 | Verde | 100% | 100% | 100 | 100 |  |  | Verde |
| 270 | 2.3.2.1.1.4 | Licitação do projeto concluída | milestone | 0d | 2019-04-12 A | 2019-04-12 A | 269 | 100% |  | 2019-04-12 | 2019-04-12 | 0d |  |  |  |  | Verde | Verde | 100% | 100 | 100 | 0% |  | Vermelho | 100% | 0% | 100 |  |  |  | Verde |
| 271 | 2.3.2.1.2 | **Elaboração do Projeto Básico** |  | 130d | 2019-04-15 A | 2019-10-18 |  | 8% | 119.6d | 2019-04-15 | 2019-10-18 | 130d |  |  | 850d |  | Verde | Verde | 7% |  |  | 100% | 100 | Verde | 11% | 11% | 11 | 11 |  |  |  |
| 272 | 2.3.2.1.2.1 | Elaborar Projeto Básico |  | 59d | 2019-04-15 A | 2019-07-10 | 270 | 17% | 49d | 2019-04-15 | 2019-07-10 | 59d | 2019-01-07 | 2019-04-07 | 789d | 0d | Verde | Verde | 16% | 17 | 16 | 106% | 106 | Verde | 16% | 17% | 16 | 17 | 02 - Execução | PG 031 | Verde |
| 273 | 2.3.2.1.2.2 | Projeto básico apresentado ao banco | milestone | 0d | 2019-07-10 | 2019-07-10 | 272 |  |  | 2019-07-10 | 2019-07-10 | 0d |  |  | 850d | 0d | Verde | Verde | 0% |  |  | 0% |  | Verde | 0% | 0% |  |  |  |  | Verde |
| 274 | 2.3.2.1.2.3 | Analisar Projeto Básico |  | 23d | 2019-07-11 | 2019-08-12 | 273 |  |  | 2019-07-11 | 2019-08-12 | 23d |  |  | 850d | 0d | Verde | Verde | 0% |  |  | 0% |  | Verde | 0% | 0% |  |  |  |  | Verde |
| 275 | 2.3.2.1.2.4 | Adequar/revisar projeto básico |  | 21d | 2019-08-13 | 2019-09-11 | 274 |  |  | 2019-08-13 | 2019-09-11 | 21d |  |  | 850d | 0d | Verde | Verde | 0% |  |  | 0% |  | Verde | 0% | 0% |  |  |  |  | Verde |
| 276 | 2.3.2.1.2.5 | Analisar projeto básico - final |  | 22d | 2019-09-12 | 2019-10-11 | 275 |  |  | 2019-09-12 | 2019-10-11 | 22d |  |  | 850d | 0d | Verde | Verde | 0% |  |  | 0% |  | Verde | 0% | 0% |  |  |  |  | Verde |
| 277 | 2.3.2.1.2.6 | Projeto básico concluído | milestone | 0d | 2019-10-11 | 2019-10-11 | 276 |  |  | 2019-10-11 | 2019-10-11 | 0d |  |  | 850d | 0d | Verde | Verde | 0% |  |  | 0% |  | Verde | 0% | 0% |  |  |  |  | Verde |
| 278 | 2.3.2.1.2.7 | Recurso do projeto básico do pleito ALPESPJ01 repassado | milestone | 0d | 2019-10-18 | 2019-10-18 | 277FS+5d |  |  | 2019-10-18 | 2019-10-18 | 0d |  |  | 850d | 125d | Verde | Verde | 0% |  |  | 0% |  | Verde | 0% | 0% |  |  |  |  | Verde |
| 279 | 2.3.2.1.3 | Realizar Licenciamento Ambiental |  | 132d | 2019-07-11 | 2020-01-20 | 272 |  |  | 2019-07-11 | 2020-01-20 | 132d | 2019-04-07 | 2019-10-04 | 789d | 64d | Verde | Verde | 0% |  |  | 0% |  | Verde | 0% | 0% |  |  | 02 - Execução | PG 031 | Verde |
| 280 | 2.3.2.1.4 | **Elaboração do Projeto Executivo** |  | 199d | 2019-07-15 | 2020-05-04 |  |  |  | 2019-07-15 | 2020-05-04 | 199d |  |  | 790d |  | Verde | Verde | 0% |  |  | 0% |  | Verde | 0% | 0% |  |  |  |  |  |
| 281 | 2.3.2.1.4.1 | Elaborar Projeto Executivo |  | 64d | 2019-07-15 | 2019-10-11 | 272FS+2d |  |  | 2019-07-15 | 2019-10-11 | 64d | 2019-04-07 | 2019-08-05 | 790d | 0d | Verde | Verde | 0% |  |  | 0% |  | Verde | 0% | 0% |  |  | 02 - Execução | PG 031 | Verde |
| 282 | 2.3.2.1.4.2 | Projeto executivo apresentado ao banco | milestone | 0d | 2019-10-11 | 2019-10-11 | 281 |  |  | 2019-10-11 | 2019-10-11 | 0d |  |  | 790d | 0d | Verde | Verde | 0% |  |  | 0% |  | Verde | 0% | 0% |  |  |  |  | Verde |
| 283 | 2.3.2.1.4.3 | Analisar projeto executivo |  | 22d | 2019-10-14 | 2019-11-12 | 282 |  |  | 2019-10-14 | 2019-11-12 | 22d |  |  | 790d | 0d | Verde | Verde | 0% |  |  | 0% |  | Verde | 0% | 0% |  |  |  |  | Verde |
| 284 | 2.3.2.1.4.4 | Adequar/revisar projeto executivo |  | 20d | 2019-11-13 | 2019-12-11 | 283 |  |  | 2019-11-13 | 2019-12-11 | 20d |  |  | 790d | 0d | Verde | Verde | 0% |  |  | 0% |  | Verde | 0% | 0% |  |  |  |  | Verde |
| 285 | 2.3.2.1.4.5 | Analisar projeto executivo - final |  | 23d | 2019-12-13 | 2020-01-17 | 284 |  |  | 2019-12-13 | 2020-01-17 | 23d |  |  | 790d | 65d | Verde | Verde | 0% |  |  | 0% |  | Verde | 0% | 0% |  |  |  |  | Verde |
| 286 | 2.3.2.1.4.6 | Projeto executivo concluído | milestone | 0d | 2020-04-24 | 2020-04-24 | 285, 279, 299, 278 |  |  | 2020-04-24 | 2020-04-24 | 0d |  |  | 725d | 0d | Verde | Verde | 0% |  |  | 0% |  | Verde | 0% | 0% |  |  |  |  | Verde |
| 287 | 2.3.2.1.4.7 | Recurso do projeto executivo do pleito ALPESPJ01 repassado | milestone | 0d | 2020-05-04 | 2020-05-04 | 286FS+5d |  |  | 2020-05-04 | 2020-05-04 | 0d |  |  | 1198d | 0d | Verde | Verde | 0% |  |  | 0% |  | Verde | 0% | 0% |  |  |  |  | Verde |
| 288 | 2.3.2.1.5 | Pleito ALPESPJ01 concluído | milestone | 0d | 2020-05-04 | 2020-05-04 | 287 |  |  | 2020-05-04 | 2020-05-04 | 0d |  |  | 1198d | 473d | Verde | Verde | 0% |  |  | 0% |  | Verde | 0% | 0% |  |  |  |  | Verde |

Notes:
- 264: O pleito de Esgotamento Sanitário de Alpercata, contempla apenas a elaboração do projeto da sede do município e do distrito de Nova Era (5,3% do valor de SES- R$250.000,00), conforme Deliberação 75. Somente após o projeto vai ser feito o pleito para as obras. Este pleito foi aprovado. / O município teve 0,8%, dos 10% do valor teto destinado a Resíduos Sólidos aprovado (R$37.131,34).
- 267: Em 11/04/2019: premissa de início de licitação baseado no início da elaboração do TR.
- 272: Em 29/04/2019: atualizado como agendado
- 278: Em 11/04/19: 5 dias após a aprovação do projeto básico o município receberá o recurso do projeto básico (40% do valor do projeto total)
- 279: Em 11/04/19: Início do licenciamento igual o fim da elaboração do projeto básico e término igual a aprovação do projeto executivo pelo banco
- 287: Em 11/04/19: o pagamento do recurso do projeto executivo (60% do valor do projeto total) será realizado 5 dias após a aprovação do mesmo

| ID | WBS | Task | Type | Duration | Start | Finish | Predecessors | Complete | Remaining | Baseline start | Baseline finish | Baseline duration | Baseline 1 start | Baseline 1 finish | Total slack | Free slack | Farol de Atraso | Farol Marcos | % Previsto Tempo | Índice de Desempenho Físico (IDF) | Farol IDF | % Previsto Ponderado | % Concluído Ponderado | Farol de Início | Responsável | Código do Contrato | % Concluída Numérico | % Previsto Tempo Numérico | IDF Numérico | % Previsto Ponderado Numérico | % Concluído Ponderado Numérico |
| --- | --- | --- | --- | --- | --- | --- | --- | --- | --- | --- | --- | --- | --- | --- | --- | --- | --- | --- | --- | --- | --- | --- | --- | --- | --- | --- | --- | --- | --- | --- | --- |
| 289 | 2.3.2.2 | **Pleito de Alpercata a definir - Aquisição de terreno** |  | 160d | 2019-08-30 | 2020-04-24 |  |  |  | 2019-08-30 | 2020-04-24 | 160d |  |  | 725d |  | Verde | Verde | 0% | 0% | Verde | 0% | 0% |  |  |  |  |  |  |  |  |
| 290 | 2.3.2.2.1 | Pleito aprovado | milestone | 0d | 2019-08-30 | 2019-08-30 | 206FS+178d |  |  | 2019-08-30 | 2019-08-30 | 0d |  |  | 725d | 0d | Verde | Verde | 0% | 0% | Verde | 0% | 0% | Verde |  |  |  |  |  |  |  |
| 291 | 2.3.2.2.2 | Autorização de compra do terreno emitida pelo banco | milestone | 0d | 2019-09-13 | 2019-09-13 | 290FS+10d |  |  | 2019-09-13 | 2019-09-13 | 0d |  |  | 725d | 0d | Verde | Verde | 0% | 0% | Verde | 0% | 0% | Verde |  |  |  |  |  |  |  |
| 292 | 2.3.2.2.3 | **Aquisição do Terreno** |  | 150d | 2019-09-16 | 2020-04-24 |  |  |  | 2019-09-16 | 2020-04-24 | 150d |  |  | 725d |  | Verde | Verde | 0% | 0% | Verde | 0% | 0% |  |  |  |  |  |  |  |  |
| 293 | 2.3.2.2.3.1 | Regularizar terreno e apresentar escritura ao banco |  | 87d | 2019-09-16 | 2020-01-21 | 291 |  |  | 2019-09-16 | 2020-01-21 | 87d |  |  | 725d | 0d | Verde | Verde | 0% | 0% | Verde | 0% | 0% | Verde |  |  |  |  |  |  |  |
| 294 | 2.3.2.2.3.2 | Analisar documentação do terreno |  | 10d | 2020-01-22 | 2020-02-04 | 293 |  |  | 2020-01-22 | 2020-02-04 | 10d |  |  | 768d | 0d | Verde | Verde | 0% | 0% | Verde | 0% | 0% | Verde |  |  |  |  |  |  |  |
| 295 | 2.3.2.2.3.3 | 50% do valor do imóvel repassado (1) | milestone | 0d | 2020-02-18 | 2020-02-18 | 294FS+10d |  |  | 2020-02-18 | 2020-02-18 | 0d |  |  | 768d | 43d | Verde | Verde | 0% | 0% | Verde | 0% | 0% | Verde |  |  |  |  |  |  |  |
| 296 | 2.3.2.2.3.4 | Registrar imóvel e apresentar documentação ao banco |  | 43d | 2020-01-22 | 2020-03-25 | 293 |  |  | 2020-01-22 | 2020-03-25 | 43d |  |  | 725d | 0d | Verde | Verde | 0% | 0% | Verde | 0% | 0% | Verde |  |  |  |  |  |  |  |
| 297 | 2.3.2.2.3.5 | Analisar documentação do terreno |  | 10d | 2020-03-26 | 2020-04-08 | 296 |  |  | 2020-03-26 | 2020-04-08 | 10d |  |  | 725d | 0d | Verde | Verde | 0% | 0% | Verde | 0% | 0% | Verde |  |  |  |  |  |  |  |
| 298 | 2.3.2.2.3.6 | 50% do valor do imóvel repassado (2) | milestone | 0d | 2020-04-24 | 2020-04-24 | 297FS+10d |  |  | 2020-04-24 | 2020-04-24 | 0d |  |  | 725d | 0d | Verde | Verde | 0% | 0% | Verde | 0% | 0% | Verde |  |  |  |  |  |  |  |
| 299 | 2.3.2.2.4 | Pleito a definir concluído | milestone | 0d | 2020-04-24 | 2020-04-24 | 295, 298 |  |  | 2020-04-24 | 2020-04-24 | 0d |  |  | 725d | 0d | Verde | Verde | 0% | 0% | Verde | 0% | 0% | Verde |  |  |  |  |  |  |  |
| 300 | 2.3.2.3 | **Pleito de Alpercata a definir - Obra de sistema de esgotamento sanitário da sede do município e distrito de Era Nova** |  | 574d | 2019-11-29 | 2022-03-25 |  |  |  | 2019-11-29 | 2022-03-25 | 574d |  |  | 725d |  | Verde | Verde | 0% | 0% | Verde | 0% | 0% |  |  |  |  |  |  |  |  |
| 301 | 2.3.2.3.1 | Pleito aprovado | milestone | 0d | 2019-11-29 | 2019-11-29 | 206FS+242d |  |  | 2019-11-29 | 2019-11-29 | 0d |  |  | 811d | 86d | Verde | Verde | 0% | 0% | Verde | 0% | 0% | Verde |  |  |  |  |  |  |  |
| 302 | 2.3.2.3.2 | **Licitação da obra** |  | 79d | 2020-04-24 | 2020-08-17 |  |  |  | 2020-04-24 | 2020-08-17 | 79d |  |  | 725d |  | Verde | Verde | 0% | 0% | Verde | 0% | 0% |  |  |  |  |  |  |  |  |
| 303 | 2.3.2.3.2.1 | Licitação da obra autorizada pelo banco | milestone | 0d | 2020-04-24 | 2020-04-24 | 301FS+10d, 286 |  |  | 2020-04-24 | 2020-04-24 | 0d |  |  | 725d | 0d | Verde | Verde | 0% | 0% | Verde | 0% | 0% | Verde |  |  |  |  |  |  |  |
| 304 | 2.3.2.3.2.2 | Licitar obra |  | 65d | 2020-04-27 | 2020-07-28 | 303 |  |  | 2020-04-27 | 2020-07-28 | 65d | 2019-08-05 | 2019-12-03 | 725d | 0d | Verde | Verde | 0% | 0% | Verde | 0% | 0% | Verde | 02 - Execução | PG 031 |  |  |  |  |  |
| 305 | 2.3.2.3.2.3 | Analisar e emitir resultado da licitação da obra |  | 14d | 2020-07-29 | 2020-08-17 | 304 |  |  | 2020-07-29 | 2020-08-17 | 14d |  |  | 725d | 0d | Verde | Verde | 0% | 0% | Verde | 0% | 0% | Verde |  |  |  |  |  |  |  |
| 306 | 2.3.2.3.2.4 | Licitação da obra concluída | milestone | 0d | 2020-08-17 | 2020-08-17 | 305 |  |  | 2020-08-17 | 2020-08-17 | 0d |  |  | 725d | 0d | Verde | Verde | 0% | 0% | Verde | 0% | 0% | Verde |  |  |  |  |  |  |  |
| 307 | 2.3.2.3.3 | Executar obra |  | 240d | 2020-09-17 | 2021-09-02 | 306FS+21d |  |  | 2020-09-17 | 2021-09-02 | 240d |  |  | 725d | 0d | Verde | Verde | 0% | 0% | Verde | 0% | 0% | Verde |  |  |  |  |  |  |  |
| 308 | 2.3.2.3.4 | Realizar processo de pré-operação da sede |  | 133d | 2021-09-03 | 2022-03-18 | 307 |  |  | 2021-09-03 | 2022-03-18 | 133d | 2020-11-27 | 2021-05-26 | 725d | 0d | Verde | Verde | 0% | 0% | Verde | 0% | 0% | Verde | 02 - Execução | PG 031 |  |  |  |  |  |
| 309 | 2.3.2.3.5 | Recurso da obra parcelado repassado | milestone | 0d | 2022-03-25 | 2022-03-25 | 308FS+5d |  |  | 2022-03-25 | 2022-03-25 | 0d |  |  | 725d | 0d | Verde | Verde | 0% | 0% | Verde | 0% | 0% | Verde |  |  |  |  |  |  |  |
| 310 | 2.3.2.3.6 | Pleito a definir concluído | milestone | 0d | 2022-03-25 | 2022-03-25 | 309 |  |  | 2022-03-25 | 2022-03-25 | 0d |  |  | 725d | 0d | Verde | Verde | 0% | 0% | Verde | 0% | 0% | Verde |  |  |  |  |  |  |  |
| 311 | 2.3.2.4 | **Pleito ALPRSPM01 - Elaboração de estudos de viabilidade para a concepção dos serviços de infraestrutura de sistemas integrados de destinação final de resíduos sólidos urbanos, bem como educação ambiental e programas de coleta seletiva** |  | 437d | 2018-06-15 A | 2020-03-11 |  | 45% | 241.47d | 2018-06-15 | 2020-03-11 | 437d |  |  | 1233d |  | Verde | Verde | 50% | 91% | Vermelho | 11% | 10% |  |  |  | 45 | 50 | 91 | 11 | 10 |
| 312 | 2.3.2.4.1 | **Licitação de Empresa para Estudo de Viabilidade** |  | 283d | 2018-06-15 A | 2019-07-26 |  | 75% | 71.39d | 2018-06-15 | 2019-07-26 | 283d |  |  | 1233d |  | Verde | Verde | 78% | 92% | Vermelho | 61% | 56% |  |  |  | 75 | 78 | 92 | 61 | 56 |
| 313 | 2.3.2.4.1.1 | Licitação da empresa para Estudo de Viabilidade autorizada pelo banco | milestone | 0d | 2018-06-15 A | 2018-06-15 A | 206FS-129d | 100% |  | 2018-06-15 | 2018-06-15 | 0d |  |  |  |  | Verde | Verde | 100% | 0% | Vermelho | 100% | 0% | Verde |  |  | 100 | 100 |  | 100 |  |
| 314 | 2.3.2.4.1.2 | Licitar empresa para Estudo de Viabilidade |  | 208d | 2018-09-03 A | 2019-07-01 | 313FS+56d | 80% | 42d | 2018-09-03 | 2019-07-01 | 208d |  |  | 1233d | 0d | Verde | Verde | 79% | 90% | Vermelho | 79% | 71% | Verde |  |  | 80 | 79 | 90 | 79 | 71 |
| 315 | 2.3.2.4.1.3 | Documentação de licitação apresentada ao banco | milestone | 0d | 2019-07-08 | 2019-07-08 | 314FS+5d |  |  | 2019-07-08 | 2019-07-08 | 0d |  |  | 1233d | 0d | Verde | Verde | 0% | 0% | Verde | 0% | 0% | Verde |  |  |  |  |  |  |  |
| 316 | 2.3.2.4.1.4 | Analisar e emitir resultado da licitação da empresa para Estudo de Viabilidade |  | 14d | 2019-07-09 | 2019-07-26 | 315 |  |  | 2019-07-09 | 2019-07-26 | 14d |  |  | 1233d | 0d | Verde | Verde | 0% | 0% | Verde | 0% | 0% | Verde |  |  |  |  |  |  |  |
| 317 | 2.3.2.4.1.5 | Licitação da empresa para Estudo de Viabilidade concluída | milestone | 0d | 2019-07-26 | 2019-07-26 | 316 |  |  | 2019-07-26 | 2019-07-26 | 0d |  |  | 1233d | 0d | Verde | Verde | 0% | 0% | Verde | 0% | 0% | Verde |  |  |  |  |  |  |  |

Notes:
- 290: Em 12/04/2019: o pleito será enviado 10/07/2019 e será aprovado pela CT/CIF até 30/08/19 (NT 33)
- 295: Em 11/04/2019: Repasse de 50% do valor do imóvel após 10 dias úteis (premissa adotada) a apresentação da escritura pública de compra e venda ao BDMG.
- 298: Em 11/04/19: repasse de 50% do valor do imóvel após 10 dias úteis (premissa adotada) a apresentação do registro da escritura pública na matrícula do imóvel ao BDMG.
- 301: Em 11/04/2019: o pleito será enviado até o dia 10/10/19, portanto o pleito será analisado pela CT/CIF até o dia 29/11/2019
- 313: Em 24/04/2019: a autorização foi enviada ao município no dia 15/06/2018
- 314: Em 24/09/2019: conforme relatórios do apoio técnico o município iniciou o processo licitatório em setembro 2018 / Em 29/04/2019: atualizado como agendado

| ID | WBS | Task | Type | Duration | Start | Finish | Predecessors | Complete | Remaining | Baseline start | Baseline finish | Baseline duration | Baseline 1 start | Baseline 1 finish | Total slack | Free slack | Farol de Atraso | Farol Marcos | % Previsto Tempo | Índice de Desempenho Físico (IDF) | Farol IDF | % Previsto Ponderado | % Concluído Ponderado | Farol de Início | IDF Numérico | % Concluída Numérico | % Previsto Tempo Numérico | % Previsto Ponderado Numérico | % Concluído Ponderado Numérico | Responsável | Código do Contrato |
| --- | --- | --- | --- | --- | --- | --- | --- | --- | --- | --- | --- | --- | --- | --- | --- | --- | --- | --- | --- | --- | --- | --- | --- | --- | --- | --- | --- | --- | --- | --- | --- |
| 318 | 2.3.2.4.2 | **Elaboração do estudo de viabilidade** |  | 149d | 2019-07-29 | 2020-03-04 |  |  |  | 2019-07-29 | 2020-03-04 | 149d |  |  | 1233d |  | Verde | Verde | 0% | 0% | Verde | 0% | 0% |  |  |  |  |  |  |  |  |
| 319 | 2.3.2.4.2.1 | Elaborar estudo de viabilidade |  | 88d | 2019-07-29 | 2019-11-29 | 317 |  |  | 2019-07-29 | 2019-11-29 | 88d |  |  | 1233d | 0d | Verde | Verde | 0% | 0% | Verde | 0% | 0% | Verde |  |  |  |  |  |  |  |
| 320 | 2.3.2.4.2.2 | Analisar estudo |  | 20d | 2019-12-02 | 2020-01-02 | 319 |  |  | 2019-12-02 | 2020-01-02 | 20d |  |  | 1233d | 0d | Verde | Verde | 0% | 0% | Verde | 0% | 0% | Verde |  |  |  |  |  |  |  |
| 321 | 2.3.2.4.2.3 | Adequar/revisar estudo |  | 22d | 2020-01-03 | 2020-02-03 | 320 |  |  | 2020-01-03 | 2020-02-03 | 22d |  |  | 1233d | 0d | Verde | Verde | 0% | 0% | Verde | 0% | 0% | Verde |  |  |  |  |  |  |  |
| 322 | 2.3.2.4.2.4 | Analisar estudo - final |  | 19d | 2020-02-04 | 2020-03-04 | 321 |  |  | 2020-02-04 | 2020-03-04 | 19d |  |  | 1233d | 0d | Verde | Verde | 0% | 0% | Verde | 0% | 0% | Verde |  |  |  |  |  |  |  |
| 323 | 2.3.2.4.2.5 | Estudo concluído | milestone | 0d | 2020-03-04 | 2020-03-04 | 322 |  |  | 2020-03-04 | 2020-03-04 | 0d |  |  | 1233d | 0d | Verde | Verde | 0% | 0% | Verde | 0% | 0% | Verde |  |  |  |  |  |  |  |
| 324 | 2.3.2.4.3 | Recurso do serviço repassado | milestone | 0d | 2020-03-11 | 2020-03-11 | 323FS+5d |  |  | 2020-03-11 | 2020-03-11 | 0d |  |  | 1233d | 0d | Verde | Verde | 0% | 0% | Verde | 0% | 0% | Verde |  |  |  |  |  |  |  |
| 325 | 2.3.2.4.4 | Pleito ALPRSPM01 concluído | milestone | 0d | 2020-03-11 | 2020-03-11 | 324 |  |  | 2020-03-11 | 2020-03-11 | 0d |  |  | 1233d | 508d | Verde | Verde | 0% | 0% | Verde | 0% | 0% | Verde |  |  |  |  |  |  |  |
| 326 | 2.3.2.5 | Recursos de Alpercata repassados | milestone | 0d | 2022-03-25 | 2022-03-25 | 288, 299, 310, 325 |  |  | 2022-03-25 | 2022-03-25 | 0d |  |  | 725d |  | Verde | Verde | 0% | 0% | Verde | 0% | 0% | Verde |  |  |  |  |  |  |  |
| 327 | 2.3.3 | **Baixo Guandu** |  | 825d | 2019-02-08 A | 2022-06-07 |  | 5% | 783.45d | 2019-02-08 | 2022-06-07 | 825d | 2018-12-04 | 2022-09-20 | 675d |  | Verde | Verde | 6% | 100% | Verde | 1% | 1% |  | 100 |  |  |  |  |  |  |
| 328 | 2.3.3.1 | **Pleito BAGESPJ01 - Elaboração de projeto de sistema de esgotamento sanitário da sede municipal (bairros: Rosário II, Rosário I, São Vicenti, Alto Guandu, Sapucaia, Centro, Mauá, São José, Santa Mônica, Vila Kenedy, Valparaíso, Ricardo Holz, São Pedro Oper** |  | 286d | 2019-02-08 A | 2020-04-07 |  | 11% | 254.42d | 2019-02-08 | 2020-04-07 | 286d |  |  | 1214d |  | Verde | Verde | 18% | 75% | Vermelho | 4% | 3% |  | 75 | 11 | 18 |  |  |  |  |
| 329 | 2.3.3.1.1 | **Licitação de Projetos** |  | 74d | 2019-02-08 A | 2019-05-31 |  | 71% | 21.29d | 2019-02-08 | 2019-05-31 | 74d |  |  | 1214d |  | Verde | Verde | 70% | 76% | Vermelho | 66% | 50% |  | 76 | 71 | 70 | 66 | 50 |  |  |
| 330 | 2.3.3.1.1.1 | Licitar projetos |  | 59d | 2019-02-08 A | 2019-05-10 | 169FS+182ed | 88% | 7d | 2019-02-08 | 2019-05-10 | 59d | 2018-12-04 | 2019-03-04 | 1214d | 0d | Verde | Verde | 88% | 76% | Vermelho | 88% | 67% | Verde | 76 | 88 | 88 | 88 | 67 |  |  |
| 331 | 2.3.3.1.1.2 | Documentação de licitação apresentada ao banco | milestone | 0d | 2019-05-13 | 2019-05-13 | 330FS+1d |  |  | 2019-05-13 | 2019-05-13 | 0d |  |  | 1214d | 0d | Verde | Verde | 0% | 0% | Verde | 0% | 0% | Verde |  |  |  |  |  |  |  |
| 332 | 2.3.3.1.1.3 | Analisar e emitir resultado da licitação do projeto |  | 14d | 2019-05-14 | 2019-05-31 | 331 |  |  | 2019-05-14 | 2019-05-31 | 14d |  |  | 1214d | 0d | Verde | Verde | 0% | 0% | Verde | 0% | 0% | Verde |  |  |  |  |  |  |  |
| 333 | 2.3.3.1.1.4 | Licitação do projeto concluída | milestone | 0d | 2019-05-31 | 2019-05-31 | 332 |  |  | 2019-05-31 | 2019-05-31 | 0d |  |  | 1214d | 0d | Verde | Verde | 0% | 0% | Verde | 0% | 0% | Verde |  |  |  |  |  |  |  |
| 334 | 2.3.3.1.2 | **Elaboração do Projeto** |  | 212d | 2019-06-03 | 2020-04-07 |  |  |  | 2019-06-03 | 2020-04-07 | 212d |  |  | 1214d |  | Verde | Verde | 0% | 0% | Verde | 0% | 0% |  |  |  |  |  |  |  |  |
| 335 | 2.3.3.1.2.1 | Elaborar Projeto |  | 124d | 2019-06-03 | 2019-11-26 | 333 |  |  | 2019-06-03 | 2019-11-26 | 124d |  |  | 1214d | 0d | Verde | Verde | 0% | 0% | Verde | 0% | 0% | Verde |  |  |  |  |  |  |  |
| 336 | 2.3.3.1.2.2 | Projeto apresentado ao banco | milestone | 0d | 2019-11-26 | 2019-11-26 | 335 |  |  | 2019-11-26 | 2019-11-26 | 0d |  |  | 1297d | 83d | Verde | Verde | 0% | 0% | Verde | 0% | 0% | Verde |  |  |  |  |  |  |  |
| 337 | 2.3.3.1.2.3 | Analisar projeto |  | 124d | 2019-07-02 | 2019-12-27 | 335SS+20d |  |  | 2019-07-02 | 2019-12-27 | 124d |  |  | 1277d | 63d | Verde | Verde | 0% | 0% | Verde | 0% | 0% | Verde |  |  |  |  |  |  |  |
| 338 | 2.3.3.1.2.4 | Projeto concluído | milestone | 0d | 2020-03-31 | 2020-03-31 | 337, 343, 336, 340 |  |  | 2020-03-31 | 2020-03-31 | 0d |  |  | 1214d | 0d | Verde | Verde | 0% | 0% | Verde | 0% | 0% | Verde |  |  |  |  |  |  |  |
| 339 | 2.3.3.1.2.5 | Recurso do projeto do pleito BAGESPJ01 repassado | milestone | 0d | 2020-04-07 | 2020-04-07 | 338FS+5d |  |  | 2020-04-07 | 2020-04-07 | 0d |  |  | 1214d | 0d | Verde | Verde | 0% | 0% | Verde | 0% | 0% | Verde |  |  |  |  |  |  |  |
| 340 | 2.3.3.1.3 | Realizar Licenciamento Ambiental |  | 23d | 2019-09-25 | 2019-10-25 | 335SS+80d |  |  | 2019-09-25 | 2019-10-25 | 23d | 2019-06-02 | 2019-11-29 | 1318d | 104d | Verde | Verde | 0% | 0% | Verde | 0% | 0% | Verde |  |  |  |  |  | 02 - Execução | PG 031 |
| 341 | 2.3.3.1.4 | **Regularização de terreno** |  | 127d | 2019-09-25 | 2020-03-31 |  |  |  | 2019-09-25 | 2020-03-31 | 127d |  |  | 1214d |  | Verde | Verde | 0% | 0% | Verde | 0% | 0% |  |  |  |  |  |  |  |  |
| 342 | 2.3.3.1.4.1 | Regularizar terreno |  | 127d | 2019-09-25 | 2020-03-31 | 335SS+80d |  |  | 2019-09-25 | 2020-03-31 | 127d |  |  | 1214d | 0d | Verde | Verde | 0% | 0% | Verde | 0% | 0% | Verde |  |  |  |  |  |  |  |
| 343 | 2.3.3.1.4.2 | Regularização de terreno concluída | milestone | 0d | 2020-03-31 | 2020-03-31 | 342 |  |  | 2020-03-31 | 2020-03-31 | 0d |  |  | 1214d | 0d | Verde | Verde | 0% | 0% | Verde | 0% | 0% | Verde |  |  |  |  |  |  |  |
| 344 | 2.3.3.1.5 | Pleito BAGESPJ01 concluído | milestone | 0d | 2020-04-07 | 2020-04-07 | 339 |  |  | 2020-04-07 | 2020-04-07 | 0d |  |  | 1214d | 539d | Verde | Verde | 0% | 0% | Verde | 0% | 0% | Verde |  |  |  |  |  |  |  |

Notes:
- 327: O pleito de Esgotamento Sanitário de Baixo Guandu, contempla apenas a elaboração do projeto da sede do município e de distritos (5,2% do valor de SES - R$650.000,00), e foi aprovado conforme Deliberação 75. Somente após o projeto, vai ser feito o pleito para as obras. / O pleito de resíduos sólido (10% do total do recurso destinado ao munícipio) foi aprovado. / Para este cronograma, foi consideradouma obra de maior porte que contempla os 14 bairros.
- 330: Em 29/04/2019: atualizado como agendado
- 331: Em 12/04/2019: considerado 1 dia para apresentação dos documentos, pois foi acordado com o município. Não foi utilizada a premissa de 5 dias.

| ID | WBS | Task | Type | Duration | Start | Finish | Predecessors | Complete | Remaining | Baseline start | Baseline finish | Baseline duration | Baseline 1 start | Baseline 1 finish | Total slack | Free slack | Farol de Atraso | Farol Marcos | % Previsto Tempo | Índice de Desempenho Físico (IDF) | Farol IDF | % Previsto Ponderado | % Concluído Ponderado | Farol de Início | Responsável | Código do Contrato | IDF Numérico | % Concluída Numérico | % Previsto Tempo Numérico | % Previsto Ponderado Numérico | % Concluído Ponderado Numérico |
| --- | --- | --- | --- | --- | --- | --- | --- | --- | --- | --- | --- | --- | --- | --- | --- | --- | --- | --- | --- | --- | --- | --- | --- | --- | --- | --- | --- | --- | --- | --- | --- |
| 345 | 2.3.3.2 | **Pleito de Baixo Guandu a definir - Obra de sistema de esgotamento sanitário da sede municipal e dos distritos** |  | 624d | 2019-11-29 | 2022-06-07 |  |  |  | 2019-11-29 | 2022-06-07 | 624d |  |  | 675d |  | Verde | Verde | 0% | 0% | Verde | 0% | 0% |  |  |  |  |  |  |  |  |
| 346 | 2.3.3.2.1 | Pleito aprovado | milestone | 0d | 2019-11-29 | 2019-11-29 | 206FS+242d |  |  | 2019-11-29 | 2019-11-29 | 0d |  |  | 675d | 0d | Verde | Verde | 0% | 0% | Verde | 0% | 0% | Verde |  |  |  |  |  |  |  |
| 347 | 2.3.3.2.2 | **Licitação da obra** |  | 58d | 2019-12-16 | 2020-03-13 |  |  |  | 2019-12-16 | 2020-03-13 | 58d |  |  | 675d |  | Verde | Verde | 0% | 0% | Verde | 0% | 0% |  |  |  |  |  |  |  |  |
| 348 | 2.3.3.2.2.1 | Licitação da obra autorizada pelo banco | milestone | 0d | 2019-12-16 | 2019-12-16 | 346FS+10d |  |  | 2019-12-16 | 2019-12-16 | 0d |  |  | 675d | 0d | Verde | Verde | 0% | 0% | Verde | 0% | 0% | Verde |  |  |  |  |  |  |  |
| 349 | 2.3.3.2.2.2 | Licitar Obra |  | 44d | 2019-12-17 | 2020-02-19 | 348 |  |  | 2019-12-17 | 2020-02-19 | 44d | 2019-11-29 | 2020-03-28 | 675d | 0d | Verde | Verde | 0% | 0% | Verde | 0% | 0% | Verde | 02 - Execução | PG 031 |  |  |  |  |  |
| 350 | 2.3.3.2.2.3 | Analisar e emitir resultado da licitação da obra |  | 14d | 2020-02-20 | 2020-03-13 | 349 |  |  | 2020-02-20 | 2020-03-13 | 14d |  |  | 675d | 0d | Verde | Verde | 0% | 0% | Verde | 0% | 0% | Verde |  |  |  |  |  |  |  |
| 351 | 2.3.3.2.2.4 | Licitação da obra concluída | milestone | 0d | 2020-03-13 | 2020-03-13 | 350 |  |  | 2020-03-13 | 2020-03-13 | 0d |  |  | 675d | 0d | Verde | Verde | 0% | 0% | Verde | 0% | 0% | Verde |  |  |  |  |  |  |  |
| 352 | 2.3.3.2.3 | Executar obra |  | 400d | 2020-04-14 | 2021-11-19 | 351FS+20d |  |  | 2020-04-14 | 2021-11-19 | 400d |  |  | 675d | 0d | Verde | Verde | 0% | 0% | Verde | 0% | 0% | Verde |  |  |  |  |  |  |  |
| 353 | 2.3.3.2.4 | Realizar processo de pré-operação |  | 131d | 2021-11-22 | 2022-05-31 | 352 |  |  | 2021-11-22 | 2022-05-31 | 131d | 2022-03-24 | 2022-09-20 | 675d | 0d | Verde | Verde | 0% | 0% | Verde | 0% | 0% | Verde | 02 - Execução | PG 031 |  |  |  |  |  |
| 354 | 2.3.3.2.5 | Recurso da obra do pleito BAGESPJ01 repassado | milestone | 0d | 2022-06-07 | 2022-06-07 | 353FS+5d |  |  | 2022-06-07 | 2022-06-07 | 0d |  |  | 675d | 0d | Verde | Verde | 0% | 0% | Verde | 0% | 0% | Verde |  |  |  |  |  |  |  |
| 355 | 2.3.3.2.6 | Pleito a definir concluído | milestone | 0d | 2022-06-07 | 2022-06-07 | 354 |  |  | 2022-06-07 | 2022-06-07 | 0d |  |  | 675d | 0d | Verde | Verde | 0% | 0% | Verde | 0% | 0% | Verde |  |  |  |  |  |  |  |
| 356 | 2.3.3.3 | **Pleito BAGRSOB01 - Viabilizar a solução consorciada, com objetivo de executar as obras para a implantação da Central de Tratamento de Resíduos – CTR Colatina.** |  | 625d | 2019-03-14 A | 2021-09-16 |  | 5% | 592.05d | 2019-03-14 | 2021-09-16 | 625d |  |  | 854d |  | Verde | Verde | 4% | 100% | Verde | 8% | 8% |  |  |  | 100 |  |  |  |  |
| 357 | 2.3.3.3.1 | **Licitação da obra** |  | 52d | 2019-03-14 A | 2019-05-30 |  | 67% | 16.96d | 2019-03-14 | 2019-05-30 | 52d |  |  | 854d |  | Verde | Verde | 59% | 95% | Vermelho | 40% | 38% |  |  |  | 95 | 67 | 59 | 40 | 38 |
| 358 | 2.3.3.3.1.1 | Licitação da obra autorizada pelo banco | milestone | 0d | 2019-03-14 A | 2019-03-14 A | 206FS+62d | 100% |  | 2019-03-14 | 2019-03-14 | 0d |  |  |  |  | Verde | Verde | 100% | 0% | Vermelho | 100% | 0% | Verde |  |  |  | 100 | 100 | 100 |  |
| 359 | 2.3.3.3.1.2 | Licitar obra |  | 38d | 2019-03-15 A | 2019-05-10 | 358 | 82% | 7d | 2019-03-15 | 2019-05-10 | 38d |  |  | 854d | 0d | Verde | Verde | 81% | 95% | Vermelho | 81% | 77% | Verde |  |  | 95 | 82 | 81 | 81 | 77 |
| 360 | 2.3.3.3.1.3 | Analisar e emitir resultado da licitação da obra |  | 8d | 2019-05-21 | 2019-05-30 | 359FS+6d |  |  | 2019-05-21 | 2019-05-30 | 8d |  |  | 854d | 0d | Verde | Verde | 0% | 0% | Verde | 0% | 0% | Verde |  |  |  |  |  |  |  |
| 361 | 2.3.3.3.1.4 | Licitação da obra concluída | milestone | 0d | 2019-05-30 | 2019-05-30 | 360 |  |  | 2019-05-30 | 2019-05-30 | 0d |  |  | 854d | 0d | Verde | Verde | 0% | 0% | Verde | 0% | 0% | Verde |  |  |  |  |  |  |  |
| 362 | 2.3.3.3.2 | Executar obra |  | 414d | 2019-07-09 | 2021-03-09 | 361FS+26d |  |  | 2019-07-09 | 2021-03-09 | 414d |  |  | 854d | 0d | Verde | Verde | 0% | 0% | Verde | 0% | 0% | Verde |  |  |  |  |  |  |  |
| 363 | 2.3.3.3.3 | Realizar processo de pré-operação |  | 128d | 2021-03-10 | 2021-09-09 | 362 |  |  | 2021-03-10 | 2021-09-09 | 128d |  |  | 854d | 0d | Verde | Verde | 0% | 0% | Verde | 0% | 0% | Verde |  |  |  |  |  |  |  |
| 364 | 2.3.3.3.4 | Recurso da obra parcelado repassado | milestone | 0d | 2021-09-16 | 2021-09-16 | 363FS+5d |  |  | 2021-09-16 | 2021-09-16 | 0d |  |  | 854d | 0d | Verde | Verde | 0% | 0% | Verde | 0% | 0% | Verde |  |  |  |  |  |  |  |
| 365 | 2.3.3.3.5 | Pleito BAGRSOB01 concluído | milestone | 0d | 2021-09-16 | 2021-09-16 | 364 |  |  | 2021-09-16 | 2021-09-16 | 0d |  |  | 854d | 179d | Verde | Verde | 0% | 0% | Verde | 0% | 0% | Verde |  |  |  |  |  |  |  |
| 366 | 2.3.3.4 | Recursos de Baixo Guandu repassados | milestone | 0d | 2022-06-07 | 2022-06-07 | 344, 355, 365 |  |  | 2022-06-07 | 2022-06-07 | 0d | 2019-07-02 | 2022-09-20 | 675d |  | Verde | Verde | 0% | 0% | Verde | 0% | 0% | Verde | 02 - Execução | PG 031 |  |  |  |  |  |
| 367 | 2.3.4 | **Barra Longa** |  | 1241d | 2019-01-29 A | 2024-01-29 |  | 13% | 1079.59d | 2019-01-29 | 2024-01-29 | 1241d | 2019-04-09 | 2021-10-25 | 268d |  | Verde | Verde | 4% | 0% | Vermelho | 0% | 0% |  |  |  |  | 13 |  |  |  |
| 368 | 2.3.4.1 | **Pleito BALESPJ01 - Adequação de projeto de engenharia da ETE de Barra Longa** |  | 207d | 2019-01-29 A | 2019-11-26 |  | 34% | 137.62d | 2019-01-29 | 2019-11-26 | 207d |  |  | 722d |  | Verde | Verde | 29% | 53% | Vermelho | 17% | 9% |  |  |  | 53 | 34 | 29 | 17 |  |
| 369 | 2.3.4.1.1 | **Licitação do Projeto** |  | 95d | 2019-01-29 A | 2019-06-18 |  | 64% | 34d | 2019-01-29 | 2019-06-18 | 95d |  |  | 722d |  | Verde | Verde | 64% | 66% | Vermelho | 50% | 33% |  |  |  | 66 | 64 | 64 | 50 | 33 |
| 370 | 2.3.4.1.1.1 | Licitar Projeto |  | 81d | 2019-01-29 A | 2019-05-29 | 170FS+121d | 75% | 20d | 2019-01-29 | 2019-05-29 | 81d |  |  | 722d | 0d | Verde | Verde | 75% | 67% | Vermelho | 75% | 50% | Verde |  |  | 67 | 75 | 75 | 75 | 50 |
| 371 | 2.3.4.1.1.2 | Analisar e emitir resultado da licitação do projeto |  | 14d | 2019-05-30 | 2019-06-18 | 370 |  |  | 2019-05-30 | 2019-06-18 | 14d |  |  | 722d | 0d | Verde | Verde | 0% | 0% | Verde | 0% | 0% | Verde |  |  |  |  |  |  |  |
| 372 | 2.3.4.1.1.3 | Licitação do projeto concluída | milestone | 0d | 2019-06-18 | 2019-06-18 | 371 |  |  | 2019-06-18 | 2019-06-18 | 0d |  |  | 722d | 0d | Verde | Verde | 0% | 0% | Verde | 0% | 0% | Verde |  |  |  |  |  |  |  |

Notes:
- 346: Em 15/04: O pleito será enviado até o final de out/2019 o município enviará e será aprovado até o dia 30/11/2019
- 352: Em 15/04/2019: valor da obra aproximado 10,9 milhões. usando a premissa da Helena seria uma obra de 20 meses
- 358: Em 24/04/2019: considerado a data de início do processo licitatório do cronograma pactuado junto ao CONDOESTE como data de autorização da licitação pelo banco
- 359: Em 29/04/2019: atualizado como agendado
- 362: Em 24/09/2019: o valor da obra do CONDOESTE é de R$ 10,9 milhões
- 366: Valor de recurso destinado ao munícipio: R$12.605.314,86
- 367: Barra Longa teve 100% dos pleitos de Esgotamento Sanitário aprovado (R$7.825.714,29), conforme Deliberação 75. / O município teve o pleito de resíduos sólidos negado (R$869.523,81, equivalente a 10% do total do recurso). / Munícipio vai solicitar mudança de pleito, vai arcar com recurso próprio o projeto e vão solicitar o valor para obra.
- 370: Em 25/04/2019: município não entregou processo licitatório ao banco conforme planilha controle gerencial Renova / Em 29/04/2019: atualizado como agendado

| ID | WBS | Task | Type | Duration | Start | Finish | Predecessors | Complete | Remaining | Baseline start | Baseline finish | Baseline duration | Baseline 1 start | Baseline 1 finish | Total slack | Free slack | Constraint | Farol de Atraso | Farol Marcos | % Previsto Tempo | Índice de Desempenho Físico (IDF) | Farol IDF | % Previsto Ponderado | % Concluído Ponderado | Farol de Início | % Concluída Numérico | % Previsto Tempo Numérico | % Previsto Ponderado Numérico | Responsável | Código do Contrato |
| --- | --- | --- | --- | --- | --- | --- | --- | --- | --- | --- | --- | --- | --- | --- | --- | --- | --- | --- | --- | --- | --- | --- | --- | --- | --- | --- | --- | --- | --- | --- |
| 373 | 2.3.4.1.2 | **Elaboração do Projeto Executivo** |  | 112d | 2019-06-19 | 2019-11-26 |  |  |  | 2019-06-19 | 2019-11-26 | 112d |  |  | 722d |  |  | Verde | Verde | 0% | 0% | Verde | 0% | 0% |  |  |  |  |  |  |
| 374 | 2.3.4.1.2.1 | Elaborar Projeto Executivo |  | 41d | 2019-06-19 | 2019-08-16 | 372 |  |  | 2019-06-19 | 2019-08-16 | 41d |  |  | 722d | 0d |  | Verde | Verde | 0% | 0% | Verde | 0% | 0% | Verde |  |  |  |  |  |
| 375 | 2.3.4.1.2.2 | Analisar projeto executivo |  | 22d | 2019-08-19 | 2019-09-17 | 374 |  |  | 2019-08-19 | 2019-09-17 | 22d |  |  | 722d | 0d |  | Verde | Verde | 0% | 0% | Verde | 0% | 0% | Verde |  |  |  |  |  |
| 376 | 2.3.4.1.2.3 | Adequar/revisar projeto executivo |  | 22d | 2019-09-18 | 2019-10-17 | 375 |  |  | 2019-09-18 | 2019-10-17 | 22d |  |  | 722d | 0d |  | Verde | Verde | 0% | 0% | Verde | 0% | 0% | Verde |  |  |  |  |  |
| 377 | 2.3.4.1.2.4 | Analisar projeto executivo - final |  | 22d | 2019-10-18 | 2019-11-19 | 376 |  |  | 2019-10-18 | 2019-11-19 | 22d |  |  | 722d | 0d |  | Verde | Verde | 0% | 0% | Verde | 0% | 0% | Verde |  |  |  |  |  |
| 378 | 2.3.4.1.2.5 | Projeto executivo concluído | milestone | 0d | 2019-11-19 | 2019-11-19 | 377, 380 |  |  | 2019-11-19 | 2019-11-19 | 0d |  |  | 722d | 0d |  | Verde | Verde | 0% | 0% | Verde | 0% | 0% | Verde |  |  |  |  |  |
| 379 | 2.3.4.1.2.6 | Recurso do projeto executivo do pleito BALESPJ01 repassado | milestone | 0d | 2019-11-26 | 2019-11-26 | 378FS+5d |  |  | 2019-11-26 | 2019-11-26 | 0d |  |  | 722d | 0d |  | Verde | Verde | 0% | 0% | Verde | 0% | 0% | Verde |  |  |  |  |  |
| 380 | 2.3.4.1.3 | Realizar Licenciamento Ambiental |  | 162d | 2019-01-29 A | 2019-09-23 | 170FS+121d | 38% | 101d | 2019-01-29 | 2019-09-23 | 162d | 2019-04-09 | 2019-10-06 | 762d | 40d |  | Verde | Verde | 37% | 0% | Vermelho | 37% | 0% | Verde | 38 | 37 | 37 |  |  |
| 381 | 2.3.4.1.4 | Pleito BALESPJ01 concluído | milestone | 0d | 2019-11-26 | 2019-11-26 | 379 |  |  | 2019-11-26 | 2019-11-26 | 0d |  |  | 722d | 0d |  | Verde | Verde | 0% | 0% | Verde | 0% | 0% | Verde |  |  |  |  |  |
| 382 | 2.3.4.2 | **Pleito BALESOB01 - Substituição de rede de esgoto incluindo execução de rede inteceptora e contrução da ETE** |  | 580d | 2019-11-26 | 2022-03-30 |  |  |  | 2019-11-26 | 2022-03-30 | 580d |  |  | 722d |  |  | Verde | Verde | 0% | 0% | Verde | 0% | 0% |  |  |  |  |  |  |
| 383 | 2.3.4.2.1 | **Licitação da obra** |  | 55d | 2019-11-26 | 2020-02-17 |  |  |  | 2019-11-26 | 2020-02-17 | 55d |  |  | 722d |  |  | Verde | Verde | 0% | 0% | Verde | 0% | 0% |  |  |  |  |  |  |
| 384 | 2.3.4.2.1.1 | Licitação da obra autorizada pelo banco | milestone | 0d | 2019-11-26 | 2019-11-26 | 381 |  |  | 2019-11-26 | 2019-11-26 | 0d |  |  | 722d | 0d |  | Verde | Verde | 0% | 0% | Verde | 0% | 0% | Verde |  |  |  |  |  |
| 385 | 2.3.4.2.1.2 | Licitar obra |  | 41d | 2019-11-27 | 2020-01-28 | 384 |  |  | 2019-11-27 | 2020-01-28 | 41d | 2019-07-08 | 2019-11-05 | 722d | 0d |  | Verde | Verde | 0% | 0% | Verde | 0% | 0% | Verde |  |  |  | 02 - Execução | PG031 |
| 386 | 2.3.4.2.1.3 | Analisar e emitir resultado da licitação da obra |  | 14d | 2020-01-29 | 2020-02-17 | 385 |  |  | 2020-01-29 | 2020-02-17 | 14d |  |  | 722d | 0d |  | Verde | Verde | 0% | 0% | Verde | 0% | 0% | Verde |  |  |  |  |  |
| 387 | 2.3.4.2.1.4 | Licitação da obra concluída | milestone | 0d | 2020-02-17 | 2020-02-17 | 386 |  |  | 2020-02-17 | 2020-02-17 | 0d |  |  | 722d | 0d |  | Verde | Verde | 0% | 0% | Verde | 0% | 0% | Verde |  |  |  |  |  |
| 388 | 2.3.4.2.2 | Executar obra |  | 390d | 2020-02-20 | 2021-09-15 | 387FS+2d |  |  | 2020-02-20 | 2021-09-15 | 390d |  |  | 722d | 0d |  | Verde | Verde | 0% | 0% | Verde | 0% | 0% | Verde |  |  |  |  |  |
| 389 | 2.3.4.2.3 | Realizar processo de pré-operação |  | 128d | 2021-09-16 | 2022-03-23 | 388 |  |  | 2021-09-16 | 2022-03-23 | 128d | 2021-04-28 | 2021-10-25 | 722d | 0d |  | Verde | Verde | 0% | 0% | Verde | 0% | 0% | Verde |  |  |  | 02 - Execução | PG031 |
| 390 | 2.3.4.2.4 | Recurso do pleito BALESOB01 repassado | milestone | 0d | 2022-03-30 | 2022-03-30 | 389FS+5d |  |  | 2022-03-30 | 2022-03-30 | 0d |  |  | 722d | 0d |  | Verde | Verde | 0% | 0% | Verde | 0% | 0% | Verde |  |  |  |  |  |
| 391 | 2.3.4.2.5 | Pleito BALESOB01 concluído | milestone | 0d | 2022-03-30 | 2022-03-30 | 390 |  |  | 2022-03-30 | 2022-03-30 | 0d |  |  | 722d | 454d |  | Verde | Verde | 0% | 0% | Verde | 0% | 0% | Verde |  |  |  |  |  |
| 392 | 2.3.4.3 | **Pleito de Barra Longa de Resíduos Sólidos a definir** |  | 1096d | 2019-08-30 | 2024-01-29 |  |  |  | 2019-08-30 | 2024-01-29 | 1096d |  |  | 0d |  |  | Verde | Verde | 0% | 0% | Verde | 0% | 0% |  |  |  |  |  |  |
| 393 | 2.3.4.3.1 | Pleito aprovado | milestone | 0d | 2019-08-30 | 2019-08-30 |  |  |  | 2019-08-30 | 2019-08-30 | 0d |  |  | 0d |  | must start on 2019-08-30 | Verde | Verde | 0% | 0% | Verde | 0% | 0% | Verde |  |  |  |  |  |
| 394 | 2.3.4.3.2 | Iniciar pleito |  | 1d | 2019-08-30 | 2019-08-30 | 393 |  |  | 2019-08-30 | 2019-08-30 | 1d |  |  | 268d | 0d |  | Verde | Verde | 0% | 0% | Verde | 0% | 0% | Verde |  |  |  |  |  |
| 395 | 2.3.4.3.3 | Pleito concluído | milestone | 0d | 2024-01-29 | 2024-01-29 | 394FS+1095d |  |  | 2024-01-29 | 2024-01-29 | 0d |  |  | 268d | 0d |  | Verde | Verde | 0% | 0% | Verde | 0% | 0% | Verde |  |  |  |  |  |
| 396 | 2.3.4.4 | Recursos de Barra Longa repassados | milestone | 0d | 2024-01-29 | 2024-01-29 | 381, 391, 395 |  |  | 2024-01-29 | 2024-01-29 | 0d | 2019-12-05 | 2021-10-25 | 268d |  |  | Verde | Verde | 0% | 0% | Verde | 0% | 0% | Verde |  |  |  | 02 - Execução | PG 031 |

Notes:
- 380: Em 29/04/2019: atualizado como agendado
- 388: Em 15/04/2019: valor da obra 7 milhões, considerada a premissa da Helena de 18 meses
- 393: Em 24/09/2018: premissa conforme NT 33 que pleito será aprovado em agosto de 2019. Município precisa elaborar e protocolar pleito em junho ou julho.
- 396: Valor de recurso destinado ao munícipio: R$8.695.238,10

| ID | WBS | Task | Type | Duration | Start | Finish | Predecessors | Complete | Remaining | Baseline start | Baseline finish | Baseline duration | Baseline 1 start | Baseline 1 finish | Total slack | Free slack | Constraint | Farol de Atraso | Farol Marcos | % Previsto Tempo | Índice de Desempenho Físico (IDF) | Farol IDF | % Previsto Ponderado | % Concluído Ponderado | IDF Numérico | % Concluída Numérico | % Previsto Tempo Numérico | % Previsto Ponderado Numérico | % Concluído Ponderado Numérico | Farol de Início |
| --- | --- | --- | --- | --- | --- | --- | --- | --- | --- | --- | --- | --- | --- | --- | --- | --- | --- | --- | --- | --- | --- | --- | --- | --- | --- | --- | --- | --- | --- | --- |
| 397 | 2.3.5 | **Belo Oriente** |  | 1475d | 2019-03-21 A | 2025-02-24 |  | 3% | 1433.56d | 2019-03-21 | 2025-02-24 | 1475d | 2018-09-02 | 2020-08-27 | 0d |  |  | Verde | Verde | 1% | 0% | Vermelho | 0% | 0% |  |  |  |  |  |  |
| 398 | 2.3.5.1 | **Pleito BEOESPJ01 - Elaboração de projetos de sistema de esgotamento sanitário da sede do município e distritos de Bom Jesus do Bagre e São Sebastião de Braúnas** |  | 324d | 2019-03-21 A | 2020-07-09 |  | 8% | 296.58d | 2019-03-21 | 2020-07-09 | 324d |  |  | 1151d |  |  | Verde | Verde | 8% | 75% | Vermelho | 4% | 3% | 75 |  |  |  |  |  |
| 399 | 2.3.5.1.1 | **Licitação do Projeto** |  | 60d | 2019-03-21 A | 2019-06-17 |  | 49% | 30.55d | 2019-03-21 | 2019-06-17 | 60d |  |  | 1151d |  |  | Verde | Verde | 45% | 77% | Vermelho | 43% | 33% | 77 | 49 | 45 | 43 | 33 |  |
| 400 | 2.3.5.1.1.1 | Licitação do projeto autorizada pelo banco | milestone | 0d | 2019-03-21 A | 2019-03-21 A |  | 100% |  | 2019-03-21 | 2019-03-21 | 0d |  |  |  |  | start no earlier than 2019-03-21 | Verde | Verde | 100% | 0% | Vermelho | 100% | 0% |  | 100 | 100 | 100 |  | Verde |
| 401 | 2.3.5.1.1.2 | Licitar projeto |  | 41d | 2019-03-21 A | 2019-05-21 | 400 | 66% | 14d | 2019-03-21 | 2019-05-21 | 41d |  |  | 1151d | 0d |  | Verde | Verde | 65% | 77% | Vermelho | 65% | 50% | 77 | 66 | 65 | 65 | 50 | Verde |
| 402 | 2.3.5.1.1.3 | Documentação de licitação apresentada ao banco | milestone | 0d | 2019-05-28 | 2019-05-28 | 401FS+5d |  |  | 2019-05-28 | 2019-05-28 | 0d |  |  | 1151d | 0d |  | Verde | Verde | 0% | 0% | Verde | 0% | 0% |  |  |  |  |  | Verde |
| 403 | 2.3.5.1.1.4 | Analisar e emitir resultado da análise de licitação do projeto |  | 14d | 2019-05-29 | 2019-06-17 | 402 |  |  | 2019-05-29 | 2019-06-17 | 14d |  |  | 1151d | 0d |  | Verde | Verde | 0% | 0% | Verde | 0% | 0% |  |  |  |  |  | Verde |
| 404 | 2.3.5.1.1.5 | Licitação do projeto concluída | milestone | 0d | 2019-06-17 | 2019-06-17 | 403 |  |  | 2019-06-17 | 2019-06-17 | 0d |  |  | 1151d | 0d |  | Verde | Verde | 0% | 0% | Verde | 0% | 0% |  |  |  |  |  | Verde |
| 405 | 2.3.5.1.2 | **Elaboração do Projeto Básico** |  | 112d | 2019-06-18 | 2019-11-25 |  |  |  | 2019-06-18 | 2019-11-25 | 112d |  |  | 1151d |  |  | Verde | Verde | 0% | 0% | Verde | 0% | 0% |  |  |  |  |  |  |
| 406 | 2.3.5.1.2.1 | Elaborar Projeto Básico |  | 43d | 2019-06-18 | 2019-08-19 | 404 |  |  | 2019-06-18 | 2019-08-19 | 43d |  |  | 1151d | 0d |  | Verde | Verde | 0% | 0% | Verde | 0% | 0% |  |  |  |  |  | Verde |
| 407 | 2.3.5.1.2.2 | Projeto básico apresentado ao banco | milestone | 0d | 2019-08-19 | 2019-08-19 | 406 |  |  | 2019-08-19 | 2019-08-19 | 0d |  |  | 1151d | 0d |  | Verde | Verde | 0% | 0% | Verde | 0% | 0% |  |  |  |  |  | Verde |
| 408 | 2.3.5.1.2.3 | Analisar Projeto Básico |  | 24d | 2019-08-20 | 2019-09-20 | 407 |  |  | 2019-08-20 | 2019-09-20 | 24d |  |  | 1151d | 0d |  | Verde | Verde | 0% | 0% | Verde | 0% | 0% |  |  |  |  |  | Verde |
| 409 | 2.3.5.1.2.4 | Adequar/revisar projeto básico |  | 23d | 2019-09-23 | 2019-10-23 | 408 |  |  | 2019-09-23 | 2019-10-23 | 23d |  |  | 1151d | 0d |  | Verde | Verde | 0% | 0% | Verde | 0% | 0% |  |  |  |  |  | Verde |
| 410 | 2.3.5.1.2.5 | Analisar projeto básico - final |  | 22d | 2019-10-24 | 2019-11-25 | 409 |  |  | 2019-10-24 | 2019-11-25 | 22d |  |  | 1151d | 0d |  | Verde | Verde | 0% | 0% | Verde | 0% | 0% |  |  |  |  |  | Verde |
| 411 | 2.3.5.1.2.6 | Projeto básico concluído | milestone | 0d | 2019-11-25 | 2019-11-25 | 410 |  |  | 2019-11-25 | 2019-11-25 | 0d |  |  | 1151d | 0d |  | Verde | Verde | 0% | 0% | Verde | 0% | 0% |  |  |  |  |  | Verde |
| 412 | 2.3.5.1.2.7 | Recurso do projeto básico do pleito BEOESPJ01 repassado | milestone | 0d | 2019-11-25 | 2019-11-25 | 411 |  |  | 2019-11-25 | 2019-11-25 | 0d |  |  | 1303d | 152d |  | Verde | Verde | 0% | 0% | Verde | 0% | 0% |  |  |  |  |  | Verde |
| 413 | 2.3.5.1.3 | **Elaboração do Projeto Executivo** |  | 152d | 2019-11-26 | 2020-07-09 |  |  |  | 2019-11-26 | 2020-07-09 | 152d |  |  | 1151d |  |  | Verde | Verde | 0% | 0% | Verde | 0% | 0% |  |  |  |  |  |  |
| 414 | 2.3.5.1.3.1 | Elaborar Projeto Executivo |  | 86d | 2019-11-26 | 2020-04-02 | 411 |  |  | 2019-11-26 | 2020-04-02 | 86d |  |  | 1151d | 0d |  | Verde | Verde | 0% | 0% | Verde | 0% | 0% |  |  |  |  |  | Verde |
| 415 | 2.3.5.1.3.2 | Projeto executivo apresentado ao banco | milestone | 0d | 2020-04-02 | 2020-04-02 | 414 |  |  | 2020-04-02 | 2020-04-02 | 0d |  |  | 1151d | 0d |  | Verde | Verde | 0% | 0% | Verde | 0% | 0% |  |  |  |  |  | Verde |
| 416 | 2.3.5.1.3.3 | Analisar projeto executivo |  | 22d | 2020-04-03 | 2020-05-07 | 415 |  |  | 2020-04-03 | 2020-05-07 | 22d |  |  | 1151d | 0d |  | Verde | Verde | 0% | 0% | Verde | 0% | 0% |  |  |  |  |  | Verde |
| 417 | 2.3.5.1.3.4 | Adequar/revisar projeto executivo |  | 21d | 2020-05-08 | 2020-06-05 | 416 |  |  | 2020-05-08 | 2020-06-05 | 21d |  |  | 1151d | 0d |  | Verde | Verde | 0% | 0% | Verde | 0% | 0% |  |  |  |  |  | Verde |
| 418 | 2.3.5.1.3.5 | Analisar projeto executivo - final |  | 23d | 2020-06-08 | 2020-07-09 | 417 |  |  | 2020-06-08 | 2020-07-09 | 23d |  |  | 1151d | 0d |  | Verde | Verde | 0% | 0% | Verde | 0% | 0% |  |  |  |  |  | Verde |
| 419 | 2.3.5.1.3.6 | Projeto executivo concluído | milestone | 0d | 2020-07-09 | 2020-07-09 | 418, 412 |  |  | 2020-07-09 | 2020-07-09 | 0d |  |  | 1151d | 0d |  | Verde | Verde | 0% | 0% | Verde | 0% | 0% |  |  |  |  |  | Verde |
| 420 | 2.3.5.1.3.7 | Recurso do projeto executivo do pleito BEOESPJ01 repassado | milestone | 0d | 2020-07-09 | 2020-07-09 | 419 |  |  | 2020-07-09 | 2020-07-09 | 0d |  |  | 1151d | 0d |  | Verde | Verde | 0% | 0% | Verde | 0% | 0% |  |  |  |  |  | Verde |
| 421 | 2.3.5.1.4 | Pleito BEOESPJ01 concluído | milestone | 0d | 2020-07-09 | 2020-07-09 | 420 |  |  | 2020-07-09 | 2020-07-09 | 0d |  |  | 1151d |  |  | Verde | Verde | 0% | 0% | Verde | 0% | 0% |  |  |  |  |  | Verde |

Notes:
- 397: Belo Oriente teve 100% dos pleitos de Esgotamento Sanitário Aprovado (R$9.926.685,00), conforme Deliberação 75. / O município teve o pleito de resíduos sólidos negado (R$1.102.965,05, equivalente a 10% do total do recurso,). / Belo Oriente solicitou mudança de pleito e foi autorizado pelo CIF na NT21. / ·Equívoco na exclusão do distrito de Cachoeira Escura do pleito de obras, solicita-se voltar com o distrito. / Aderiu à ata de registro de preço.
- 400: Em 25/04/2019: em 21/03/2019 o banco informou que o processo licitatório está desconforme e o município irá reiniciar o processo.
- 401: Em 29/04/2019: atualizado como agendado

| ID | WBS | Task | Type | Duration | Start | Finish | Predecessors | Complete | Remaining | Baseline start | Baseline finish | Baseline duration | Baseline 1 start | Baseline 1 finish | Total slack | Free slack | Constraint | Farol de Atraso | Farol Marcos | % Previsto Tempo | Índice de Desempenho Físico (IDF) | Farol IDF | % Previsto Ponderado | % Concluído Ponderado | Farol de Início | Responsável | Código do Contrato | % Concluída Numérico | % Previsto Tempo Numérico | % Previsto Ponderado Numérico |
| --- | --- | --- | --- | --- | --- | --- | --- | --- | --- | --- | --- | --- | --- | --- | --- | --- | --- | --- | --- | --- | --- | --- | --- | --- | --- | --- | --- | --- | --- | --- |
| 422 | 2.3.5.2 | **Pleito BEOESOB01 - Implantação de rede e interceptor de esgotamento sanitário da sede** |  | 1d | 2019-05-31 | 2019-05-31 |  |  |  | 2019-05-31 | 2019-05-31 | 1d |  |  | 752d |  |  | Verde | Verde | 0% | 0% | Verde | 0% | 0% |  |  |  |  |  |  |
| 423 | 2.3.5.2.1 | Avaliar pleito |  | 1d | 2019-05-31 | 2019-05-31 |  |  |  | 2019-05-31 | 2019-05-31 | 1d |  |  | 752d | 0d | start no earlier than 2019-05-31 | Verde | Verde | 0% | 0% | Verde | 0% | 0% | Verde |  |  |  |  |  |
| 424 | 2.3.5.2.2 | Pleito BEOESOB01 concluído | milestone | 0d | 2019-05-31 | 2019-05-31 | 423 |  |  | 2019-05-31 | 2019-05-31 | 0d |  |  | 1426d |  |  | Verde | Verde | 0% | 0% | Verde | 0% | 0% | Verde |  |  |  |  |  |
| 425 | 2.3.5.3 | **Pleito BEOESOB02 - Ampliação e reestruturação de redes coletoras no município e implantação do programa caça esgoto** |  | 1d | 2019-06-03 | 2019-06-03 |  |  |  | 2019-06-03 | 2019-06-03 | 1d |  |  | 1425d |  |  | Verde | Verde | 0% | 0% | Verde | 0% | 0% |  |  |  |  |  |  |
| 426 | 2.3.5.3.1 | Avaliar pleito |  | 1d | 2019-06-03 | 2019-06-03 | 423 |  |  | 2019-06-03 | 2019-06-03 | 1d |  |  | 1425d | 0d |  | Verde | Verde | 0% | 0% | Verde | 0% | 0% | Verde |  |  |  |  |  |
| 427 | 2.3.5.3.2 | Pleito BEOESOB02 concluído | milestone | 0d | 2019-06-03 | 2019-06-03 | 426 |  |  | 2019-06-03 | 2019-06-03 | 0d |  |  | 1425d |  |  | Verde | Verde | 0% | 0% | Verde | 0% | 0% | Verde |  |  |  |  |  |
| 428 | 2.3.5.4 | **Pleito BEOESOB04 - Implantação do SES na sede e distritos de São Sebatião de Braúnas e de Perpétuo Socorro (Cachoeira Escura)** |  | 674d | 2019-05-31 | 2022-02-11 |  |  |  | 2019-05-31 | 2022-02-11 | 674d |  |  | 752d |  |  | Verde | Verde | 0% | 0% | Verde | 0% | 0% |  |  |  |  |  |  |
| 429 | 2.3.5.4.1 | Alteração do pleito aprovada | milestone | 0d | 2019-05-31 | 2019-05-31 | 423 |  |  | 2019-05-31 | 2019-05-31 | 0d |  |  | 752d | 0d |  | Verde | Verde | 0% | 0% | Verde | 0% | 0% | Verde |  |  |  |  |  |
| 430 | 2.3.5.4.2 | **Licitação da obra** |  | 78d | 2019-06-14 | 2019-10-04 |  |  |  | 2019-06-14 | 2019-10-04 | 78d |  |  | 752d |  |  | Verde | Verde | 0% | 0% | Verde | 0% | 0% |  |  |  |  |  |  |
| 431 | 2.3.5.4.2.1 | Licitação da obra autorizada pelo banco | milestone | 0d | 2019-06-14 | 2019-06-14 | 429FS+10d |  |  | 2019-06-14 | 2019-06-14 | 0d |  |  | 752d | 0d |  | Verde | Verde | 0% | 0% | Verde | 0% | 0% | Verde |  |  |  |  |  |
| 432 | 2.3.5.4.2.2 | Licitar obra |  | 64d | 2019-06-17 | 2019-09-16 | 431 |  |  | 2019-06-17 | 2019-09-16 | 64d | 2019-03-01 | 2019-06-29 | 752d | 0d |  | Verde | Verde | 0% | 0% | Verde | 0% | 0% | Verde | 02 - Execução | PG 031 |  |  |  |
| 433 | 2.3.5.4.2.3 | Analisar e emitir resultado da análise de licitação da obra |  | 14d | 2019-09-17 | 2019-10-04 | 432 |  |  | 2019-09-17 | 2019-10-04 | 14d |  |  | 752d | 0d |  | Verde | Verde | 0% | 0% | Verde | 0% | 0% | Verde |  |  |  |  |  |
| 434 | 2.3.5.4.2.4 | Licitação da obra concluída | milestone | 0d | 2019-10-04 | 2019-10-04 | 433 |  |  | 2019-10-04 | 2019-10-04 | 0d |  |  | 752d | 0d |  | Verde | Verde | 0% | 0% | Verde | 0% | 0% | Verde |  |  |  |  |  |
| 435 | 2.3.5.4.3 | Executar obra |  | 433d | 2019-11-04 | 2021-08-03 | 434FS+20d |  |  | 2019-11-04 | 2021-08-03 | 433d |  |  | 752d | 0d |  | Verde | Verde | 0% | 0% | Verde | 0% | 0% | Verde |  |  |  |  |  |
| 436 | 2.3.5.4.4 | Realizar processo de pré-operação |  | 128d | 2021-08-04 | 2022-02-04 | 435 |  |  | 2021-08-04 | 2022-02-04 | 128d | 2019-12-31 | 2020-08-27 | 752d | 0d |  | Verde | Verde | 0% | 0% | Verde | 0% | 0% | Verde | 02 - Execução | PG 031 |  |  |  |
| 437 | 2.3.5.4.5 | Recurso da obra parcelado repassado | milestone | 0d | 2022-02-11 | 2022-02-11 | 436FS+5d |  |  | 2022-02-11 | 2022-02-11 | 0d |  |  | 752d | 0d |  | Verde | Verde | 0% | 0% | Verde | 0% | 0% | Verde |  |  |  |  |  |
| 438 | 2.3.5.4.6 | Pleito BEOESOB04 concluído | milestone | 0d | 2022-02-11 | 2022-02-11 | 437 |  |  | 2022-02-11 | 2022-02-11 | 0d |  |  | 752d | 71d |  | Verde | Verde | 0% | 0% | Verde | 0% | 0% | Verde |  |  |  |  |  |
| 439 | 2.3.5.5 | **Pleito de Belo Oriente de Resíduos Sólidos a definir** |  | 1364d | 2019-08-30 | 2025-02-24 |  |  |  | 2019-08-30 | 2025-02-24 | 1364d |  |  | 0d |  |  | Verde | Verde | 0% | 0% | Verde | 0% | 0% |  |  |  |  |  |  |
| 440 | 2.3.5.5.1 | Pleito aprovado | milestone | 0d | 2019-08-30 | 2019-08-30 |  |  |  | 2019-08-30 | 2019-08-30 | 0d |  |  | 0d |  | must start on 2019-08-30 | Verde | Verde | 0% | 0% | Verde | 0% | 0% | Verde |  |  |  |  |  |
| 441 | 2.3.5.5.2 | Iniciar pleito |  | 1d | 2019-08-30 | 2019-08-30 | 440 |  |  | 2019-08-30 | 2019-08-30 | 1d |  |  | 0d |  |  | Verde | Verde | 0% | 0% | Verde | 0% | 0% | Verde |  |  |  |  |  |
| 442 | 2.3.5.5.3 | Pleito de Belo Oriente de Resíduos Sólidos a definir concluído | milestone | 0d | 2025-02-24 | 2025-02-24 | 441FS+1363d |  |  | 2025-02-24 | 2025-02-24 | 0d |  |  | 0d |  |  | Verde | Verde | 0% | 0% | Verde | 0% | 0% | Verde |  |  |  |  |  |
| 443 | 2.3.5.6 | Recursos de Belo Oriente repassados | milestone | 0d | 2025-02-24 | 2025-02-24 | 421, 424, 427, 438, 442 |  |  | 2025-02-24 | 2025-02-24 | 0d | 2019-03-31 | 2020-08-27 | 0d |  |  | Verde | Verde | 0% | 0% | Verde | 0% | 0% | Verde | 02 - Execução | PG 031 |  |  |  |
| 444 | 2.3.6 | **Bom Jesus do Galho** |  | 935d | 2019-03-29 A | 2023-01-02 |  | 1% | 922.57d | 2019-03-29 | 2023-01-02 | 935d | 2018-12-04 | 2021-10-26 | 533d |  |  | Verde | Verde | 2% | 0% | Vermelho | 0% | 0% |  |  |  |  |  |  |
| 445 | 2.3.6.1 | **Pleito BJGESPJ02 - Elaboração de projetos de sistemas de esgotamento sanitário para a sede do município e para o distrito de Revés do Belém.** |  | 380d | 2019-03-29 A | 2020-10-07 |  | 1% | 375.09d | 2019-03-29 | 2020-10-07 | 380d |  |  | 1088d |  |  | Verde | Verde | 5% | 0% | Vermelho | 1% | 0% |  |  |  |  |  |  |
| 446 | 2.3.6.1.1 | Pleito aprovado | milestone | 0d | 2019-03-29 A | 2019-03-29 A | 206FS+73d | 100% |  | 2019-03-29 | 2019-03-29 | 0d |  |  |  |  |  | Verde | Verde | 100% | 0% | Vermelho | 100% | 0% | Verde |  |  | 100 | 100 | 100 |

Notes:
- 423: Em 25/04/2019: município informou que vai pedir o cancelamento do pleito da sede e manter apenas Cachoeira Escura. Foi considerado que o pleito será aprovado em 31/05/2019 no próximo CIF.
- 426: Em 25/04/2019: município informou que vai pedir o cancelamento do pleito da sede e manter apenas Cachoeira Escura. Foi considerado que o pleito será aprovado em 31/05/2019 no próximo CIF.
- 429: Em 25/04/2019: município informou que vai pedir o cancelamento do pleito da sede e manter apenas Cachoeira Escura. Foi considerado que o pleito será aprovado em 31/05/2019 no próximo CIF.
- 440: Em 24/04/2019: no prazo foi considerado estudo de viabilidade, projeto e obra (vide Ipatinga)
- 443: Valor de recurso destinado ao munícipio: R$11.029.650,50
- 444: Bom Jesus do Galho teve 100% dos pleitos de Esgotamento Sanitário aprovado (R$7.090.489,61), conforme Deliberação 75. / O município teve o pleito de resíduos sólidos negado (R$787.832,18, equivalente a 10% do total do recurso).
- 446: Em 15/04: a alteração do pleito de projeto foi aprovada pela Renova no dia 29/03/2019

| ID | WBS | Task | Type | Duration | Start | Finish | Predecessors | Complete | Remaining | Baseline start | Baseline finish | Baseline duration | Baseline 1 start | Baseline 1 finish | Total slack | Free slack | Farol de Atraso | Farol Marcos | % Previsto Tempo | % Concluída Numérico | % Previsto Tempo Numérico | Índice de Desempenho Físico (IDF) | Farol IDF | % Previsto Ponderado | % Previsto Ponderado Numérico | % Concluído Ponderado | Farol de Início | Responsável | Código do Contrato |
| --- | --- | --- | --- | --- | --- | --- | --- | --- | --- | --- | --- | --- | --- | --- | --- | --- | --- | --- | --- | --- | --- | --- | --- | --- | --- | --- | --- | --- | --- |
| 447 | 2.3.6.1.2 | **Licitação do projeto** |  | 60d | 2019-04-16 A | 2019-07-15 |  | 15% | 51.27d | 2019-04-16 | 2019-07-15 | 60d |  |  | 533d |  | Verde | Verde | 13% | 15 | 13 | 0% | Vermelho | 10% | 10 | 0% |  |  |  |
| 448 | 2.3.6.1.2.1 | Licitação do projeto autorizada | milestone | 0d | 2019-04-16 A | 2019-04-16 A | 446FS+12d | 100% |  | 2019-04-16 | 2019-04-16 | 0d |  |  |  |  | Verde | Verde | 100% | 100 | 100 | 0% | Vermelho | 100% | 100 | 0% | Verde |  |  |
| 449 | 2.3.6.1.2.2 | Licitar projeto |  | 41d | 2019-04-17 A | 2019-06-17 | 448 | 20% | 33d | 2019-04-17 | 2019-06-17 | 41d | 2018-12-04 | 2019-03-04 | 533d | 0d | Verde | Verde | 19% | 20 | 19 | 0% | Vermelho | 19% | 19 | 0% | Verde | 02 - Execução | PG031 |
| 450 | 2.3.6.1.2.3 | Documentação de licitação apresentada ao banco | milestone | 0d | 2019-06-25 | 2019-06-25 | 449FS+5d |  |  | 2019-06-25 | 2019-06-25 | 0d |  |  | 533d | 0d | Verde | Verde | 0% |  |  | 0% | Verde | 0% |  | 0% | Verde |  |  |
| 451 | 2.3.6.1.2.4 | Analisar e emitir resultado da análise de licitação do projeto |  | 14d | 2019-06-26 | 2019-07-15 | 450 |  |  | 2019-06-26 | 2019-07-15 | 14d |  |  | 533d | 0d | Verde | Verde | 0% |  |  | 0% | Verde | 0% |  | 0% | Verde |  |  |
| 452 | 2.3.6.1.2.5 | Licitação do projeto concluída | milestone | 0d | 2019-07-15 | 2019-07-15 | 451 |  |  | 2019-07-15 | 2019-07-15 | 0d |  |  | 533d | 0d | Verde | Verde | 0% |  |  | 0% | Verde | 0% |  | 0% | Verde |  |  |
| 453 | 2.3.6.1.3 | **Elaboração do Projeto Básico** |  | 177d | 2019-07-16 | 2020-03-31 |  |  |  | 2019-07-16 | 2020-03-31 | 177d |  |  | 533d |  | Verde | Verde | 0% |  |  | 0% | Verde | 0% |  | 0% |  |  |  |
| 454 | 2.3.6.1.3.1 | Elaborar Projeto Básico |  | 107d | 2019-07-16 | 2019-12-16 | 452 |  |  | 2019-07-16 | 2019-12-16 | 107d | 2019-03-04 | 2019-06-02 | 533d | 0d | Verde | Verde | 0% |  |  | 0% | Verde | 0% |  | 0% | Verde | 02 - Execução | PG031 |
| 455 | 2.3.6.1.3.2 | Projeto básico apresentado ao banco | milestone | 0d | 2019-12-16 | 2019-12-16 | 454 |  |  | 2019-12-16 | 2019-12-16 | 0d |  |  | 659d | 0d | Verde | Verde | 0% |  |  | 0% | Verde | 0% |  | 0% | Verde |  |  |
| 456 | 2.3.6.1.3.3 | Analisar Projeto Básico |  | 23d | 2019-12-17 | 2020-01-21 | 455 |  |  | 2019-12-17 | 2020-01-21 | 23d |  |  | 659d | 0d | Verde | Verde | 0% |  |  | 0% | Verde | 0% |  | 0% | Verde |  |  |
| 457 | 2.3.6.1.3.4 | Adequar/revisar projeto básico |  | 21d | 2020-01-22 | 2020-02-19 | 456 |  |  | 2020-01-22 | 2020-02-19 | 21d |  |  | 659d | 0d | Verde | Verde | 0% |  |  | 0% | Verde | 0% |  | 0% | Verde |  |  |
| 458 | 2.3.6.1.3.5 | Analisar projeto básico |  | 21d | 2020-02-20 | 2020-03-24 | 457 |  |  | 2020-02-20 | 2020-03-24 | 21d |  |  | 659d | 0d | Verde | Verde | 0% |  |  | 0% | Verde | 0% |  | 0% | Verde |  |  |
| 459 | 2.3.6.1.3.6 | Projeto Básico concluído | milestone | 0d | 2020-03-24 | 2020-03-24 | 458 |  |  | 2020-03-24 | 2020-03-24 | 0d |  |  | 659d | 0d | Verde | Verde | 0% |  |  | 0% | Verde | 0% |  | 0% | Verde |  |  |
| 460 | 2.3.6.1.3.7 | Recurso do projeto básico do pleito BJGESPJ02 repassado | milestone | 0d | 2020-03-31 | 2020-03-31 | 459FS+5d |  |  | 2020-03-31 | 2020-03-31 | 0d |  |  | 659d | 126d | Verde | Verde | 0% |  |  | 0% | Verde | 0% |  | 0% | Verde |  |  |
| 461 | 2.3.6.1.4 | Realizar Licenciamento Ambiental |  | 196d | 2019-12-17 | 2020-09-30 | 454 |  |  | 2019-12-17 | 2020-09-30 | 196d | 2019-06-02 | 2019-11-29 | 533d | 0d | Verde | Verde | 0% |  |  | 0% | Verde | 0% |  | 0% | Verde | 02 - Execução | PG031 |
| 462 | 2.3.6.1.5 | **Elaboração do Projeto Executivo** |  | 201d | 2019-12-17 | 2020-10-07 |  |  |  | 2019-12-17 | 2020-10-07 | 201d |  |  | 533d |  | Verde | Verde | 0% |  |  | 0% | Verde | 0% |  | 0% |  |  |  |
| 463 | 2.3.6.1.5.1 | Elaborar Projeto Executivo |  | 130d | 2019-12-17 | 2020-06-29 | 454 |  |  | 2019-12-17 | 2020-06-29 | 130d | 2019-06-02 | 2019-09-30 | 533d | 0d | Verde | Verde | 0% |  |  | 0% | Verde | 0% |  | 0% | Verde | 02 - Execução | PG031 |
| 464 | 2.3.6.1.5.2 | Projeto executivo apresentado ao banco | milestone | 0d | 2020-06-29 | 2020-06-29 | 463 |  |  | 2020-06-29 | 2020-06-29 | 0d |  |  | 533d | 0d | Verde | Verde | 0% |  |  | 0% | Verde | 0% |  | 0% | Verde |  |  |
| 465 | 2.3.6.1.5.3 | Analisar projeto executivo |  | 22d | 2020-06-30 | 2020-07-29 | 464 |  |  | 2020-06-30 | 2020-07-29 | 22d |  |  | 533d | 0d | Verde | Verde | 0% |  |  | 0% | Verde | 0% |  | 0% | Verde |  |  |
| 466 | 2.3.6.1.5.4 | Adequar/revisar projeto executivo |  | 21d | 2020-07-30 | 2020-08-27 | 465 |  |  | 2020-07-30 | 2020-08-27 | 21d |  |  | 533d | 0d | Verde | Verde | 0% |  |  | 0% | Verde | 0% |  | 0% | Verde |  |  |
| 467 | 2.3.6.1.5.5 | Analisar projeto executivo - final |  | 23d | 2020-08-28 | 2020-09-30 | 466 |  |  | 2020-08-28 | 2020-09-30 | 23d |  |  | 533d | 0d | Verde | Verde | 0% |  |  | 0% | Verde | 0% |  | 0% | Verde |  |  |
| 468 | 2.3.6.1.5.6 | Projeto executivo concluído | milestone | 0d | 2020-09-30 | 2020-09-30 | 467, 460, 461 |  |  | 2020-09-30 | 2020-09-30 | 0d |  |  | 533d | 0d | Verde | Verde | 0% |  |  | 0% | Verde | 0% |  | 0% | Verde |  |  |
| 469 | 2.3.6.1.5.7 | Recurso do projeto executivo do pleito BJGESPJ02 repassado | milestone | 0d | 2020-10-07 | 2020-10-07 | 468FS+5d |  |  | 2020-10-07 | 2020-10-07 | 0d |  |  | 1088d | 0d | Verde | Verde | 0% |  |  | 0% | Verde | 0% |  | 0% | Verde |  |  |
| 470 | 2.3.6.1.6 | Pleito BJGESPJ02 concluído | milestone | 0d | 2020-10-07 | 2020-10-07 | 469 |  |  | 2020-10-07 | 2020-10-07 | 0d |  |  | 1088d | 555d | Verde | Verde | 0% |  |  | 0% | Verde | 0% |  | 0% | Verde |  |  |

Notes:
- 449: 19/12/18 - Devido aos conflitos políticos entre revés e Belem, o processo havia sido paralizado. Ainda é necessário cria a TR para então iniciar a licitação (Sem previsão). Será considerado o prazo para inicio no final de março de 2019 até obtermos informações precisas / Em 29/04/2019: atualizado como agendado
- 454: Em 15/04/19: duração de 5 meses para projeto básico

| ID | WBS | Task | Type | Duration | Start | Finish | Predecessors | Complete | Remaining | Baseline start | Baseline finish | Baseline duration | Baseline 1 start | Baseline 1 finish | Total slack | Free slack | Farol de Atraso | Farol Marcos | % Previsto Tempo | Índice de Desempenho Físico (IDF) | Farol IDF | % Previsto Ponderado | % Concluído Ponderado | Farol de Início | Responsável | Código do Contrato | IDF Numérico | % Concluída Numérico | % Previsto Tempo Numérico | % Previsto Ponderado Numérico | % Concluído Ponderado Numérico |
| --- | --- | --- | --- | --- | --- | --- | --- | --- | --- | --- | --- | --- | --- | --- | --- | --- | --- | --- | --- | --- | --- | --- | --- | --- | --- | --- | --- | --- | --- | --- | --- |
| 471 | 2.3.6.2 | **Pleito BJGESCT01 - Aquisição de imóvel para implantação da Estação de Tratamento de Esgoto - ETE.** |  | 141d | 2020-01-22 | 2020-08-14 |  |  |  | 2020-01-22 | 2020-08-14 | 141d |  |  | 1125d |  | Verde | Verde | 0% | 0% | Verde | 0% | 0% |  |  |  |  |  |  |  |  |
| 472 | 2.3.6.2.1 | **Aquisição de Terreno** |  | 141d | 2020-01-22 | 2020-08-14 |  |  |  | 2020-01-22 | 2020-08-14 | 141d |  |  | 1125d |  | Verde | Verde | 0% | 0% | Verde | 0% | 0% |  |  |  |  |  |  |  |  |
| 473 | 2.3.6.2.1.1 | Regularizar terreno e apresentar escritura ao banco |  | 82d | 2020-01-22 | 2020-05-22 | 456 |  |  | 2020-01-22 | 2020-05-22 | 82d |  |  | 1125d | 0d | Verde | Verde | 0% | 0% | Verde | 0% | 0% | Verde |  |  |  |  |  |  |  |
| 474 | 2.3.6.2.1.2 | Analisar documentação do terreno |  | 10d | 2020-05-25 | 2020-06-05 | 473 |  |  | 2020-05-25 | 2020-06-05 | 10d |  |  | 1169d | 0d | Verde | Verde | 0% | 0% | Verde | 0% | 0% | Verde |  |  |  |  |  |  |  |
| 475 | 2.3.6.2.1.3 | 50% do valor do imóvel repassado (1) | milestone | 0d | 2020-06-15 | 2020-06-15 | 474FS+5d |  |  | 2020-06-15 | 2020-06-15 | 0d |  |  | 1169d | 44d | Verde | Verde | 0% | 0% | Verde | 0% | 0% | Verde |  |  |  |  |  |  |  |
| 476 | 2.3.6.2.1.4 | Registrar imóvel e apresentar documentação ao banco |  | 44d | 2020-05-25 | 2020-07-24 | 473 |  |  | 2020-05-25 | 2020-07-24 | 44d |  |  | 1125d | 0d | Verde | Verde | 0% | 0% | Verde | 0% | 0% | Verde |  |  |  |  |  |  |  |
| 477 | 2.3.6.2.1.5 | Analisar documentação do terreno |  | 10d | 2020-07-27 | 2020-08-07 | 476 |  |  | 2020-07-27 | 2020-08-07 | 10d |  |  | 1125d | 0d | Verde | Verde | 0% | 0% | Verde | 0% | 0% | Verde |  |  |  |  |  |  |  |
| 478 | 2.3.6.2.1.6 | 50% do valor do imóvel repassado (2) | milestone | 0d | 2020-08-14 | 2020-08-14 | 477FS+5d |  |  | 2020-08-14 | 2020-08-14 | 0d |  |  | 1125d | 0d | Verde | Verde | 0% | 0% | Verde | 0% | 0% | Verde |  |  |  |  |  |  |  |
| 479 | 2.3.6.2.1.7 | Aquisição de Terreno concluída | milestone | 0d | 2020-08-14 | 2020-08-14 | 475, 478 |  |  | 2020-08-14 | 2020-08-14 | 0d |  |  | 1125d | 0d | Verde | Verde | 0% | 0% | Verde | 0% | 0% | Verde |  |  |  |  |  |  |  |
| 480 | 2.3.6.2.2 | Pleito BJGESCT01 concluído | milestone | 0d | 2020-08-14 | 2020-08-14 | 479 |  |  | 2020-08-14 | 2020-08-14 | 0d |  |  | 1125d | 592d | Verde | Verde | 0% | 0% | Verde | 0% | 0% | Verde |  |  |  |  |  |  |  |
| 481 | 2.3.6.3 | **Pleito BJGESOB02 - Implantação do sistema de esgotamento sanitário da sede do município** |  | 560d | 2020-09-30 | 2023-01-02 |  |  |  | 2020-09-30 | 2023-01-02 | 560d |  |  | 533d |  | Verde | Verde | 0% | 0% | Verde | 0% | 0% |  |  |  |  |  |  |  |  |
| 482 | 2.3.6.3.1 | **Licitação da obra** |  | 76d | 2020-09-30 | 2021-01-21 |  |  |  | 2020-09-30 | 2021-01-21 | 76d |  |  | 533d |  | Verde | Verde | 0% | 0% | Verde | 0% | 0% |  |  |  |  |  |  |  |  |
| 483 | 2.3.6.3.1.1 | Licitação da obra autorizada pelo banco | milestone | 0d | 2020-09-30 | 2020-09-30 | 468 |  |  | 2020-09-30 | 2020-09-30 | 0d |  |  | 533d | 0d | Verde | Verde | 0% | 0% | Verde | 0% | 0% | Verde |  |  |  |  |  |  |  |
| 484 | 2.3.6.3.1.2 | Licitar obra |  | 62d | 2020-10-01 | 2020-12-31 | 483 |  |  | 2020-10-01 | 2020-12-31 | 62d | 2019-09-30 | 2020-01-28 | 533d | 0d | Verde | Verde | 0% | 0% | Verde | 0% | 0% | Verde | 02 - Execução | PG031 |  |  |  |  |  |
| 485 | 2.3.6.3.1.3 | Analisar licitação da obra |  | 14d | 2021-01-04 | 2021-01-21 | 484 |  |  | 2021-01-04 | 2021-01-21 | 14d |  |  | 533d | 0d | Verde | Verde | 0% | 0% | Verde | 0% | 0% | Verde |  |  |  |  |  |  |  |
| 486 | 2.3.6.3.1.4 | Licitação da obra concluída | milestone | 0d | 2021-01-21 | 2021-01-21 | 485 |  |  | 2021-01-21 | 2021-01-21 | 0d |  |  | 533d | 0d | Verde | Verde | 0% | 0% | Verde | 0% | 0% | Verde |  |  |  |  |  |  |  |
| 487 | 2.3.6.3.2 | Executar obra |  | 332d | 2021-02-24 | 2022-06-22 | 486FS+20d |  |  | 2021-02-24 | 2022-06-22 | 332d |  |  | 533d | 0d | Verde | Verde | 0% | 0% | Verde | 0% | 0% | Verde |  |  |  |  |  |  |  |
| 488 | 2.3.6.3.3 | Realizar processo de pré-operação |  | 127d | 2022-06-23 | 2022-12-26 | 487 |  |  | 2022-06-23 | 2022-12-26 | 127d | 2021-04-29 | 2021-10-26 | 533d | 0d | Verde | Verde | 0% | 0% | Verde | 0% | 0% | Verde | 02 - Execução | PG031 |  |  |  |  |  |
| 489 | 2.3.6.3.4 | Recurso da obra parcelado repassado | milestone | 0d | 2023-01-02 | 2023-01-02 | 488FS+5d |  |  | 2023-01-02 | 2023-01-02 | 0d |  |  | 533d | 0d | Verde | Verde | 0% | 0% | Verde | 0% | 0% | Verde |  |  |  |  |  |  |  |
| 490 | 2.3.6.3.5 | Pleito BJGESOB02 concluído | milestone | 0d | 2023-01-02 | 2023-01-02 | 489 |  |  | 2023-01-02 | 2023-01-02 | 0d |  |  | 533d | 0d | Verde | Verde | 0% | 0% | Verde | 0% | 0% | Verde |  |  |  |  |  |  |  |
| 491 | 2.3.6.4 | **Pleito BJGRSOB02 - Ampliação de aterro sanitário, incluindo uma Unidade de Triagem e Compostagem – UTC** |  | 606d | 2019-04-03 A | 2021-09-09 |  | 3% | 588.27d | 2019-04-03 | 2021-09-09 | 606d |  |  | 859d |  | Verde | Verde | 2% | 100% | Verde | 4% | 4% |  |  |  | 100 |  |  |  |  |
| 492 | 2.3.6.4.1 | **Aprovação do Projeto Executivo** |  | 64d | 2019-04-03 A | 2019-07-08 |  | 27% | 47d | 2019-04-03 | 2019-07-08 | 64d |  |  | 859d |  | Verde | Verde | 26% | 90% | Vermelho | 42% | 38% |  |  |  | 90 | 27 | 26 | 42 | 38 |
| 493 | 2.3.6.4.1.1 | Projeto apresentado ao banco | milestone | 0d | 2019-04-03 A | 2019-04-03 A | 206FS+76d | 100% |  | 2019-04-03 | 2019-04-03 | 0d |  |  |  |  | Verde | Verde | 100% | 0% | Vermelho | 100% | 0% | Verde |  |  |  | 100 | 100 | 100 |  |
| 494 | 2.3.6.4.1.2 | Analisar projeto |  | 20d | 2019-04-04 A | 2019-05-06 | 493 | 85% | 3d | 2019-04-04 | 2019-05-06 | 20d |  |  | 859d | 0d | Verde | Verde | 85% | 88% | Vermelho | 85% | 75% | Verde |  |  | 88 | 85 | 85 | 85 | 75 |
| 495 | 2.3.6.4.1.3 | Adequar/revisar projeto |  | 22d | 2019-05-07 | 2019-06-05 | 494 |  |  | 2019-05-07 | 2019-06-05 | 22d |  |  | 859d | 0d | Verde | Verde | 0% | 0% | Verde | 0% | 0% | Verde |  |  |  |  |  |  |  |
| 496 | 2.3.6.4.1.4 | Analisar projeto - final |  | 22d | 2019-06-06 | 2019-07-08 | 495 |  |  | 2019-06-06 | 2019-07-08 | 22d |  |  | 859d | 0d | Verde | Verde | 0% | 0% | Verde | 0% | 0% | Verde |  |  |  |  |  |  |  |
| 497 | 2.3.6.4.1.5 | Projeto concluído | milestone | 0d | 2019-07-08 | 2019-07-08 | 496 |  |  | 2019-07-08 | 2019-07-08 | 0d |  |  | 859d | 0d | Verde | Verde | 0% | 0% | Verde | 0% | 0% | Verde |  |  |  |  |  |  |  |

Notes:
- 493: Em 24/04/2019: conforme orientação da Cynthia foi inserido como início do processo o último contato do município para esclarecimento de informações ao banco.
- 494: Em 29/04/2019: atualizado como agendado

| ID | WBS | Task | Type | Duration | Start | Finish | Predecessors | Complete | Remaining | Baseline start | Baseline finish | Baseline duration | Baseline 1 start | Baseline 1 finish | Total slack | Free slack | Farol de Atraso | Farol Marcos | % Previsto Tempo | Índice de Desempenho Físico (IDF) | Farol IDF | % Previsto Ponderado | % Concluído Ponderado | Farol de Início | Responsável | Código do Contrato | % Previsto Tempo Numérico |
| --- | --- | --- | --- | --- | --- | --- | --- | --- | --- | --- | --- | --- | --- | --- | --- | --- | --- | --- | --- | --- | --- | --- | --- | --- | --- | --- | --- |
| 498 | 2.3.6.4.2 | **Licitação da obra** |  | 80d | 2019-07-08 | 2019-10-29 |  |  |  | 2019-07-08 | 2019-10-29 | 80d |  |  | 859d |  | Verde | Verde | 0% | 0% | Verde | 0% | 0% |  |  |  |  |
| 499 | 2.3.6.4.2.1 | Licitação da obra autorizada pelo banco | milestone | 0d | 2019-07-08 | 2019-07-08 | 497 |  |  | 2019-07-08 | 2019-07-08 | 0d |  |  | 859d | 0d | Verde | Verde | 0% | 0% | Verde | 0% | 0% | Verde |  |  |  |
| 500 | 2.3.6.4.2.2 | Licitar obra |  | 66d | 2019-07-09 | 2019-10-09 | 499 |  |  | 2019-07-09 | 2019-10-09 | 66d |  |  | 859d | 0d | Verde | Verde | 0% | 0% | Verde | 0% | 0% | Verde |  |  |  |
| 501 | 2.3.6.4.2.3 | Analisar e emitir resultado da licitação da obra |  | 14d | 2019-10-10 | 2019-10-29 | 500 |  |  | 2019-10-10 | 2019-10-29 | 14d |  |  | 859d | 0d | Verde | Verde | 0% | 0% | Verde | 0% | 0% | Verde |  |  |  |
| 502 | 2.3.6.4.2.4 | Licitação da obra concluída | milestone | 0d | 2019-10-29 | 2019-10-29 | 501 |  |  | 2019-10-29 | 2019-10-29 | 0d |  |  | 859d | 0d | Verde | Verde | 0% | 0% | Verde | 0% | 0% | Verde |  |  |  |
| 503 | 2.3.6.4.3 | Executar obra |  | 309d | 2019-11-28 | 2021-03-02 | 502FS+20d |  |  | 2019-11-28 | 2021-03-02 | 309d |  |  | 859d | 0d | Verde | Verde | 0% | 0% | Verde | 0% | 0% | Verde |  |  |  |
| 504 | 2.3.6.4.4 | Realizar processo de pré-operação |  | 128d | 2021-03-03 | 2021-09-01 | 503 |  |  | 2021-03-03 | 2021-09-01 | 128d |  |  | 859d | 0d | Verde | Verde | 0% | 0% | Verde | 0% | 0% | Verde |  |  |  |
| 505 | 2.3.6.4.5 | Recurso da obra parcelado repassado | milestone | 0d | 2021-09-09 | 2021-09-09 | 504FS+5d |  |  | 2021-09-09 | 2021-09-09 | 0d |  |  | 859d | 0d | Verde | Verde | 0% | 0% | Verde | 0% | 0% | Verde |  |  |  |
| 506 | 2.3.6.4.6 | Pleito BJGRSOB02 concluído | milestone | 0d | 2021-09-09 | 2021-09-09 | 505 |  |  | 2021-09-09 | 2021-09-09 | 0d |  |  | 859d | 74d | Verde | Verde | 0% | 0% | Verde | 0% | 0% | Verde |  |  |  |
| 507 | 2.3.6.5 | Recursos de Bom Jesus do Galho repassados | milestone | 0d | 2023-01-02 | 2023-01-02 | 470, 480, 490, 506 |  |  | 2023-01-02 | 2023-01-02 | 0d | 2019-07-02 | 2021-10-26 | 533d |  | Verde | Verde | 0% | 0% | Verde | 0% | 0% | Verde | 02 - Execução | PG 031 |  |
| 508 | 2.3.7 | **Bugre** |  | 784d | 2018-12-03 A | 2022-01-25 |  | 7% | 732.68d | 2018-12-03 | 2022-01-25 | 784d | 2018-09-04 | 2021-01-28 | 765d |  | Verde | Verde | 12% | 0% | Vermelho | 0% | 0% |  |  |  | 12 |
| 509 | 2.3.7.1 | **Pleito BUGESPJ01 - Elaboração de projetos de sistema de esgotamento sanitário das localidades de Bugre, Boachá, São Lourenço, Livramento e São José do Bugre** |  | 212d | 2019-05-02 | 2020-03-09 |  |  |  | 2019-05-02 | 2020-03-09 | 212d |  |  | 765d |  | Verde | Verde | 0% | 0% | Verde | 0% | 0% |  |  |  |  |
| 510 | 2.3.7.1.1 | **Licitação do Projeto** |  | 14d | 2019-05-02 | 2019-05-22 |  |  |  | 2019-05-02 | 2019-05-22 | 14d |  |  | 765d |  | Verde | Verde | 0% | 0% | Verde | 0% | 0% |  |  |  |  |
| 511 | 2.3.7.1.1.1 | Documentação de licitação apresentada ao banco | milestone | 0d | 2019-05-02 | 2019-05-02 | 173FS+181d |  |  | 2019-05-02 | 2019-05-02 | 0d |  |  | 765d | 0d | Verde | Verde | 0% | 0% | Verde | 0% | 0% | Verde |  |  |  |
| 512 | 2.3.7.1.1.2 | Analisar e emitir resultado da licitação do projeto |  | 14d | 2019-05-03 | 2019-05-22 | 511 |  |  | 2019-05-03 | 2019-05-22 | 14d |  |  | 765d | 0d | Verde | Verde | 0% | 0% | Verde | 0% | 0% | Verde |  |  |  |
| 513 | 2.3.7.1.1.3 | Licitação do projeto concluída | milestone | 0d | 2019-05-22 | 2019-05-22 | 512 |  |  | 2019-05-22 | 2019-05-22 | 0d |  |  | 765d | 0d | Verde | Verde | 0% | 0% | Verde | 0% | 0% | Verde |  |  |  |
| 514 | 2.3.7.1.2 | **Elaboração do Projeto Básico** |  | 116d | 2019-05-23 | 2019-11-04 |  |  |  | 2019-05-23 | 2019-11-04 | 116d |  |  | 765d |  | Verde | Verde | 0% | 0% | Verde | 0% | 0% |  |  |  |  |
| 515 | 2.3.7.1.2.1 | Elaborar Projeto Básico |  | 43d | 2019-05-23 | 2019-07-23 | 513 |  |  | 2019-05-23 | 2019-07-23 | 43d |  |  | 765d | 0d | Verde | Verde | 0% | 0% | Verde | 0% | 0% | Verde |  |  |  |
| 516 | 2.3.7.1.2.2 | Projeto básico apresentado ao banco | milestone | 0d | 2019-07-23 | 2019-07-23 | 515 |  |  | 2019-07-23 | 2019-07-23 | 0d |  |  | 765d | 0d | Verde | Verde | 0% | 0% | Verde | 0% | 0% | Verde |  |  |  |
| 517 | 2.3.7.1.2.3 | Analisar Projeto Básico |  | 22d | 2019-07-24 | 2019-08-23 | 516 |  |  | 2019-07-24 | 2019-08-23 | 22d |  |  | 842d | 0d | Verde | Verde | 0% | 0% | Verde | 0% | 0% | Verde |  |  |  |
| 518 | 2.3.7.1.2.4 | Adequar/revisar projeto básico |  | 24d | 2019-08-26 | 2019-09-26 | 517 |  |  | 2019-08-26 | 2019-09-26 | 24d |  |  | 842d | 0d | Verde | Verde | 0% | 0% | Verde | 0% | 0% | Verde |  |  |  |
| 519 | 2.3.7.1.2.5 | Analisar projeto básico - final |  | 22d | 2019-09-27 | 2019-10-28 | 518 |  |  | 2019-09-27 | 2019-10-28 | 22d |  |  | 842d | 0d | Verde | Verde | 0% | 0% | Verde | 0% | 0% | Verde |  |  |  |
| 520 | 2.3.7.1.2.6 | Projeto básico concluído | milestone | 0d | 2019-10-28 | 2019-10-28 | 519 |  |  | 2019-10-28 | 2019-10-28 | 0d |  |  | 842d | 0d | Verde | Verde | 0% | 0% | Verde | 0% | 0% | Verde |  |  |  |
| 521 | 2.3.7.1.2.7 | Recurso do projeto básico do pleito BUGESPJ01 repassado | milestone | 0d | 2019-11-04 | 2019-11-04 | 520FS+5d |  |  | 2019-11-04 | 2019-11-04 | 0d |  |  | 842d | 77d | Verde | Verde | 0% | 0% | Verde | 0% | 0% | Verde |  |  |  |
| 522 | 2.3.7.1.3 | Realizar Licenciamento Ambiental |  | 150d | 2019-07-24 | 2020-03-02 | 516 |  |  | 2019-07-24 | 2020-03-02 | 150d |  |  | 765d | 0d | Verde | Verde | 0% | 0% | Verde | 0% | 0% | Verde |  |  |  |

Notes:
- 503: Em 24/09/2019: o valor da obra do CIDESLESTE é R$ 5,9 milhões
- 507: Valor de recurso destinado ao munícipio: R$7.878.321,79
- 508: Bugre teve 100% dos pleitos de Esgotamento Sanitário aprovado (R$4.254.293,76), conforme Deliberação 75. / O pleito de resíduos sólido (10% do total do recurso destinado ao munícipio, R$472.699,30) foi aprovado na NT20. / Aderiu à ata de registro de preço. / Bugre não quer Apoio Técnico, o que dificulta a elaboração de um cronograma.

| ID | WBS | Task | Type | Duration | Start | Finish | Predecessors | Complete | Remaining | Baseline start | Baseline finish | Baseline duration | Baseline 1 start | Baseline 1 finish | Total slack | Free slack | Constraint | Farol de Atraso | Farol Marcos | % Previsto Tempo | Índice de Desempenho Físico (IDF) | Farol IDF | % Previsto Ponderado | % Concluído Ponderado | Farol de Início | Responsável | Código do Contrato | % Concluída Numérico | % Previsto Tempo Numérico | % Previsto Ponderado Numérico |
| --- | --- | --- | --- | --- | --- | --- | --- | --- | --- | --- | --- | --- | --- | --- | --- | --- | --- | --- | --- | --- | --- | --- | --- | --- | --- | --- | --- | --- | --- | --- |
| 523 | 2.3.7.1.4 | **Elaboração do Projeto Executivo** |  | 155d | 2019-07-24 | 2020-03-09 |  |  |  | 2019-07-24 | 2020-03-09 | 155d |  |  | 765d |  |  | Verde | Verde | 0% | 0% | Verde | 0% | 0% |  |  |  |  |  |  |
| 524 | 2.3.7.1.4.1 | Elaborar projeto executivo |  | 85d | 2019-07-24 | 2019-11-21 | 516 |  |  | 2019-07-24 | 2019-11-21 | 85d |  |  | 765d | 0d |  | Verde | Verde | 0% | 0% | Verde | 0% | 0% | Verde |  |  |  |  |  |
| 525 | 2.3.7.1.4.2 | Projeto executivo apresentado ao banco | milestone | 0d | 2019-11-21 | 2019-11-21 | 524 |  |  | 2019-11-21 | 2019-11-21 | 0d |  |  | 765d | 0d |  | Verde | Verde | 0% | 0% | Verde | 0% | 0% | Verde |  |  |  |  |  |
| 526 | 2.3.7.1.4.3 | Analisar projeto executivo |  | 21d | 2019-11-22 | 2019-12-23 | 525 |  |  | 2019-11-22 | 2019-12-23 | 21d |  |  | 765d | 0d |  | Verde | Verde | 0% | 0% | Verde | 0% | 0% | Verde |  |  |  |  |  |
| 527 | 2.3.7.1.4.4 | Adequar/revisar projeto executivo |  | 22d | 2019-12-26 | 2020-01-27 | 526 |  |  | 2019-12-26 | 2020-01-27 | 22d |  |  | 765d | 0d |  | Verde | Verde | 0% | 0% | Verde | 0% | 0% | Verde |  |  |  |  |  |
| 528 | 2.3.7.1.4.5 | Analisar projeto executivo - final |  | 22d | 2020-01-28 | 2020-03-02 | 527 |  |  | 2020-01-28 | 2020-03-02 | 22d |  |  | 765d | 0d |  | Verde | Verde | 0% | 0% | Verde | 0% | 0% | Verde |  |  |  |  |  |
| 529 | 2.3.7.1.4.6 | Projeto executivo concluído | milestone | 0d | 2020-03-02 | 2020-03-02 | 528, 521, 522 |  |  | 2020-03-02 | 2020-03-02 | 0d |  |  | 765d | 0d |  | Verde | Verde | 0% | 0% | Verde | 0% | 0% | Verde |  |  |  |  |  |
| 530 | 2.3.7.1.4.7 | Recurso do projeto executivo do pleito BUGESPJ01 repassado | milestone | 0d | 2020-03-09 | 2020-03-09 | 529FS+5d |  |  | 2020-03-09 | 2020-03-09 | 0d |  |  | 1235d | 0d |  | Verde | Verde | 0% | 0% | Verde | 0% | 0% | Verde |  |  |  |  |  |
| 531 | 2.3.7.1.5 | Pleito BUGESPJ01 concluído | milestone | 0d | 2020-03-09 | 2020-03-09 | 530 |  |  | 2020-03-09 | 2020-03-09 | 0d |  |  | 1235d | 470d |  | Verde | Verde | 0% | 0% | Verde | 0% | 0% | Verde |  |  |  |  |  |
| 532 | 2.3.7.2 | **Pleito BUGESOB01 - Implantação de sistema de esgotamento sanitário das localidades de Bugre, Boachá, São Lourenço, Livramento e São José do Bugre** |  | 475d | 2020-03-02 | 2022-01-25 |  |  |  | 2020-03-02 | 2022-01-25 | 475d |  |  | 765d |  |  | Verde | Verde | 0% | 0% | Verde | 0% | 0% |  |  |  |  |  |  |
| 533 | 2.3.7.2.1 | **Licitação da obra** |  | 78d | 2020-03-02 | 2020-06-24 |  |  |  | 2020-03-02 | 2020-06-24 | 78d |  |  | 765d |  |  | Verde | Verde | 0% | 0% | Verde | 0% | 0% |  |  |  |  |  |  |
| 534 | 2.3.7.2.1.1 | Licitação da obra autorizada pelo banco | milestone | 0d | 2020-03-02 | 2020-03-02 | 529 |  |  | 2020-03-02 | 2020-03-02 | 0d |  |  | 765d | 0d |  | Verde | Verde | 0% | 0% | Verde | 0% | 0% | Verde |  |  |  |  |  |
| 535 | 2.3.7.2.1.2 | Licitar obra |  | 64d | 2020-03-03 | 2020-06-03 | 534 |  |  | 2020-03-03 | 2020-06-03 | 64d | 2019-04-02 | 2019-07-31 | 765d | 0d |  | Verde | Verde | 0% | 0% | Verde | 0% | 0% | Verde | 02 - Execução | PG 031 |  |  |  |
| 536 | 2.3.7.2.1.3 | Analisar e emitir resultado da licitação da obra |  | 14d | 2020-06-04 | 2020-06-24 | 535 |  |  | 2020-06-04 | 2020-06-24 | 14d |  |  | 765d | 0d |  | Verde | Verde | 0% | 0% | Verde | 0% | 0% | Verde |  |  |  |  |  |
| 537 | 2.3.7.2.1.4 | Licitação da obra concluída | milestone | 0d | 2020-06-24 | 2020-06-24 | 536 |  |  | 2020-06-24 | 2020-06-24 | 0d |  |  | 765d | 0d |  | Verde | Verde | 0% | 0% | Verde | 0% | 0% | Verde |  |  |  |  |  |
| 538 | 2.3.7.2.2 | Executar obra |  | 264d | 2020-06-25 | 2021-07-15 | 537 |  |  | 2020-06-25 | 2021-07-15 | 264d |  |  | 765d | 0d |  | Verde | Verde | 0% | 0% | Verde | 0% | 0% | Verde |  |  |  |  |  |
| 539 | 2.3.7.2.3 | Realizar processo de pré-operação |  | 128d | 2021-07-16 | 2022-01-18 | 538 |  |  | 2021-07-16 | 2022-01-18 | 128d | 2020-08-01 | 2021-01-28 | 765d | 0d |  | Verde | Verde | 0% | 0% | Verde | 0% | 0% | Verde | 02 - Execução | PG 031 |  |  |  |
| 540 | 2.3.7.2.4 | Recurso da obra parcelado repassado | milestone | 0d | 2022-01-25 | 2022-01-25 | 539FS+5d |  |  | 2022-01-25 | 2022-01-25 | 0d |  |  | 765d | 0d |  | Verde | Verde | 0% | 0% | Verde | 0% | 0% | Verde |  |  |  |  |  |
| 541 | 2.3.7.2.5 | Pleito BUGESOB01 concluído | milestone | 0d | 2022-01-25 | 2022-01-25 | 540 |  |  | 2022-01-25 | 2022-01-25 | 0d |  |  | 765d | 0d |  | Verde | Verde | 0% | 0% | Verde | 0% | 0% | Verde |  |  |  |  |  |
| 542 | 2.3.7.3 | **Pleito BUGRSPM01 - Elaboração de estudos ambientais para implantação de aterro sanitário** |  | 214d | 2018-12-03 A | 2019-10-09 |  | 50% | 108.05d | 2018-12-03 | 2019-10-09 | 214d |  |  | 1335d |  |  | Verde | Verde | 47% | 0% | Vermelho | 14% | 0% |  |  |  | 50 | 47 | 14 |
| 543 | 2.3.7.3.1 | **Licitação de Empresa para Licenciamento Ambiental** |  | 161d | 2018-12-03 A | 2019-07-25 |  | 65% | 56.76d | 2018-12-03 | 2019-07-25 | 161d |  |  | 941d |  |  | Verde | Verde | 62% | 0% | Vermelho | 36% | 0% |  |  |  | 65 | 62 | 36 |
| 544 | 2.3.7.3.1.1 | Licitação da empresa para Licenciamento Ambiental autorizada pelo banco | milestone | 0d | 2018-12-03 A | 2018-12-03 A |  | 100% |  | 2018-12-03 | 2018-12-03 | 0d |  |  |  |  | must start on 2018-12-03 | Verde | Verde | 100% | 0% | Vermelho | 100% | 0% | Verde |  |  | 100 | 100 | 100 |
| 545 | 2.3.7.3.1.2 | Licitar empresa para Licenciamento Ambiental |  | 142d | 2018-12-03 A | 2019-06-28 | 544 | 71% | 41d | 2018-12-03 | 2019-06-28 | 142d |  |  | 941d | 0d |  | Verde | Verde | 71% | 0% | Vermelho | 71% | 0% | Verde |  |  | 71 | 71 | 71 |
| 546 | 2.3.7.3.1.3 | Documentação de licitação apresentada ao banco | milestone | 0d | 2019-07-05 | 2019-07-05 | 545FS+5d |  |  | 2019-07-05 | 2019-07-05 | 0d |  |  | 941d | 0d |  | Verde | Verde | 0% | 0% | Verde | 0% | 0% | Verde |  |  |  |  |  |
| 547 | 2.3.7.3.1.4 | Analisar e emitir resultado da licitação do empresa para Licenciamento Ambiental |  | 14d | 2019-07-08 | 2019-07-25 | 546 |  |  | 2019-07-08 | 2019-07-25 | 14d |  |  | 941d | 0d |  | Verde | Verde | 0% | 0% | Verde | 0% | 0% | Verde |  |  |  |  |  |
| 548 | 2.3.7.3.1.5 | Licitação da empresa para Licenciamento Ambiental concluída | milestone | 0d | 2019-07-25 | 2019-07-25 | 547 |  |  | 2019-07-25 | 2019-07-25 | 0d |  |  | 941d | 0d |  | Verde | Verde | 0% | 0% | Verde | 0% | 0% | Verde |  |  |  |  |  |
| 549 | 2.3.7.3.2 | Executar o Licenciamento Ambiental |  | 48d | 2019-07-26 | 2019-10-02 | 548 |  |  | 2019-07-26 | 2019-10-02 | 48d |  |  | 941d | 0d |  | Verde | Verde | 0% | 0% | Verde | 0% | 0% | Verde |  |  |  |  |  |
| 550 | 2.3.7.3.3 | Recurso do serviço parcelado repassado | milestone | 0d | 2019-10-09 | 2019-10-09 | 549FS+5d |  |  | 2019-10-09 | 2019-10-09 | 0d |  |  | 1335d | 0d |  | Verde | Verde | 0% | 0% | Verde | 0% | 0% | Verde |  |  |  |  |  |
| 551 | 2.3.7.3.4 | Pleito BUGRSPM01 concluído | milestone | 0d | 2019-10-09 | 2019-10-09 | 550 |  |  | 2019-10-09 | 2019-10-09 | 0d |  |  | 1335d | 570d |  | Verde | Verde | 0% | 0% | Verde | 0% | 0% | Verde |  |  |  |  |  |

Notes:
- 544: Em 24/04/2019: na planilha do plano de aceleração de dezembro de 2018 foi encontrado o primeiro relato de início de elaboração de TR para contratação da empresa de licenciamento ambiental
- 545: Em 24/04/2019: em virtude do recorrente atraso na elaboração do TR de contratação da empresa para licenciamento e da dificuldade de aceitação do apoio técnico pelo consórcio, Sara V. estimou mais dois meses para a conclusão do processo. / Em 29/04/2019: atualizado como agendado

| ID | WBS | Task | Type | Duration | Start | Finish | Predecessors | Complete | Remaining | Baseline start | Baseline finish | Baseline duration | Baseline 1 start | Baseline 1 finish | Total slack | Free slack | Constraint | Farol de Atraso | Farol Marcos | % Previsto Tempo | Índice de Desempenho Físico (IDF) | Farol IDF | % Previsto Ponderado | % Concluído Ponderado | Farol de Início | Responsável | Código do Contrato | % Previsto Tempo Numérico | IDF Numérico | % Concluída Numérico | % Previsto Ponderado Numérico | % Concluído Ponderado Numérico |
| --- | --- | --- | --- | --- | --- | --- | --- | --- | --- | --- | --- | --- | --- | --- | --- | --- | --- | --- | --- | --- | --- | --- | --- | --- | --- | --- | --- | --- | --- | --- | --- | --- |
| 552 | 2.3.7.4 | **Pleito BUGRSOB02 - Implantação do aterro sanitário compartilhado** |  | 467d | 2019-06-28 | 2021-05-17 |  |  |  | 2019-06-28 | 2021-05-17 | 467d |  |  | 940d |  |  | Verde | Verde | 0% | 0% | Verde | 0% | 0% |  |  |  |  |  |  |  |  |
| 553 | 2.3.7.4.1 | **Aprovação do Projeto Executivo** |  | 68d | 2019-06-28 | 2019-10-03 |  |  |  | 2019-06-28 | 2019-10-03 | 68d |  |  | 940d |  |  | Verde | Verde | 0% | 0% | Verde | 0% | 0% |  |  |  |  |  |  |  |  |
| 554 | 2.3.7.4.1.1 | Projeto apresentado ao banco | milestone | 0d | 2019-06-28 | 2019-06-28 | 206FS+134d |  |  | 2019-06-28 | 2019-06-28 | 0d |  |  | 940d | 0d |  | Verde | Verde | 0% | 0% | Verde | 0% | 0% | Verde |  |  |  |  |  |  |  |
| 555 | 2.3.7.4.1.2 | Analisar projeto |  | 22d | 2019-07-01 | 2019-07-30 | 554 |  |  | 2019-07-01 | 2019-07-30 | 22d |  |  | 940d | 0d |  | Verde | Verde | 0% | 0% | Verde | 0% | 0% | Verde |  |  |  |  |  |  |  |
| 556 | 2.3.7.4.1.3 | Adequar/revisar projeto |  | 23d | 2019-07-31 | 2019-09-02 | 555 |  |  | 2019-07-31 | 2019-09-02 | 23d |  |  | 940d | 0d |  | Verde | Verde | 0% | 0% | Verde | 0% | 0% | Verde |  |  |  |  |  |  |  |
| 557 | 2.3.7.4.1.4 | Analisar projeto - final |  | 23d | 2019-09-03 | 2019-10-03 | 556 |  |  | 2019-09-03 | 2019-10-03 | 23d |  |  | 940d | 0d |  | Verde | Verde | 0% | 0% | Verde | 0% | 0% | Verde |  |  |  |  |  |  |  |
| 558 | 2.3.7.4.1.5 | Projeto concluído | milestone | 0d | 2019-10-03 | 2019-10-03 | 557, 549 |  |  | 2019-10-03 | 2019-10-03 | 0d |  |  | 940d | 0d |  | Verde | Verde | 0% | 0% | Verde | 0% | 0% | Verde |  |  |  |  |  |  |  |
| 559 | 2.3.7.4.2 | **Licitação da obra** |  | 80d | 2019-10-03 | 2020-01-30 |  |  |  | 2019-10-03 | 2020-01-30 | 80d |  |  | 940d |  |  | Verde | Verde | 0% | 0% | Verde | 0% | 0% |  |  |  |  |  |  |  |  |
| 560 | 2.3.7.4.2.1 | Licitação da obra autorizada pelo banco | milestone | 0d | 2019-10-03 | 2019-10-03 | 558 |  |  | 2019-10-03 | 2019-10-03 | 0d |  |  | 940d | 0d |  | Verde | Verde | 0% | 0% | Verde | 0% | 0% | Verde |  |  |  |  |  |  |  |
| 561 | 2.3.7.4.2.2 | Licitar obra |  | 66d | 2019-10-04 | 2020-01-10 | 560 |  |  | 2019-10-04 | 2020-01-10 | 66d |  |  | 940d | 0d |  | Verde | Verde | 0% | 0% | Verde | 0% | 0% | Verde |  |  |  |  |  |  |  |
| 562 | 2.3.7.4.2.3 | Analisar e emitir resultado da licitação da obra |  | 14d | 2020-01-13 | 2020-01-30 | 561 |  |  | 2020-01-13 | 2020-01-30 | 14d |  |  | 940d | 0d |  | Verde | Verde | 0% | 0% | Verde | 0% | 0% | Verde |  |  |  |  |  |  |  |
| 563 | 2.3.7.4.2.4 | Licitação da obra concluída | milestone | 0d | 2020-01-30 | 2020-01-30 | 562 |  |  | 2020-01-30 | 2020-01-30 | 0d |  |  | 940d | 0d |  | Verde | Verde | 0% | 0% | Verde | 0% | 0% | Verde |  |  |  |  |  |  |  |
| 564 | 2.3.7.4.3 | Executar obra |  | 168d | 2020-03-02 | 2020-10-29 | 563FS+18d |  |  | 2020-03-02 | 2020-10-29 | 168d |  |  | 940d | 0d |  | Verde | Verde | 0% | 0% | Verde | 0% | 0% | Verde |  |  |  |  |  |  |  |
| 565 | 2.3.7.4.4 | Realizar processo de pré-operação |  | 128d | 2020-10-30 | 2021-05-10 | 564 |  |  | 2020-10-30 | 2021-05-10 | 128d |  |  | 940d | 0d |  | Verde | Verde | 0% | 0% | Verde | 0% | 0% | Verde |  |  |  |  |  |  |  |
| 566 | 2.3.7.4.5 | Recurso da obra parcelado repassado | milestone | 0d | 2021-05-17 | 2021-05-17 | 565FS+5d |  |  | 2021-05-17 | 2021-05-17 | 0d |  |  | 940d | 0d |  | Verde | Verde | 0% | 0% | Verde | 0% | 0% | Verde |  |  |  |  |  |  |  |
| 567 | 2.3.7.4.6 | Pleito BUGRSOB02 concluído | milestone | 0d | 2021-05-17 | 2021-05-17 | 566 |  |  | 2021-05-17 | 2021-05-17 | 0d |  |  | 940d | 175d |  | Verde | Verde | 0% | 0% | Verde | 0% | 0% | Verde |  |  |  |  |  |  |  |
| 568 | 2.3.7.5 | Recursos de Bugre repassados | milestone | 0d | 2022-01-25 | 2022-01-25 | 531, 541, 551, 567 |  |  | 2022-01-25 | 2022-01-25 | 0d | 2019-05-02 | 2021-01-28 | 765d |  |  | Verde | Verde | 0% | 0% | Verde | 0% | 0% | Verde | 02 - Execução | PG 031 |  |  |  |  |  |
| 569 | 2.3.8 | **Caratinga** |  | 681d | 2019-04-03 A | 2021-12-28 |  | 2% | 666.34d | 2019-04-03 | 2021-12-28 | 681d | 2018-10-02 | 2021-03-26 | 785d |  |  | Verde | Verde | 2% | 0% | Vermelho | 0% | 0% |  |  |  |  |  |  |  |  |
| 570 | 2.3.8.1 | **Pleito CARESPJ01 - Elaboração de projeto técnico para instalação de ETE nos 10 distritos do município** |  | 90d | 2019-04-16 A | 2019-08-26 |  | 6% | 84.21d | 2019-04-16 | 2019-08-26 | 90d |  |  | 1367d |  |  | Verde | Verde | 10% | 67% | Vermelho | 3% | 2% |  |  |  | 10 | 67 |  |  |  |
| 571 | 2.3.8.1.1 | Alteração do pleito aprovada | milestone | 0d | 2019-05-31 | 2019-05-31 |  |  |  | 2019-05-31 | 2019-05-31 | 0d |  |  | 889d | 0d | start no earlier than 2019-05-31 | Verde | Verde | 0% | 0% | Verde | 0% | 0% | Verde |  |  |  |  |  |  |  |
| 572 | 2.3.8.1.2 | **Licitação do Projeto** |  | 19d | 2019-04-16 A | 2019-05-15 |  | 47% | 10d | 2019-04-16 | 2019-05-15 | 19d |  |  | 889d |  |  | Verde | Verde | 47% | 70% | Vermelho | 47% | 33% |  |  |  | 47 | 70 | 47 | 47 | 33 |
| 573 | 2.3.8.1.2.1 | Analisar e emitir resultado da licitação do projeto |  | 19d | 2019-04-16 A | 2019-05-15 |  | 47% | 10d | 2019-04-16 | 2019-05-15 | 19d |  |  | 889d | 0d | start no earlier than 2019-04-16 | Verde | Verde | 47% | 70% | Vermelho | 47% | 33% | Verde |  |  | 47 | 70 | 47 | 47 | 33 |
| 574 | 2.3.8.1.2.2 | Licitação do projeto concluída | milestone | 0d | 2019-05-15 | 2019-05-15 | 573 |  |  | 2019-05-15 | 2019-05-15 | 0d |  |  | 889d | 0d |  | Verde | Verde | 0% | 0% | Verde | 0% | 0% | Verde |  |  |  |  |  |  |  |
| 575 | 2.3.8.1.3 | **Elaboração do Projeto** |  | 71d | 2019-05-15 | 2019-08-26 |  |  |  | 2019-05-15 | 2019-08-26 | 71d |  |  | 889d |  |  | Verde | Verde | 0% | 0% | Verde | 0% | 0% |  |  |  |  |  |  |  |  |
| 576 | 2.3.8.1.3.1 | Projeto apresentado ao banco | milestone | 0d | 2019-05-15 | 2019-05-15 | 574 |  |  | 2019-05-15 | 2019-05-15 | 0d |  |  | 889d | 0d |  | Verde | Verde | 0% | 0% | Verde | 0% | 0% | Verde |  |  |  |  |  |  |  |
| 577 | 2.3.8.1.3.2 | Analisar projeto |  | 22d | 2019-05-16 | 2019-06-14 | 576 |  |  | 2019-05-16 | 2019-06-14 | 22d |  |  | 889d | 0d |  | Verde | Verde | 0% | 0% | Verde | 0% | 0% | Verde |  |  |  |  |  |  |  |
| 578 | 2.3.8.1.3.3 | Adequar/revisar projeto |  | 22d | 2019-06-17 | 2019-07-17 | 577 |  |  | 2019-06-17 | 2019-07-17 | 22d |  |  | 889d | 0d |  | Verde | Verde | 0% | 0% | Verde | 0% | 0% | Verde |  |  |  |  |  |  |  |
| 579 | 2.3.8.1.3.4 | Analisar projeto - final |  | 22d | 2019-07-18 | 2019-08-19 | 578 |  |  | 2019-07-18 | 2019-08-19 | 22d |  |  | 889d | 0d |  | Verde | Verde | 0% | 0% | Verde | 0% | 0% | Verde |  |  |  |  |  |  |  |
| 580 | 2.3.8.1.3.5 | Projeto concluído | milestone | 0d | 2019-08-19 | 2019-08-19 | 579, 582 |  |  | 2019-08-19 | 2019-08-19 | 0d |  |  | 889d | 0d |  | Verde | Verde | 0% | 0% | Verde | 0% | 0% | Verde |  |  |  |  |  |  |  |
| 581 | 2.3.8.1.3.6 | Recurso do projeto do pleito CARESPJ01 repassado | milestone | 0d | 2019-08-26 | 2019-08-26 | 580FS+5d |  |  | 2019-08-26 | 2019-08-26 | 0d |  |  | 1367d | 0d |  | Verde | Verde | 0% | 0% | Verde | 0% | 0% | Verde |  |  |  |  |  |  |  |
| 582 | 2.3.8.1.4 | Realizar Licenciamento Ambiental |  | 55d | 2019-05-31 | 2019-08-19 | 571 |  |  | 2019-05-31 | 2019-08-19 | 55d |  |  | 889d | 0d |  | Verde | Verde | 0% | 0% | Verde | 0% | 0% | Verde |  |  |  |  |  |  |  |
| 583 | 2.3.8.1.5 | Pleito CARESPJ01 concluído | milestone | 0d | 2019-08-26 | 2019-08-26 | 581 |  |  | 2019-08-26 | 2019-08-26 | 0d |  |  | 1367d | 582d |  | Verde | Verde | 0% | 0% | Verde | 0% | 0% | Verde |  |  |  |  |  |  |  |

Notes:
- 554: Em 24/09/2019: em virtude de ainda não ter sido discutido cronograma com os consórcios e devido aos recorrentes atrasos do CIMVA 1, Sara V. estimou a apresentação do projeto em até 2 meses considerando que foi reportado que o projeto está concluído desde meados de 2018.
- 564: Em 24/04/2019: o valor da obra de CIMVA1 é de R$ 1,8 milhões
- 568: Valor de recurso destinado ao munícipio: R$4.726.993,07
- 569: Caratinga teve 70,0% (R$15.441.510,07) dos recursos destinado para Esgotamento Sanitário aprovado, conforme Deliberação 75. / O município teve o pleito de resíduos sólidos negado (R$2.205.930,10 equivalente a 10% do total do recurso,). / Caratinga solicitou mudança de pleito, mas ainda não foi autorizado pelo CIF. / · Destinação de 13% do teto de esgotamento sanitário para resíduos sólidos. / Aderiu à ata de registro de preço.
- 571: Em 25/04/2019: o ofício 37/2019 de alteração de pleito foi enviado dia 22/04/2019 e provavelmente será aprovado no CIF de 31/05/2019.
- 573: Em 25/04/2019: o município protocolou 16/04/2019 o processo licitatório completo no banco, após primeira negativa do banco do processo de licitação em 21/03/2019. / Em 29/04/2019: atualizado como agendado

| ID | WBS | Task | Type | Duration | Start | Finish | Predecessors | Complete | Remaining | Baseline start | Baseline finish | Baseline duration | Baseline 1 start | Baseline 1 finish | Total slack | Free slack | Constraint | Farol de Atraso | Farol Marcos | % Previsto Tempo | Índice de Desempenho Físico (IDF) | Farol IDF | % Previsto Ponderado | % Concluído Ponderado | Farol de Início | IDF Numérico | % Concluída Numérico | % Previsto Tempo Numérico | % Previsto Ponderado Numérico | % Concluído Ponderado Numérico | Responsável | Código do Contrato |
| --- | --- | --- | --- | --- | --- | --- | --- | --- | --- | --- | --- | --- | --- | --- | --- | --- | --- | --- | --- | --- | --- | --- | --- | --- | --- | --- | --- | --- | --- | --- | --- | --- |
| 584 | 2.3.8.2 | **Pleito CARESOB01 - Instalação de ETEs nos 10 distritos de Caratinga** |  | 538d | 2019-05-31 | 2021-07-28 |  |  |  | 2019-05-31 | 2021-07-28 | 538d |  |  | 889d |  |  | Verde | Verde | 0% | 0% | Verde | 0% | 0% |  |  |  |  |  |  |  |  |
| 585 | 2.3.8.2.1 | Alteração do pleito aprovada | milestone | 0d | 2019-05-31 | 2019-05-31 | 571 |  |  | 2019-05-31 | 2019-05-31 | 0d |  |  | 944d | 55d |  | Verde | Verde | 0% | 0% | Verde | 0% | 0% | Verde |  |  |  |  |  |  |  |
| 586 | 2.3.8.2.2 | **Licitação da obra** |  | 80d | 2019-08-19 | 2019-12-10 |  |  |  | 2019-08-19 | 2019-12-10 | 80d |  |  | 889d |  |  | Verde | Verde | 0% | 0% | Verde | 0% | 0% |  |  |  |  |  |  |  |  |
| 587 | 2.3.8.2.2.1 | Licitação da obra autorizada pelo banco | milestone | 0d | 2019-08-19 | 2019-08-19 | 580, 585 |  |  | 2019-08-19 | 2019-08-19 | 0d |  |  | 889d | 0d |  | Verde | Verde | 0% | 0% | Verde | 0% | 0% | Verde |  |  |  |  |  |  |  |
| 588 | 2.3.8.2.2.2 | Licitar obra |  | 66d | 2019-08-20 | 2019-11-20 | 587 |  |  | 2019-08-20 | 2019-11-20 | 66d |  |  | 889d | 0d |  | Verde | Verde | 0% | 0% | Verde | 0% | 0% | Verde |  |  |  |  |  |  |  |
| 589 | 2.3.8.2.2.3 | Analisar licitação da obra |  | 14d | 2019-11-21 | 2019-12-10 | 588 |  |  | 2019-11-21 | 2019-12-10 | 14d |  |  | 889d | 0d |  | Verde | Verde | 0% | 0% | Verde | 0% | 0% | Verde |  |  |  |  |  |  |  |
| 590 | 2.3.8.2.2.4 | Licitação da obra concluída | milestone | 0d | 2019-12-10 | 2019-12-10 | 589 |  |  | 2019-12-10 | 2019-12-10 | 0d |  |  | 889d | 0d |  | Verde | Verde | 0% | 0% | Verde | 0% | 0% | Verde |  |  |  |  |  |  |  |
| 591 | 2.3.8.2.3 | Executar obra |  | 250d | 2020-01-14 | 2021-01-14 | 590FS+20d |  |  | 2020-01-14 | 2021-01-14 | 250d |  |  | 889d | 0d |  | Verde | Verde | 0% | 0% | Verde | 0% | 0% | Verde |  |  |  |  |  |  |  |
| 592 | 2.3.8.2.4 | Realizar processo de pré-operação |  | 128d | 2021-01-15 | 2021-07-21 | 591 |  |  | 2021-01-15 | 2021-07-21 | 128d |  |  | 889d | 0d |  | Verde | Verde | 0% | 0% | Verde | 0% | 0% | Verde |  |  |  |  |  |  |  |
| 593 | 2.3.8.2.5 | Recurso da obra parcelado repassado | milestone | 0d | 2021-07-28 | 2021-07-28 | 592FS+5d |  |  | 2021-07-28 | 2021-07-28 | 0d |  |  | 889d | 0d |  | Verde | Verde | 0% | 0% | Verde | 0% | 0% | Verde |  |  |  |  |  |  |  |
| 594 | 2.3.8.2.6 | Pleito CARESOB01 concluído | milestone | 0d | 2021-07-28 | 2021-07-28 | 593 |  |  | 2021-07-28 | 2021-07-28 | 0d |  |  | 889d | 104d |  | Verde | Verde | 0% | 0% | Verde | 0% | 0% | Verde |  |  |  |  |  |  |  |
| 595 | 2.3.8.3 | **Pleito CARRSOB02 - Ampliação do aterro sanitário de Caratinga, incluindo uma Unidade de Triagem e Compostagem - UTC** |  | 681d | 2019-04-03 A | 2021-12-28 |  | 3% | 662.31d | 2019-04-03 | 2021-12-28 | 681d |  |  | 785d |  |  | Verde | Verde | 2% | 100% | Verde | 1% | 1% |  | 100 |  |  |  |  |  |  |
| 596 | 2.3.8.3.1 | **Aprovação do Projeto Executivo** |  | 139d | 2019-04-03 A | 2019-10-21 |  | 13% | 121d | 2019-04-03 | 2019-10-21 | 139d |  |  | 785d |  |  | Verde | Verde | 12% | 83% | Vermelho | 6% | 5% |  | 83 | 13 | 12 |  |  |  |  |
| 597 | 2.3.8.3.1.1 | Projeto apresentado ao banco | milestone | 0d | 2019-04-03 A | 2019-04-03 A |  | 100% |  | 2019-04-03 | 2019-04-03 | 0d |  |  |  |  | must start on 2019-04-03 | Verde | Verde | 100% | 0% | Vermelho | 100% | 0% | Verde |  | 100 | 100 | 100 |  |  |  |
| 598 | 2.3.8.3.1.2 | Analisar projeto |  | 95d | 2019-04-03 A | 2019-08-20 | 597 | 19% | 77d | 2019-04-03 | 2019-08-20 | 95d |  |  | 785d | 0d |  | Verde | Verde | 18% | 89% | Vermelho | 18% | 16% | Verde | 89 | 19 | 18 | 18 | 16 |  |  |
| 599 | 2.3.8.3.1.3 | Adequar/revisar projeto |  | 22d | 2019-08-21 | 2019-09-19 | 598 |  |  | 2019-08-21 | 2019-09-19 | 22d |  |  | 785d | 0d |  | Verde | Verde | 0% | 0% | Verde | 0% | 0% | Verde |  |  |  |  |  |  |  |
| 600 | 2.3.8.3.1.4 | Analisar projeto - final |  | 22d | 2019-09-20 | 2019-10-21 | 599 |  |  | 2019-09-20 | 2019-10-21 | 22d |  |  | 785d | 0d |  | Verde | Verde | 0% | 0% | Verde | 0% | 0% | Verde |  |  |  |  |  |  |  |
| 601 | 2.3.8.3.1.5 | Projeto concluído | milestone | 0d | 2019-10-21 | 2019-10-21 | 600 |  |  | 2019-10-21 | 2019-10-21 | 0d |  |  | 785d | 0d |  | Verde | Verde | 0% | 0% | Verde | 0% | 0% | Verde |  |  |  |  |  |  |  |
| 602 | 2.3.8.3.2 | **Licitação da obra** |  | 80d | 2019-10-21 | 2020-02-17 |  |  |  | 2019-10-21 | 2020-02-17 | 80d |  |  | 785d |  |  | Verde | Verde | 0% | 0% | Verde | 0% | 0% |  |  |  |  |  |  |  |  |
| 603 | 2.3.8.3.2.1 | Licitação da obra autorizada pelo banco | milestone | 0d | 2019-10-21 | 2019-10-21 | 601 |  |  | 2019-10-21 | 2019-10-21 | 0d |  |  | 785d | 0d |  | Verde | Verde | 0% | 0% | Verde | 0% | 0% | Verde |  |  |  |  |  |  |  |
| 604 | 2.3.8.3.2.2 | Licitar obra |  | 66d | 2019-10-22 | 2020-01-28 | 603 |  |  | 2019-10-22 | 2020-01-28 | 66d |  |  | 785d | 0d |  | Verde | Verde | 0% | 0% | Verde | 0% | 0% | Verde |  |  |  |  |  |  |  |
| 605 | 2.3.8.3.2.3 | Analisar e emitir resultado da licitação da obra |  | 14d | 2020-01-29 | 2020-02-17 | 604 |  |  | 2020-01-29 | 2020-02-17 | 14d |  |  | 785d | 0d |  | Verde | Verde | 0% | 0% | Verde | 0% | 0% | Verde |  |  |  |  |  |  |  |
| 606 | 2.3.8.3.2.4 | Licitação da obra concluída | milestone | 0d | 2020-02-17 | 2020-02-17 | 605 |  |  | 2020-02-17 | 2020-02-17 | 0d |  |  | 785d | 0d |  | Verde | Verde | 0% | 0% | Verde | 0% | 0% | Verde |  |  |  |  |  |  |  |
| 607 | 2.3.8.3.3 | Executar obra |  | 309d | 2020-03-20 | 2021-06-17 | 606FS+20d |  |  | 2020-03-20 | 2021-06-17 | 309d |  |  | 785d | 0d |  | Verde | Verde | 0% | 0% | Verde | 0% | 0% | Verde |  |  |  |  |  |  |  |
| 608 | 2.3.8.3.4 | Realizar processo de pré-operação |  | 128d | 2021-06-18 | 2021-12-20 | 607 |  |  | 2021-06-18 | 2021-12-20 | 128d |  |  | 785d | 0d |  | Verde | Verde | 0% | 0% | Verde | 0% | 0% | Verde |  |  |  |  |  |  |  |
| 609 | 2.3.8.3.5 | Recurso da obra parcelado repassado | milestone | 0d | 2021-12-28 | 2021-12-28 | 608FS+5d |  |  | 2021-12-28 | 2021-12-28 | 0d |  |  | 785d | 0d |  | Verde | Verde | 0% | 0% | Verde | 0% | 0% | Verde |  |  |  |  |  |  |  |
| 610 | 2.3.8.3.6 | Pleito CARRSOB02 concluído | milestone | 0d | 2021-12-28 | 2021-12-28 | 609 |  |  | 2021-12-28 | 2021-12-28 | 0d |  |  | 785d | 0d |  | Verde | Verde | 0% | 0% | Verde | 0% | 0% | Verde |  |  |  |  |  |  |  |
| 611 | 2.3.8.4 | Recursos de Caratinga repassados | milestone | 0d | 2021-12-28 | 2021-12-28 | 583, 594, 610 |  |  | 2021-12-28 | 2021-12-28 | 0d | 2019-04-30 | 2021-03-26 | 785d |  |  | Verde | Verde | 0% | 0% | Verde | 0% | 0% | Verde |  |  |  |  |  | 02 - Execução | PG 031 |

Notes:
- 591: Em 25/04/2019: valor total das obras 15 milhões, foi considerado que as obras ocorrerão em paralelo com valores iguais.
- 598: Em 29/04/2019: atualizado como agendado
- 607: Em 24/09/2019: o valor da obra do CIDESLESTE é R$ 5,9 milhões
- 611: Valor de recurso destinado ao munícipio: R$22.059.301,00

| ID | WBS | Task | Type | Duration | Start | Finish | Predecessors | Complete | Remaining | Baseline start | Baseline finish | Baseline duration | Baseline 1 start | Baseline 1 finish | Total slack | Free slack | Farol de Atraso | Farol Marcos | % Previsto Tempo | Índice de Desempenho Físico (IDF) | IDF Numérico | Farol IDF | % Previsto Ponderado | % Concluído Ponderado | % Concluída Numérico | % Previsto Tempo Numérico | % Previsto Ponderado Numérico | % Concluído Ponderado Numérico | Farol de Início |
| --- | --- | --- | --- | --- | --- | --- | --- | --- | --- | --- | --- | --- | --- | --- | --- | --- | --- | --- | --- | --- | --- | --- | --- | --- | --- | --- | --- | --- | --- |
| 612 | 2.3.9 | **Colatina** |  | 867d | 2019-03-14 A | 2022-09-05 |  | 1% | 857.85d | 2019-03-14 | 2022-09-05 | 867d | 2019-01-07 | 2021-07-15 | 613d |  | Verde | Verde | 3% | 100% | 100 | Verde | 4% | 4% |  |  |  |  |  |
| 613 | 2.3.9.1 | **Pleito COLESOB03 - Complementação de recursos de contrapartida para implantação de 1ª etapa ETE (Valor orçado para conclusão, obra em execução)** |  | 294d | 2019-03-14 A | 2020-05-20 |  | 11% | 261.45d | 2019-03-14 | 2020-05-20 | 294d |  |  | 1186d |  | Verde | Verde | 10% | 109% | 109 | Verde | 11% | 12% | 11 | 10 | 11 | 12 |  |
| 614 | 2.3.9.1.1 | Reembolso do pleito aprovado | milestone | 0d | 2019-05-31 | 2019-05-31 | 206FS+115d |  |  | 2019-05-31 | 2019-05-31 | 0d |  |  | 31d | 0d | Verde | Verde | 0% | 0% |  | Verde | 0% | 0% |  |  |  |  | Verde |
| 615 | 2.3.9.1.2 | Recurso parcial do pleito COLESOB03 repassado | milestone | 0d | 2019-06-07 | 2019-06-07 | 614FS+5d |  |  | 2019-06-07 | 2019-06-07 | 0d |  |  | 1421d | 235d | Verde | Verde | 0% | 0% |  | Verde | 0% | 0% |  |  |  |  | Verde |
| 616 | 2.3.9.1.3 | Executar obra |  | 161d | 2019-03-14 A | 2019-10-31 | 614FS-53d | 20% | 129d | 2019-03-14 | 2019-10-31 | 161d |  |  | 1186d | 0d | Verde | Verde | 19% | 105% | 105 | Verde | 19% | 20% | 20 | 19 | 19 | 20 | Verde |
| 617 | 2.3.9.1.4 | Realizar processo de pré-operação |  | 128d | 2019-11-01 | 2020-05-13 | 616 |  |  | 2019-11-01 | 2020-05-13 | 128d |  |  | 1186d | 0d | Verde | Verde | 0% | 0% |  | Verde | 0% | 0% |  |  |  |  | Verde |
| 618 | 2.3.9.1.5 | Recurso da obra parcelado repassado | milestone | 0d | 2020-05-20 | 2020-05-20 | 617FS+5d |  |  | 2020-05-20 | 2020-05-20 | 0d |  |  | 1186d | 0d | Verde | Verde | 0% | 0% |  | Verde | 0% | 0% |  |  |  |  | Verde |
| 619 | 2.3.9.1.6 | Pleito COLESOB03 concluído | milestone | 0d | 2020-05-20 | 2020-05-20 | 618, 615 |  |  | 2020-05-20 | 2020-05-20 | 0d |  |  | 1186d | 573d | Verde | Verde | 0% | 0% |  | Verde | 0% | 0% |  |  |  |  | Verde |
| 620 | 2.3.9.2 | **Pleito COLESOB01 - Complementação de recursos de contrapartida para implantação da LR 503, parte integrante do SES do Lado Sul (em execução)** |  | 74d | 2019-03-25 A | 2019-07-10 |  | 47% | 39.09d | 2019-03-25 | 2019-07-10 | 74d |  |  | 1399d |  | Verde | Verde | 33% | 100% | 100 | Verde | 35% | 35% | 47 | 33 | 35 | 35 |  |
| 621 | 2.3.9.2.1 | Reembolso do pleito aprovado | milestone | 0d | 2019-05-31 | 2019-05-31 | 206FS+115d |  |  | 2019-05-31 | 2019-05-31 | 0d |  |  | 23d | 0d | Verde | Verde | 0% | 0% |  | Verde | 0% | 0% |  |  |  |  | Verde |
| 622 | 2.3.9.2.2 | Protocolar documentação de reembolso |  | 43d | 2019-03-25 A | 2019-05-27 | 621FS-45d | 58% | 18d | 2019-03-25 | 2019-05-27 | 43d |  |  | 1399d | 0d | Verde | Verde | 58% | 98% | 98 | Vermelho | 58% | 57% | 58 | 58 | 58 | 57 | Verde |
| 623 | 2.3.9.2.3 | Analisar documentação de reembolso |  | 10d | 2019-05-28 | 2019-06-10 | 622 |  |  | 2019-05-28 | 2019-06-10 | 10d |  |  | 1399d | 0d | Verde | Verde | 0% | 0% |  | Verde | 0% | 0% |  |  |  |  | Verde |
| 624 | 2.3.9.2.4 | Recurso do reembolso repassado | milestone | 0d | 2019-07-10 | 2019-07-10 | 623FS+21d |  |  | 2019-07-10 | 2019-07-10 | 0d |  |  | 1399d | 0d | Verde | Verde | 0% | 0% |  | Verde | 0% | 0% |  |  |  |  | Verde |
| 625 | 2.3.9.2.5 | Pleito COLESOB01 concluído | milestone | 0d | 2019-07-10 | 2019-07-10 | 624 |  |  | 2019-07-10 | 2019-07-10 | 0d |  |  | 1399d | 786d | Verde | Verde | 0% | 0% |  | Verde | 0% | 0% |  |  |  |  | Verde |
| 626 | 2.3.9.3 | **Pleito COLESOB02 - Complementação de recursos de contrapartida para implantação da EEE S02 e EEE S04, parte integrante do SES do Lado Sul (em execução)** |  | 74d | 2019-03-25 A | 2019-07-10 |  | 47% | 39.09d | 2019-03-25 | 2019-07-10 | 74d |  |  | 1399d |  | Verde | Verde | 33% | 97% | 97 | Vermelho | 35% | 34% | 47 | 33 | 35 | 34 |  |
| 627 | 2.3.9.3.1 | Reembolso aprovado | milestone | 0d | 2019-05-31 | 2019-05-31 | 621SS |  |  | 2019-05-31 | 2019-05-31 | 0d |  |  | 23d | 0d | Verde | Verde | 0% | 0% |  | Verde | 0% | 0% |  |  |  |  | Verde |
| 628 | 2.3.9.3.2 | Protocolar documentação de reembolso |  | 43d | 2019-03-25 A | 2019-05-27 | 627FS-45d | 58% | 18d | 2019-03-25 | 2019-05-27 | 43d |  |  | 1399d | 0d | Verde | Verde | 58% | 98% | 98 | Vermelho | 58% | 57% | 58 | 58 | 58 | 57 | Verde |
| 629 | 2.3.9.3.3 | Analisar documentação de reembolso |  | 10d | 2019-05-28 | 2019-06-10 | 628 |  |  | 2019-05-28 | 2019-06-10 | 10d |  |  | 1399d | 0d | Verde | Verde | 0% | 0% |  | Verde | 0% | 0% |  |  |  |  | Verde |
| 630 | 2.3.9.3.4 | Recurso do reembolso repassado | milestone | 0d | 2019-07-10 | 2019-07-10 | 629FS+21d |  |  | 2019-07-10 | 2019-07-10 | 0d |  |  | 1399d | 0d | Verde | Verde | 0% | 0% |  | Verde | 0% | 0% |  |  |  |  | Verde |
| 631 | 2.3.9.3.5 | Pleito COLESOB02 concluído | milestone | 0d | 2019-07-10 | 2019-07-10 | 630 |  |  | 2019-07-10 | 2019-07-10 | 0d |  |  | 1399d | 786d | Verde | Verde | 0% | 0% |  | Verde | 0% | 0% |  |  |  |  | Verde |
| 632 | 2.3.9.4 | **Pleito COLESOB07 - Implantação da 2ª etapa do SES do Lado Norte da sede municipal - EEEs e LRs** |  | 473d | 2019-03-25 | 2021-02-18 |  |  |  | 2019-03-25 | 2021-02-18 | 473d |  |  | 1000d |  | Verde | Verde | 5% | 0% |  | Vermelho | 3% | 0% |  |  |  |  |  |
| 633 | 2.3.9.4.1 | Alteração do pleito aprovada | milestone | 0d | 2019-06-27 | 2019-06-27 | 206FS+133d |  |  | 2019-06-27 | 2019-06-27 | 0d |  |  | 1000d | 0d | Verde | Verde | 0% | 0% |  | Verde | 0% | 0% |  |  |  |  | Verde |
| 634 | 2.3.9.4.2 | **Apresentação do Projeto** |  | 65d | 2019-03-25 | 2019-06-27 |  |  |  | 2019-03-25 | 2019-06-27 | 65d |  |  | 1000d |  | Verde | Verde | 38% | 0% |  | Vermelho | 33% | 0% |  | 38 | 33 |  |  |
| 635 | 2.3.9.4.2.1 | Elaborar projeto |  | 47d | 2019-03-25 | 2019-05-31 | 206FS+68d |  |  | 2019-03-25 | 2019-05-31 | 47d |  |  | 1004d | 0d | Verde | Verde | 53% | 0% |  | Vermelho | 53% | 0% |  | 53 | 53 |  | Verde |
| 636 | 2.3.9.4.2.2 | Projeto apresentado ao banco | milestone | 0d | 2019-05-31 | 2019-05-31 | 635 |  |  | 2019-05-31 | 2019-05-31 | 0d |  |  | 1004d | 4d | Verde | Verde | 0% | 0% |  | Verde | 0% | 0% |  |  |  |  | Verde |
| 637 | 2.3.9.4.2.3 | Analisar projeto |  | 14d | 2019-06-07 | 2019-06-27 | 636, 633FF |  |  | 2019-06-07 | 2019-06-27 | 14d |  |  | 1000d | 0d | Verde | Verde | 0% | 0% |  | Verde | 0% | 0% |  |  |  |  | Verde |
| 638 | 2.3.9.4.2.4 | Projeto aprovado | milestone | 0d | 2019-06-27 | 2019-06-27 | 637 |  |  | 2019-06-27 | 2019-06-27 | 0d |  |  | 1000d | 0d | Verde | Verde | 0% | 0% |  | Verde | 0% | 0% |  |  |  |  | Verde |

Notes:
- 612: Colatina teve 100% dos pleitos de Esgotamento Sanitário Aprovado. / O pleito de resíduos sólido (10% do total do recurso destinado ao munícipio) foi aprovado. / Colatina tem obras na prioridade 2, 3 e 5. / Para a prioridade 3 ainda não temos informações de como está o licenciamento ambiental, o que poderá impactar a programação destas obras.
- 613: Cronograma 1
- 614: Em 16/04/2019: o município enviou o ofício de alteração de pleito no dia 20/03/2019 para receber o reembolso do % executado das obras com recurso da renova. A análise do pleito não foi analisado na câmara técnica de 2/04/2019 ficando para o dia 07/05/2019 e CIF no dia 31/05/2019.
- 615: Em 16/04/2019: 795.048,64 reembolso
- 616: Em 16/04/2019: premissa - início de obra (início de uso do recurso da Renova) 30 dias antes do envio da primeira medição / Em 29/04/2019: atualizado como agendado
- 621: Em 16/04/2019: a alteração do pleito será aprovada no dia 30/05 pelo CIF.
- 622: Em 16/04/2019: na reunião do dia 25/03 município informou que parte da documentação foi apresentada ao banco (projeto). Foi constatado durante a reunião a necessidade de apresentação de outros documentos (licença, terreno, etc.), por isso a data foi postergada até final de maio. / Em 29/04/2019: atualizado como agendado
- 628: Em 29/04/2019: atualizado como agendado
- 633: Em 16/04/2019: o processo de alteração e aprovação do pleito será realizado em paralelo com a elaboração do projeto
- 635: Em 29/04/2019: município está finalizando o projeto (fonte: Cynthia). Atualizado como agendado

| ID | WBS | Task | Type | Duration | Start | Finish | Predecessors | Complete | Remaining | Baseline start | Baseline finish | Baseline duration | Total slack | Free slack | Farol de Atraso | Farol Marcos | % Previsto Tempo | Índice de Desempenho Físico (IDF) | Farol IDF | % Previsto Ponderado | % Concluído Ponderado | Farol de Início | IDF Numérico | % Concluída Numérico | % Previsto Tempo Numérico | % Previsto Ponderado Numérico | % Concluído Ponderado Numérico |
| --- | --- | --- | --- | --- | --- | --- | --- | --- | --- | --- | --- | --- | --- | --- | --- | --- | --- | --- | --- | --- | --- | --- | --- | --- | --- | --- | --- |
| 639 | 2.3.9.4.3 | **Licitação da obra** |  | 74d | 2019-07-04 | 2019-10-17 |  |  |  | 2019-07-04 | 2019-10-17 | 74d | 1000d |  | Verde | Verde | 0% | 0% | Verde | 0% | 0% |  |  |  |  |  |  |
| 640 | 2.3.9.4.3.1 | Licitação da obra autorizada pelo banco | milestone | 0d | 2019-07-04 | 2019-07-04 | 638FS+5d |  |  | 2019-07-04 | 2019-07-04 | 0d | 1000d | 0d | Verde | Verde | 0% | 0% | Verde | 0% | 0% | Verde |  |  |  |  |  |
| 641 | 2.3.9.4.3.2 | Licitar obra |  | 66d | 2019-07-05 | 2019-10-07 | 640 |  |  | 2019-07-05 | 2019-10-07 | 66d | 1000d | 0d | Verde | Verde | 0% | 0% | Verde | 0% | 0% | Verde |  |  |  |  |  |
| 642 | 2.3.9.4.3.3 | Analisar e emitir resultado da licitação da obra |  | 8d | 2019-10-08 | 2019-10-17 | 641 |  |  | 2019-10-08 | 2019-10-17 | 8d | 1000d | 0d | Verde | Verde | 0% | 0% | Verde | 0% | 0% | Verde |  |  |  |  |  |
| 643 | 2.3.9.4.3.4 | Licitação da obra concluída | milestone | 0d | 2019-10-17 | 2019-10-17 | 642 |  |  | 2019-10-17 | 2019-10-17 | 0d | 1000d | 0d | Verde | Verde | 0% | 0% | Verde | 0% | 0% | Verde |  |  |  |  |  |
| 644 | 2.3.9.4.4 | Executar obra |  | 176d | 2019-11-18 | 2020-08-04 | 643FS+20d |  |  | 2019-11-18 | 2020-08-04 | 176d | 1000d | 0d | Verde | Verde | 0% | 0% | Verde | 0% | 0% | Verde |  |  |  |  |  |
| 645 | 2.3.9.4.5 | Realizar processo de pré-operação |  | 128d | 2020-08-05 | 2021-02-08 | 644 |  |  | 2020-08-05 | 2021-02-08 | 128d | 1000d | 0d | Verde | Verde | 0% | 0% | Verde | 0% | 0% | Verde |  |  |  |  |  |
| 646 | 2.3.9.4.6 | Recurso da obra parcelado repassado | milestone | 0d | 2021-02-18 | 2021-02-18 | 645FS+5d |  |  | 2021-02-18 | 2021-02-18 | 0d | 1000d | 0d | Verde | Verde | 0% | 0% | Verde | 0% | 0% | Verde |  |  |  |  |  |
| 647 | 2.3.9.4.7 | Pleito COLESOB07 concluído | milestone | 0d | 2021-02-18 | 2021-02-18 | 646 |  |  | 2021-02-18 | 2021-02-18 | 0d | 1000d | 387d | Verde | Verde | 0% | 0% | Verde | 0% | 0% | Verde |  |  |  |  |  |
| 648 | 2.3.9.5 | **Pleito COLESOB06 - Complementação do SES do Lado Norte da sede municipal - EEEs, LRs e interceptor** |  | 800d | 2019-03-25 A | 2022-06-09 |  | 3% | 773.79d | 2019-03-25 | 2022-06-09 | 800d | 673d |  | Verde | Verde | 3% | 100% | Verde | 2% | 2% |  | 100 |  |  |  |  |
| 649 | 2.3.9.5.1 | Alteração do pleito aprovado | milestone | 0d | 2019-08-29 | 2019-08-29 | 206FS+177d |  |  | 2019-08-29 | 2019-08-29 | 0d | 673d | 0d | Verde | Verde | 0% | 0% | Verde | 0% | 0% | Verde |  |  |  |  |  |
| 650 | 2.3.9.5.2 | **Elaboração do Projeto** |  | 109d | 2019-03-25 A | 2019-08-29 |  | 24% | 82.54d | 2019-03-25 | 2019-08-29 | 109d | 673d |  | Verde | Verde | 22% | 100% | Verde | 22% | 22% |  | 100 | 24 | 22 | 22 | 22 |
| 651 | 2.3.9.5.2.1 | Elaborar projeto |  | 89d | 2019-03-25 A | 2019-07-31 | 206FS+68d | 28% | 64d | 2019-03-25 | 2019-07-31 | 89d | 679d | 0d | Verde | Verde | 28% | 100% | Verde | 28% | 28% | Verde | 100 | 28 | 28 | 28 | 28 |
| 652 | 2.3.9.5.2.2 | Projeto apresentado ao banco | milestone | 0d | 2019-07-31 | 2019-07-31 | 651 |  |  | 2019-07-31 | 2019-07-31 | 0d | 679d | 6d | Verde | Verde | 0% | 0% | Verde | 0% | 0% | Verde |  |  |  |  |  |
| 653 | 2.3.9.5.2.3 | Analisar projeto |  | 14d | 2019-08-09 | 2019-08-29 | 652, 649FF |  |  | 2019-08-09 | 2019-08-29 | 14d | 673d | 0d | Verde | Verde | 0% | 0% | Verde | 0% | 0% | Verde |  |  |  |  |  |
| 654 | 2.3.9.5.2.4 | Projeto concluído | milestone | 0d | 2019-08-29 | 2019-08-29 | 653 |  |  | 2019-08-29 | 2019-08-29 | 0d | 673d | 0d | Verde | Verde | 0% | 0% | Verde | 0% | 0% | Verde |  |  |  |  |  |
| 655 | 2.3.9.5.3 | **Licitação da obra** |  | 92d | 2019-09-05 | 2020-01-20 |  |  |  | 2019-09-05 | 2020-01-20 | 92d | 673d |  | Verde | Verde | 0% | 0% | Verde | 0% | 0% |  |  |  |  |  |  |
| 656 | 2.3.9.5.3.1 | Licitação da obra autorizada pelo banco | milestone | 0d | 2019-09-05 | 2019-09-05 | 654FS+5d |  |  | 2019-09-05 | 2019-09-05 | 0d | 673d | 0d | Verde | Verde | 0% | 0% | Verde | 0% | 0% | Verde |  |  |  |  |  |
| 657 | 2.3.9.5.3.2 | Licitar obra |  | 86d | 2019-09-06 | 2020-01-10 | 656 |  |  | 2019-09-06 | 2020-01-10 | 86d | 673d | 0d | Verde | Verde | 0% | 0% | Verde | 0% | 0% | Verde |  |  |  |  |  |
| 658 | 2.3.9.5.3.3 | Analisar e emitir resultado da licitação da obra |  | 6d | 2020-01-13 | 2020-01-20 | 657 |  |  | 2020-01-13 | 2020-01-20 | 6d | 673d | 0d | Verde | Verde | 0% | 0% | Verde | 0% | 0% | Verde |  |  |  |  |  |
| 659 | 2.3.9.5.3.4 | Licitação da obra concluída | milestone | 0d | 2020-01-20 | 2020-01-20 | 658 |  |  | 2020-01-20 | 2020-01-20 | 0d | 673d | 0d | Verde | Verde | 0% | 0% | Verde | 0% | 0% | Verde |  |  |  |  |  |
| 660 | 2.3.9.5.4 | Executar obra |  | 440d | 2020-02-19 | 2021-11-26 | 659FS+21d |  |  | 2020-02-19 | 2021-11-26 | 440d | 673d | 0d | Verde | Verde | 0% | 0% | Verde | 0% | 0% | Verde |  |  |  |  |  |
| 661 | 2.3.9.5.5 | Realizar processo de pré-operação |  | 128d | 2021-11-29 | 2022-06-02 | 660 |  |  | 2021-11-29 | 2022-06-02 | 128d | 673d | 0d | Verde | Verde | 0% | 0% | Verde | 0% | 0% | Verde |  |  |  |  |  |
| 662 | 2.3.9.5.6 | Recurso da obra parcelado repassado | milestone | 0d | 2022-06-09 | 2022-06-09 | 661FS+5d |  |  | 2022-06-09 | 2022-06-09 | 0d | 673d | 0d | Verde | Verde | 0% | 0% | Verde | 0% | 0% | Verde |  |  |  |  |  |
| 663 | 2.3.9.5.7 | Pleito COLESOB06 concluído | milestone | 0d | 2022-06-09 | 2022-06-09 | 662 |  |  | 2022-06-09 | 2022-06-09 | 0d | 673d | 60d | Verde | Verde | 0% | 0% | Verde | 0% | 0% | Verde |  |  |  |  |  |

Notes:
- 651: Em 29/04/2019: atualizado como agendado

| ID | WBS | Task | Type | Duration | Start | Finish | Predecessors | Baseline start | Baseline finish | Baseline duration | Total slack | Free slack | Farol de Atraso | Farol Marcos | % Previsto Tempo | Índice de Desempenho Físico (IDF) | Farol IDF | % Previsto Ponderado | % Concluído Ponderado | Farol de Início |
| --- | --- | --- | --- | --- | --- | --- | --- | --- | --- | --- | --- | --- | --- | --- | --- | --- | --- | --- | --- | --- |
| 664 | 2.3.9.6 | **Pleito COLESPJ01 - Elaboração de projetos executivos de recuperação da ETE do bairro Columbia** |  | 277d | 2019-12-02 | 2021-01-14 |  | 2019-12-02 | 2021-01-14 | 277d | 623d |  | Verde | Verde | 0% | 0% | Verde | 0% | 0% |  |
| 665 | 2.3.9.6.1 | **Licitação do Projeto** |  | 61d | 2019-12-02 | 2020-03-04 |  | 2019-12-02 | 2020-03-04 | 61d | 623d |  | Verde | Verde | 0% | 0% | Verde | 0% | 0% |  |
| 666 | 2.3.9.6.1.1 | Licitar projeto |  | 42d | 2019-12-02 | 2020-02-03 | 206FS+242d | 2019-12-02 | 2020-02-03 | 42d | 623d | 0d | Verde | Verde | 0% | 0% | Verde | 0% | 0% | Verde |
| 667 | 2.3.9.6.1.2 | Documentação de licitação apresentada ao banco | milestone | 0d | 2020-02-10 | 2020-02-10 | 666FS+5d | 2020-02-10 | 2020-02-10 | 0d | 623d | 0d | Verde | Verde | 0% | 0% | Verde | 0% | 0% | Verde |
| 668 | 2.3.9.6.1.3 | Analisar e emitir resultado da licitação do projeto |  | 14d | 2020-02-11 | 2020-03-04 | 667 | 2020-02-11 | 2020-03-04 | 14d | 623d | 0d | Verde | Verde | 0% | 0% | Verde | 0% | 0% | Verde |
| 669 | 2.3.9.6.1.4 | Licitação do projeto concluída | milestone | 0d | 2020-03-04 | 2020-03-04 | 668 | 2020-03-04 | 2020-03-04 | 0d | 623d | 0d | Verde | Verde | 0% | 0% | Verde | 0% | 0% | Verde |
| 670 | 2.3.9.6.2 | **Elaboração do Projeto Básico** |  | 134d | 2020-03-05 | 2020-09-15 |  | 2020-03-05 | 2020-09-15 | 134d | 623d |  | Verde | Verde | 0% | 0% | Verde | 0% | 0% |  |
| 671 | 2.3.9.6.2.1 | Elaborar Projeto Básico |  | 62d | 2020-03-05 | 2020-06-03 | 669 | 2020-03-05 | 2020-06-03 | 62d | 623d | 0d | Verde | Verde | 0% | 0% | Verde | 0% | 0% | Verde |
| 672 | 2.3.9.6.2.2 | Projeto básico apresentado ao banco | milestone | 0d | 2020-06-03 | 2020-06-03 | 671 | 2020-06-03 | 2020-06-03 | 0d | 623d | 0d | Verde | Verde | 0% | 0% | Verde | 0% | 0% | Verde |
| 673 | 2.3.9.6.2.3 | Analisar Projeto Básico |  | 22d | 2020-06-04 | 2020-07-06 | 672 | 2020-06-04 | 2020-07-06 | 22d | 700d | 0d | Verde | Verde | 0% | 0% | Verde | 0% | 0% | Verde |
| 674 | 2.3.9.6.2.4 | Adequar/revisar projeto básico |  | 23d | 2020-07-07 | 2020-08-06 | 673 | 2020-07-07 | 2020-08-06 | 23d | 700d | 0d | Verde | Verde | 0% | 0% | Verde | 0% | 0% | Verde |
| 675 | 2.3.9.6.2.5 | Analisar projeto básico - final |  | 22d | 2020-08-07 | 2020-09-08 | 674 | 2020-08-07 | 2020-09-08 | 22d | 700d | 0d | Verde | Verde | 0% | 0% | Verde | 0% | 0% | Verde |
| 676 | 2.3.9.6.2.6 | Projeto básico concluído | milestone | 0d | 2020-09-08 | 2020-09-08 | 675 | 2020-09-08 | 2020-09-08 | 0d | 700d | 0d | Verde | Verde | 0% | 0% | Verde | 0% | 0% | Verde |
| 677 | 2.3.9.6.2.7 | Recurso do projeto básico do pleito repassado | milestone | 0d | 2020-09-15 | 2020-09-15 | 676FS+5d | 2020-09-15 | 2020-09-15 | 0d | 700d | 77d | Verde | Verde | 0% | 0% | Verde | 0% | 0% | Verde |
| 678 | 2.3.9.6.3 | Realizar Licenciamento Ambiental |  | 149d | 2020-06-04 | 2021-01-07 | 672 | 2020-06-04 | 2021-01-07 | 149d | 623d | 0d | Verde | Verde | 0% | 0% | Verde | 0% | 0% | Verde |
| 679 | 2.3.9.6.4 | **Elaboração do Projeto Executivo** |  | 154d | 2020-06-04 | 2021-01-14 |  | 2020-06-04 | 2021-01-14 | 154d | 623d |  | Verde | Verde | 0% | 0% | Verde | 0% | 0% |  |
| 680 | 2.3.9.6.4.1 | Elaborar Projeto Executivo |  | 84d | 2020-06-04 | 2020-10-01 | 672 | 2020-06-04 | 2020-10-01 | 84d | 623d | 0d | Verde | Verde | 0% | 0% | Verde | 0% | 0% | Verde |
| 681 | 2.3.9.6.4.2 | Projeto executivo apresentado ao banco | milestone | 0d | 2020-10-01 | 2020-10-01 | 680 | 2020-10-01 | 2020-10-01 | 0d | 623d | 0d | Verde | Verde | 0% | 0% | Verde | 0% | 0% | Verde |
| 682 | 2.3.9.6.4.3 | Analisar projeto executivo |  | 24d | 2020-10-02 | 2020-11-06 | 681 | 2020-10-02 | 2020-11-06 | 24d | 623d | 0d | Verde | Verde | 0% | 0% | Verde | 0% | 0% | Verde |
| 683 | 2.3.9.6.4.4 | Adequar/revisar projeto executivo |  | 18d | 2020-11-09 | 2020-12-02 | 682 | 2020-11-09 | 2020-12-02 | 18d | 623d | 0d | Verde | Verde | 0% | 0% | Verde | 0% | 0% | Verde |
| 684 | 2.3.9.6.4.5 | Analisar projeto executivo - final |  | 23d | 2020-12-03 | 2021-01-07 | 683 | 2020-12-03 | 2021-01-07 | 23d | 623d | 0d | Verde | Verde | 0% | 0% | Verde | 0% | 0% | Verde |
| 685 | 2.3.9.6.4.6 | Projeto executivo concluído | milestone | 0d | 2021-01-07 | 2021-01-07 | 684, 678, 677 | 2021-01-07 | 2021-01-07 | 0d | 623d | 0d | Verde | Verde | 0% | 0% | Verde | 0% | 0% | Verde |
| 686 | 2.3.9.6.4.7 | Recurso do projeto executivo do pleito repassado | milestone | 0d | 2021-01-14 | 2021-01-14 | 685FS+5d | 2021-01-14 | 2021-01-14 | 0d | 623d | 0d | Verde | Verde | 0% | 0% | Verde | 0% | 0% | Verde |
| 687 | 2.3.9.6.5 | Pleito COLESPJ01 concluído | milestone | 0d | 2021-01-14 | 2021-01-14 | 686 | 2021-01-14 | 2021-01-14 | 0d | 623d | 0d | Verde | Verde | 0% | 0% | Verde | 0% | 0% | Verde |

| ID | WBS | Task | Type | Duration | Start | Finish | Predecessors | Baseline start | Baseline finish | Baseline duration | Total slack | Free slack | Farol de Atraso | Farol Marcos | % Previsto Tempo | Índice de Desempenho Físico (IDF) | Farol IDF | % Previsto Ponderado | % Concluído Ponderado | Farol de Início |
| --- | --- | --- | --- | --- | --- | --- | --- | --- | --- | --- | --- | --- | --- | --- | --- | --- | --- | --- | --- | --- |
| 688 | 2.3.9.7 | **Pleito COLESOB08 - Recuperação da ETE do Bairro Columbia** |  | 399d | 2021-01-14 | 2022-08-22 |  | 2021-01-14 | 2022-08-22 | 399d | 623d |  | Verde | Verde | 0% | 0% | Verde | 0% | 0% |  |
| 689 | 2.3.9.7.1 | **Licitação da Obra** |  | 75d | 2021-01-14 | 2021-05-06 |  | 2021-01-14 | 2021-05-06 | 75d | 623d |  | Verde | Verde | 0% | 0% | Verde | 0% | 0% |  |
| 690 | 2.3.9.7.1.1 | Licitação da obra autorizada pelo banco | milestone | 0d | 2021-01-14 | 2021-01-14 | 687 | 2021-01-14 | 2021-01-14 | 0d | 623d | 0d | Verde | Verde | 0% | 0% | Verde | 0% | 0% | Verde |
| 691 | 2.3.9.7.1.2 | Licitar Obra |  | 61d | 2021-01-15 | 2021-04-15 | 690 | 2021-01-15 | 2021-04-15 | 61d | 623d | 0d | Verde | Verde | 0% | 0% | Verde | 0% | 0% | Verde |
| 692 | 2.3.9.7.1.3 | Analisar e emitir resultado da licitação da obra |  | 14d | 2021-04-16 | 2021-05-06 | 691 | 2021-04-16 | 2021-05-06 | 14d | 623d | 0d | Verde | Verde | 0% | 0% | Verde | 0% | 0% | Verde |
| 693 | 2.3.9.7.1.4 | Licitação da obra concluída | milestone | 0d | 2021-05-06 | 2021-05-06 | 692 | 2021-05-06 | 2021-05-06 | 0d | 623d | 0d | Verde | Verde | 0% | 0% | Verde | 0% | 0% | Verde |
| 694 | 2.3.9.7.2 | Executar obra |  | 171d | 2021-06-07 | 2022-02-07 | 693FS+20d | 2021-06-07 | 2022-02-07 | 171d | 623d | 0d | Verde | Verde | 0% | 0% | Verde | 0% | 0% | Verde |
| 695 | 2.3.9.7.3 | Realizar processo de pré-operação |  | 128d | 2022-02-08 | 2022-08-12 | 694 | 2022-02-08 | 2022-08-12 | 128d | 623d | 0d | Verde | Verde | 0% | 0% | Verde | 0% | 0% | Verde |
| 696 | 2.3.9.7.4 | Recurso da obra parcelado repassado | milestone | 0d | 2022-08-22 | 2022-08-22 | 695FS+5d | 2022-08-22 | 2022-08-22 | 0d | 623d | 0d | Verde | Verde | 0% | 0% | Verde | 0% | 0% | Verde |
| 697 | 2.3.9.7.5 | Pleito COLESOB08 concluído | milestone | 0d | 2022-08-22 | 2022-08-22 | 696 | 2022-08-22 | 2022-08-22 | 0d | 623d | 10d | Verde | Verde | 0% | 0% | Verde | 0% | 0% | Verde |
| 698 | 2.3.9.8 | **Pleito COLESPJ02 - Elaboração de projetos executivos de recuperação da ETE do bairro Luiz Iglesias (Acampamento)** |  | 277d | 2019-12-02 | 2021-01-14 |  | 2019-12-02 | 2021-01-14 | 277d | 666d |  | Verde | Verde | 0% | 0% | Verde | 0% | 0% |  |
| 699 | 2.3.9.8.1 | **Licitação do Projeto** |  | 56d | 2019-12-02 | 2020-02-21 |  | 2019-12-02 | 2020-02-21 | 56d | 666d |  | Verde | Verde | 0% | 0% | Verde | 0% | 0% |  |
| 700 | 2.3.9.8.1.1 | Licitar projeto |  | 42d | 2019-12-02 | 2020-02-03 | 206FS+242d | 2019-12-02 | 2020-02-03 | 42d | 666d | 0d | Verde | Verde | 0% | 0% | Verde | 0% | 0% | Verde |
| 701 | 2.3.9.8.1.2 | Documentação de licitação apresentada ao banco | milestone | 0d | 2020-02-03 | 2020-02-03 | 700 | 2020-02-03 | 2020-02-03 | 0d | 666d | 0d | Verde | Verde | 0% | 0% | Verde | 0% | 0% | Verde |
| 702 | 2.3.9.8.1.3 | Analisar e emitir resultado da licitação do projeto |  | 14d | 2020-02-04 | 2020-02-21 | 701 | 2020-02-04 | 2020-02-21 | 14d | 666d | 0d | Verde | Verde | 0% | 0% | Verde | 0% | 0% | Verde |
| 703 | 2.3.9.8.1.4 | Licitação do projeto concluída | milestone | 0d | 2020-02-21 | 2020-02-21 | 702 | 2020-02-21 | 2020-02-21 | 0d | 666d | 0d | Verde | Verde | 0% | 0% | Verde | 0% | 0% | Verde |
| 704 | 2.3.9.8.2 | **Elaboração do Projeto Básico** |  | 134d | 2020-02-27 | 2020-09-08 |  | 2020-02-27 | 2020-09-08 | 134d | 666d |  | Verde | Verde | 0% | 0% | Verde | 0% | 0% |  |
| 705 | 2.3.9.8.2.1 | Elaborar Projeto Básico |  | 62d | 2020-02-27 | 2020-05-27 | 703 | 2020-02-27 | 2020-05-27 | 62d | 666d | 0d | Verde | Verde | 0% | 0% | Verde | 0% | 0% | Verde |
| 706 | 2.3.9.8.2.2 | Projeto básico apresentado ao banco | milestone | 0d | 2020-05-27 | 2020-05-27 | 705 | 2020-05-27 | 2020-05-27 | 0d | 666d | 0d | Verde | Verde | 0% | 0% | Verde | 0% | 0% | Verde |
| 707 | 2.3.9.8.2.3 | Analisar Projeto Básico |  | 22d | 2020-05-28 | 2020-06-29 | 706 | 2020-05-28 | 2020-06-29 | 22d | 748d | 0d | Verde | Verde | 0% | 0% | Verde | 0% | 0% | Verde |
| 708 | 2.3.9.8.2.4 | Adequar/revisar projeto básico |  | 23d | 2020-06-30 | 2020-07-30 | 707 | 2020-06-30 | 2020-07-30 | 23d | 748d | 0d | Verde | Verde | 0% | 0% | Verde | 0% | 0% | Verde |
| 709 | 2.3.9.8.2.5 | Analisar projeto básico - final |  | 22d | 2020-07-31 | 2020-08-31 | 708 | 2020-07-31 | 2020-08-31 | 22d | 748d | 0d | Verde | Verde | 0% | 0% | Verde | 0% | 0% | Verde |
| 710 | 2.3.9.8.2.6 | Projeto básico concluído | milestone | 0d | 2020-08-31 | 2020-08-31 | 709 | 2020-08-31 | 2020-08-31 | 0d | 748d | 0d | Verde | Verde | 0% | 0% | Verde | 0% | 0% | Verde |
| 711 | 2.3.9.8.2.7 | Recurso do projeto básico do pleito repassado | milestone | 0d | 2020-09-08 | 2020-09-08 | 710FS+5d | 2020-09-08 | 2020-09-08 | 0d | 748d | 82d | Verde | Verde | 0% | 0% | Verde | 0% | 0% | Verde |
| 712 | 2.3.9.8.3 | Realizar Licenciamento Ambiental |  | 149d | 2020-05-28 | 2020-12-30 | 706 | 2020-05-28 | 2020-12-30 | 149d | 671d | 5d | Verde | Verde | 0% | 0% | Verde | 0% | 0% | Verde |

| ID | WBS | Task | Type | Duration | Start | Finish | Predecessors | Baseline start | Baseline finish | Baseline duration | Total slack | Free slack | Farol de Atraso | Farol Marcos | % Previsto Tempo | Índice de Desempenho Físico (IDF) | Farol IDF | % Previsto Ponderado | % Concluído Ponderado | Farol de Início |
| --- | --- | --- | --- | --- | --- | --- | --- | --- | --- | --- | --- | --- | --- | --- | --- | --- | --- | --- | --- | --- |
| 713 | 2.3.9.8.4 | **Elaboração do Projeto Executivo** |  | 159d | 2020-05-28 | 2021-01-14 |  | 2020-05-28 | 2021-01-14 | 159d | 666d |  | Verde | Verde | 0% | 0% | Verde | 0% | 0% |  |
| 714 | 2.3.9.8.4.1 | Elaborar Projeto Executivo |  | 88d | 2020-05-28 | 2020-09-30 | 706 | 2020-05-28 | 2020-09-30 | 88d | 666d | 0d | Verde | Verde | 0% | 0% | Verde | 0% | 0% | Verde |
| 715 | 2.3.9.8.4.2 | Projeto executivo apresentado ao banco | milestone | 0d | 2020-09-30 | 2020-09-30 | 714 | 2020-09-30 | 2020-09-30 | 0d | 666d | 0d | Verde | Verde | 0% | 0% | Verde | 0% | 0% | Verde |
| 716 | 2.3.9.8.4.3 | Analisar projeto executivo |  | 22d | 2020-10-01 | 2020-11-03 | 715 | 2020-10-01 | 2020-11-03 | 22d | 666d | 0d | Verde | Verde | 0% | 0% | Verde | 0% | 0% | Verde |
| 717 | 2.3.9.8.4.4 | Adequar/revisar projeto executivo |  | 22d | 2020-11-04 | 2020-12-03 | 716 | 2020-11-04 | 2020-12-03 | 22d | 666d | 0d | Verde | Verde | 0% | 0% | Verde | 0% | 0% | Verde |
| 718 | 2.3.9.8.4.5 | Analisar projeto executivo - final |  | 22d | 2020-12-04 | 2021-01-07 | 717 | 2020-12-04 | 2021-01-07 | 22d | 666d | 0d | Verde | Verde | 0% | 0% | Verde | 0% | 0% | Verde |
| 719 | 2.3.9.8.4.6 | Projeto executivo concluído | milestone | 0d | 2021-01-07 | 2021-01-07 | 718, 712, 711 | 2021-01-07 | 2021-01-07 | 0d | 666d | 0d | Verde | Verde | 0% | 0% | Verde | 0% | 0% | Verde |
| 720 | 2.3.9.8.4.7 | Recurso do projeto executivo do pleito repassado | milestone | 0d | 2021-01-14 | 2021-01-14 | 719FS+5d | 2021-01-14 | 2021-01-14 | 0d | 666d | 0d | Verde | Verde | 0% | 0% | Verde | 0% | 0% | Verde |
| 721 | 2.3.9.8.5 | Pleito COLESPJ02 concluído | milestone | 0d | 2021-01-14 | 2021-01-14 | 720 | 2021-01-14 | 2021-01-14 | 0d | 666d | 0d | Verde | Verde | 0% | 0% | Verde | 0% | 0% | Verde |
| 722 | 2.3.9.9 | **Pleito COLESOB09 - Recuperação da ETE do bairro Luiz Iglesias (Acamopamento)** |  | 356d | 2021-01-14 | 2022-06-21 |  | 2021-01-14 | 2022-06-21 | 356d | 666d |  | Verde | Verde | 0% | 0% | Verde | 0% | 0% |  |
| 723 | 2.3.9.9.1 | **Licitação da Obra** |  | 75d | 2021-01-14 | 2021-05-06 |  | 2021-01-14 | 2021-05-06 | 75d | 666d |  | Verde | Verde | 0% | 0% | Verde | 0% | 0% |  |
| 724 | 2.3.9.9.1.1 | Licitação da obra autorizada pelo banco | milestone | 0d | 2021-01-14 | 2021-01-14 | 721 | 2021-01-14 | 2021-01-14 | 0d | 666d | 0d | Verde | Verde | 0% | 0% | Verde | 0% | 0% | Verde |
| 725 | 2.3.9.9.1.2 | Licitar Obra |  | 61d | 2021-01-15 | 2021-04-15 | 724 | 2021-01-15 | 2021-04-15 | 61d | 666d | 0d | Verde | Verde | 0% | 0% | Verde | 0% | 0% | Verde |
| 726 | 2.3.9.9.1.3 | Analisar e emitir resultado da licitação da obra |  | 14d | 2021-04-16 | 2021-05-06 | 725 | 2021-04-16 | 2021-05-06 | 14d | 666d | 0d | Verde | Verde | 0% | 0% | Verde | 0% | 0% | Verde |
| 727 | 2.3.9.9.1.4 | Licitação da obra concluída | milestone | 0d | 2021-05-06 | 2021-05-06 | 726 | 2021-05-06 | 2021-05-06 | 0d | 666d | 0d | Verde | Verde | 0% | 0% | Verde | 0% | 0% | Verde |
| 728 | 2.3.9.9.2 | Executar obra |  | 128d | 2021-06-07 | 2021-12-07 | 727FS+20d | 2021-06-07 | 2021-12-07 | 128d | 666d | 0d | Verde | Verde | 0% | 0% | Verde | 0% | 0% | Verde |
| 729 | 2.3.9.9.3 | Realizar processo de pré-operação |  | 128d | 2021-12-08 | 2022-06-13 | 728 | 2021-12-08 | 2022-06-13 | 128d | 666d | 0d | Verde | Verde | 0% | 0% | Verde | 0% | 0% | Verde |
| 730 | 2.3.9.9.4 | Recurso da obra parcelado repassado | milestone | 0d | 2022-06-21 | 2022-06-21 | 729FS+5d | 2022-06-21 | 2022-06-21 | 0d | 666d | 0d | Verde | Verde | 0% | 0% | Verde | 0% | 0% | Verde |
| 731 | 2.3.9.9.5 | Pleito COLESOB09 concluído | milestone | 0d | 2022-06-21 | 2022-06-21 | 730 | 2022-06-21 | 2022-06-21 | 0d | 666d | 53d | Verde | Verde | 0% | 0% | Verde | 0% | 0% | Verde |
| 732 | 2.3.9.10 | **Pleito COLESPJ03 - Elaboração de projeto executivo de complementação do SES do distrito de Itapina** |  | 277d | 2019-12-02 | 2021-01-14 |  | 2019-12-02 | 2021-01-14 | 277d | 666d |  | Verde | Verde | 0% | 0% | Verde | 0% | 0% |  |
| 733 | 2.3.9.10.1 | **Licitação do Projeto** |  | 61d | 2019-12-02 | 2020-03-04 |  | 2019-12-02 | 2020-03-04 | 61d | 666d |  | Verde | Verde | 0% | 0% | Verde | 0% | 0% |  |
| 734 | 2.3.9.10.1.1 | Licitar projeto |  | 42d | 2019-12-02 | 2020-02-03 | 206FS+242d | 2019-12-02 | 2020-02-03 | 42d | 666d | 0d | Verde | Verde | 0% | 0% | Verde | 0% | 0% | Verde |
| 735 | 2.3.9.10.1.2 | Documentação de licitação apresentada ao banco | milestone | 0d | 2020-02-10 | 2020-02-10 | 734FS+5d | 2020-02-10 | 2020-02-10 | 0d | 666d | 0d | Verde | Verde | 0% | 0% | Verde | 0% | 0% | Verde |
| 736 | 2.3.9.10.1.3 | Analisar e emitir resultado da licitação do projeto |  | 14d | 2020-02-11 | 2020-03-04 | 735 | 2020-02-11 | 2020-03-04 | 14d | 666d | 0d | Verde | Verde | 0% | 0% | Verde | 0% | 0% | Verde |
| 737 | 2.3.9.10.1.4 | Licitação do projeto concluída | milestone | 0d | 2020-03-04 | 2020-03-04 | 736 | 2020-03-04 | 2020-03-04 | 0d | 666d | 0d | Verde | Verde | 0% | 0% | Verde | 0% | 0% | Verde |

| ID | WBS | Task | Type | Duration | Start | Finish | Predecessors | Baseline start | Baseline finish | Baseline duration | Total slack | Free slack | Farol de Atraso | Farol Marcos | % Previsto Tempo | Índice de Desempenho Físico (IDF) | Farol IDF | % Previsto Ponderado | % Concluído Ponderado | Farol de Início |
| --- | --- | --- | --- | --- | --- | --- | --- | --- | --- | --- | --- | --- | --- | --- | --- | --- | --- | --- | --- | --- |
| 738 | 2.3.9.10.2 | **Elaboração do Projeto Básico** |  | 134d | 2020-03-05 | 2020-09-15 |  | 2020-03-05 | 2020-09-15 | 134d | 666d |  | Verde | Verde | 0% | 0% | Verde | 0% | 0% |  |
| 739 | 2.3.9.10.2.1 | Elaborar Projeto Básico |  | 62d | 2020-03-05 | 2020-06-03 | 737 | 2020-03-05 | 2020-06-03 | 62d | 666d | 0d | Verde | Verde | 0% | 0% | Verde | 0% | 0% | Verde |
| 740 | 2.3.9.10.2.2 | Projeto básico apresentado ao banco | milestone | 0d | 2020-06-03 | 2020-06-03 | 739 | 2020-06-03 | 2020-06-03 | 0d | 666d | 0d | Verde | Verde | 0% | 0% | Verde | 0% | 0% | Verde |
| 741 | 2.3.9.10.2.3 | Analisar Projeto Básico |  | 22d | 2020-06-04 | 2020-07-06 | 740 | 2020-06-04 | 2020-07-06 | 22d | 743d | 0d | Verde | Verde | 0% | 0% | Verde | 0% | 0% | Verde |
| 742 | 2.3.9.10.2.4 | Adequar/revisar projeto básico |  | 23d | 2020-07-07 | 2020-08-06 | 741 | 2020-07-07 | 2020-08-06 | 23d | 743d | 0d | Verde | Verde | 0% | 0% | Verde | 0% | 0% | Verde |
| 743 | 2.3.9.10.2.5 | Analisar projeto básico - final |  | 22d | 2020-08-07 | 2020-09-08 | 742 | 2020-08-07 | 2020-09-08 | 22d | 743d | 0d | Verde | Verde | 0% | 0% | Verde | 0% | 0% | Verde |
| 744 | 2.3.9.10.2.6 | Projeto básico concluído | milestone | 0d | 2020-09-08 | 2020-09-08 | 743 | 2020-09-08 | 2020-09-08 | 0d | 743d | 0d | Verde | Verde | 0% | 0% | Verde | 0% | 0% | Verde |
| 745 | 2.3.9.10.2.7 | Recurso do projeto básico do pleito repassado | milestone | 0d | 2020-09-15 | 2020-09-15 | 744FS+5d | 2020-09-15 | 2020-09-15 | 0d | 743d | 77d | Verde | Verde | 0% | 0% | Verde | 0% | 0% | Verde |
| 746 | 2.3.9.10.3 | Realizar Licenciamento Ambiental |  | 149d | 2020-06-04 | 2021-01-07 | 740 | 2020-06-04 | 2021-01-07 | 149d | 666d | 0d | Verde | Verde | 0% | 0% | Verde | 0% | 0% | Verde |
| 747 | 2.3.9.10.4 | **Elaboração do Projeto Executivo** |  | 154d | 2020-06-04 | 2021-01-14 |  | 2020-06-04 | 2021-01-14 | 154d | 666d |  | Verde | Verde | 0% | 0% | Verde | 0% | 0% |  |
| 748 | 2.3.9.10.4.1 | Elaborar Projeto Executivo |  | 84d | 2020-06-04 | 2020-10-01 | 740 | 2020-06-04 | 2020-10-01 | 84d | 666d | 0d | Verde | Verde | 0% | 0% | Verde | 0% | 0% | Verde |
| 749 | 2.3.9.10.4.2 | Projeto executivo apresentado ao banco | milestone | 0d | 2020-10-01 | 2020-10-01 | 748 | 2020-10-01 | 2020-10-01 | 0d | 666d | 0d | Verde | Verde | 0% | 0% | Verde | 0% | 0% | Verde |
| 750 | 2.3.9.10.4.3 | Analisar projeto executivo |  | 24d | 2020-10-02 | 2020-11-06 | 749 | 2020-10-02 | 2020-11-06 | 24d | 666d | 0d | Verde | Verde | 0% | 0% | Verde | 0% | 0% | Verde |
| 751 | 2.3.9.10.4.4 | Adequar/revisar projeto executivo |  | 18d | 2020-11-09 | 2020-12-02 | 750 | 2020-11-09 | 2020-12-02 | 18d | 666d | 0d | Verde | Verde | 0% | 0% | Verde | 0% | 0% | Verde |
| 752 | 2.3.9.10.4.5 | Analisar projeto executivo - final |  | 23d | 2020-12-03 | 2021-01-07 | 751 | 2020-12-03 | 2021-01-07 | 23d | 666d | 0d | Verde | Verde | 0% | 0% | Verde | 0% | 0% | Verde |
| 753 | 2.3.9.10.4.6 | Projeto executivo concluído | milestone | 0d | 2021-01-07 | 2021-01-07 | 752, 746, 745 | 2021-01-07 | 2021-01-07 | 0d | 666d | 0d | Verde | Verde | 0% | 0% | Verde | 0% | 0% | Verde |
| 754 | 2.3.9.10.4.7 | Recurso do projeto executivo do pleito repassado | milestone | 0d | 2021-01-14 | 2021-01-14 | 753FS+5d | 2021-01-14 | 2021-01-14 | 0d | 666d | 0d | Verde | Verde | 0% | 0% | Verde | 0% | 0% | Verde |
| 755 | 2.3.9.10.5 | Pleito COLESPJ03 concluído | milestone | 0d | 2021-01-14 | 2021-01-14 | 754 | 2021-01-14 | 2021-01-14 | 0d | 666d | 0d | Verde | Verde | 0% | 0% | Verde | 0% | 0% | Verde |
| 756 | 2.3.9.11 | **Pleito COLESOB10 - Complementação do SES do distrito de Itapina** |  | 356d | 2021-01-14 | 2022-06-21 |  | 2021-01-14 | 2022-06-21 | 356d | 666d |  | Verde | Verde | 0% | 0% | Verde | 0% | 0% |  |
| 757 | 2.3.9.11.1 | **Licitação da Obra** |  | 75d | 2021-01-14 | 2021-05-06 |  | 2021-01-14 | 2021-05-06 | 75d | 666d |  | Verde | Verde | 0% | 0% | Verde | 0% | 0% |  |
| 758 | 2.3.9.11.1.1 | Licitação da obra autorizada pelo banco | milestone | 0d | 2021-01-14 | 2021-01-14 | 755 | 2021-01-14 | 2021-01-14 | 0d | 666d | 0d | Verde | Verde | 0% | 0% | Verde | 0% | 0% | Verde |
| 759 | 2.3.9.11.1.2 | Licitar Obra |  | 61d | 2021-01-15 | 2021-04-15 | 758 | 2021-01-15 | 2021-04-15 | 61d | 666d | 0d | Verde | Verde | 0% | 0% | Verde | 0% | 0% | Verde |
| 760 | 2.3.9.11.1.3 | Analisar e emitir resultado da licitação da obra |  | 14d | 2021-04-16 | 2021-05-06 | 759 | 2021-04-16 | 2021-05-06 | 14d | 666d | 0d | Verde | Verde | 0% | 0% | Verde | 0% | 0% | Verde |
| 761 | 2.3.9.11.1.4 | Licitação da obra concluída | milestone | 0d | 2021-05-06 | 2021-05-06 | 760 | 2021-05-06 | 2021-05-06 | 0d | 666d | 0d | Verde | Verde | 0% | 0% | Verde | 0% | 0% | Verde |
| 762 | 2.3.9.11.2 | Executar obra |  | 128d | 2021-06-07 | 2021-12-07 | 761FS+20d | 2021-06-07 | 2021-12-07 | 128d | 666d | 0d | Verde | Verde | 0% | 0% | Verde | 0% | 0% | Verde |
| 763 | 2.3.9.11.3 | Realizar processo de pré-operação |  | 128d | 2021-12-08 | 2022-06-13 | 762 | 2021-12-08 | 2022-06-13 | 128d | 666d | 0d | Verde | Verde | 0% | 0% | Verde | 0% | 0% | Verde |
| 764 | 2.3.9.11.4 | Recurso da obra parcelado repassado | milestone | 0d | 2022-06-21 | 2022-06-21 | 763FS+5d | 2022-06-21 | 2022-06-21 | 0d | 666d | 0d | Verde | Verde | 0% | 0% | Verde | 0% | 0% | Verde |
| 765 | 2.3.9.11.5 | Pleito COLESOB10 concluído | milestone | 0d | 2022-06-21 | 2022-06-21 | 764 | 2022-06-21 | 2022-06-21 | 0d | 666d | 53d | Verde | Verde | 0% | 0% | Verde | 0% | 0% | Verde |

| ID | WBS | Task | Type | Duration | Start | Finish | Predecessors | Baseline start | Baseline finish | Baseline duration | Total slack | Free slack | Farol de Atraso | Farol Marcos | % Previsto Tempo | Índice de Desempenho Físico (IDF) | Farol IDF | % Previsto Ponderado | % Concluído Ponderado | Farol de Início |
| --- | --- | --- | --- | --- | --- | --- | --- | --- | --- | --- | --- | --- | --- | --- | --- | --- | --- | --- | --- | --- |
| 766 | 2.3.9.12 | **Pleito COLESPJ04 - Elaboração de projeto executivo de complementação do SES do distrito de Boapaba** |  | 277d | 2019-12-02 | 2021-01-14 |  | 2019-12-02 | 2021-01-14 | 277d | 666d |  | Verde | Verde | 0% | 0% | Verde | 0% | 0% |  |
| 767 | 2.3.9.12.1 | **Licitação do Projeto** |  | 61d | 2019-12-02 | 2020-03-04 |  | 2019-12-02 | 2020-03-04 | 61d | 666d |  | Verde | Verde | 0% | 0% | Verde | 0% | 0% |  |
| 768 | 2.3.9.12.1.1 | Licitar projeto |  | 42d | 2019-12-02 | 2020-02-03 | 206FS+242d | 2019-12-02 | 2020-02-03 | 42d | 666d | 0d | Verde | Verde | 0% | 0% | Verde | 0% | 0% | Verde |
| 769 | 2.3.9.12.1.2 | Documentação de licitação apresentada ao banco | milestone | 0d | 2020-02-10 | 2020-02-10 | 768FS+5d | 2020-02-10 | 2020-02-10 | 0d | 666d | 0d | Verde | Verde | 0% | 0% | Verde | 0% | 0% | Verde |
| 770 | 2.3.9.12.1.3 | Analisar e emitir resultado da licitação do projeto |  | 14d | 2020-02-11 | 2020-03-04 | 769 | 2020-02-11 | 2020-03-04 | 14d | 666d | 0d | Verde | Verde | 0% | 0% | Verde | 0% | 0% | Verde |
| 771 | 2.3.9.12.1.4 | Licitação do projeto concluída | milestone | 0d | 2020-03-04 | 2020-03-04 | 770 | 2020-03-04 | 2020-03-04 | 0d | 666d | 0d | Verde | Verde | 0% | 0% | Verde | 0% | 0% | Verde |
| 772 | 2.3.9.12.2 | **Elaboração do Projeto Básico** |  | 134d | 2020-03-05 | 2020-09-15 |  | 2020-03-05 | 2020-09-15 | 134d | 666d |  | Verde | Verde | 0% | 0% | Verde | 0% | 0% |  |
| 773 | 2.3.9.12.2.1 | Elaborar Projeto Básico |  | 62d | 2020-03-05 | 2020-06-03 | 771 | 2020-03-05 | 2020-06-03 | 62d | 666d | 0d | Verde | Verde | 0% | 0% | Verde | 0% | 0% | Verde |
| 774 | 2.3.9.12.2.2 | Projeto básico apresentado ao banco | milestone | 0d | 2020-06-03 | 2020-06-03 | 773 | 2020-06-03 | 2020-06-03 | 0d | 666d | 0d | Verde | Verde | 0% | 0% | Verde | 0% | 0% | Verde |
| 775 | 2.3.9.12.2.3 | Analisar Projeto Básico |  | 22d | 2020-06-04 | 2020-07-06 | 774 | 2020-06-04 | 2020-07-06 | 22d | 748d | 0d | Verde | Verde | 0% | 0% | Verde | 0% | 0% | Verde |
| 776 | 2.3.9.12.2.4 | Adequar/revisar projeto básico |  | 23d | 2020-07-07 | 2020-08-06 | 775 | 2020-07-07 | 2020-08-06 | 23d | 748d | 0d | Verde | Verde | 0% | 0% | Verde | 0% | 0% | Verde |
| 777 | 2.3.9.12.2.5 | Analisar projeto básico - final |  | 22d | 2020-08-07 | 2020-09-08 | 776 | 2020-08-07 | 2020-09-08 | 22d | 748d | 0d | Verde | Verde | 0% | 0% | Verde | 0% | 0% | Verde |
| 778 | 2.3.9.12.2.6 | Projeto básico concluído | milestone | 0d | 2020-09-08 | 2020-09-08 | 777 | 2020-09-08 | 2020-09-08 | 0d | 748d | 0d | Verde | Verde | 0% | 0% | Verde | 0% | 0% | Verde |
| 779 | 2.3.9.12.2.7 | Recurso do projeto básico do pleito repassado | milestone | 0d | 2020-09-15 | 2020-09-15 | 778FS+5d | 2020-09-15 | 2020-09-15 | 0d | 748d | 82d | Verde | Verde | 0% | 0% | Verde | 0% | 0% | Verde |
| 780 | 2.3.9.12.3 | Realizar Licenciamento Ambiental |  | 149d | 2020-06-04 | 2021-01-07 | 774 | 2020-06-04 | 2021-01-07 | 149d | 671d | 5d | Verde | Verde | 0% | 0% | Verde | 0% | 0% | Verde |
| 781 | 2.3.9.12.4 | **Elaboração do Projeto Executivo** |  | 154d | 2020-06-04 | 2021-01-14 |  | 2020-06-04 | 2021-01-14 | 154d | 666d |  | Verde | Verde | 0% | 0% | Verde | 0% | 0% |  |
| 782 | 2.3.9.12.4.1 | Elaborar Projeto Executivo |  | 84d | 2020-06-04 | 2020-10-01 | 774 | 2020-06-04 | 2020-10-01 | 84d | 666d | 0d | Verde | Verde | 0% | 0% | Verde | 0% | 0% | Verde |
| 783 | 2.3.9.12.4.2 | Projeto executivo apresentado ao banco | milestone | 0d | 2020-10-01 | 2020-10-01 | 782 | 2020-10-01 | 2020-10-01 | 0d | 666d | 0d | Verde | Verde | 0% | 0% | Verde | 0% | 0% | Verde |
| 784 | 2.3.9.12.4.3 | Analisar projeto executivo |  | 24d | 2020-10-02 | 2020-11-06 | 783 | 2020-10-02 | 2020-11-06 | 24d | 666d | 0d | Verde | Verde | 0% | 0% | Verde | 0% | 0% | Verde |
| 785 | 2.3.9.12.4.4 | Adequar/revisar projeto executivo |  | 18d | 2020-11-09 | 2020-12-02 | 784 | 2020-11-09 | 2020-12-02 | 18d | 666d | 0d | Verde | Verde | 0% | 0% | Verde | 0% | 0% | Verde |
| 786 | 2.3.9.12.4.5 | Analisar projeto executivo - final |  | 23d | 2020-12-03 | 2021-01-07 | 785 | 2020-12-03 | 2021-01-07 | 23d | 666d | 0d | Verde | Verde | 0% | 0% | Verde | 0% | 0% | Verde |
| 787 | 2.3.9.12.4.6 | Projeto executivo concluído | milestone | 0d | 2021-01-07 | 2021-01-07 | 786 | 2021-01-07 | 2021-01-07 | 0d | 666d | 0d | Verde | Verde | 0% | 0% | Verde | 0% | 0% | Verde |
| 788 | 2.3.9.12.4.7 | Recurso do projeto executivo do pleito repassado | milestone | 0d | 2021-01-14 | 2021-01-14 | 787FS+5d | 2021-01-14 | 2021-01-14 | 0d | 666d | 0d | Verde | Verde | 0% | 0% | Verde | 0% | 0% | Verde |
| 789 | 2.3.9.12.5 | Pleito COLESPJ04 concluído | milestone | 0d | 2021-01-14 | 2021-01-14 | 779, 780, 788 | 2021-01-14 | 2021-01-14 | 0d | 666d | 0d | Verde | Verde | 0% | 0% | Verde | 0% | 0% | Verde |

| ID | WBS | Task | Type | Duration | Start | Finish | Predecessors | Baseline start | Baseline finish | Baseline duration | Total slack | Free slack | Farol de Atraso | Farol Marcos | % Previsto Tempo | Índice de Desempenho Físico (IDF) | Farol IDF | % Previsto Ponderado | % Concluído Ponderado | Farol de Início |
| --- | --- | --- | --- | --- | --- | --- | --- | --- | --- | --- | --- | --- | --- | --- | --- | --- | --- | --- | --- | --- |
| 790 | 2.3.9.13 | **Pleito COLESOB11 - Complementação do SES do distrito de Boapaba** |  | 356d | 2021-01-14 | 2022-06-21 |  | 2021-01-14 | 2022-06-21 | 356d | 666d |  | Verde | Verde | 0% | 0% | Verde | 0% | 0% |  |
| 791 | 2.3.9.13.1 | **Licitação da Obra** |  | 75d | 2021-01-14 | 2021-05-06 |  | 2021-01-14 | 2021-05-06 | 75d | 666d |  | Verde | Verde | 0% | 0% | Verde | 0% | 0% |  |
| 792 | 2.3.9.13.1.1 | Licitação da obra autorizada pelo banco | milestone | 0d | 2021-01-14 | 2021-01-14 | 789 | 2021-01-14 | 2021-01-14 | 0d | 666d | 0d | Verde | Verde | 0% | 0% | Verde | 0% | 0% | Verde |
| 793 | 2.3.9.13.1.2 | Licitar Obra |  | 61d | 2021-01-15 | 2021-04-15 | 792 | 2021-01-15 | 2021-04-15 | 61d | 666d | 0d | Verde | Verde | 0% | 0% | Verde | 0% | 0% | Verde |
| 794 | 2.3.9.13.1.3 | Analisar e emitir resultado da licitação da obra |  | 14d | 2021-04-16 | 2021-05-06 | 793 | 2021-04-16 | 2021-05-06 | 14d | 666d | 0d | Verde | Verde | 0% | 0% | Verde | 0% | 0% | Verde |
| 795 | 2.3.9.13.1.4 | Licitação da obra concluída | milestone | 0d | 2021-05-06 | 2021-05-06 | 794 | 2021-05-06 | 2021-05-06 | 0d | 666d | 0d | Verde | Verde | 0% | 0% | Verde | 0% | 0% | Verde |
| 796 | 2.3.9.13.2 | Executar obra |  | 128d | 2021-06-07 | 2021-12-07 | 795FS+20d | 2021-06-07 | 2021-12-07 | 128d | 666d | 0d | Verde | Verde | 0% | 0% | Verde | 0% | 0% | Verde |
| 797 | 2.3.9.13.3 | Realizar processo de pré-operação |  | 128d | 2021-12-08 | 2022-06-13 | 796 | 2021-12-08 | 2022-06-13 | 128d | 666d | 0d | Verde | Verde | 0% | 0% | Verde | 0% | 0% | Verde |
| 798 | 2.3.9.13.4 | Recurso da obra parcelado repassado | milestone | 0d | 2022-06-21 | 2022-06-21 | 797FS+5d | 2022-06-21 | 2022-06-21 | 0d | 666d | 0d | Verde | Verde | 0% | 0% | Verde | 0% | 0% | Verde |
| 799 | 2.3.9.13.5 | Pleito COLESOB11 concluído | milestone | 0d | 2022-06-21 | 2022-06-21 | 798 | 2022-06-21 | 2022-06-21 | 0d | 666d | 53d | Verde | Verde | 0% | 0% | Verde | 0% | 0% | Verde |
| 800 | 2.3.9.14 | **Pleito COLESPJ05 - Elaboração de projeto executivo de complementação do SES do bairro Gordiana Guimarães (Ponte do Pancas)** |  | 277d | 2019-12-02 | 2021-01-14 |  | 2019-12-02 | 2021-01-14 | 277d | 656d |  | Verde | Verde | 0% | 0% | Verde | 0% | 0% |  |
| 801 | 2.3.9.14.1 | **Licitação do Projeto** |  | 61d | 2019-12-02 | 2020-03-04 |  | 2019-12-02 | 2020-03-04 | 61d | 656d |  | Verde | Verde | 0% | 0% | Verde | 0% | 0% |  |
| 802 | 2.3.9.14.1.1 | Licitar projeto |  | 42d | 2019-12-02 | 2020-02-03 | 206FS+242d | 2019-12-02 | 2020-02-03 | 42d | 656d | 0d | Verde | Verde | 0% | 0% | Verde | 0% | 0% | Verde |
| 803 | 2.3.9.14.1.2 | Documentação de licitação apresentada ao banco | milestone | 0d | 2020-02-10 | 2020-02-10 | 802FS+5d | 2020-02-10 | 2020-02-10 | 0d | 656d | 0d | Verde | Verde | 0% | 0% | Verde | 0% | 0% | Verde |
| 804 | 2.3.9.14.1.3 | Analisar e emitir resultado da licitação do projeto |  | 14d | 2020-02-11 | 2020-03-04 | 803 | 2020-02-11 | 2020-03-04 | 14d | 656d | 0d | Verde | Verde | 0% | 0% | Verde | 0% | 0% | Verde |
| 805 | 2.3.9.14.1.4 | Licitação do projeto concluída | milestone | 0d | 2020-03-04 | 2020-03-04 | 804 | 2020-03-04 | 2020-03-04 | 0d | 656d | 0d | Verde | Verde | 0% | 0% | Verde | 0% | 0% | Verde |
| 806 | 2.3.9.14.2 | **Elaboração do Projeto Básico** |  | 134d | 2020-03-05 | 2020-09-15 |  | 2020-03-05 | 2020-09-15 | 134d | 656d |  | Verde | Verde | 0% | 0% | Verde | 0% | 0% |  |
| 807 | 2.3.9.14.2.1 | Elaborar Projeto Básico |  | 62d | 2020-03-05 | 2020-06-03 | 805 | 2020-03-05 | 2020-06-03 | 62d | 656d | 0d | Verde | Verde | 0% | 0% | Verde | 0% | 0% | Verde |
| 808 | 2.3.9.14.2.2 | Projeto básico apresentado ao banco | milestone | 0d | 2020-06-03 | 2020-06-03 | 807 | 2020-06-03 | 2020-06-03 | 0d | 656d | 0d | Verde | Verde | 0% | 0% | Verde | 0% | 0% | Verde |
| 809 | 2.3.9.14.2.3 | Analisar Projeto Básico |  | 22d | 2020-06-04 | 2020-07-06 | 808 | 2020-06-04 | 2020-07-06 | 22d | 738d | 0d | Verde | Verde | 0% | 0% | Verde | 0% | 0% | Verde |
| 810 | 2.3.9.14.2.4 | Adequar/revisar projeto básico |  | 23d | 2020-07-07 | 2020-08-06 | 809 | 2020-07-07 | 2020-08-06 | 23d | 738d | 0d | Verde | Verde | 0% | 0% | Verde | 0% | 0% | Verde |
| 811 | 2.3.9.14.2.5 | Analisar projeto básico - final |  | 22d | 2020-08-07 | 2020-09-08 | 810 | 2020-08-07 | 2020-09-08 | 22d | 738d | 0d | Verde | Verde | 0% | 0% | Verde | 0% | 0% | Verde |
| 812 | 2.3.9.14.2.6 | Projeto básico concluído | milestone | 0d | 2020-09-08 | 2020-09-08 | 811 | 2020-09-08 | 2020-09-08 | 0d | 738d | 0d | Verde | Verde | 0% | 0% | Verde | 0% | 0% | Verde |
| 813 | 2.3.9.14.2.7 | Recurso do projeto básico do pleito repassado | milestone | 0d | 2020-09-15 | 2020-09-15 | 812FS+5d | 2020-09-15 | 2020-09-15 | 0d | 738d | 82d | Verde | Verde | 0% | 0% | Verde | 0% | 0% | Verde |
| 814 | 2.3.9.14.3 | Realizar Licenciamento Ambiental |  | 149d | 2020-06-04 | 2021-01-07 | 808 | 2020-06-04 | 2021-01-07 | 149d | 661d | 5d | Verde | Verde | 0% | 0% | Verde | 0% | 0% | Verde |

| ID | WBS | Task | Type | Duration | Start | Finish | Predecessors | Baseline start | Baseline finish | Baseline duration | Total slack | Free slack | Farol de Atraso | Farol Marcos | % Previsto Tempo | Índice de Desempenho Físico (IDF) | Farol IDF | % Previsto Ponderado | % Concluído Ponderado | Farol de Início |
| --- | --- | --- | --- | --- | --- | --- | --- | --- | --- | --- | --- | --- | --- | --- | --- | --- | --- | --- | --- | --- |
| 815 | 2.3.9.14.4 | **Elaboração do Projeto Executivo** |  | 154d | 2020-06-04 | 2021-01-14 |  | 2020-06-04 | 2021-01-14 | 154d | 656d |  | Verde | Verde | 0% | 0% | Verde | 0% | 0% |  |
| 816 | 2.3.9.14.4.1 | Elaborar Projeto Executivo |  | 84d | 2020-06-04 | 2020-10-01 | 808 | 2020-06-04 | 2020-10-01 | 84d | 656d | 0d | Verde | Verde | 0% | 0% | Verde | 0% | 0% | Verde |
| 817 | 2.3.9.14.4.2 | Projeto executivo apresentado ao banco | milestone | 0d | 2020-10-01 | 2020-10-01 | 816 | 2020-10-01 | 2020-10-01 | 0d | 656d | 0d | Verde | Verde | 0% | 0% | Verde | 0% | 0% | Verde |
| 818 | 2.3.9.14.4.3 | Analisar projeto executivo |  | 24d | 2020-10-02 | 2020-11-06 | 817 | 2020-10-02 | 2020-11-06 | 24d | 656d | 0d | Verde | Verde | 0% | 0% | Verde | 0% | 0% | Verde |
| 819 | 2.3.9.14.4.4 | Adequar/revisar projeto executivo |  | 18d | 2020-11-09 | 2020-12-02 | 818 | 2020-11-09 | 2020-12-02 | 18d | 656d | 0d | Verde | Verde | 0% | 0% | Verde | 0% | 0% | Verde |
| 820 | 2.3.9.14.4.5 | Analisar projeto executivo - final |  | 23d | 2020-12-03 | 2021-01-07 | 819 | 2020-12-03 | 2021-01-07 | 23d | 656d | 0d | Verde | Verde | 0% | 0% | Verde | 0% | 0% | Verde |
| 821 | 2.3.9.14.4.6 | Projeto executivo concluído | milestone | 0d | 2021-01-07 | 2021-01-07 | 820 | 2021-01-07 | 2021-01-07 | 0d | 656d | 0d | Verde | Verde | 0% | 0% | Verde | 0% | 0% | Verde |
| 822 | 2.3.9.14.4.7 | Recurso do projeto executivo do pleito repassado | milestone | 0d | 2021-01-14 | 2021-01-14 | 821FS+5d | 2021-01-14 | 2021-01-14 | 0d | 656d | 0d | Verde | Verde | 0% | 0% | Verde | 0% | 0% | Verde |
| 823 | 2.3.9.14.5 | Pleito COLESPJ05 concluído | milestone | 0d | 2021-01-14 | 2021-01-14 | 813, 814, 822 | 2021-01-14 | 2021-01-14 | 0d | 656d | 0d | Verde | Verde | 0% | 0% | Verde | 0% | 0% | Verde |
| 824 | 2.3.9.15 | **Pleito COLESOB12 - Complementação do SES do bairro Gordiano Guimarães (Ponte dos Pancas)** |  | 366d | 2021-01-14 | 2022-07-05 |  | 2021-01-14 | 2022-07-05 | 366d | 656d |  | Verde | Verde | 0% | 0% | Verde | 0% | 0% |  |
| 825 | 2.3.9.15.1 | **Licitação da Obra** |  | 75d | 2021-01-14 | 2021-05-06 |  | 2021-01-14 | 2021-05-06 | 75d | 656d |  | Verde | Verde | 0% | 0% | Verde | 0% | 0% |  |
| 826 | 2.3.9.15.1.1 | Licitação da obra autorizada pelo banco | milestone | 0d | 2021-01-14 | 2021-01-14 | 823 | 2021-01-14 | 2021-01-14 | 0d | 656d | 0d | Verde | Verde | 0% | 0% | Verde | 0% | 0% | Verde |
| 827 | 2.3.9.15.1.2 | Licitar Obra |  | 61d | 2021-01-15 | 2021-04-15 | 826 | 2021-01-15 | 2021-04-15 | 61d | 656d | 0d | Verde | Verde | 0% | 0% | Verde | 0% | 0% | Verde |
| 828 | 2.3.9.15.1.3 | Analisar e emitir resultado da licitação da obra |  | 14d | 2021-04-16 | 2021-05-06 | 827 | 2021-04-16 | 2021-05-06 | 14d | 656d | 0d | Verde | Verde | 0% | 0% | Verde | 0% | 0% | Verde |
| 829 | 2.3.9.15.1.4 | Licitação da obra concluída | milestone | 0d | 2021-05-06 | 2021-05-06 | 828 | 2021-05-06 | 2021-05-06 | 0d | 656d | 0d | Verde | Verde | 0% | 0% | Verde | 0% | 0% | Verde |
| 830 | 2.3.9.15.2 | Executar obra |  | 128d | 2021-06-21 | 2021-12-21 | 829FS+30d | 2021-06-21 | 2021-12-21 | 128d | 656d | 0d | Verde | Verde | 0% | 0% | Verde | 0% | 0% | Verde |
| 831 | 2.3.9.15.3 | Realizar processo de pré-operação |  | 128d | 2021-12-22 | 2022-06-28 | 830 | 2021-12-22 | 2022-06-28 | 128d | 656d | 0d | Verde | Verde | 0% | 0% | Verde | 0% | 0% | Verde |
| 832 | 2.3.9.15.4 | Recurso da obra parcelado repassado | milestone | 0d | 2022-07-05 | 2022-07-05 | 831FS+5d | 2022-07-05 | 2022-07-05 | 0d | 656d | 0d | Verde | Verde | 0% | 0% | Verde | 0% | 0% | Verde |
| 833 | 2.3.9.15.5 | Pleito COLESOB12 concluído | milestone | 0d | 2022-07-05 | 2022-07-05 | 832 | 2022-07-05 | 2022-07-05 | 0d | 656d | 43d | Verde | Verde | 0% | 0% | Verde | 0% | 0% | Verde |
| 834 | 2.3.9.16 | **Pleito COLESPJ06 - Elaboração de projeto executivo de complementação do SES do bairro XV de Outubro (Campestre)** |  | 277d | 2019-12-02 | 2021-01-14 |  | 2019-12-02 | 2021-01-14 | 277d | 613d |  | Verde | Verde | 0% | 0% | Verde | 0% | 0% |  |
| 835 | 2.3.9.16.1 | **Licitação do Projeto** |  | 61d | 2019-12-02 | 2020-03-04 |  | 2019-12-02 | 2020-03-04 | 61d | 613d |  | Verde | Verde | 0% | 0% | Verde | 0% | 0% |  |
| 836 | 2.3.9.16.1.1 | Licitar projeto |  | 42d | 2019-12-02 | 2020-02-03 | 175FS+242d | 2019-12-02 | 2020-02-03 | 42d | 613d | 0d | Verde | Verde | 0% | 0% | Verde | 0% | 0% | Verde |
| 837 | 2.3.9.16.1.2 | Documentação de licitação apresentada ao banco | milestone | 0d | 2020-02-10 | 2020-02-10 | 836FS+5d | 2020-02-10 | 2020-02-10 | 0d | 613d | 0d | Verde | Verde | 0% | 0% | Verde | 0% | 0% | Verde |
| 838 | 2.3.9.16.1.3 | Analisar e emitir resultado da licitação do projeto |  | 14d | 2020-02-11 | 2020-03-04 | 837 | 2020-02-11 | 2020-03-04 | 14d | 613d | 0d | Verde | Verde | 0% | 0% | Verde | 0% | 0% | Verde |
| 839 | 2.3.9.16.1.4 | Licitação do projeto concluída | milestone | 0d | 2020-03-04 | 2020-03-04 | 838 | 2020-03-04 | 2020-03-04 | 0d | 613d | 0d | Verde | Verde | 0% | 0% | Verde | 0% | 0% | Verde |

| ID | WBS | Task | Type | Duration | Start | Finish | Predecessors | Baseline start | Baseline finish | Baseline duration | Total slack | Free slack | Farol de Atraso | Farol Marcos | % Previsto Tempo | Índice de Desempenho Físico (IDF) | Farol IDF | % Previsto Ponderado | % Concluído Ponderado | Farol de Início |
| --- | --- | --- | --- | --- | --- | --- | --- | --- | --- | --- | --- | --- | --- | --- | --- | --- | --- | --- | --- | --- |
| 840 | 2.3.9.16.2 | **Elaboração do Projeto Básico** |  | 134d | 2020-03-05 | 2020-09-15 |  | 2020-03-05 | 2020-09-15 | 134d | 613d |  | Verde | Verde | 0% | 0% | Verde | 0% | 0% |  |
| 841 | 2.3.9.16.2.1 | Elaborar Projeto Básico |  | 62d | 2020-03-05 | 2020-06-03 | 839 | 2020-03-05 | 2020-06-03 | 62d | 613d | 0d | Verde | Verde | 0% | 0% | Verde | 0% | 0% | Verde |
| 842 | 2.3.9.16.2.2 | Projeto básico apresentado ao banco | milestone | 0d | 2020-06-03 | 2020-06-03 | 841 | 2020-06-03 | 2020-06-03 | 0d | 613d | 0d | Verde | Verde | 0% | 0% | Verde | 0% | 0% | Verde |
| 843 | 2.3.9.16.2.3 | Analisar Projeto Básico |  | 22d | 2020-06-04 | 2020-07-06 | 842 | 2020-06-04 | 2020-07-06 | 22d | 695d | 0d | Verde | Verde | 0% | 0% | Verde | 0% | 0% | Verde |
| 844 | 2.3.9.16.2.4 | Adequar/revisar projeto básico |  | 23d | 2020-07-07 | 2020-08-06 | 843 | 2020-07-07 | 2020-08-06 | 23d | 695d | 0d | Verde | Verde | 0% | 0% | Verde | 0% | 0% | Verde |
| 845 | 2.3.9.16.2.5 | Analisar projeto básico - final |  | 22d | 2020-08-07 | 2020-09-08 | 844 | 2020-08-07 | 2020-09-08 | 22d | 695d | 0d | Verde | Verde | 0% | 0% | Verde | 0% | 0% | Verde |
| 846 | 2.3.9.16.2.6 | Projeto básico concluído | milestone | 0d | 2020-09-08 | 2020-09-08 | 845 | 2020-09-08 | 2020-09-08 | 0d | 695d | 0d | Verde | Verde | 0% | 0% | Verde | 0% | 0% | Verde |
| 847 | 2.3.9.16.2.7 | Recurso do projeto básico do pleito repassado | milestone | 0d | 2020-09-15 | 2020-09-15 | 846FS+5d | 2020-09-15 | 2020-09-15 | 0d | 695d | 82d | Verde | Verde | 0% | 0% | Verde | 0% | 0% | Verde |
| 848 | 2.3.9.16.3 | Realizar Licenciamento Ambiental |  | 149d | 2020-06-04 | 2021-01-07 | 842 | 2020-06-04 | 2021-01-07 | 149d | 618d | 5d | Verde | Verde | 0% | 0% | Verde | 0% | 0% | Verde |
| 849 | 2.3.9.16.4 | **Elaboração do Projeto Executivo** |  | 154d | 2020-06-04 | 2021-01-14 |  | 2020-06-04 | 2021-01-14 | 154d | 613d |  | Verde | Verde | 0% | 0% | Verde | 0% | 0% |  |
| 850 | 2.3.9.16.4.1 | Elaborar Projeto Executivo |  | 84d | 2020-06-04 | 2020-10-01 | 842 | 2020-06-04 | 2020-10-01 | 84d | 613d | 0d | Verde | Verde | 0% | 0% | Verde | 0% | 0% | Verde |
| 851 | 2.3.9.16.4.2 | Projeto executivo apresentado ao banco | milestone | 0d | 2020-10-01 | 2020-10-01 | 850 | 2020-10-01 | 2020-10-01 | 0d | 613d | 0d | Verde | Verde | 0% | 0% | Verde | 0% | 0% | Verde |
| 852 | 2.3.9.16.4.3 | Analisar projeto executivo |  | 24d | 2020-10-02 | 2020-11-06 | 851 | 2020-10-02 | 2020-11-06 | 24d | 613d | 0d | Verde | Verde | 0% | 0% | Verde | 0% | 0% | Verde |
| 853 | 2.3.9.16.4.4 | Adequar/revisar projeto executivo |  | 18d | 2020-11-09 | 2020-12-02 | 852 | 2020-11-09 | 2020-12-02 | 18d | 613d | 0d | Verde | Verde | 0% | 0% | Verde | 0% | 0% | Verde |
| 854 | 2.3.9.16.4.5 | Analisar projeto executivo - final |  | 23d | 2020-12-03 | 2021-01-07 | 853 | 2020-12-03 | 2021-01-07 | 23d | 613d | 0d | Verde | Verde | 0% | 0% | Verde | 0% | 0% | Verde |
| 855 | 2.3.9.16.4.6 | Projeto executivo concluído | milestone | 0d | 2021-01-07 | 2021-01-07 | 854 | 2021-01-07 | 2021-01-07 | 0d | 613d | 0d | Verde | Verde | 0% | 0% | Verde | 0% | 0% | Verde |
| 856 | 2.3.9.16.4.7 | Recurso do projeto executivo do pleito repassado | milestone | 0d | 2021-01-14 | 2021-01-14 | 855FS+5d | 2021-01-14 | 2021-01-14 | 0d | 613d | 0d | Verde | Verde | 0% | 0% | Verde | 0% | 0% | Verde |
| 857 | 2.3.9.16.5 | Pleito COLESPJ06 concluído | milestone | 0d | 2021-01-14 | 2021-01-14 | 847, 848, 856 | 2021-01-14 | 2021-01-14 | 0d | 613d | 0d | Verde | Verde | 0% | 0% | Verde | 0% | 0% | Verde |
| 858 | 2.3.9.17 | **Pleito COLESOB13 - Complementação do SES do bairro XV de outubro (Campestre)** |  | 409d | 2021-01-14 | 2022-09-05 |  | 2021-01-14 | 2022-09-05 | 409d | 613d |  | Verde | Verde | 0% | 0% | Verde | 0% | 0% |  |
| 859 | 2.3.9.17.1 | **Licitação da Obra** |  | 75d | 2021-01-14 | 2021-05-06 |  | 2021-01-14 | 2021-05-06 | 75d | 613d |  | Verde | Verde | 0% | 0% | Verde | 0% | 0% |  |
| 860 | 2.3.9.17.1.1 | Licitação da obra autorizada pelo banco | milestone | 0d | 2021-01-14 | 2021-01-14 | 857 | 2021-01-14 | 2021-01-14 | 0d | 613d | 0d | Verde | Verde | 0% | 0% | Verde | 0% | 0% | Verde |
| 861 | 2.3.9.17.1.2 | Licitar Obra |  | 61d | 2021-01-15 | 2021-04-15 | 860 | 2021-01-15 | 2021-04-15 | 61d | 613d | 0d | Verde | Verde | 0% | 0% | Verde | 0% | 0% | Verde |
| 862 | 2.3.9.17.1.3 | Analisar e emitir resultado da licitação da obra |  | 14d | 2021-04-16 | 2021-05-06 | 861 | 2021-04-16 | 2021-05-06 | 14d | 613d | 0d | Verde | Verde | 0% | 0% | Verde | 0% | 0% | Verde |
| 863 | 2.3.9.17.1.4 | Licitação da obra concluída | milestone | 0d | 2021-05-06 | 2021-05-06 | 862 | 2021-05-06 | 2021-05-06 | 0d | 613d | 0d | Verde | Verde | 0% | 0% | Verde | 0% | 0% | Verde |
| 864 | 2.3.9.17.2 | Executar obra |  | 171d | 2021-06-21 | 2022-02-21 | 863FS+30d | 2021-06-21 | 2022-02-21 | 171d | 613d | 0d | Verde | Verde | 0% | 0% | Verde | 0% | 0% | Verde |
| 865 | 2.3.9.17.3 | Realizar processo de pré-operação |  | 128d | 2022-02-22 | 2022-08-29 | 864 | 2022-02-22 | 2022-08-29 | 128d | 613d | 0d | Verde | Verde | 0% | 0% | Verde | 0% | 0% | Verde |
| 866 | 2.3.9.17.4 | Recurso da obra parcelado repassado | milestone | 0d | 2022-09-05 | 2022-09-05 | 865FS+5d | 2022-09-05 | 2022-09-05 | 0d | 613d | 0d | Verde | Verde | 0% | 0% | Verde | 0% | 0% | Verde |
| 867 | 2.3.9.17.5 | Pleito COLESOB13 concluído | milestone | 0d | 2022-09-05 | 2022-09-05 | 866 | 2022-09-05 | 2022-09-05 | 0d | 613d | 0d | Verde | Verde | 0% | 0% | Verde | 0% | 0% | Verde |

| ID | WBS | Task | Type | Duration | Start | Finish | Predecessors | Baseline start | Baseline finish | Baseline duration | Total slack | Free slack | Farol de Atraso | Farol Marcos | % Previsto Tempo | Índice de Desempenho Físico (IDF) | Farol IDF | % Previsto Ponderado | % Concluído Ponderado | Farol de Início |
| --- | --- | --- | --- | --- | --- | --- | --- | --- | --- | --- | --- | --- | --- | --- | --- | --- | --- | --- | --- | --- |
| 868 | 2.3.9.18 | **Pleito COLESPJ07 - Elaboração do projeto executivo do SES da localidade Maria Ortiz** |  | 277d | 2019-12-02 | 2021-01-14 |  | 2019-12-02 | 2021-01-14 | 277d | 656d |  | Verde | Verde | 0% | 0% | Verde | 0% | 0% |  |
| 869 | 2.3.9.18.1 | **Licitação do Projeto** |  | 61d | 2019-12-02 | 2020-03-04 |  | 2019-12-02 | 2020-03-04 | 61d | 656d |  | Verde | Verde | 0% | 0% | Verde | 0% | 0% |  |
| 870 | 2.3.9.18.1.1 | Licitar projeto |  | 42d | 2019-12-02 | 2020-02-03 | 175FS+242d | 2019-12-02 | 2020-02-03 | 42d | 656d | 0d | Verde | Verde | 0% | 0% | Verde | 0% | 0% | Verde |
| 871 | 2.3.9.18.1.2 | Documentação de licitação apresentada ao banco | milestone | 0d | 2020-02-10 | 2020-02-10 | 870FS+5d | 2020-02-10 | 2020-02-10 | 0d | 656d | 0d | Verde | Verde | 0% | 0% | Verde | 0% | 0% | Verde |
| 872 | 2.3.9.18.1.3 | Analisar e emitir resultado da licitação do projeto |  | 14d | 2020-02-11 | 2020-03-04 | 871 | 2020-02-11 | 2020-03-04 | 14d | 656d | 0d | Verde | Verde | 0% | 0% | Verde | 0% | 0% | Verde |
| 873 | 2.3.9.18.1.4 | Licitação do projeto concluída | milestone | 0d | 2020-03-04 | 2020-03-04 | 872 | 2020-03-04 | 2020-03-04 | 0d | 656d | 0d | Verde | Verde | 0% | 0% | Verde | 0% | 0% | Verde |
| 874 | 2.3.9.18.2 | **Elaboração do Projeto Básico** |  | 134d | 2020-03-05 | 2020-09-15 |  | 2020-03-05 | 2020-09-15 | 134d | 656d |  | Verde | Verde | 0% | 0% | Verde | 0% | 0% |  |
| 875 | 2.3.9.18.2.1 | Elaborar Projeto Básico |  | 62d | 2020-03-05 | 2020-06-03 | 873 | 2020-03-05 | 2020-06-03 | 62d | 656d | 0d | Verde | Verde | 0% | 0% | Verde | 0% | 0% | Verde |
| 876 | 2.3.9.18.2.2 | Projeto básico apresentado ao banco | milestone | 0d | 2020-06-03 | 2020-06-03 | 875 | 2020-06-03 | 2020-06-03 | 0d | 656d | 0d | Verde | Verde | 0% | 0% | Verde | 0% | 0% | Verde |
| 877 | 2.3.9.18.2.3 | Analisar Projeto Básico |  | 22d | 2020-06-04 | 2020-07-06 | 876 | 2020-06-04 | 2020-07-06 | 22d | 738d | 0d | Verde | Verde | 0% | 0% | Verde | 0% | 0% | Verde |
| 878 | 2.3.9.18.2.4 | Adequar/revisar projeto básico |  | 23d | 2020-07-07 | 2020-08-06 | 877 | 2020-07-07 | 2020-08-06 | 23d | 738d | 0d | Verde | Verde | 0% | 0% | Verde | 0% | 0% | Verde |
| 879 | 2.3.9.18.2.5 | Analisar projeto básico - final |  | 22d | 2020-08-07 | 2020-09-08 | 878 | 2020-08-07 | 2020-09-08 | 22d | 738d | 0d | Verde | Verde | 0% | 0% | Verde | 0% | 0% | Verde |
| 880 | 2.3.9.18.2.6 | Projeto básico concluído | milestone | 0d | 2020-09-08 | 2020-09-08 | 879 | 2020-09-08 | 2020-09-08 | 0d | 738d | 0d | Verde | Verde | 0% | 0% | Verde | 0% | 0% | Verde |
| 881 | 2.3.9.18.2.7 | Recurso do projeto básico do pleito repassado | milestone | 0d | 2020-09-15 | 2020-09-15 | 880FS+5d | 2020-09-15 | 2020-09-15 | 0d | 738d | 82d | Verde | Verde | 0% | 0% | Verde | 0% | 0% | Verde |
| 882 | 2.3.9.18.3 | Realizar Licenciamento Ambiental |  | 149d | 2020-06-04 | 2021-01-07 | 876 | 2020-06-04 | 2021-01-07 | 149d | 661d | 5d | Verde | Verde | 0% | 0% | Verde | 0% | 0% | Verde |
| 883 | 2.3.9.18.4 | **Elaboração do Projeto Executivo** |  | 154d | 2020-06-04 | 2021-01-14 |  | 2020-06-04 | 2021-01-14 | 154d | 656d |  | Verde | Verde | 0% | 0% | Verde | 0% | 0% |  |
| 884 | 2.3.9.18.4.1 | Elaborar Projeto Executivo |  | 84d | 2020-06-04 | 2020-10-01 | 876 | 2020-06-04 | 2020-10-01 | 84d | 656d | 0d | Verde | Verde | 0% | 0% | Verde | 0% | 0% | Verde |
| 885 | 2.3.9.18.4.2 | Projeto executivo apresentado ao banco | milestone | 0d | 2020-10-01 | 2020-10-01 | 884 | 2020-10-01 | 2020-10-01 | 0d | 656d | 0d | Verde | Verde | 0% | 0% | Verde | 0% | 0% | Verde |
| 886 | 2.3.9.18.4.3 | Analisar projeto executivo |  | 24d | 2020-10-02 | 2020-11-06 | 885 | 2020-10-02 | 2020-11-06 | 24d | 656d | 0d | Verde | Verde | 0% | 0% | Verde | 0% | 0% | Verde |
| 887 | 2.3.9.18.4.4 | Adequar/revisar projeto executivo |  | 18d | 2020-11-09 | 2020-12-02 | 886 | 2020-11-09 | 2020-12-02 | 18d | 656d | 0d | Verde | Verde | 0% | 0% | Verde | 0% | 0% | Verde |
| 888 | 2.3.9.18.4.5 | Analisar projeto executivo - final |  | 23d | 2020-12-03 | 2021-01-07 | 887 | 2020-12-03 | 2021-01-07 | 23d | 656d | 0d | Verde | Verde | 0% | 0% | Verde | 0% | 0% | Verde |
| 889 | 2.3.9.18.4.6 | Projeto executivo concluído | milestone | 0d | 2021-01-07 | 2021-01-07 | 888 | 2021-01-07 | 2021-01-07 | 0d | 656d | 0d | Verde | Verde | 0% | 0% | Verde | 0% | 0% | Verde |
| 890 | 2.3.9.18.4.7 | Recurso do projeto executivo do pleito repassado | milestone | 0d | 2021-01-14 | 2021-01-14 | 889FS+5d | 2021-01-14 | 2021-01-14 | 0d | 656d | 0d | Verde | Verde | 0% | 0% | Verde | 0% | 0% | Verde |
| 891 | 2.3.9.18.5 | Pleito COLESPJ07 concluído | milestone | 0d | 2021-01-14 | 2021-01-14 | 881, 882, 890 | 2021-01-14 | 2021-01-14 | 0d | 656d | 0d | Verde | Verde | 0% | 0% | Verde | 0% | 0% | Verde |

| ID | WBS | Task | Type | Duration | Start | Finish | Predecessors | Baseline start | Baseline finish | Baseline duration | Total slack | Free slack | Farol de Atraso | Farol Marcos | % Previsto Tempo | Índice de Desempenho Físico (IDF) | Farol IDF | % Previsto Ponderado | % Concluído Ponderado | Farol de Início |
| --- | --- | --- | --- | --- | --- | --- | --- | --- | --- | --- | --- | --- | --- | --- | --- | --- | --- | --- | --- | --- |
| 892 | 2.3.9.19 | **Pleito COLESOB14 - Implantação do SES da localidade Maria Ortiz** |  | 366d | 2021-01-14 | 2022-07-05 |  | 2021-01-14 | 2022-07-05 | 366d | 656d |  | Verde | Verde | 0% | 0% | Verde | 0% | 0% |  |
| 893 | 2.3.9.19.1 | **Licitação da Obra** |  | 75d | 2021-01-14 | 2021-05-06 |  | 2021-01-14 | 2021-05-06 | 75d | 656d |  | Verde | Verde | 0% | 0% | Verde | 0% | 0% |  |
| 894 | 2.3.9.19.1.1 | Licitação da obra autorizada pelo banco | milestone | 0d | 2021-01-14 | 2021-01-14 | 891 | 2021-01-14 | 2021-01-14 | 0d | 656d | 0d | Verde | Verde | 0% | 0% | Verde | 0% | 0% | Verde |
| 895 | 2.3.9.19.1.2 | Licitar Obra |  | 61d | 2021-01-15 | 2021-04-15 | 894 | 2021-01-15 | 2021-04-15 | 61d | 656d | 0d | Verde | Verde | 0% | 0% | Verde | 0% | 0% | Verde |
| 896 | 2.3.9.19.1.3 | Analisar e emitir resultado da licitação da obra |  | 14d | 2021-04-16 | 2021-05-06 | 895 | 2021-04-16 | 2021-05-06 | 14d | 656d | 0d | Verde | Verde | 0% | 0% | Verde | 0% | 0% | Verde |
| 897 | 2.3.9.19.1.4 | Licitação da obra concluída | milestone | 0d | 2021-05-06 | 2021-05-06 | 896 | 2021-05-06 | 2021-05-06 | 0d | 656d | 0d | Verde | Verde | 0% | 0% | Verde | 0% | 0% | Verde |
| 898 | 2.3.9.19.2 | Executar obra |  | 128d | 2021-06-21 | 2021-12-21 | 897FS+30d | 2021-06-21 | 2021-12-21 | 128d | 656d | 0d | Verde | Verde | 0% | 0% | Verde | 0% | 0% | Verde |
| 899 | 2.3.9.19.3 | Realizar processo de pré-operação |  | 128d | 2021-12-22 | 2022-06-28 | 898 | 2021-12-22 | 2022-06-28 | 128d | 656d | 0d | Verde | Verde | 0% | 0% | Verde | 0% | 0% | Verde |
| 900 | 2.3.9.19.4 | Recurso da obra parcelado repassado | milestone | 0d | 2022-07-05 | 2022-07-05 | 899FS+5d | 2022-07-05 | 2022-07-05 | 0d | 656d | 0d | Verde | Verde | 0% | 0% | Verde | 0% | 0% | Verde |
| 901 | 2.3.9.19.5 | Pleito COLESOB14 concluído | milestone | 0d | 2022-07-05 | 2022-07-05 | 900 | 2022-07-05 | 2022-07-05 | 0d | 656d | 43d | Verde | Verde | 0% | 0% | Verde | 0% | 0% | Verde |
| 902 | 2.3.9.20 | **Pleito COLESPJ09 - Elaboração de projeto executivo de redes coletoras do SES das micro bacias dos bairros Santa Helena e Mário Giurizatto** |  | 277d | 2019-12-02 | 2021-01-14 |  | 2019-12-02 | 2021-01-14 | 277d | 613d |  | Verde | Verde | 0% | 0% | Verde | 0% | 0% |  |
| 903 | 2.3.9.20.1 | **Licitação do Projeto** |  | 61d | 2019-12-02 | 2020-03-04 |  | 2019-12-02 | 2020-03-04 | 61d | 613d |  | Verde | Verde | 0% | 0% | Verde | 0% | 0% |  |
| 904 | 2.3.9.20.1.1 | Licitar projeto |  | 42d | 2019-12-02 | 2020-02-03 | 175FS+242d | 2019-12-02 | 2020-02-03 | 42d | 613d | 0d | Verde | Verde | 0% | 0% | Verde | 0% | 0% | Verde |
| 905 | 2.3.9.20.1.2 | Documentação de licitação apresentada ao banco | milestone | 0d | 2020-02-10 | 2020-02-10 | 904FS+5d | 2020-02-10 | 2020-02-10 | 0d | 613d | 0d | Verde | Verde | 0% | 0% | Verde | 0% | 0% | Verde |
| 906 | 2.3.9.20.1.3 | Analisar e emitir resultado da licitação do projeto |  | 14d | 2020-02-11 | 2020-03-04 | 905 | 2020-02-11 | 2020-03-04 | 14d | 613d | 0d | Verde | Verde | 0% | 0% | Verde | 0% | 0% | Verde |
| 907 | 2.3.9.20.1.4 | Licitação do projeto concluída | milestone | 0d | 2020-03-04 | 2020-03-04 | 906 | 2020-03-04 | 2020-03-04 | 0d | 613d | 0d | Verde | Verde | 0% | 0% | Verde | 0% | 0% | Verde |
| 908 | 2.3.9.20.2 | **Elaboração do Projeto Básico** |  | 134d | 2020-03-05 | 2020-09-15 |  | 2020-03-05 | 2020-09-15 | 134d | 613d |  | Verde | Verde | 0% | 0% | Verde | 0% | 0% |  |
| 909 | 2.3.9.20.2.1 | Elaborar Projeto Básico |  | 62d | 2020-03-05 | 2020-06-03 | 907 | 2020-03-05 | 2020-06-03 | 62d | 613d | 0d | Verde | Verde | 0% | 0% | Verde | 0% | 0% | Verde |
| 910 | 2.3.9.20.2.2 | Projeto básico apresentado ao banco | milestone | 0d | 2020-06-03 | 2020-06-03 | 909 | 2020-06-03 | 2020-06-03 | 0d | 613d | 0d | Verde | Verde | 0% | 0% | Verde | 0% | 0% | Verde |
| 911 | 2.3.9.20.2.3 | Analisar Projeto Básico |  | 22d | 2020-06-04 | 2020-07-06 | 910 | 2020-06-04 | 2020-07-06 | 22d | 695d | 0d | Verde | Verde | 0% | 0% | Verde | 0% | 0% | Verde |
| 912 | 2.3.9.20.2.4 | Adequar/revisar projeto básico |  | 23d | 2020-07-07 | 2020-08-06 | 911 | 2020-07-07 | 2020-08-06 | 23d | 695d | 0d | Verde | Verde | 0% | 0% | Verde | 0% | 0% | Verde |
| 913 | 2.3.9.20.2.5 | Analisar projeto básico - final |  | 22d | 2020-08-07 | 2020-09-08 | 912 | 2020-08-07 | 2020-09-08 | 22d | 695d | 0d | Verde | Verde | 0% | 0% | Verde | 0% | 0% | Verde |
| 914 | 2.3.9.20.2.6 | Projeto básico concluído | milestone | 0d | 2020-09-08 | 2020-09-08 | 913 | 2020-09-08 | 2020-09-08 | 0d | 695d | 0d | Verde | Verde | 0% | 0% | Verde | 0% | 0% | Verde |
| 915 | 2.3.9.20.2.7 | Recurso do projeto básico do pleito repassado | milestone | 0d | 2020-09-15 | 2020-09-15 | 914FS+5d | 2020-09-15 | 2020-09-15 | 0d | 695d | 82d | Verde | Verde | 0% | 0% | Verde | 0% | 0% | Verde |
| 916 | 2.3.9.20.3 | Realizar Licenciamento Ambiental |  | 149d | 2020-06-04 | 2021-01-07 | 910 | 2020-06-04 | 2021-01-07 | 149d | 618d | 5d | Verde | Verde | 0% | 0% | Verde | 0% | 0% | Verde |

| ID | WBS | Task | Type | Duration | Start | Finish | Predecessors | Baseline start | Baseline finish | Baseline duration | Total slack | Free slack | Farol de Atraso | Farol Marcos | % Previsto Tempo | Índice de Desempenho Físico (IDF) | Farol IDF | % Previsto Ponderado | % Concluído Ponderado | Farol de Início |
| --- | --- | --- | --- | --- | --- | --- | --- | --- | --- | --- | --- | --- | --- | --- | --- | --- | --- | --- | --- | --- |
| 917 | 2.3.9.20.4 | **Elaboração do Projeto Executivo** |  | 154d | 2020-06-04 | 2021-01-14 |  | 2020-06-04 | 2021-01-14 | 154d | 613d |  | Verde | Verde | 0% | 0% | Verde | 0% | 0% |  |
| 918 | 2.3.9.20.4.1 | Elaborar Projeto Executivo |  | 84d | 2020-06-04 | 2020-10-01 | 910 | 2020-06-04 | 2020-10-01 | 84d | 613d | 0d | Verde | Verde | 0% | 0% | Verde | 0% | 0% | Verde |
| 919 | 2.3.9.20.4.2 | Projeto executivo apresentado ao banco | milestone | 0d | 2020-10-01 | 2020-10-01 | 918 | 2020-10-01 | 2020-10-01 | 0d | 613d | 0d | Verde | Verde | 0% | 0% | Verde | 0% | 0% | Verde |
| 920 | 2.3.9.20.4.3 | Analisar projeto executivo |  | 24d | 2020-10-02 | 2020-11-06 | 919 | 2020-10-02 | 2020-11-06 | 24d | 613d | 0d | Verde | Verde | 0% | 0% | Verde | 0% | 0% | Verde |
| 921 | 2.3.9.20.4.4 | Adequar/revisar projeto executivo |  | 18d | 2020-11-09 | 2020-12-02 | 920 | 2020-11-09 | 2020-12-02 | 18d | 613d | 0d | Verde | Verde | 0% | 0% | Verde | 0% | 0% | Verde |
| 922 | 2.3.9.20.4.5 | Analisar projeto executivo - final |  | 23d | 2020-12-03 | 2021-01-07 | 921 | 2020-12-03 | 2021-01-07 | 23d | 613d | 0d | Verde | Verde | 0% | 0% | Verde | 0% | 0% | Verde |
| 923 | 2.3.9.20.4.6 | Projeto executivo concluído | milestone | 0d | 2021-01-07 | 2021-01-07 | 922 | 2021-01-07 | 2021-01-07 | 0d | 613d | 0d | Verde | Verde | 0% | 0% | Verde | 0% | 0% | Verde |
| 924 | 2.3.9.20.4.7 | Recurso do projeto executivo do pleito repassado | milestone | 0d | 2021-01-14 | 2021-01-14 | 923FS+5d | 2021-01-14 | 2021-01-14 | 0d | 613d | 0d | Verde | Verde | 0% | 0% | Verde | 0% | 0% | Verde |
| 925 | 2.3.9.20.5 | Pleito COLESPJ09 concluído | milestone | 0d | 2021-01-14 | 2021-01-14 | 915, 916, 924 | 2021-01-14 | 2021-01-14 | 0d | 613d | 0d | Verde | Verde | 0% | 0% | Verde | 0% | 0% | Verde |
| 926 | 2.3.9.21 | **Pleito COLESOB15 - Implantação de redes coletoras nos bairros Santa Helena e Mário Giurizatto** |  | 409d | 2021-01-14 | 2022-09-05 |  | 2021-01-14 | 2022-09-05 | 409d | 613d |  | Verde | Verde | 0% | 0% | Verde | 0% | 0% |  |
| 927 | 2.3.9.21.1 | **Licitação da Obra** |  | 75d | 2021-01-14 | 2021-05-06 |  | 2021-01-14 | 2021-05-06 | 75d | 613d |  | Verde | Verde | 0% | 0% | Verde | 0% | 0% |  |
| 928 | 2.3.9.21.1.1 | Licitação da obra autorizada pelo banco | milestone | 0d | 2021-01-14 | 2021-01-14 | 925 | 2021-01-14 | 2021-01-14 | 0d | 613d | 0d | Verde | Verde | 0% | 0% | Verde | 0% | 0% | Verde |
| 929 | 2.3.9.21.1.2 | Licitar Obra |  | 61d | 2021-01-15 | 2021-04-15 | 928 | 2021-01-15 | 2021-04-15 | 61d | 613d | 0d | Verde | Verde | 0% | 0% | Verde | 0% | 0% | Verde |
| 930 | 2.3.9.21.1.3 | Analisar e emitir resultado da licitação da obra |  | 14d | 2021-04-16 | 2021-05-06 | 929 | 2021-04-16 | 2021-05-06 | 14d | 613d | 0d | Verde | Verde | 0% | 0% | Verde | 0% | 0% | Verde |
| 931 | 2.3.9.21.1.4 | Licitação da obra concluída | milestone | 0d | 2021-05-06 | 2021-05-06 | 930 | 2021-05-06 | 2021-05-06 | 0d | 613d | 0d | Verde | Verde | 0% | 0% | Verde | 0% | 0% | Verde |
| 932 | 2.3.9.21.2 | Executar obra |  | 171d | 2021-06-21 | 2022-02-21 | 931FS+30d | 2021-06-21 | 2022-02-21 | 171d | 613d | 0d | Verde | Verde | 0% | 0% | Verde | 0% | 0% | Verde |
| 933 | 2.3.9.21.3 | Realizar processo de pré-operação |  | 128d | 2022-02-22 | 2022-08-29 | 932 | 2022-02-22 | 2022-08-29 | 128d | 613d | 0d | Verde | Verde | 0% | 0% | Verde | 0% | 0% | Verde |
| 934 | 2.3.9.21.4 | Recurso da obra parcelado repassado | milestone | 0d | 2022-09-05 | 2022-09-05 | 933FS+5d | 2022-09-05 | 2022-09-05 | 0d | 613d | 0d | Verde | Verde | 0% | 0% | Verde | 0% | 0% | Verde |
| 935 | 2.3.9.21.5 | Pleito COLESOB15 concluído | milestone | 0d | 2022-09-05 | 2022-09-05 | 934 | 2022-09-05 | 2022-09-05 | 0d | 613d | 0d | Verde | Verde | 0% | 0% | Verde | 0% | 0% | Verde |
| 936 | 2.3.9.22 | **Pleito COLESOB04 - Contratação de assessoria técnica para supervisão geral da implantação de todos os componentes do SES da sede municipal** |  | 812d | 2019-06-03 | 2022-09-05 |  | 2019-06-03 | 2022-09-05 | 812d | 613d |  | Verde | Verde | 0% | 0% | Verde | 0% | 0% |  |
| 937 | 2.3.9.22.1 | **Licitação da Empresa Gerenciadora** |  | 76d | 2019-06-03 | 2019-09-19 |  | 2019-06-03 | 2019-09-19 | 76d | 613d |  | Verde | Verde | 0% | 0% | Verde | 0% | 0% |  |
| 938 | 2.3.9.22.1.1 | Licitação da gerenciadora autorizada pelo banco | milestone | 0d | 2019-06-03 | 2019-06-03 | 175FS+116d | 2019-06-03 | 2019-06-03 | 0d | 613d | 0d | Verde | Verde | 0% | 0% | Verde | 0% | 0% | Verde |
| 939 | 2.3.9.22.1.2 | Licitar gerenciadora |  | 66d | 2019-06-04 | 2019-09-05 | 938 | 2019-06-04 | 2019-09-05 | 66d | 613d | 0d | Verde | Verde | 0% | 0% | Verde | 0% | 0% | Verde |
| 940 | 2.3.9.22.1.3 | Analisar e emitir resultado da licitação da gerenciadora |  | 10d | 2019-09-06 | 2019-09-19 | 939 | 2019-09-06 | 2019-09-19 | 10d | 613d | 0d | Verde | Verde | 0% | 0% | Verde | 0% | 0% | Verde |
| 941 | 2.3.9.22.1.4 | Licitação da gerenciadora concluída | milestone | 0d | 2019-09-19 | 2019-09-19 | 940 | 2019-09-19 | 2019-09-19 | 0d | 613d | 0d | Verde | Verde | 0% | 0% | Verde | 0% | 0% | Verde |
| 942 | 2.3.9.22.2 | Acompanhar obras |  | 736d | 2019-09-20 | 2022-09-05 | 941 | 2019-09-20 | 2022-09-05 | 736d | 613d | 0d | Verde | Verde | 0% | 0% | Verde | 0% | 0% | Verde |
| 943 | 2.3.9.22.3 | Pleito COLESOB04 concluído | milestone | 0d | 2022-09-05 | 2022-09-05 | 942 | 2022-09-05 | 2022-09-05 | 0d | 613d | 0d | Verde | Verde | 0% | 0% | Verde | 0% | 0% | Verde |

| ID | WBS | Task | Type | Duration | Start | Finish | Predecessors | Baseline start | Baseline finish | Baseline duration | Total slack | Free slack | Constraint | Farol de Atraso | Farol Marcos | % Previsto Tempo | Índice de Desempenho Físico (IDF) | Farol IDF | % Previsto Ponderado | % Concluído Ponderado | Farol de Início |
| --- | --- | --- | --- | --- | --- | --- | --- | --- | --- | --- | --- | --- | --- | --- | --- | --- | --- | --- | --- | --- | --- |
| 944 | 2.3.9.23 | **Pleito COLESOB05 - Outras ações complementares - execução de ligações domiciliares de esgoto às redes coletoras existentes, e execução de interligações das redes coletoras existentes às redes novas e interceptores** |  | 267d | 2021-08-11 | 2022-09-05 |  | 2021-08-11 | 2022-09-05 | 267d | 0d |  |  | Verde | Verde | 0% | 0% | Verde | 0% | 0% |  |
| 945 | 2.3.9.23.1 | **Licitação da Obra** |  | 80d | 2021-08-11 | 2021-12-06 |  | 2021-08-11 | 2021-12-06 | 80d | 0d |  |  | Verde | Verde | 0% | 0% | Verde | 0% | 0% |  |
| 946 | 2.3.9.23.1.1 | Licitação da obra autorizada pelo banco | milestone | 0d | 2021-08-11 | 2021-08-11 |  | 2021-08-11 | 2021-08-11 | 0d | 0d |  | must start on 2021-08-11 | Verde | Verde | 0% | 0% | Verde | 0% | 0% | Verde |
| 947 | 2.3.9.23.1.2 | Licitar Obra |  | 66d | 2021-08-11 | 2021-11-16 | 946 | 2021-08-11 | 2021-11-16 | 66d | 613d | 0d |  | Verde | Verde | 0% | 0% | Verde | 0% | 0% | Verde |
| 948 | 2.3.9.23.1.3 | Analisar e emitir resultado da licitação da obra |  | 14d | 2021-11-17 | 2021-12-06 | 947 | 2021-11-17 | 2021-12-06 | 14d | 613d | 0d |  | Verde | Verde | 0% | 0% | Verde | 0% | 0% | Verde |
| 949 | 2.3.9.23.1.4 | Licitação da obra concluída | milestone | 0d | 2021-12-06 | 2021-12-06 | 948 | 2021-12-06 | 2021-12-06 | 0d | 613d | 0d |  | Verde | Verde | 0% | 0% | Verde | 0% | 0% | Verde |
| 950 | 2.3.9.23.2 | Executar obras |  | 187d | 2021-12-07 | 2022-09-05 | 949 | 2021-12-07 | 2022-09-05 | 187d | 613d | 0d |  | Verde | Verde | 0% | 0% | Verde | 0% | 0% | Verde |
| 951 | 2.3.9.23.3 | Pleito COLESOB05 concluído | milestone | 0d | 2022-09-05 | 2022-09-05 | 950 | 2022-09-05 | 2022-09-05 | 0d | 613d | 0d |  | Verde | Verde | 0% | 0% | Verde | 0% | 0% | Verde |
| 952 | 2.3.9.24 | **Pleito COLESPJ08 - Elaboração de projeto executivo de redes interceptoras de sistemas de esgotamento sanitário das micro bacias da sede municipal (Centro – Lado Sul e São Silvano – Lado Norte) que despejam esgoto “in natura” nos córregos municipais** |  | 277d | 2019-12-02 | 2021-01-14 |  | 2019-12-02 | 2021-01-14 | 277d | 623d |  |  | Verde | Verde | 0% | 0% | Verde | 0% | 0% |  |
| 953 | 2.3.9.24.1 | **Licitação do Projeto** |  | 61d | 2019-12-02 | 2020-03-04 |  | 2019-12-02 | 2020-03-04 | 61d | 623d |  |  | Verde | Verde | 0% | 0% | Verde | 0% | 0% |  |
| 954 | 2.3.9.24.1.1 | Licitar projeto |  | 42d | 2019-12-02 | 2020-02-03 | 175FS+242d | 2019-12-02 | 2020-02-03 | 42d | 623d | 0d |  | Verde | Verde | 0% | 0% | Verde | 0% | 0% | Verde |
| 955 | 2.3.9.24.1.2 | Documentação de licitação apresentada ao banco | milestone | 0d | 2020-02-10 | 2020-02-10 | 954FS+5d | 2020-02-10 | 2020-02-10 | 0d | 623d | 0d |  | Verde | Verde | 0% | 0% | Verde | 0% | 0% | Verde |
| 956 | 2.3.9.24.1.3 | Analisar e emitir resultado da licitação do projeto |  | 14d | 2020-02-11 | 2020-03-04 | 955 | 2020-02-11 | 2020-03-04 | 14d | 623d | 0d |  | Verde | Verde | 0% | 0% | Verde | 0% | 0% | Verde |
| 957 | 2.3.9.24.1.4 | Licitação do projeto concluída | milestone | 0d | 2020-03-04 | 2020-03-04 | 956 | 2020-03-04 | 2020-03-04 | 0d | 623d | 0d |  | Verde | Verde | 0% | 0% | Verde | 0% | 0% | Verde |
| 958 | 2.3.9.24.2 | **Elaboração do Projeto Básico** |  | 134d | 2020-03-05 | 2020-09-15 |  | 2020-03-05 | 2020-09-15 | 134d | 623d |  |  | Verde | Verde | 0% | 0% | Verde | 0% | 0% |  |
| 959 | 2.3.9.24.2.1 | Elaborar Projeto Básico |  | 62d | 2020-03-05 | 2020-06-03 | 957 | 2020-03-05 | 2020-06-03 | 62d | 623d | 0d |  | Verde | Verde | 0% | 0% | Verde | 0% | 0% | Verde |
| 960 | 2.3.9.24.2.2 | Projeto básico apresentado ao banco | milestone | 0d | 2020-06-03 | 2020-06-03 | 959 | 2020-06-03 | 2020-06-03 | 0d | 623d | 0d |  | Verde | Verde | 0% | 0% | Verde | 0% | 0% | Verde |
| 961 | 2.3.9.24.2.3 | Analisar Projeto Básico |  | 22d | 2020-06-04 | 2020-07-06 | 960 | 2020-06-04 | 2020-07-06 | 22d | 705d | 0d |  | Verde | Verde | 0% | 0% | Verde | 0% | 0% | Verde |
| 962 | 2.3.9.24.2.4 | Adequar/revisar projeto básico |  | 23d | 2020-07-07 | 2020-08-06 | 961 | 2020-07-07 | 2020-08-06 | 23d | 705d | 0d |  | Verde | Verde | 0% | 0% | Verde | 0% | 0% | Verde |
| 963 | 2.3.9.24.2.5 | Analisar projeto básico - final |  | 22d | 2020-08-07 | 2020-09-08 | 962 | 2020-08-07 | 2020-09-08 | 22d | 705d | 0d |  | Verde | Verde | 0% | 0% | Verde | 0% | 0% | Verde |
| 964 | 2.3.9.24.2.6 | Projeto básico concluído | milestone | 0d | 2020-09-08 | 2020-09-08 | 963 | 2020-09-08 | 2020-09-08 | 0d | 705d | 0d |  | Verde | Verde | 0% | 0% | Verde | 0% | 0% | Verde |
| 965 | 2.3.9.24.2.7 | Recurso do projeto básico do pleito repassado | milestone | 0d | 2020-09-15 | 2020-09-15 | 964FS+5d | 2020-09-15 | 2020-09-15 | 0d | 705d | 82d |  | Verde | Verde | 0% | 0% | Verde | 0% | 0% | Verde |
| 966 | 2.3.9.24.3 | Realizar Licenciamento Ambiental |  | 149d | 2020-06-04 | 2021-01-07 | 960 | 2020-06-04 | 2021-01-07 | 149d | 628d | 5d |  | Verde | Verde | 0% | 0% | Verde | 0% | 0% | Verde |
| 967 | 2.3.9.24.4 | **Elaboração do Projeto Executivo** |  | 154d | 2020-06-04 | 2021-01-14 |  | 2020-06-04 | 2021-01-14 | 154d | 623d |  |  | Verde | Verde | 0% | 0% | Verde | 0% | 0% |  |
| 968 | 2.3.9.24.4.1 | Elaborar Projeto Executivo |  | 84d | 2020-06-04 | 2020-10-01 | 960 | 2020-06-04 | 2020-10-01 | 84d | 623d | 0d |  | Verde | Verde | 0% | 0% | Verde | 0% | 0% | Verde |
| 969 | 2.3.9.24.4.2 | Projeto executivo apresentado ao banco | milestone | 0d | 2020-10-01 | 2020-10-01 | 968 | 2020-10-01 | 2020-10-01 | 0d | 623d | 0d |  | Verde | Verde | 0% | 0% | Verde | 0% | 0% | Verde |
| 970 | 2.3.9.24.4.3 | Analisar projeto executivo |  | 24d | 2020-10-02 | 2020-11-06 | 969 | 2020-10-02 | 2020-11-06 | 24d | 623d | 0d |  | Verde | Verde | 0% | 0% | Verde | 0% | 0% | Verde |
| 971 | 2.3.9.24.4.4 | Adequar/revisar projeto executivo |  | 18d | 2020-11-09 | 2020-12-02 | 970 | 2020-11-09 | 2020-12-02 | 18d | 623d | 0d |  | Verde | Verde | 0% | 0% | Verde | 0% | 0% | Verde |
| 972 | 2.3.9.24.4.5 | Analisar projeto executivo - final |  | 23d | 2020-12-03 | 2021-01-07 | 971 | 2020-12-03 | 2021-01-07 | 23d | 623d | 0d |  | Verde | Verde | 0% | 0% | Verde | 0% | 0% | Verde |
| 973 | 2.3.9.24.4.6 | Projeto executivo concluído | milestone | 0d | 2021-01-07 | 2021-01-07 | 972 | 2021-01-07 | 2021-01-07 | 0d | 623d | 0d |  | Verde | Verde | 0% | 0% | Verde | 0% | 0% | Verde |
| 974 | 2.3.9.24.4.7 | Recurso do projeto executivo do pleito repassado | milestone | 0d | 2021-01-14 | 2021-01-14 | 973FS+5d | 2021-01-14 | 2021-01-14 | 0d | 623d | 0d |  | Verde | Verde | 0% | 0% | Verde | 0% | 0% | Verde |
| 975 | 2.3.9.24.5 | Pleito COLESPJ08 concluído | milestone | 0d | 2021-01-14 | 2021-01-14 | 965, 966, 974 | 2021-01-14 | 2021-01-14 | 0d | 623d | 0d |  | Verde | Verde | 0% | 0% | Verde | 0% | 0% | Verde |

Notes:
- 952: Nome do pleito completo: Elaboração de projeto executivo de redes interceptoras de sistemas de esgotamento sanitário das micro bacias da sede municipal (Centro Lado Sul e São Silvano Lado Norte) que despejam esgoto in natura nos córregos municipais. Projetos de rede coletora/interceptores nas micro bacias dos bairros Santa Terezinha, Maria Ismênia, Operário, São Vicente, Colatina Velha, Santa Mônica, Vila Verdi e São Miguel

| ID | WBS | Task | Type | Duration | Start | Finish | Predecessors | Baseline start | Baseline finish | Baseline duration | Total slack | Free slack | Farol de Atraso | Farol Marcos | % Previsto Tempo | Índice de Desempenho Físico (IDF) | Farol IDF | % Previsto Ponderado | % Concluído Ponderado | Farol de Início |
| --- | --- | --- | --- | --- | --- | --- | --- | --- | --- | --- | --- | --- | --- | --- | --- | --- | --- | --- | --- | --- |
| 976 | 2.3.9.25 | **Pleito COLESOB16 - Implantação de rede interceptora de esgoto sanitário na micro bacia do bairro Santa Terezinha** |  | 399d | 2021-01-14 | 2022-08-22 |  | 2021-01-14 | 2022-08-22 | 399d | 623d |  | Verde | Verde | 0% | 0% | Verde | 0% | 0% |  |
| 977 | 2.3.9.25.1 | **Licitação da Obra** |  | 75d | 2021-01-14 | 2021-05-06 |  | 2021-01-14 | 2021-05-06 | 75d | 623d |  | Verde | Verde | 0% | 0% | Verde | 0% | 0% |  |
| 978 | 2.3.9.25.1.1 | Licitação da obra autorizada pelo banco | milestone | 0d | 2021-01-14 | 2021-01-14 | 975 | 2021-01-14 | 2021-01-14 | 0d | 623d | 0d | Verde | Verde | 0% | 0% | Verde | 0% | 0% | Verde |
| 979 | 2.3.9.25.1.2 | Licitar Obra |  | 61d | 2021-01-15 | 2021-04-15 | 978 | 2021-01-15 | 2021-04-15 | 61d | 623d | 0d | Verde | Verde | 0% | 0% | Verde | 0% | 0% | Verde |
| 980 | 2.3.9.25.1.3 | Analisar e emitir resultado da licitação da obra |  | 14d | 2021-04-16 | 2021-05-06 | 979 | 2021-04-16 | 2021-05-06 | 14d | 623d | 0d | Verde | Verde | 0% | 0% | Verde | 0% | 0% | Verde |
| 981 | 2.3.9.25.1.4 | Licitação da obra concluída | milestone | 0d | 2021-05-06 | 2021-05-06 | 980 | 2021-05-06 | 2021-05-06 | 0d | 623d | 0d | Verde | Verde | 0% | 0% | Verde | 0% | 0% | Verde |
| 982 | 2.3.9.25.2 | Executar obra |  | 171d | 2021-06-07 | 2022-02-07 | 981FS+20d | 2021-06-07 | 2022-02-07 | 171d | 623d | 0d | Verde | Verde | 0% | 0% | Verde | 0% | 0% | Verde |
| 983 | 2.3.9.25.3 | Realizar processo de pré-operação |  | 128d | 2022-02-08 | 2022-08-12 | 982 | 2022-02-08 | 2022-08-12 | 128d | 623d | 0d | Verde | Verde | 0% | 0% | Verde | 0% | 0% | Verde |
| 984 | 2.3.9.25.4 | Recurso da obra parcelado repassado | milestone | 0d | 2022-08-22 | 2022-08-22 | 983FS+5d | 2022-08-22 | 2022-08-22 | 0d | 623d | 0d | Verde | Verde | 0% | 0% | Verde | 0% | 0% | Verde |
| 985 | 2.3.9.25.5 | Pleito COLESOB16 concluído | milestone | 0d | 2022-08-22 | 2022-08-22 | 984 | 2022-08-22 | 2022-08-22 | 0d | 623d | 10d | Verde | Verde | 0% | 0% | Verde | 0% | 0% | Verde |
| 986 | 2.3.9.26 | **Pleito COLESOB17 - Implantação de rede interceptora de esgoto sanitário na micro bacia do bairro Maria Ismênia** |  | 356d | 2021-01-14 | 2022-06-21 |  | 2021-01-14 | 2022-06-21 | 356d | 666d |  | Verde | Verde | 0% | 0% | Verde | 0% | 0% |  |
| 987 | 2.3.9.26.1 | **Licitação da Obra** |  | 75d | 2021-01-14 | 2021-05-06 |  | 2021-01-14 | 2021-05-06 | 75d | 666d |  | Verde | Verde | 0% | 0% | Verde | 0% | 0% |  |
| 988 | 2.3.9.26.1.1 | Licitação da obra autorizada pelo banco | milestone | 0d | 2021-01-14 | 2021-01-14 | 975 | 2021-01-14 | 2021-01-14 | 0d | 666d | 0d | Verde | Verde | 0% | 0% | Verde | 0% | 0% | Verde |
| 989 | 2.3.9.26.1.2 | Licitar Obra |  | 61d | 2021-01-15 | 2021-04-15 | 988 | 2021-01-15 | 2021-04-15 | 61d | 666d | 0d | Verde | Verde | 0% | 0% | Verde | 0% | 0% | Verde |
| 990 | 2.3.9.26.1.3 | Analisar e emitir resultado da licitação da obra |  | 14d | 2021-04-16 | 2021-05-06 | 989 | 2021-04-16 | 2021-05-06 | 14d | 666d | 0d | Verde | Verde | 0% | 0% | Verde | 0% | 0% | Verde |
| 991 | 2.3.9.26.1.4 | Licitação da obra concluída | milestone | 0d | 2021-05-06 | 2021-05-06 | 990 | 2021-05-06 | 2021-05-06 | 0d | 666d | 0d | Verde | Verde | 0% | 0% | Verde | 0% | 0% | Verde |
| 992 | 2.3.9.26.2 | Executar obra |  | 128d | 2021-06-07 | 2021-12-07 | 991FS+20d | 2021-06-07 | 2021-12-07 | 128d | 666d | 0d | Verde | Verde | 0% | 0% | Verde | 0% | 0% | Verde |
| 993 | 2.3.9.26.3 | Realizar processo de pré-operação |  | 128d | 2021-12-08 | 2022-06-13 | 992 | 2021-12-08 | 2022-06-13 | 128d | 666d | 0d | Verde | Verde | 0% | 0% | Verde | 0% | 0% | Verde |
| 994 | 2.3.9.26.4 | Recurso da obra parcelado repassado | milestone | 0d | 2022-06-21 | 2022-06-21 | 993FS+5d | 2022-06-21 | 2022-06-21 | 0d | 666d | 0d | Verde | Verde | 0% | 0% | Verde | 0% | 0% | Verde |
| 995 | 2.3.9.26.5 | Pleito COLESOB17 concluído | milestone | 0d | 2022-06-21 | 2022-06-21 | 994 | 2022-06-21 | 2022-06-21 | 0d | 666d | 53d | Verde | Verde | 0% | 0% | Verde | 0% | 0% | Verde |
| 996 | 2.3.9.27 | **Pleito COLESOB18 - Implantação de rede interceptora de esgoto sanitário na micro bacia do bairro Operário** |  | 399d | 2021-01-14 | 2022-08-22 |  | 2021-01-14 | 2022-08-22 | 399d | 623d |  | Verde | Verde | 0% | 0% | Verde | 0% | 0% |  |
| 997 | 2.3.9.27.1 | **Licitação da Obra** |  | 75d | 2021-01-14 | 2021-05-06 |  | 2021-01-14 | 2021-05-06 | 75d | 623d |  | Verde | Verde | 0% | 0% | Verde | 0% | 0% |  |
| 998 | 2.3.9.27.1.1 | Licitação da obra autorizada pelo banco | milestone | 0d | 2021-01-14 | 2021-01-14 | 975 | 2021-01-14 | 2021-01-14 | 0d | 623d | 0d | Verde | Verde | 0% | 0% | Verde | 0% | 0% | Verde |
| 999 | 2.3.9.27.1.2 | Licitar Obra |  | 61d | 2021-01-15 | 2021-04-15 | 998 | 2021-01-15 | 2021-04-15 | 61d | 623d | 0d | Verde | Verde | 0% | 0% | Verde | 0% | 0% | Verde |
| 1000 | 2.3.9.27.1.3 | Analisar e emitir resultado da licitação da obra |  | 14d | 2021-04-16 | 2021-05-06 | 999 | 2021-04-16 | 2021-05-06 | 14d | 623d | 0d | Verde | Verde | 0% | 0% | Verde | 0% | 0% | Verde |
| 1001 | 2.3.9.27.1.4 | Licitação da obra concluída | milestone | 0d | 2021-05-06 | 2021-05-06 | 1000 | 2021-05-06 | 2021-05-06 | 0d | 623d | 0d | Verde | Verde | 0% | 0% | Verde | 0% | 0% | Verde |
| 1002 | 2.3.9.27.2 | Executar obra |  | 171d | 2021-06-07 | 2022-02-07 | 1001FS+20d | 2021-06-07 | 2022-02-07 | 171d | 623d | 0d | Verde | Verde | 0% | 0% | Verde | 0% | 0% | Verde |
| 1003 | 2.3.9.27.3 | Realizar processo de pré-operação |  | 128d | 2022-02-08 | 2022-08-12 | 1002 | 2022-02-08 | 2022-08-12 | 128d | 623d | 0d | Verde | Verde | 0% | 0% | Verde | 0% | 0% | Verde |
| 1004 | 2.3.9.27.4 | Recurso da obra parcelado repassado | milestone | 0d | 2022-08-22 | 2022-08-22 | 1003FS+5d | 2022-08-22 | 2022-08-22 | 0d | 623d | 0d | Verde | Verde | 0% | 0% | Verde | 0% | 0% | Verde |
| 1005 | 2.3.9.27.5 | Pleito COLESOB18 concluído | milestone | 0d | 2022-08-22 | 2022-08-22 | 1004 | 2022-08-22 | 2022-08-22 | 0d | 623d | 10d | Verde | Verde | 0% | 0% | Verde | 0% | 0% | Verde |

| ID | WBS | Task | Type | Duration | Start | Finish | Predecessors | Baseline start | Baseline finish | Baseline duration | Total slack | Free slack | Farol de Atraso | Farol Marcos | % Previsto Tempo | Índice de Desempenho Físico (IDF) | Farol IDF | % Previsto Ponderado | % Concluído Ponderado | Farol de Início |
| --- | --- | --- | --- | --- | --- | --- | --- | --- | --- | --- | --- | --- | --- | --- | --- | --- | --- | --- | --- | --- |
| 1006 | 2.3.9.28 | **Pleito COLESOB19 - Implantação de rede interceptora de esgoto sanitário na micro bacia do bairro São Vicente** |  | 356d | 2021-01-14 | 2022-06-21 |  | 2021-01-14 | 2022-06-21 | 356d | 666d |  | Verde | Verde | 0% | 0% | Verde | 0% | 0% |  |
| 1007 | 2.3.9.28.1 | **Licitação da Obra** |  | 75d | 2021-01-14 | 2021-05-06 |  | 2021-01-14 | 2021-05-06 | 75d | 666d |  | Verde | Verde | 0% | 0% | Verde | 0% | 0% |  |
| 1008 | 2.3.9.28.1.1 | Licitação da obra autorizada pelo banco | milestone | 0d | 2021-01-14 | 2021-01-14 | 975 | 2021-01-14 | 2021-01-14 | 0d | 666d | 0d | Verde | Verde | 0% | 0% | Verde | 0% | 0% | Verde |
| 1009 | 2.3.9.28.1.2 | Licitar Obra |  | 61d | 2021-01-15 | 2021-04-15 | 1008 | 2021-01-15 | 2021-04-15 | 61d | 666d | 0d | Verde | Verde | 0% | 0% | Verde | 0% | 0% | Verde |
| 1010 | 2.3.9.28.1.3 | Analisar e emitir resultado da licitação da obra |  | 14d | 2021-04-16 | 2021-05-06 | 1009 | 2021-04-16 | 2021-05-06 | 14d | 666d | 0d | Verde | Verde | 0% | 0% | Verde | 0% | 0% | Verde |
| 1011 | 2.3.9.28.1.4 | Licitação da obra concluída | milestone | 0d | 2021-05-06 | 2021-05-06 | 1010 | 2021-05-06 | 2021-05-06 | 0d | 666d | 0d | Verde | Verde | 0% | 0% | Verde | 0% | 0% | Verde |
| 1012 | 2.3.9.28.2 | Executar obra |  | 128d | 2021-06-07 | 2021-12-07 | 1011FS+20d | 2021-06-07 | 2021-12-07 | 128d | 666d | 0d | Verde | Verde | 0% | 0% | Verde | 0% | 0% | Verde |
| 1013 | 2.3.9.28.3 | Realizar processo de pré-operação |  | 128d | 2021-12-08 | 2022-06-13 | 1012 | 2021-12-08 | 2022-06-13 | 128d | 666d | 0d | Verde | Verde | 0% | 0% | Verde | 0% | 0% | Verde |
| 1014 | 2.3.9.28.4 | Recurso da obra parcelado repassado | milestone | 0d | 2022-06-21 | 2022-06-21 | 1013FS+5d | 2022-06-21 | 2022-06-21 | 0d | 666d | 0d | Verde | Verde | 0% | 0% | Verde | 0% | 0% | Verde |
| 1015 | 2.3.9.28.5 | Pleito COLESOB19 concluído | milestone | 0d | 2022-06-21 | 2022-06-21 | 1014 | 2022-06-21 | 2022-06-21 | 0d | 666d | 53d | Verde | Verde | 0% | 0% | Verde | 0% | 0% | Verde |
| 1016 | 2.3.9.29 | **Pleito COLESOB20 - Implantação de rede interceptora de esgoto sanitário na micro bacia do bairro Colatina Velha** |  | 356d | 2021-01-14 | 2022-06-21 |  | 2021-01-14 | 2022-06-21 | 356d | 666d |  | Verde | Verde | 0% | 0% | Verde | 0% | 0% |  |
| 1017 | 2.3.9.29.1 | **Licitação da Obra** |  | 75d | 2021-01-14 | 2021-05-06 |  | 2021-01-14 | 2021-05-06 | 75d | 666d |  | Verde | Verde | 0% | 0% | Verde | 0% | 0% |  |
| 1018 | 2.3.9.29.1.1 | Licitação da obra autorizada pelo banco | milestone | 0d | 2021-01-14 | 2021-01-14 | 975 | 2021-01-14 | 2021-01-14 | 0d | 666d | 0d | Verde | Verde | 0% | 0% | Verde | 0% | 0% | Verde |
| 1019 | 2.3.9.29.1.2 | Licitar Obra |  | 61d | 2021-01-15 | 2021-04-15 | 1018 | 2021-01-15 | 2021-04-15 | 61d | 666d | 0d | Verde | Verde | 0% | 0% | Verde | 0% | 0% | Verde |
| 1020 | 2.3.9.29.1.3 | Analisar e emitir resultado da licitação da obra |  | 14d | 2021-04-16 | 2021-05-06 | 1019 | 2021-04-16 | 2021-05-06 | 14d | 666d | 0d | Verde | Verde | 0% | 0% | Verde | 0% | 0% | Verde |
| 1021 | 2.3.9.29.1.4 | Licitação da obra concluída | milestone | 0d | 2021-05-06 | 2021-05-06 | 1020 | 2021-05-06 | 2021-05-06 | 0d | 666d | 0d | Verde | Verde | 0% | 0% | Verde | 0% | 0% | Verde |
| 1022 | 2.3.9.29.2 | Executar obra |  | 128d | 2021-06-07 | 2021-12-07 | 1021FS+20d | 2021-06-07 | 2021-12-07 | 128d | 666d | 0d | Verde | Verde | 0% | 0% | Verde | 0% | 0% | Verde |
| 1023 | 2.3.9.29.3 | Realizar processo de pré-operação |  | 128d | 2021-12-08 | 2022-06-13 | 1022 | 2021-12-08 | 2022-06-13 | 128d | 666d | 0d | Verde | Verde | 0% | 0% | Verde | 0% | 0% | Verde |
| 1024 | 2.3.9.29.4 | Recurso da obra parcelado repassado | milestone | 0d | 2022-06-21 | 2022-06-21 | 1023FS+5d | 2022-06-21 | 2022-06-21 | 0d | 666d | 0d | Verde | Verde | 0% | 0% | Verde | 0% | 0% | Verde |
| 1025 | 2.3.9.29.5 | Pleito COLESOB20 concluído | milestone | 0d | 2022-06-21 | 2022-06-21 | 1024 | 2022-06-21 | 2022-06-21 | 0d | 666d | 53d | Verde | Verde | 0% | 0% | Verde | 0% | 0% | Verde |
| 1026 | 2.3.9.30 | **Pleito COLESOB21 - Implantação de rede interceptora de esgoto sanitário na micro bacia do bairro Santa Mônica** |  | 399d | 2021-01-14 | 2022-08-22 |  | 2021-01-14 | 2022-08-22 | 399d | 623d |  | Verde | Verde | 0% | 0% | Verde | 0% | 0% |  |
| 1027 | 2.3.9.30.1 | **Licitação da Obra** |  | 75d | 2021-01-14 | 2021-05-06 |  | 2021-01-14 | 2021-05-06 | 75d | 623d |  | Verde | Verde | 0% | 0% | Verde | 0% | 0% |  |
| 1028 | 2.3.9.30.1.1 | Licitação da obra autorizada pelo banco | milestone | 0d | 2021-01-14 | 2021-01-14 | 975 | 2021-01-14 | 2021-01-14 | 0d | 623d | 0d | Verde | Verde | 0% | 0% | Verde | 0% | 0% | Verde |
| 1029 | 2.3.9.30.1.2 | Licitar Obra |  | 61d | 2021-01-15 | 2021-04-15 | 1028 | 2021-01-15 | 2021-04-15 | 61d | 623d | 0d | Verde | Verde | 0% | 0% | Verde | 0% | 0% | Verde |
| 1030 | 2.3.9.30.1.3 | Analisar e emitir resultado da licitação da obra |  | 14d | 2021-04-16 | 2021-05-06 | 1029 | 2021-04-16 | 2021-05-06 | 14d | 623d | 0d | Verde | Verde | 0% | 0% | Verde | 0% | 0% | Verde |
| 1031 | 2.3.9.30.1.4 | Licitação da obra concluída | milestone | 0d | 2021-05-06 | 2021-05-06 | 1030 | 2021-05-06 | 2021-05-06 | 0d | 623d | 0d | Verde | Verde | 0% | 0% | Verde | 0% | 0% | Verde |
| 1032 | 2.3.9.30.2 | Executar obra |  | 171d | 2021-06-07 | 2022-02-07 | 1031FS+20d | 2021-06-07 | 2022-02-07 | 171d | 623d | 0d | Verde | Verde | 0% | 0% | Verde | 0% | 0% | Verde |
| 1033 | 2.3.9.30.3 | Realizar processo de pré-operação |  | 128d | 2022-02-08 | 2022-08-12 | 1032 | 2022-02-08 | 2022-08-12 | 128d | 623d | 0d | Verde | Verde | 0% | 0% | Verde | 0% | 0% | Verde |
| 1034 | 2.3.9.30.4 | Recurso da obra parcelado repassado | milestone | 0d | 2022-08-22 | 2022-08-22 | 1033FS+5d | 2022-08-22 | 2022-08-22 | 0d | 623d | 0d | Verde | Verde | 0% | 0% | Verde | 0% | 0% | Verde |
| 1035 | 2.3.9.30.5 | Pleito COLESOB21 concluído | milestone | 0d | 2022-08-22 | 2022-08-22 | 1034 | 2022-08-22 | 2022-08-22 | 0d | 623d | 10d | Verde | Verde | 0% | 0% | Verde | 0% | 0% | Verde |

| ID | WBS | Task | Type | Duration | Start | Finish | Predecessors | Complete | Remaining | Baseline start | Baseline finish | Baseline duration | Baseline 1 start | Baseline 1 finish | Total slack | Free slack | Farol de Atraso | Farol Marcos | % Previsto Tempo | Índice de Desempenho Físico (IDF) | Farol IDF | % Previsto Ponderado | % Concluído Ponderado | Farol de Início | IDF Numérico | % Previsto Ponderado Numérico | % Concluído Ponderado Numérico | % Concluída Numérico | % Previsto Tempo Numérico | Responsável | Código do Contrato |
| --- | --- | --- | --- | --- | --- | --- | --- | --- | --- | --- | --- | --- | --- | --- | --- | --- | --- | --- | --- | --- | --- | --- | --- | --- | --- | --- | --- | --- | --- | --- | --- |
| 1036 | 2.3.9.31 | **Pleito COLESOB22 - Implantação de rede interceptora de esgoto sanitário na micro bacia do bairro Vila Verdi** |  | 351d | 2021-01-14 | 2022-06-13 |  |  |  | 2021-01-14 | 2022-06-13 | 351d |  |  | 671d |  | Verde | Verde | 0% | 0% | Verde | 0% | 0% |  |  |  |  |  |  |  |  |
| 1037 | 2.3.9.31.1 | **Licitação da Obra** |  | 75d | 2021-01-14 | 2021-05-06 |  |  |  | 2021-01-14 | 2021-05-06 | 75d |  |  | 671d |  | Verde | Verde | 0% | 0% | Verde | 0% | 0% |  |  |  |  |  |  |  |  |
| 1038 | 2.3.9.31.1.1 | Licitação da obra autorizada pelo banco | milestone | 0d | 2021-01-14 | 2021-01-14 | 975 |  |  | 2021-01-14 | 2021-01-14 | 0d |  |  | 671d | 0d | Verde | Verde | 0% | 0% | Verde | 0% | 0% | Verde |  |  |  |  |  |  |  |
| 1039 | 2.3.9.31.1.2 | Licitar Obra |  | 61d | 2021-01-15 | 2021-04-15 | 1038 |  |  | 2021-01-15 | 2021-04-15 | 61d |  |  | 671d | 0d | Verde | Verde | 0% | 0% | Verde | 0% | 0% | Verde |  |  |  |  |  |  |  |
| 1040 | 2.3.9.31.1.3 | Analisar e emitir resultado da licitação da obra |  | 14d | 2021-04-16 | 2021-05-06 | 1039 |  |  | 2021-04-16 | 2021-05-06 | 14d |  |  | 671d | 0d | Verde | Verde | 0% | 0% | Verde | 0% | 0% | Verde |  |  |  |  |  |  |  |
| 1041 | 2.3.9.31.1.4 | Licitação da obra concluída | milestone | 0d | 2021-05-06 | 2021-05-06 | 1040 |  |  | 2021-05-06 | 2021-05-06 | 0d |  |  | 671d | 0d | Verde | Verde | 0% | 0% | Verde | 0% | 0% | Verde |  |  |  |  |  |  |  |
| 1042 | 2.3.9.31.2 | Executar obra |  | 128d | 2021-06-07 | 2021-12-07 | 1041FS+20d |  |  | 2021-06-07 | 2021-12-07 | 128d |  |  | 671d | 0d | Verde | Verde | 0% | 0% | Verde | 0% | 0% | Verde |  |  |  |  |  |  |  |
| 1043 | 2.3.9.31.3 | Realizar processo de pré-operação |  | 128d | 2021-12-08 | 2022-06-13 | 1042 |  |  | 2021-12-08 | 2022-06-13 | 128d |  |  | 671d | 0d | Verde | Verde | 0% | 0% | Verde | 0% | 0% | Verde |  |  |  |  |  |  |  |
| 1044 | 2.3.9.31.4 | Recurso da obra parcelado repassado | milestone | 0d | 2022-06-13 | 2022-06-13 | 1043 |  |  | 2022-06-13 | 2022-06-13 | 0d |  |  | 671d | 0d | Verde | Verde | 0% | 0% | Verde | 0% | 0% | Verde |  |  |  |  |  |  |  |
| 1045 | 2.3.9.31.5 | Pleito COLESOB22 concluído | milestone | 0d | 2022-06-13 | 2022-06-13 | 1044 |  |  | 2022-06-13 | 2022-06-13 | 0d |  |  | 671d | 58d | Verde | Verde | 0% | 0% | Verde | 0% | 0% | Verde |  |  |  |  |  |  |  |
| 1046 | 2.3.9.32 | **Pleito COLESOB23 - Implantação de rede interceptora de esgoto sanitário na micro bacia do bairro São Miguel** |  | 356d | 2021-01-14 | 2022-06-21 |  |  |  | 2021-01-14 | 2022-06-21 | 356d |  |  | 666d |  | Verde | Verde | 0% | 0% | Verde | 0% | 0% |  |  |  |  |  |  |  |  |
| 1047 | 2.3.9.32.1 | **Licitação da Obra** |  | 75d | 2021-01-14 | 2021-05-06 |  |  |  | 2021-01-14 | 2021-05-06 | 75d |  |  | 666d |  | Verde | Verde | 0% | 0% | Verde | 0% | 0% |  |  |  |  |  |  |  |  |
| 1048 | 2.3.9.32.1.1 | Licitação da obra autorizada pelo banco | milestone | 0d | 2021-01-14 | 2021-01-14 | 975 |  |  | 2021-01-14 | 2021-01-14 | 0d |  |  | 666d | 0d | Verde | Verde | 0% | 0% | Verde | 0% | 0% | Verde |  |  |  |  |  |  |  |
| 1049 | 2.3.9.32.1.2 | Licitar Obra |  | 61d | 2021-01-15 | 2021-04-15 | 1048 |  |  | 2021-01-15 | 2021-04-15 | 61d |  |  | 666d | 0d | Verde | Verde | 0% | 0% | Verde | 0% | 0% | Verde |  |  |  |  |  |  |  |
| 1050 | 2.3.9.32.1.3 | Analisar e emitir resultado da licitação da obra |  | 14d | 2021-04-16 | 2021-05-06 | 1049 |  |  | 2021-04-16 | 2021-05-06 | 14d |  |  | 666d | 0d | Verde | Verde | 0% | 0% | Verde | 0% | 0% | Verde |  |  |  |  |  |  |  |
| 1051 | 2.3.9.32.1.4 | Licitação da obra concluída | milestone | 0d | 2021-05-06 | 2021-05-06 | 1050 |  |  | 2021-05-06 | 2021-05-06 | 0d |  |  | 666d | 0d | Verde | Verde | 0% | 0% | Verde | 0% | 0% | Verde |  |  |  |  |  |  |  |
| 1052 | 2.3.9.32.2 | Executar obra |  | 128d | 2021-06-07 | 2021-12-07 | 1051FS+20d |  |  | 2021-06-07 | 2021-12-07 | 128d |  |  | 666d | 0d | Verde | Verde | 0% | 0% | Verde | 0% | 0% | Verde |  |  |  |  |  |  |  |
| 1053 | 2.3.9.32.3 | Realizar processo de pré-operação |  | 128d | 2021-12-08 | 2022-06-13 | 1052 |  |  | 2021-12-08 | 2022-06-13 | 128d |  |  | 666d | 0d | Verde | Verde | 0% | 0% | Verde | 0% | 0% | Verde |  |  |  |  |  |  |  |
| 1054 | 2.3.9.32.4 | Recurso da obra parcelado repassado | milestone | 0d | 2022-06-21 | 2022-06-21 | 1053FS+5d |  |  | 2022-06-21 | 2022-06-21 | 0d |  |  | 666d | 0d | Verde | Verde | 0% | 0% | Verde | 0% | 0% | Verde |  |  |  |  |  |  |  |
| 1055 | 2.3.9.32.5 | Pleito COLESOB23 concluído | milestone | 0d | 2022-06-21 | 2022-06-21 | 1054 |  |  | 2022-06-21 | 2022-06-21 | 0d |  |  | 666d | 53d | Verde | Verde | 0% | 0% | Verde | 0% | 0% | Verde |  |  |  |  |  |  |  |
| 1056 | 2.3.9.33 | **Pleito COLRSOB01 - O município de Colatina é membro do Consórcio Público para tratamento e destinação final adequada de resíduos sólidos da região doce oeste do Estado do Espírito Santo – CONDOESTE, e fez opção por alocar o montante de R$ 4.302.883,14 pa** |  | 625d | 2019-03-14 A | 2021-09-15 |  | 5% | 590.99d | 2019-03-14 | 2021-09-15 | 625d |  |  | 855d |  | Verde | Verde | 5% | 100% | Verde | 10% | 10% |  | 100 | 10 | 10 |  |  |  |  |
| 1057 | 2.3.9.33.1 | **Licitação da obra** |  | 52d | 2019-03-14 A | 2019-05-29 |  | 70% | 15.83d | 2019-03-14 | 2019-05-29 | 52d |  |  | 855d |  | Verde | Verde | 61% | 100% | Verde | 67% | 67% |  | 100 | 67 | 67 | 70 | 61 |  |  |
| 1058 | 2.3.9.33.1.1 | Licitação da obra autorizada pelo banco | milestone | 0d | 2019-03-14 A | 2019-03-14 A | 358 | 100% |  | 2019-03-14 | 2019-03-14 | 0d |  |  |  |  | Verde | Verde | 100% | 0% | Vermelho | 100% | 0% | Verde |  | 100 |  | 100 | 100 |  |  |
| 1059 | 2.3.9.33.1.2 | Licitar obra |  | 38d | 2019-03-14 A | 2019-05-09 | 1058 | 84% | 6d | 2019-03-14 | 2019-05-09 | 38d |  |  | 855d | 0d | Verde | Verde | 84% | 100% | Verde | 84% | 84% | Verde | 100 | 84 | 84 | 84 | 84 |  |  |
| 1060 | 2.3.9.33.1.3 | Analisar e emitir resultado da licitação da obra |  | 8d | 2019-05-20 | 2019-05-29 | 1059FS+6d |  |  | 2019-05-20 | 2019-05-29 | 8d |  |  | 855d | 0d | Verde | Verde | 0% | 0% | Verde | 0% | 0% | Verde |  |  |  |  |  |  |  |
| 1061 | 2.3.9.33.1.4 | Licitação da obra concluída | milestone | 0d | 2019-05-29 | 2019-05-29 | 1060 |  |  | 2019-05-29 | 2019-05-29 | 0d |  |  | 855d | 0d | Verde | Verde | 0% | 0% | Verde | 0% | 0% | Verde |  |  |  |  |  |  |  |
| 1062 | 2.3.9.33.2 | Executar obra |  | 414d | 2019-07-08 | 2021-03-08 | 1061FS+26d |  |  | 2019-07-08 | 2021-03-08 | 414d |  |  | 855d | 0d | Verde | Verde | 0% | 0% | Verde | 0% | 0% | Verde |  |  |  |  |  |  |  |
| 1063 | 2.3.9.33.3 | Realizar processo de pré-operação |  | 128d | 2021-03-09 | 2021-09-08 | 1062 |  |  | 2021-03-09 | 2021-09-08 | 128d |  |  | 855d | 0d | Verde | Verde | 0% | 0% | Verde | 0% | 0% | Verde |  |  |  |  |  |  |  |
| 1064 | 2.3.9.33.4 | Recurso da obra parcelado repassado | milestone | 0d | 2021-09-15 | 2021-09-15 | 1063FS+5d |  |  | 2021-09-15 | 2021-09-15 | 0d |  |  | 855d | 0d | Verde | Verde | 0% | 0% | Verde | 0% | 0% | Verde |  |  |  |  |  |  |  |
| 1065 | 2.3.9.33.5 | Pleito COLRSOB01 concluído | milestone | 0d | 2021-09-15 | 2021-09-15 | 1064 |  |  | 2021-09-15 | 2021-09-15 | 0d |  |  | 855d | 242d | Verde | Verde | 0% | 0% | Verde | 0% | 0% | Verde |  |  |  |  |  |  |  |
| 1066 | 2.3.9.34 | Recursos de Colatina repassados | milestone | 0d | 2022-09-05 | 2022-09-05 | 619, 625, 631, 647, 663, 687, 697, 721, 731, 755, 765, 789, 799, 823, 833, 857, 867, 891, 901, 925, 935, 943, 951, 975, 985, 995, 1005, 1015, 1025, 1035, 1045, 1055, 1065 |  |  | 2022-09-05 | 2022-09-05 | 0d | 2019-04-07 | 2021-03-14 | 613d |  | Verde | Verde | 0% | 0% | Verde | 0% | 0% | Verde |  |  |  |  |  | 02 - Execução | PG 031 |

Notes:
- 1058: Em 24/09/2019: mesma obra do pleito de baixo guandu para o consórcio CONDOESTE
- 1059: Em 29/04/2019: atualizado como agendado
- 1066: Valor de recurso destinado ao munícipio: R$43.028.831,34

| ID | WBS | Task | Type | Duration | Start | Finish | Predecessors | Complete | Remaining | Baseline start | Baseline finish | Baseline duration | Baseline 1 start | Baseline 1 finish | Total slack | Free slack | Farol de Atraso | Farol Marcos | % Previsto Tempo | Índice de Desempenho Físico (IDF) | Farol IDF | % Previsto Ponderado | % Concluído Ponderado | % Previsto Tempo Numérico | % Concluída Numérico | % Previsto Ponderado Numérico | Farol de Início | Responsável | Código do Contrato |
| --- | --- | --- | --- | --- | --- | --- | --- | --- | --- | --- | --- | --- | --- | --- | --- | --- | --- | --- | --- | --- | --- | --- | --- | --- | --- | --- | --- | --- | --- |
| 1067 | 2.3.10 | **Conselheiro Pena** |  | 945d | 2019-03-28 A | 2023-01-13 |  | 1% | 935.41d | 2019-03-28 | 2023-01-13 | 945d | 2018-10-30 | 2021-11-20 | 524d |  | Verde | Verde | 2% | 0% | Vermelho | 0% | 0% |  |  |  |  |  |  |
| 1068 | 2.3.10.1 | **Pleito COPESPJ01 - Contratação de empresa especializada para elaboração dos projetos executivos** |  | 170d | 2019-03-28 A | 2019-11-29 |  | 5% | 160.75d | 2019-03-28 | 2019-11-29 | 170d |  |  | 634d |  | Verde | Verde | 12% | 0% | Vermelho | 2% | 0% | 12 |  |  |  |  |  |
| 1069 | 2.3.10.1.1 | Pleito aprovado | milestone | 0d | 2019-03-28 A | 2019-03-28 A | 206FS+72d | 100% |  | 2019-03-28 | 2019-03-28 | 0d |  |  |  |  | Verde | Verde | 100% | 0% | Vermelho | 100% | 0% | 100 | 100 | 100 | Verde |  |  |
| 1070 | 2.3.10.1.2 | **Licitação do projeto** |  | 60d | 2019-04-16 A | 2019-07-15 |  | 15% | 51.27d | 2019-04-16 | 2019-07-15 | 60d |  |  | 634d |  | Verde | Verde | 13% | 0% | Vermelho | 15% | 0% | 13 | 15 | 15 |  |  |  |
| 1071 | 2.3.10.1.2.1 | Licitação do projeto autorizada pelo banco | milestone | 0d | 2019-04-16 A | 2019-04-16 A | 1069FS+13d | 100% |  | 2019-04-16 | 2019-04-16 | 0d |  |  |  |  | Verde | Verde | 100% | 0% | Vermelho | 100% | 0% | 100 | 100 | 100 | Verde |  |  |
| 1072 | 2.3.10.1.2.2 | Licitar projeto |  | 41d | 2019-04-17 A | 2019-06-17 | 1071 | 20% | 33d | 2019-04-17 | 2019-06-17 | 41d |  |  | 634d | 0d | Verde | Verde | 19% | 0% | Vermelho | 19% | 0% | 19 | 20 | 19 | Verde |  |  |
| 1073 | 2.3.10.1.2.3 | Documentação de licitação apresentada ao banco | milestone | 0d | 2019-06-25 | 2019-06-25 | 1072FS+5d |  |  | 2019-06-25 | 2019-06-25 | 0d |  |  | 634d | 0d | Verde | Verde | 0% | 0% | Verde | 0% | 0% |  |  |  | Verde |  |  |
| 1074 | 2.3.10.1.2.4 | Analisar e emitir resultado da licitação do projeto |  | 14d | 2019-06-26 | 2019-07-15 | 1073 |  |  | 2019-06-26 | 2019-07-15 | 14d |  |  | 634d | 0d | Verde | Verde | 0% | 0% | Verde | 0% | 0% |  |  |  | Verde |  |  |
| 1075 | 2.3.10.1.2.5 | Licitação do projeto concluída | milestone | 0d | 2019-07-15 | 2019-07-15 | 1074 |  |  | 2019-07-15 | 2019-07-15 | 0d |  |  | 634d | 0d | Verde | Verde | 0% | 0% | Verde | 0% | 0% |  |  |  | Verde |  |  |
| 1076 | 2.3.10.1.3 | **Elaboração do Projeto Executivo** |  | 97d | 2019-07-16 | 2019-11-29 |  |  |  | 2019-07-16 | 2019-11-29 | 97d |  |  | 634d |  | Verde | Verde | 0% | 0% | Verde | 0% | 0% |  |  |  |  |  |  |
| 1077 | 2.3.10.1.3.1 | Elaborar Projeto Executivo |  | 23d | 2019-07-16 | 2019-08-16 | 1075 |  |  | 2019-07-16 | 2019-08-16 | 23d |  |  | 634d | 0d | Verde | Verde | 0% | 0% | Verde | 0% | 0% |  |  |  | Verde |  |  |
| 1078 | 2.3.10.1.3.2 | Projeto executivo apresentado ao banco | milestone | 0d | 2019-08-16 | 2019-08-16 | 1077 |  |  | 2019-08-16 | 2019-08-16 | 0d |  |  | 634d | 0d | Verde | Verde | 0% | 0% | Verde | 0% | 0% |  |  |  | Verde |  |  |
| 1079 | 2.3.10.1.3.3 | Analisar projeto executivo |  | 24d | 2019-08-19 | 2019-09-19 | 1078 |  |  | 2019-08-19 | 2019-09-19 | 24d |  |  | 634d | 0d | Verde | Verde | 0% | 0% | Verde | 0% | 0% |  |  |  | Verde |  |  |
| 1080 | 2.3.10.1.3.4 | Adequar/revisar projeto executivo |  | 22d | 2019-09-20 | 2019-10-21 | 1079 |  |  | 2019-09-20 | 2019-10-21 | 22d |  |  | 634d | 0d | Verde | Verde | 0% | 0% | Verde | 0% | 0% |  |  |  | Verde |  |  |
| 1081 | 2.3.10.1.3.5 | Analisar projeto executivo - final |  | 23d | 2019-10-22 | 2019-11-22 | 1080 |  |  | 2019-10-22 | 2019-11-22 | 23d |  |  | 634d | 0d | Verde | Verde | 0% | 0% | Verde | 0% | 0% |  |  |  | Verde |  |  |
| 1082 | 2.3.10.1.3.6 | Projeto executivo concluído | milestone | 0d | 2019-11-22 | 2019-11-22 | 1081 |  |  | 2019-11-22 | 2019-11-22 | 0d |  |  | 634d | 0d | Verde | Verde | 0% | 0% | Verde | 0% | 0% |  |  |  | Verde |  |  |
| 1083 | 2.3.10.1.3.7 | Recurso do projeto executivo do pleito COPESPJ01 repassado | milestone | 0d | 2019-11-29 | 2019-11-29 | 1082FS+5d |  |  | 2019-11-29 | 2019-11-29 | 0d |  |  | 634d | 0d | Verde | Verde | 0% | 0% | Verde | 0% | 0% |  |  |  | Verde |  |  |
| 1084 | 2.3.10.1.4 | Pleito COPESPJ01 concluído | milestone | 0d | 2019-11-29 | 2019-11-29 | 1083 |  |  | 2019-11-29 | 2019-11-29 | 0d |  |  | 634d | 0d | Verde | Verde | 0% | 0% | Verde | 0% | 0% |  |  |  | Verde |  |  |
| 1085 | 2.3.10.2 | **Pleito COPESOB01 - Construção do sistema de esgotamento sanitário da sede do município.** |  | 665d | 2019-11-29 | 2022-08-04 |  |  |  | 2019-11-29 | 2022-08-04 | 665d |  |  | 634d |  | Verde | Verde | 0% | 0% | Verde | 0% | 0% |  |  |  |  |  |  |
| 1086 | 2.3.10.2.1 | **Licitação da obra** |  | 73d | 2019-11-29 | 2020-03-20 |  |  |  | 2019-11-29 | 2020-03-20 | 73d |  |  | 634d |  | Verde | Verde | 0% | 0% | Verde | 0% | 0% |  |  |  |  |  |  |
| 1087 | 2.3.10.2.1.1 | Licitação da obra autorizada pelo banco | milestone | 0d | 2019-11-29 | 2019-11-29 | 1084 |  |  | 2019-11-29 | 2019-11-29 | 0d |  |  | 634d | 0d | Verde | Verde | 0% | 0% | Verde | 0% | 0% |  |  |  | Verde |  |  |
| 1088 | 2.3.10.2.1.2 | Licitar obra |  | 59d | 2019-12-02 | 2020-03-02 | 1087 |  |  | 2019-12-02 | 2020-03-02 | 59d | 2019-05-28 | 2019-09-25 | 634d | 0d | Verde | Verde | 0% | 0% | Verde | 0% | 0% |  |  |  | Verde |  |  |
| 1089 | 2.3.10.2.1.3 | Analisar e emitir resultado da licitação da obra |  | 14d | 2020-03-03 | 2020-03-20 | 1088 |  |  | 2020-03-03 | 2020-03-20 | 14d |  |  | 634d | 0d | Verde | Verde | 0% | 0% | Verde | 0% | 0% |  |  |  | Verde |  |  |
| 1090 | 2.3.10.2.1.4 | Licitação da obra concluída | milestone | 0d | 2020-03-20 | 2020-03-20 | 1089 |  |  | 2020-03-20 | 2020-03-20 | 0d |  |  | 634d | 0d | Verde | Verde | 0% | 0% | Verde | 0% | 0% |  |  |  | Verde |  |  |
| 1091 | 2.3.10.2.2 | Executar obra |  | 439d | 2020-04-22 | 2022-01-21 | 1090FS+20d |  |  | 2020-04-22 | 2022-01-21 | 439d |  |  | 634d | 0d | Verde | Verde | 0% | 0% | Verde | 0% | 0% |  |  |  | Verde |  |  |
| 1092 | 2.3.10.2.3 | Realizar processo de pré-operação |  | 128d | 2022-01-24 | 2022-07-28 | 1091 |  |  | 2022-01-24 | 2022-07-28 | 128d | 2021-05-24 | 2021-11-20 | 634d | 0d | Verde | Verde | 0% | 0% | Verde | 0% | 0% |  |  |  | Verde | 02 - Execução | PG031 |
| 1093 | 2.3.10.2.4 | Recurso da obra parcelado repassado | milestone | 0d | 2022-08-04 | 2022-08-04 | 1092FS+5d |  |  | 2022-08-04 | 2022-08-04 | 0d |  |  | 634d | 0d | Verde | Verde | 0% | 0% | Verde | 0% | 0% |  |  |  | Verde |  |  |
| 1094 | 2.3.10.2.5 | Pleito COPESOB01 concluído | milestone | 0d | 2022-08-04 | 2022-08-04 | 1093 |  |  | 2022-08-04 | 2022-08-04 | 0d |  |  | 634d | 110d | Verde | Verde | 0% | 0% | Verde | 0% | 0% |  |  |  | Verde |  |  |

Notes:
- 1067: Conselheiro Pena teve 100% dos pleitos de Esgotamento Sanitário aprovado (R$8.508.587,53), conforme Deliberação 75. / Conselheiro Pena solicitou mudança de pleito, mas ainda não foi autorizado pelo CIF. / ·Uso de 100% do teto em esgotamento sanitário para a sede (construção do SES e muros do tipo Gabião, para estabilização das margens do ribeirão João Pinto e proteção das redes) / Município está querendo mudar o pleito para solicitar recurso para projeto, o que mudaria as atividades do cronograma.
- 1069: Em 17/04/2019: pleito foi aprovado no dia 28/03 na deliberação 269.
- 1071: Em 16/04/2019: licitação autorizada pelo BDMG conforme e-mail enviado pelo Gislaine.
- 1072: Em 29/04/2019: atualizado como agendado

| ID | WBS | Task | Type | Duration | Start | Finish | Predecessors | Complete | Remaining | Baseline start | Baseline finish | Baseline duration | Baseline 1 start | Baseline 1 finish | Total slack | Free slack | Farol de Atraso | Farol Marcos | % Previsto Tempo | Índice de Desempenho Físico (IDF) | Farol IDF | % Previsto Ponderado | % Concluído Ponderado | Farol de Início | Responsável | Código do Contrato | % Concluída Numérico | IDF Numérico | % Previsto Tempo Numérico | % Previsto Ponderado Numérico | % Concluído Ponderado Numérico |
| --- | --- | --- | --- | --- | --- | --- | --- | --- | --- | --- | --- | --- | --- | --- | --- | --- | --- | --- | --- | --- | --- | --- | --- | --- | --- | --- | --- | --- | --- | --- | --- |
| 1095 | 2.3.10.3 | **Pleito de Conselheiro Pena de Resíduos Sólidos a definir** |  | 839d | 2019-08-30 | 2023-01-13 |  |  |  | 2019-08-30 | 2023-01-13 | 839d |  |  | 524d |  | Verde | Verde | 0% | 0% | Verde | 0% | 0% |  |  |  |  |  |  |  |  |
| 1096 | 2.3.10.3.1 | Pleito aprovado | milestone | 0d | 2019-08-30 | 2019-08-30 | 206FS+178d |  |  | 2019-08-30 | 2019-08-30 | 0d |  |  | 524d | 0d | Verde | Verde | 0% | 0% | Verde | 0% | 0% | Verde |  |  |  |  |  |  |  |
| 1097 | 2.3.10.3.2 | Iniciar pleito |  | 1d | 2019-09-02 | 2019-09-02 | 1096 |  |  | 2019-09-02 | 2019-09-02 | 1d |  |  | 524d | 0d | Verde | Verde | 0% | 0% | Verde | 0% | 0% | Verde |  |  |  |  |  |  |  |
| 1098 | 2.3.10.3.3 | Pleito concluído | milestone | 0d | 2023-01-13 | 2023-01-13 | 1097FS+838d |  |  | 2023-01-13 | 2023-01-13 | 0d |  |  | 524d | 0d | Verde | Verde | 0% | 0% | Verde | 0% | 0% | Verde |  |  |  |  |  |  |  |
| 1099 | 2.3.10.4 | Recursos de Conselheiro Pena repassados | milestone | 0d | 2023-01-13 | 2023-01-13 | 1084, 1094, 1098 |  |  | 2023-01-13 | 2023-01-13 | 0d | 2019-06-27 | 2021-11-13 | 524d |  | Verde | Verde | 0% | 0% | Verde | 0% | 0% | Verde | 02 - Execução | PG 031 |  |  |  |  |  |
| 1100 | 2.3.11 | **Córrego Novo** |  | 1570d | 2018-11-01 A | 2025-02-24 |  | 22% | 1226.3d | 2018-11-01 | 2025-02-24 | 1570d | 2018-11-01 | 2020-11-27 | 0d |  | Verde | Verde | 7% | 100% | Verde | 7% | 7% |  |  |  | 22 | 100 |  |  |  |
| 1101 | 2.3.11.1 | **Pleito CONESOB01 - Implantação de sistema de esgotamento sanitário da sede do município** |  | 567d | 2018-11-01 A | 2021-02-10 |  | 22% | 442.66d | 2018-11-01 | 2021-02-10 | 567d |  |  | 1003d |  | Verde | Verde | 21% | 100% | Verde | 8% | 8% |  |  |  | 22 | 100 | 21 |  |  |
| 1102 | 2.3.11.1.1 | **Elaboração do Projeto** |  | 20d | 2019-04-08 A | 2019-05-08 |  | 75% | 5d | 2019-04-08 | 2019-05-08 | 20d |  |  | 1003d |  | Verde | Verde | 75% | 97% | Vermelho | 75% | 73% |  |  |  | 75 | 97 | 75 | 75 | 73 |
| 1103 | 2.3.11.1.1.1 | Analisar projeto - final |  | 20d | 2019-04-08 A | 2019-05-08 | 177FS+182d | 75% | 5d | 2019-04-08 | 2019-05-08 | 20d |  |  | 1003d | 0d | Verde | Verde | 75% | 97% | Vermelho | 75% | 73% | Verde |  |  | 75 | 97 | 75 | 75 | 73 |
| 1104 | 2.3.11.1.1.2 | Projeto concluído | milestone | 0d | 2019-05-08 | 2019-05-08 | 1103, 1105 |  |  | 2019-05-08 | 2019-05-08 | 0d |  |  | 1003d | 0d | Verde | Verde | 0% | 0% | Verde | 0% | 0% | Verde |  |  |  |  |  |  |  |
| 1105 | 2.3.11.1.2 | Realizar Licenciamento Ambiental |  | 115d | 2018-11-01 A | 2019-05-08 | 177FS+105ed | 96% | 5d | 2018-11-01 | 2019-05-08 | 115d | 2018-11-01 | 2019-04-30 | 1003d | 0d | Verde | Verde | 96% | 98% | Vermelho | 96% | 94% | Verde |  |  | 96 | 98 | 96 | 96 | 94 |
| 1106 | 2.3.11.1.3 | **Licitação da obra** |  | 57d | 2019-05-08 | 2019-07-29 |  |  |  | 2019-05-08 | 2019-07-29 | 57d |  |  | 1003d |  | Verde | Verde | 0% | 0% | Verde | 0% | 0% |  |  |  |  |  |  |  |  |
| 1107 | 2.3.11.1.3.1 | Licitação da obra autorizada pelo banco | milestone | 0d | 2019-05-08 | 2019-05-08 | 1104 |  |  | 2019-05-08 | 2019-05-08 | 0d |  |  | 1003d | 0d | Verde | Verde | 0% | 0% | Verde | 0% | 0% | Verde |  |  |  |  |  |  |  |
| 1108 | 2.3.11.1.3.2 | Licitar obra |  | 43d | 2019-05-09 | 2019-07-09 | 1107 |  |  | 2019-05-09 | 2019-07-09 | 43d |  |  | 1003d | 0d | Verde | Verde | 0% | 0% | Verde | 0% | 0% | Verde |  |  |  |  |  |  |  |
| 1109 | 2.3.11.1.3.3 | Analisar e emitir resultado da licitação da obra |  | 14d | 2019-07-10 | 2019-07-29 | 1108 |  |  | 2019-07-10 | 2019-07-29 | 14d |  |  | 1003d | 0d | Verde | Verde | 0% | 0% | Verde | 0% | 0% | Verde |  |  |  |  |  |  |  |
| 1110 | 2.3.11.1.3.4 | Licitação da obra concluída | milestone | 0d | 2019-07-29 | 2019-07-29 | 1109 |  |  | 2019-07-29 | 2019-07-29 | 0d |  |  | 1003d | 0d | Verde | Verde | 0% | 0% | Verde | 0% | 0% | Verde |  |  |  |  |  |  |  |
| 1111 | 2.3.11.1.4 | Executar obra |  | 250d | 2019-07-30 | 2020-07-30 | 1110 |  |  | 2019-07-30 | 2020-07-30 | 250d |  |  | 1003d | 0d | Verde | Verde | 0% | 0% | Verde | 0% | 0% | Verde |  |  |  |  |  |  |  |
| 1112 | 2.3.11.1.5 | Realizar processo de pré-operação |  | 128d | 2020-07-31 | 2021-02-03 | 1111 |  |  | 2020-07-31 | 2021-02-03 | 128d | 2020-05-31 | 2020-11-27 | 1003d | 0d | Verde | Verde | 0% | 0% | Verde | 0% | 0% | Verde | 02 - Execução | PG031 |  |  |  |  |  |
| 1113 | 2.3.11.1.6 | Recurso da obra parcelado repassado | milestone | 0d | 2021-02-10 | 2021-02-10 | 1112FS+5d |  |  | 2021-02-10 | 2021-02-10 | 0d |  |  | 1003d | 0d | Verde | Verde | 0% | 0% | Verde | 0% | 0% | Verde |  |  |  |  |  |  |  |
| 1114 | 2.3.11.1.7 | Pleito CONESOB01 concluído | milestone | 0d | 2021-02-10 | 2021-02-10 | 1113 |  |  | 2021-02-10 | 2021-02-10 | 0d |  |  | 1003d |  | Verde | Verde | 0% | 0% | Verde | 0% | 0% | Verde |  |  |  |  |  |  |  |
| 1115 | 2.3.11.2 | **Pleito de Córrego Novo de Resíduos Sólidos a definir** |  | 1364d | 2019-08-30 | 2025-02-24 |  |  |  | 2019-08-30 | 2025-02-24 | 1364d |  |  | 0d |  | Verde | Verde | 0% | 0% | Verde | 0% | 0% |  |  |  |  |  |  |  |  |
| 1116 | 2.3.11.2.1 | Pleito aprovado | milestone | 0d | 2019-08-30 | 2019-08-30 | 440 |  |  | 2019-08-30 | 2019-08-30 | 0d |  |  | 0d |  | Verde | Verde | 0% | 0% | Verde | 0% | 0% | Verde |  |  |  |  |  |  |  |
| 1117 | 2.3.11.2.2 | Iniciar pleito |  | 1d | 2019-08-30 | 2019-08-30 | 1116 |  |  | 2019-08-30 | 2019-08-30 | 1d |  |  | 0d |  | Verde | Verde | 0% | 0% | Verde | 0% | 0% | Verde |  |  |  |  |  |  |  |
| 1118 | 2.3.11.2.3 | Pleito concluído | milestone | 0d | 2025-02-24 | 2025-02-24 | 1117FS+1363d |  |  | 2025-02-24 | 2025-02-24 | 0d |  |  | 0d |  | Verde | Verde | 0% | 0% | Verde | 0% | 0% | Verde |  |  |  |  |  |  |  |
| 1119 | 2.3.11.3 | Recursos de Córrego Novo repassados | milestone | 0d | 2025-02-24 | 2025-02-24 | 1114, 1118 |  |  | 2025-02-24 | 2025-02-24 | 0d | 2019-07-06 | 2020-11-27 | 0d |  | Verde | Verde | 0% | 0% | Verde | 0% | 0% | Verde | 02 - Execução | PG 031 |  |  |  |  |  |

Notes:
- 1096: Em 24/04/2019: considerado que pleito será elaborado até julho e aprovado no CT/CIF de agosto/2019
- 1099: Valor de recurso destinado ao munícipio: R$9.453.986,14
- 1100: Córrego Novo solicitou 91,9% do total de recurso destinado ao munícipio para Esgotamento Sanitário, mas foi aprovado 90% (R$4.254.293,76) do valor teto para este fim, conforme Deliberação 75. / O município teve o pleito de resíduos sólidos negado (R$472.699,31), equivalente a 10% do total do recurso).
- 1103: Em 29/04/2019: atualizado como agendado
- 1105: O licenciamento ambiental somente poderá ser concluido após a certidão do cartório de posse do terreno. / Emissão do registro previsto para nov/18. / Em 29/04/2019: atualizado como agendado
- 1119: Valor de recurso destinado ao munícipio: R$4.726.993,07

| ID | WBS | Task | Type | Duration | Start | Finish | Predecessors | Complete | Remaining | Baseline start | Baseline finish | Baseline duration | Baseline 1 start | Baseline 1 finish | Total slack | Free slack | Farol de Atraso | Farol Marcos | % Previsto Tempo | % Concluída Numérico | % Previsto Tempo Numérico | Índice de Desempenho Físico (IDF) | IDF Numérico | Farol IDF | % Previsto Ponderado | % Concluído Ponderado | % Previsto Ponderado Numérico | % Concluído Ponderado Numérico | Farol de Início |
| --- | --- | --- | --- | --- | --- | --- | --- | --- | --- | --- | --- | --- | --- | --- | --- | --- | --- | --- | --- | --- | --- | --- | --- | --- | --- | --- | --- | --- | --- |
| 1120 | 2.3.12 | **Dionísio** |  | 670d | 2018-11-06 A | 2021-07-16 |  | 19% | 544.1d | 2018-11-06 | 2021-07-16 | 670d | 2018-11-06 | 2021-02-23 | 897d |  | Verde | Verde | 17% | 19 | 17 | 83% | 83 | Vermelho | 6% | 5% |  |  |  |
| 1121 | 2.3.12.1 | **Pleito DIORSPM02 - Elaboração de PRAD para lixão/aterro controlado** |  | 128d | 2019-02-01 A | 2019-08-08 |  | 47% | 67.64d | 2019-02-01 | 2019-08-08 | 128d |  |  | 1378d |  | Verde | Verde | 45% | 47 | 45 | 91% | 91 | Vermelho | 70% | 64% | 70 | 64 |  |
| 1122 | 2.3.12.1.1 | **Elaboração do Plano de Recuperação de Área Degradada** |  | 123d | 2019-02-01 A | 2019-08-01 |  | 47% | 65d | 2019-02-01 | 2019-08-01 | 123d |  |  | 1378d |  | Verde | Verde | 47% | 47 | 47 | 91% | 91 | Vermelho | 70% | 64% | 70 | 64 |  |
| 1123 | 2.3.12.1.1.1 | Elaborar PRAD |  | 59d | 2019-02-01 A | 2019-05-02 | 206FS+35d | 98% | 1d | 2019-02-01 | 2019-05-02 | 59d |  |  | 1378d | 0d | Verde | Verde | 98% | 98 | 98 | 92% | 92 | Vermelho | 98% | 90% | 98 | 90 | Verde |
| 1124 | 2.3.12.1.1.2 | PRAD apresentado ao banco | milestone | 0d | 2019-05-02 | 2019-05-02 | 1123 |  |  | 2019-05-02 | 2019-05-02 | 0d |  |  | 1378d | 0d | Verde | Verde | 0% |  |  | 0% |  | Verde | 0% | 0% |  |  | Verde |
| 1125 | 2.3.12.1.1.3 | Analisar PRAD |  | 22d | 2019-05-03 | 2019-06-03 | 1124 |  |  | 2019-05-03 | 2019-06-03 | 22d |  |  | 1378d | 0d | Verde | Verde | 0% |  |  | 0% |  | Verde | 0% | 0% |  |  | Verde |
| 1126 | 2.3.12.1.1.4 | Adequar/revisar PRAD |  | 18d | 2019-06-04 | 2019-06-28 | 1125 |  |  | 2019-06-04 | 2019-06-28 | 18d |  |  | 1378d | 0d | Verde | Verde | 0% |  |  | 0% |  | Verde | 0% | 0% |  |  | Verde |
| 1127 | 2.3.12.1.1.5 | Analisar PRAD - final |  | 24d | 2019-07-01 | 2019-08-01 | 1126 |  |  | 2019-07-01 | 2019-08-01 | 24d |  |  | 1378d | 0d | Verde | Verde | 0% |  |  | 0% |  | Verde | 0% | 0% |  |  | Verde |
| 1128 | 2.3.12.1.1.6 | PRAD concluído | milestone | 0d | 2019-08-01 | 2019-08-01 | 1127 |  |  | 2019-08-01 | 2019-08-01 | 0d |  |  | 1378d | 0d | Verde | Verde | 0% |  |  | 0% |  | Verde | 0% | 0% |  |  | Verde |
| 1129 | 2.3.12.1.2 | Recurso do PRAD do pleito repassado | milestone | 0d | 2019-08-08 | 2019-08-08 | 1128FS+5d |  |  | 2019-08-08 | 2019-08-08 | 0d |  |  | 1378d | 0d | Verde | Verde | 0% |  |  | 0% |  | Verde | 0% | 0% |  |  | Verde |
| 1130 | 2.3.12.1.3 | Pleito DIORSPM02 concluído | milestone | 0d | 2019-08-08 | 2019-08-08 | 1129 |  |  | 2019-08-08 | 2019-08-08 | 0d |  |  | 1378d | 481d | Verde | Verde | 0% |  |  | 0% |  | Verde | 0% | 0% |  |  | Verde |
| 1131 | 2.3.12.2 | **Pleito DIORSPM01 - Elaboração de estudo de viabilidade p/ implantação de aterro regional compartilhado junto ao COMDIN, posteriormente será solicitado recurso p/ sua implantação.** |  | 217d | 2019-05-03 | 2020-03-17 |  |  |  | 2019-05-03 | 2020-03-17 | 217d |  |  | 1229d |  | Verde | Verde | 0% |  |  | 0% |  | Verde | 0% | 0% |  |  |  |
| 1132 | 2.3.12.2.1 | **Licitação de Empresa para Estudo de Viabilidade** |  | 63d | 2019-05-03 | 2019-08-01 |  |  |  | 2019-05-03 | 2019-08-01 | 63d |  |  | 1229d |  | Verde | Verde | 0% |  |  | 0% |  | Verde | 0% | 0% |  |  |  |
| 1133 | 2.3.12.2.1.1 | Licitação da empresa para Estudo de Viabilidade autorizada pelo banco | milestone | 0d | 2019-05-03 | 2019-05-03 | 206FS+95d |  |  | 2019-05-03 | 2019-05-03 | 0d |  |  | 1229d | 0d | Verde | Verde | 0% |  |  | 0% |  | Verde | 0% | 0% |  |  | Verde |
| 1134 | 2.3.12.2.1.2 | Licitar empresa para Estudo de Viabilidade |  | 44d | 2019-05-06 | 2019-07-05 | 1133 |  |  | 2019-05-06 | 2019-07-05 | 44d |  |  | 1229d | 0d | Verde | Verde | 0% |  |  | 0% |  | Verde | 0% | 0% |  |  | Verde |
| 1135 | 2.3.12.2.1.3 | Documentação de licitação apresentada ao banco | milestone | 0d | 2019-07-12 | 2019-07-12 | 1134FS+5d |  |  | 2019-07-12 | 2019-07-12 | 0d |  |  | 1229d | 0d | Verde | Verde | 0% |  |  | 0% |  | Verde | 0% | 0% |  |  | Verde |
| 1136 | 2.3.12.2.1.4 | Analisar e emitir resultado da licitação da empresa para Estudo de Viabilidade |  | 14d | 2019-07-15 | 2019-08-01 | 1135 |  |  | 2019-07-15 | 2019-08-01 | 14d |  |  | 1229d | 0d | Verde | Verde | 0% |  |  | 0% |  | Verde | 0% | 0% |  |  | Verde |
| 1137 | 2.3.12.2.1.5 | Licitação da empresa para Estudo de Viabilidade concluída | milestone | 0d | 2019-08-01 | 2019-08-01 | 1136 |  |  | 2019-08-01 | 2019-08-01 | 0d |  |  | 1229d | 0d | Verde | Verde | 0% |  |  | 0% |  | Verde | 0% | 0% |  |  | Verde |
| 1138 | 2.3.12.2.2 | **Elaboração do estudo de viabilidade** |  | 149d | 2019-08-02 | 2020-03-10 |  |  |  | 2019-08-02 | 2020-03-10 | 149d |  |  | 1229d |  | Verde | Verde | 0% |  |  | 0% |  | Verde | 0% | 0% |  |  |  |
| 1139 | 2.3.12.2.2.1 | Elaborar estudo de viabilidade |  | 88d | 2019-08-02 | 2019-12-05 | 1137 |  |  | 2019-08-02 | 2019-12-05 | 88d |  |  | 1229d | 0d | Verde | Verde | 0% |  |  | 0% |  | Verde | 0% | 0% |  |  | Verde |
| 1140 | 2.3.12.2.2.2 | Analisar estudo |  | 20d | 2019-12-06 | 2020-01-08 | 1139 |  |  | 2019-12-06 | 2020-01-08 | 20d |  |  | 1229d | 0d | Verde | Verde | 0% |  |  | 0% |  | Verde | 0% | 0% |  |  | Verde |
| 1141 | 2.3.12.2.2.3 | Adequar/revisar estudo |  | 22d | 2020-01-09 | 2020-02-07 | 1140 |  |  | 2020-01-09 | 2020-02-07 | 22d |  |  | 1229d | 0d | Verde | Verde | 0% |  |  | 0% |  | Verde | 0% | 0% |  |  | Verde |
| 1142 | 2.3.12.2.2.4 | Analisar estudo - final |  | 19d | 2020-02-10 | 2020-03-10 | 1141 |  |  | 2020-02-10 | 2020-03-10 | 19d |  |  | 1229d | 0d | Verde | Verde | 0% |  |  | 0% |  | Verde | 0% | 0% |  |  | Verde |
| 1143 | 2.3.12.2.2.5 | Estudo concluído | milestone | 0d | 2020-03-10 | 2020-03-10 | 1142 |  |  | 2020-03-10 | 2020-03-10 | 0d |  |  | 1229d | 0d | Verde | Verde | 0% |  |  | 0% |  | Verde | 0% | 0% |  |  | Verde |
| 1144 | 2.3.12.2.3 | Recurso do serviço repassado | milestone | 0d | 2020-03-17 | 2020-03-17 | 1143FS+5d |  |  | 2020-03-17 | 2020-03-17 | 0d |  |  | 1229d | 0d | Verde | Verde | 0% |  |  | 0% |  | Verde | 0% | 0% |  |  | Verde |
| 1145 | 2.3.12.2.4 | Pleito DIORSPM01 concluído | milestone | 0d | 2020-03-17 | 2020-03-17 | 1144 |  |  | 2020-03-17 | 2020-03-17 | 0d |  |  | 1229d | 332d | Verde | Verde | 0% |  |  | 0% |  | Verde | 0% | 0% |  |  | Verde |

Notes:
- 1120: O pleito de Esgotamento Sanitário de Dionísio, contempla apenas a elaboração e adequação do projeto da sede do município e dos distritos de Baixa Verde e Conceição de Minas (5,3% - R$250.000,00 do valor de SES), conforme Deliberação 75. Somente após o projeto vai ser feito o pleito para as obras. Este pleito foi aprovado. / O município teve 1,7% dos 10% do valor teto destinado a Resíduos Sólidos aprovado (R$79.889,97). / Aderiu à ata de registro de preço.
- 1123: Em 24/04/2019: início da elaboração do PRAD no dia 01/02/2019 conforme planilha do plano de aceleração / Em 29/04/2019: atualizado como agendado.
- 1133: Em 24/04/2019: banco não autorizou início de licitação pois reportou que o município pretendia cancelar o pleito. Francisco vai confirmar informação até 25/04/2019.

| ID | WBS | Task | Type | Duration | Start | Finish | Predecessors | Complete | Remaining | Baseline start | Baseline finish | Baseline duration | Baseline 1 start | Baseline 1 finish | Total slack | Free slack | Farol de Atraso | Farol Marcos | % Previsto Tempo | % Concluída Numérico | % Previsto Tempo Numérico | Índice de Desempenho Físico (IDF) | IDF Numérico | Farol IDF | % Previsto Ponderado | % Previsto Ponderado Numérico | % Concluído Ponderado | % Concluído Ponderado Numérico | Responsável | Código do Contrato | Farol de Início |
| --- | --- | --- | --- | --- | --- | --- | --- | --- | --- | --- | --- | --- | --- | --- | --- | --- | --- | --- | --- | --- | --- | --- | --- | --- | --- | --- | --- | --- | --- | --- | --- |
| 1146 | 2.3.12.3 | **Pleito DIOESPJ01 - Elaboração e adequação de projetos de engenharia de sistema de esgotamento sanitário da sede do município e dos distritos de Baixa Verde e Conceição de Minas.** |  | 191d | 2018-11-06 A | 2019-08-12 |  | 52% | 92.35d | 2018-11-06 | 2019-08-12 | 191d |  |  | 1376d |  | Verde | Verde | 62% | 52 | 62 | 93% | 93 | Vermelho | 72% | 72 | 67% | 67 |  |  |  |
| 1147 | 2.3.12.3.1 | **Elaboração do Projeto** |  | 191d | 2018-11-06 A | 2019-08-12 |  | 62% | 73.13d | 2018-11-06 | 2019-08-12 | 191d |  |  | 1376d |  | Verde | Verde | 62% | 62 | 62 | 96% | 96 | Vermelho | 74% | 74 | 71% | 71 |  |  |  |
| 1148 | 2.3.12.3.1.1 | Elaborar Projeto Básico/Executivo |  | 109d | 2018-11-06 A | 2019-05-02 | 178FS+54ed | 99% | 1d | 2018-11-06 | 2019-05-02 | 109d | 2018-11-06 | 2019-05-05 | 1376d | 0d | Verde | Verde | 99% | 99 | 99 | 95% | 95 | Vermelho | 99% | 99 | 94% | 94 | 02 - Execução | PG 031 | Verde |
| 1149 | 2.3.12.3.1.2 | Projeto apresentado ao banco | milestone | 0d | 2019-05-02 | 2019-05-02 | 1148 |  |  | 2019-05-02 | 2019-05-02 | 0d |  |  | 1376d | 0d | Verde | Verde | 0% |  |  | 0% |  | Verde | 0% |  | 0% |  |  |  | Verde |
| 1150 | 2.3.12.3.1.3 | Analisar projeto |  | 22d | 2019-05-03 | 2019-06-03 | 1149 |  |  | 2019-05-03 | 2019-06-03 | 22d |  |  | 1376d | 0d | Verde | Verde | 0% |  |  | 0% |  | Verde | 0% |  | 0% |  |  |  | Verde |
| 1151 | 2.3.12.3.1.4 | Adequar/revisar projeto |  | 22d | 2019-06-04 | 2019-07-04 | 1150 |  |  | 2019-06-04 | 2019-07-04 | 22d |  |  | 1376d | 0d | Verde | Verde | 0% |  |  | 0% |  | Verde | 0% |  | 0% |  |  |  | Verde |
| 1152 | 2.3.12.3.1.5 | Analisar projeto - final |  | 22d | 2019-07-05 | 2019-08-05 | 1151 |  |  | 2019-07-05 | 2019-08-05 | 22d |  |  | 1376d | 0d | Verde | Verde | 0% |  |  | 0% |  | Verde | 0% |  | 0% |  |  |  | Verde |
| 1153 | 2.3.12.3.1.6 | Projeto concluído | milestone | 0d | 2019-08-05 | 2019-08-05 | 1152, 1155 |  |  | 2019-08-05 | 2019-08-05 | 0d |  |  | 1376d | 0d | Verde | Verde | 0% |  |  | 0% |  | Verde | 0% |  | 0% |  |  |  | Verde |
| 1154 | 2.3.12.3.1.7 | Recurso do projeto do pleito DIOESPJ01 repassado | milestone | 0d | 2019-08-12 | 2019-08-12 | 1153FS+5d |  |  | 2019-08-12 | 2019-08-12 | 0d |  |  | 1376d | 0d | Verde | Verde | 0% |  |  | 0% |  | Verde | 0% |  | 0% |  |  |  | Verde |
| 1155 | 2.3.12.3.2 | Realizar Licenciamento Ambiental |  | 98d | 2019-02-04 A | 2019-07-01 | 1148SS+63d | 34% | 65d | 2019-02-04 | 2019-07-01 | 98d | 2019-01-05 | 2019-07-04 | 1401d | 25d | Verde | Verde | 57% | 34 | 57 | 58% | 58 | Vermelho | 57% | 57 | 33% | 33 | 02 - Execução | PG 031 | Verde |
| 1156 | 2.3.12.3.3 | Pleito DIOESPJ01 concluído | milestone | 0d | 2019-08-12 | 2019-08-12 | 1154 |  |  | 2019-08-12 | 2019-08-12 | 0d |  |  | 1376d | 479d | Verde | Verde | 0% |  |  | 0% |  | Verde | 0% |  | 0% |  |  |  | Verde |
| 1157 | 2.3.12.4 | **Pleito de Dionísio a definir - Obra de sistema de esgotamento sanitário da sede do município e dos distritos de Baixa Verde e Conceição de Minas** |  | 466d | 2019-08-30 | 2021-07-16 |  |  |  | 2019-08-30 | 2021-07-16 | 466d |  |  | 897d |  | Verde | Verde | 0% |  |  | 0% |  | Verde | 0% |  | 0% |  |  |  |  |
| 1158 | 2.3.12.4.1 | Pleito aprovado | milestone | 0d | 2019-08-30 | 2019-08-30 | 206FS+178d |  |  | 2019-08-30 | 2019-08-30 | 0d |  |  | 897d | 0d | Verde | Verde | 0% |  |  | 0% |  | Verde | 0% |  | 0% |  |  |  | Verde |
| 1159 | 2.3.12.4.2 | **Licitação da obra** |  | 80d | 2019-09-13 | 2020-01-10 |  |  |  | 2019-09-13 | 2020-01-10 | 80d |  |  | 897d |  | Verde | Verde | 0% |  |  | 0% |  | Verde | 0% |  | 0% |  |  |  |  |
| 1160 | 2.3.12.4.2.1 | Licitação da obra autorizada pelo banco | milestone | 0d | 2019-09-13 | 2019-09-13 | 1158FS+10d |  |  | 2019-09-13 | 2019-09-13 | 0d |  |  | 897d | 0d | Verde | Verde | 0% |  |  | 0% |  | Verde | 0% |  | 0% |  |  |  | Verde |
| 1161 | 2.3.12.4.2.2 | Licitar obra |  | 66d | 2019-09-16 | 2019-12-18 | 1160 |  |  | 2019-09-16 | 2019-12-18 | 66d | 2019-05-05 | 2019-09-02 | 897d | 0d | Verde | Verde | 0% |  |  | 0% |  | Verde | 0% |  | 0% |  | 02 - Execução | PG031 | Verde |
| 1162 | 2.3.12.4.2.3 | Analisar e emitir resultado da licitação da obra |  | 14d | 2019-12-19 | 2020-01-10 | 1161 |  |  | 2019-12-19 | 2020-01-10 | 14d |  |  | 897d | 0d | Verde | Verde | 0% |  |  | 0% |  | Verde | 0% |  | 0% |  |  |  | Verde |
| 1163 | 2.3.12.4.2.4 | Licitação da obra concluído | milestone | 0d | 2020-01-10 | 2020-01-10 | 1162 |  |  | 2020-01-10 | 2020-01-10 | 0d |  |  | 897d | 0d | Verde | Verde | 0% |  |  | 0% |  | Verde | 0% |  | 0% |  |  |  | Verde |
| 1164 | 2.3.12.4.3 | Executar obra |  | 248d | 2020-01-13 | 2021-01-11 | 1163 |  |  | 2020-01-13 | 2021-01-11 | 248d |  |  | 897d | 0d | Verde | Verde | 0% |  |  | 0% |  | Verde | 0% |  | 0% |  |  |  | Verde |
| 1165 | 2.3.12.4.4 | Realizar processo de pré-operação |  | 128d | 2021-01-12 | 2021-07-16 | 1164 |  |  | 2021-01-12 | 2021-07-16 | 128d | 2020-08-27 | 2021-02-23 | 897d | 0d | Verde | Verde | 0% |  |  | 0% |  | Verde | 0% |  | 0% |  | 02 - Execução | PG031 | Verde |
| 1166 | 2.3.12.4.5 | Recurso da obra parcelado repassado | milestone | 0d | 2021-07-16 | 2021-07-16 | 1165 |  |  | 2021-07-16 | 2021-07-16 | 0d |  |  | 897d | 0d | Verde | Verde | 0% |  |  | 0% |  | Verde | 0% |  | 0% |  |  |  | Verde |
| 1167 | 2.3.12.4.6 | Pleito a definir concluído | milestone | 0d | 2021-07-16 | 2021-07-16 | 1166 |  |  | 2021-07-16 | 2021-07-16 | 0d |  |  | 897d | 0d | Verde | Verde | 0% |  |  | 0% |  | Verde | 0% |  | 0% |  |  |  | Verde |
| 1168 | 2.3.12.5 | Recursos de Dionísio repassados | milestone | 0d | 2021-07-16 | 2021-07-16 | 1145, 1156, 1167, 1130 |  |  | 2021-07-16 | 2021-07-16 | 0d | 2019-06-04 | 2021-02-23 | 897d |  | Verde | Verde | 0% |  |  | 0% |  | Verde | 0% |  | 0% |  | 02 - Execução | PG 031 | Verde |
| 1169 | 2.3.13 | **Fernandes Tourinho** |  | 899d | 2018-06-15 A | 2022-01-17 |  | 16% | 757.22d | 2018-06-15 | 2022-01-17 | 899d | 2018-11-03 | 2021-03-02 | 771d |  | Verde | Verde | 24% | 16 | 24 | 0% |  | Vermelho | 1% |  | 0% |  |  |  |  |
| 1170 | 2.3.13.1 | **Pleito FETESPJ01 - Elaboração de projeto depara implantação da ETE do distrito de Senhora da Penha** |  | 428d | 2018-11-05 A | 2020-07-23 |  | 18% | 350.36d | 2018-11-05 | 2020-07-23 | 428d |  |  | 1141d |  | Verde | Verde | 28% | 18 | 28 | 0% |  | Vermelho | 6% |  | 0% |  |  |  |  |
| 1171 | 2.3.13.1.1 | **Licitação do Projeto** |  | 150d | 2018-11-05 A | 2019-06-11 |  | 83% | 24.83d | 2018-11-05 | 2019-06-11 | 150d |  |  | 771d |  | Verde | Verde | 80% | 83 | 80 | 0% |  | Vermelho | 46% | 46 | 0% |  |  |  |  |
| 1172 | 2.3.13.1.1.1 | Licitar Projeto |  | 131d | 2018-11-05 A | 2019-05-15 | 179FS+77d | 92% | 10d | 2018-11-05 | 2019-05-15 | 131d |  |  | 771d | 0d | Verde | Verde | 92% | 92 | 92 | 0% |  | Vermelho | 92% | 92 | 0% |  |  |  | Verde |
| 1173 | 2.3.13.1.1.2 | Documentação de licitação apresentado ao banco | milestone | 0d | 2019-05-22 | 2019-05-22 | 1172FS+5d |  |  | 2019-05-22 | 2019-05-22 | 0d |  |  | 771d | 0d | Verde | Verde | 0% |  |  | 0% |  | Verde | 0% |  | 0% |  |  |  | Verde |
| 1174 | 2.3.13.1.1.3 | Analisar e emitir resultado da licitação do projeto |  | 14d | 2019-05-23 | 2019-06-11 | 1173 |  |  | 2019-05-23 | 2019-06-11 | 14d |  |  | 771d | 0d | Verde | Verde | 0% |  |  | 0% |  | Verde | 0% |  | 0% |  |  |  | Verde |
| 1175 | 2.3.13.1.1.4 | Licitação do projeto concluída | milestone | 0d | 2019-06-11 | 2019-06-11 | 1174 |  |  | 2019-06-11 | 2019-06-11 | 0d |  |  | 771d | 0d | Verde | Verde | 0% |  |  | 0% |  | Verde | 0% |  | 0% |  |  |  | Verde |

Notes:
- 1148: Em 29/04/2019: atualizado como agendado
- 1155: 25/01/19 - Está aguardando confirmação do projetista para saber se será possível o aproveitamento das estruturas existentes. Caso afirmativo, esta área já está licenciada. Em relação aos distritos, estão aguardando a definição de localização da ETE / Em 29/04/2019: atualizado como agendado
- 1158: Em 17/04/2019: o pleito será enviado após apresentação do proj. executivo dia 02/05 e será aprovado pela CT/CIF até o dia 31/08 (NT33)
- 1168: Valor de recurso destinado ao munícipio: R$4.726.993,07
- 1169: Fernandes Tourinhos solicitou 78,2% (R$2.081.606,95) dos 90% de recursos destinado para Esgotamento Sanitário e teve todo o pleito aprovado, conforme Deliberação 75. / O município teve 0,8%, dos 10% do valor teto destinado a Resíduos Sólidos aprovado (R$20.903,52). / Munícipio vai solicitar mudança de pleito, solicitando projeto e obra de ampliação e melhoria da ETE da sede.
- 1172: 22/01/19 - O TR para projeto da sede foi concluído e estava aguardando a mudança de pleito para publicação do edital. no entanto o município decidiu prosseguir com a licitação do projeto da sede separadamente do distrito Ns Penha (aguardando mudança de pleito) / Em 29/04/2019: atualizado como agendado

| ID | WBS | Task | Type | Duration | Start | Finish | Predecessors | Baseline start | Baseline finish | Baseline duration | Total slack | Free slack | Farol de Atraso | Farol Marcos | % Previsto Tempo | Índice de Desempenho Físico (IDF) | Farol IDF | % Previsto Ponderado | % Concluído Ponderado | Farol de Início |
| --- | --- | --- | --- | --- | --- | --- | --- | --- | --- | --- | --- | --- | --- | --- | --- | --- | --- | --- | --- | --- |
| 1176 | 2.3.13.1.2 | **Elaboração do Projeto Básico** |  | 137d | 2019-06-12 | 2019-12-27 |  | 2019-06-12 | 2019-12-27 | 137d | 771d |  | Verde | Verde | 0% | 0% | Verde | 0% | 0% |  |
| 1177 | 2.3.13.1.2.1 | Elaborar Projeto Básico |  | 65d | 2019-06-12 | 2019-09-12 | 1175 | 2019-06-12 | 2019-09-12 | 65d | 771d | 0d | Verde | Verde | 0% | 0% | Verde | 0% | 0% | Verde |
| 1178 | 2.3.13.1.2.2 | Projeto básico apresentado ao banco | milestone | 0d | 2019-09-12 | 2019-09-12 | 1177 | 2019-09-12 | 2019-09-12 | 0d | 771d | 0d | Verde | Verde | 0% | 0% | Verde | 0% | 0% | Verde |
| 1179 | 2.3.13.1.2.3 | Analisar projeto básico |  | 22d | 2019-09-13 | 2019-10-14 | 1178 | 2019-09-13 | 2019-10-14 | 22d | 771d | 0d | Verde | Verde | 0% | 0% | Verde | 0% | 0% | Verde |
| 1180 | 2.3.13.1.2.4 | Adequar/revisar projeto básico |  | 23d | 2019-10-15 | 2019-11-14 | 1179 | 2019-10-15 | 2019-11-14 | 23d | 771d | 0d | Verde | Verde | 0% | 0% | Verde | 0% | 0% | Verde |
| 1181 | 2.3.13.1.2.5 | Analisar projeto básico - final |  | 22d | 2019-11-18 | 2019-12-18 | 1180 | 2019-11-18 | 2019-12-18 | 22d | 771d | 0d | Verde | Verde | 0% | 0% | Verde | 0% | 0% | Verde |
| 1182 | 2.3.13.1.2.6 | Projeto básico concluído | milestone | 0d | 2019-12-18 | 2019-12-18 | 1181 | 2019-12-18 | 2019-12-18 | 0d | 771d | 0d | Verde | Verde | 0% | 0% | Verde | 0% | 0% | Verde |
| 1183 | 2.3.13.1.2.7 | Recurso do projeto básico do pleito FETESPJ01 repassado | milestone | 0d | 2019-12-27 | 2019-12-27 | 1182FS+5d | 2019-12-27 | 2019-12-27 | 0d | 907d | 136d | Verde | Verde | 0% | 0% | Verde | 0% | 0% | Verde |
| 1184 | 2.3.13.1.3 | **Aquisição de Imóvel** |  | 140d | 2019-10-15 | 2020-05-12 |  | 2019-10-15 | 2020-05-12 | 140d | 817d |  | Verde | Verde | 0% | 0% | Verde | 0% | 0% |  |
| 1185 | 2.3.13.1.3.1 | Regularizar terreno e apresentar escritura ao banco |  | 85d | 2019-10-15 | 2020-02-17 | 1179 | 2019-10-15 | 2020-02-17 | 85d | 817d | 0d | Verde | Verde | 0% | 0% | Verde | 0% | 0% | Verde |
| 1186 | 2.3.13.1.3.2 | Analisar documentação do terreno |  | 10d | 2020-02-18 | 2020-03-05 | 1185 | 2020-02-18 | 2020-03-05 | 10d | 857d | 0d | Verde | Verde | 0% | 0% | Verde | 0% | 0% | Verde |
| 1187 | 2.3.13.1.3.3 | 50% do valor do imóvel repassado (1) | milestone | 0d | 2020-03-12 | 2020-03-12 | 1186FS+5d | 2020-03-12 | 2020-03-12 | 0d | 857d | 40d | Verde | Verde | 0% | 0% | Verde | 0% | 0% | Verde |
| 1188 | 2.3.13.1.3.4 | Registrar imóvel e apresentar documentação ao banco |  | 40d | 2020-02-18 | 2020-04-17 | 1185 | 2020-02-18 | 2020-04-17 | 40d | 817d | 0d | Verde | Verde | 0% | 0% | Verde | 0% | 0% | Verde |
| 1189 | 2.3.13.1.3.5 | Analisar documentação do terreno |  | 10d | 2020-04-20 | 2020-05-05 | 1188 | 2020-04-20 | 2020-05-05 | 10d | 817d | 0d | Verde | Verde | 0% | 0% | Verde | 0% | 0% | Verde |
| 1190 | 2.3.13.1.3.6 | 50% do valor do imóvel repassado (2) | milestone | 0d | 2020-05-12 | 2020-05-12 | 1189FS+5d | 2020-05-12 | 2020-05-12 | 0d | 817d | 0d | Verde | Verde | 0% | 0% | Verde | 0% | 0% | Verde |
| 1191 | 2.3.13.1.3.7 | Aquisição de imóvel concluída | milestone | 0d | 2020-05-12 | 2020-05-12 | 1187, 1190 | 2020-05-12 | 2020-05-12 | 0d | 817d | 46d | Verde | Verde | 0% | 0% | Verde | 0% | 0% | Verde |
| 1192 | 2.3.13.1.4 | Realizar Licenciamento Ambiental |  | 104d | 2019-09-13 | 2020-02-12 | 1178 | 2019-09-13 | 2020-02-12 | 104d | 875d | 104d | Verde | Verde | 0% | 0% | Verde | 0% | 0% | Verde |
| 1193 | 2.3.13.1.5 | **Elaboração do Projeto Executivo** |  | 146d | 2019-12-19 | 2020-07-23 |  | 2019-12-19 | 2020-07-23 | 146d | 771d |  | Verde | Verde | 0% | 0% | Verde | 0% | 0% |  |
| 1194 | 2.3.13.1.5.1 | Elaborar Projeto Executivo |  | 76d | 2019-12-19 | 2020-04-13 | 1182 | 2019-12-19 | 2020-04-13 | 76d | 771d | 0d | Verde | Verde | 0% | 0% | Verde | 0% | 0% | Verde |
| 1195 | 2.3.13.1.5.2 | Projeto executivo apresentado ao banco | milestone | 0d | 2020-04-13 | 2020-04-13 | 1194 | 2020-04-13 | 2020-04-13 | 0d | 771d | 0d | Verde | Verde | 0% | 0% | Verde | 0% | 0% | Verde |
| 1196 | 2.3.13.1.5.3 | Analisar projeto executivo |  | 21d | 2020-04-14 | 2020-05-14 | 1195 | 2020-04-14 | 2020-05-14 | 21d | 771d | 0d | Verde | Verde | 0% | 0% | Verde | 0% | 0% | Verde |
| 1197 | 2.3.13.1.5.4 | Adequar/revisar projeto executivo |  | 21d | 2020-05-15 | 2020-06-15 | 1196 | 2020-05-15 | 2020-06-15 | 21d | 771d | 0d | Verde | Verde | 0% | 0% | Verde | 0% | 0% | Verde |
| 1198 | 2.3.13.1.5.5 | Analisar projeto executivo - final |  | 23d | 2020-06-16 | 2020-07-16 | 1197 | 2020-06-16 | 2020-07-16 | 23d | 771d | 0d | Verde | Verde | 0% | 0% | Verde | 0% | 0% | Verde |
| 1199 | 2.3.13.1.5.6 | Projeto executivo concluído | milestone | 0d | 2020-07-16 | 2020-07-16 | 1198, 1191, 1192, 1183 | 2020-07-16 | 2020-07-16 | 0d | 771d | 0d | Verde | Verde | 0% | 0% | Verde | 0% | 0% | Verde |
| 1200 | 2.3.13.1.5.7 | Recurso do projeto executivo do pleito FETESPJ01 repassado | milestone | 0d | 2020-07-23 | 2020-07-23 | 1199FS+5d | 2020-07-23 | 2020-07-23 | 0d | 1141d | 0d | Verde | Verde | 0% | 0% | Verde | 0% | 0% | Verde |
| 1201 | 2.3.13.1.6 | Pleito FETESPJ01 concluído | milestone | 0d | 2020-07-23 | 2020-07-23 | 1200 | 2020-07-23 | 2020-07-23 | 0d | 1141d | 370d | Verde | Verde | 0% | 0% | Verde | 0% | 0% | Verde |

| ID | WBS | Task | Type | Duration | Start | Finish | Predecessors | Complete | Remaining | Baseline start | Baseline finish | Baseline duration | Total slack | Free slack | Farol de Atraso | Farol Marcos | % Previsto Tempo | Índice de Desempenho Físico (IDF) | Farol IDF | % Previsto Ponderado | % Concluído Ponderado | Farol de Início | % Concluída Numérico | % Previsto Tempo Numérico | % Previsto Ponderado Numérico |
| --- | --- | --- | --- | --- | --- | --- | --- | --- | --- | --- | --- | --- | --- | --- | --- | --- | --- | --- | --- | --- | --- | --- | --- | --- | --- |
| 1202 | 2.3.13.2 | **Pleito FETESOB02 - Contratação de empresa para obra de construção de ETE e revitalização na rede coletora de esgotos existente e construção de ramais secundários no distrito de Senhora da Penha.** |  | 375d | 2020-07-16 | 2022-01-17 |  |  |  | 2020-07-16 | 2022-01-17 | 375d | 771d |  | Verde | Verde | 0% | 0% | Verde | 0% | 0% |  |  |  |  |
| 1203 | 2.3.13.2.1 | **Licitação da obra** |  | 58d | 2020-07-16 | 2020-10-07 |  |  |  | 2020-07-16 | 2020-10-07 | 58d | 771d |  | Verde | Verde | 0% | 0% | Verde | 0% | 0% |  |  |  |  |
| 1204 | 2.3.13.2.1.1 | Licitação da obra autorizada pelo banco | milestone | 0d | 2020-07-16 | 2020-07-16 | 1199 |  |  | 2020-07-16 | 2020-07-16 | 0d | 771d | 0d | Verde | Verde | 0% | 0% | Verde | 0% | 0% | Verde |  |  |  |
| 1205 | 2.3.13.2.1.2 | Licitar obra |  | 44d | 2020-07-17 | 2020-09-17 | 1204 |  |  | 2020-07-17 | 2020-09-17 | 44d | 771d | 0d | Verde | Verde | 0% | 0% | Verde | 0% | 0% | Verde |  |  |  |
| 1206 | 2.3.13.2.1.3 | Analisar e emitir resultado da licitação da obra |  | 14d | 2020-09-18 | 2020-10-07 | 1205 |  |  | 2020-09-18 | 2020-10-07 | 14d | 771d | 0d | Verde | Verde | 0% | 0% | Verde | 0% | 0% | Verde |  |  |  |
| 1207 | 2.3.13.2.1.4 | Licitação da obra concluída | milestone | 0d | 2020-10-07 | 2020-10-07 | 1206 |  |  | 2020-10-07 | 2020-10-07 | 0d | 771d | 0d | Verde | Verde | 0% | 0% | Verde | 0% | 0% | Verde |  |  |  |
| 1208 | 2.3.13.2.2 | Executar obra |  | 164d | 2020-11-09 | 2021-07-07 | 1207FS+20d |  |  | 2020-11-09 | 2021-07-07 | 164d | 771d | 0d | Verde | Verde | 0% | 0% | Verde | 0% | 0% | Verde |  |  |  |
| 1209 | 2.3.13.2.3 | Realizar processo de pré-operação |  | 128d | 2021-07-08 | 2022-01-10 | 1208 |  |  | 2021-07-08 | 2022-01-10 | 128d | 771d | 0d | Verde | Verde | 0% | 0% | Verde | 0% | 0% | Verde |  |  |  |
| 1210 | 2.3.13.2.4 | Recurso da obra parcelado repassado | milestone | 0d | 2022-01-17 | 2022-01-17 | 1209FS+5d |  |  | 2022-01-17 | 2022-01-17 | 0d | 771d | 0d | Verde | Verde | 0% | 0% | Verde | 0% | 0% | Verde |  |  |  |
| 1211 | 2.3.13.2.5 | Pleito FETESOB02 concluído | milestone | 0d | 2022-01-17 | 2022-01-17 | 1210 |  |  | 2022-01-17 | 2022-01-17 | 0d | 771d | 0d | Verde | Verde | 0% | 0% | Verde | 0% | 0% | Verde |  |  |  |
| 1212 | 2.3.13.3 | **Pleito FETESPJ02 - Adequação de projeto de sistema de esgotamento sanitário da sede do município** |  | 428d | 2018-11-05 A | 2020-07-23 |  | 23% | 328.79d | 2018-11-05 | 2020-07-23 | 428d | 1141d |  | Verde | Verde | 28% | 0% | Vermelho | 8% | 0% |  | 23 | 28 |  |
| 1213 | 2.3.13.3.1 | **Licitação do Projeto** |  | 150d | 2018-11-05 A | 2019-06-11 |  | 83% | 24.83d | 2018-11-05 | 2019-06-11 | 150d | 771d |  | Verde | Verde | 80% | 0% | Vermelho | 46% | 0% |  | 83 | 80 | 46 |
| 1214 | 2.3.13.3.1.1 | Licitar projeto |  | 131d | 2018-11-05 A | 2019-05-15 | 179FS+77d | 92% | 10d | 2018-11-05 | 2019-05-15 | 131d | 771d | 0d | Verde | Verde | 92% | 0% | Vermelho | 92% | 0% | Verde | 92 | 92 | 92 |
| 1215 | 2.3.13.3.1.2 | Documentação de licitação apresentado ao banco | milestone | 0d | 2019-05-22 | 2019-05-22 | 1214FS+5d |  |  | 2019-05-22 | 2019-05-22 | 0d | 771d | 0d | Verde | Verde | 0% | 0% | Verde | 0% | 0% | Verde |  |  |  |
| 1216 | 2.3.13.3.1.3 | Analisar e emitir resultado da licitação do projeto |  | 14d | 2019-05-23 | 2019-06-11 | 1215 |  |  | 2019-05-23 | 2019-06-11 | 14d | 771d | 0d | Verde | Verde | 0% | 0% | Verde | 0% | 0% | Verde |  |  |  |
| 1217 | 2.3.13.3.1.4 | Licitação do projeto concluída | milestone | 0d | 2019-06-11 | 2019-06-11 | 1216 |  |  | 2019-06-11 | 2019-06-11 | 0d | 771d | 0d | Verde | Verde | 0% | 0% | Verde | 0% | 0% | Verde |  |  |  |
| 1218 | 2.3.13.3.2 | **Elaboração do Projeto Básico** |  | 137d | 2019-06-12 | 2019-12-27 |  |  |  | 2019-06-12 | 2019-12-27 | 137d | 771d |  | Verde | Verde | 0% | 0% | Verde | 0% | 0% |  |  |  |  |
| 1219 | 2.3.13.3.2.1 | Elaborar Projeto Básico |  | 65d | 2019-06-12 | 2019-09-12 | 1217 |  |  | 2019-06-12 | 2019-09-12 | 65d | 771d | 0d | Verde | Verde | 0% | 0% | Verde | 0% | 0% | Verde |  |  |  |
| 1220 | 2.3.13.3.2.2 | Projeto básico apresentado ao banco | milestone | 0d | 2019-09-12 | 2019-09-12 | 1219 |  |  | 2019-09-12 | 2019-09-12 | 0d | 771d | 0d | Verde | Verde | 0% | 0% | Verde | 0% | 0% | Verde |  |  |  |
| 1221 | 2.3.13.3.2.3 | Analisar projeto básico |  | 22d | 2019-09-13 | 2019-10-14 | 1220 |  |  | 2019-09-13 | 2019-10-14 | 22d | 771d | 0d | Verde | Verde | 0% | 0% | Verde | 0% | 0% | Verde |  |  |  |
| 1222 | 2.3.13.3.2.4 | Adequar/revisar projeto básico |  | 23d | 2019-10-15 | 2019-11-14 | 1221 |  |  | 2019-10-15 | 2019-11-14 | 23d | 771d | 0d | Verde | Verde | 0% | 0% | Verde | 0% | 0% | Verde |  |  |  |
| 1223 | 2.3.13.3.2.5 | Analisar projeto básico - final |  | 22d | 2019-11-18 | 2019-12-18 | 1222 |  |  | 2019-11-18 | 2019-12-18 | 22d | 771d | 0d | Verde | Verde | 0% | 0% | Verde | 0% | 0% | Verde |  |  |  |
| 1224 | 2.3.13.3.2.6 | Projeto básico concluído | milestone | 0d | 2019-12-18 | 2019-12-18 | 1223 |  |  | 2019-12-18 | 2019-12-18 | 0d | 771d | 0d | Verde | Verde | 0% | 0% | Verde | 0% | 0% | Verde |  |  |  |
| 1225 | 2.3.13.3.2.7 | Recurso do projeto básico do pleito FETESPJ02 repassado | milestone | 0d | 2019-12-27 | 2019-12-27 | 1224FS+5d |  |  | 2019-12-27 | 2019-12-27 | 0d | 907d | 136d | Verde | Verde | 0% | 0% | Verde | 0% | 0% | Verde |  |  |  |
| 1226 | 2.3.13.3.3 | Realizar Licenciamento Ambiental |  | 104d | 2019-09-13 | 2020-02-12 | 1220 |  |  | 2019-09-13 | 2020-02-12 | 104d | 875d | 104d | Verde | Verde | 0% | 0% | Verde | 0% | 0% | Verde |  |  |  |

Notes:
- 1214: Em 29/04/2019: atualizado como agendado

| ID | WBS | Task | Type | Duration | Start | Finish | Predecessors | Baseline start | Baseline finish | Baseline duration | Baseline 1 start | Baseline 1 finish | Total slack | Free slack | Farol de Atraso | Farol Marcos | % Previsto Tempo | Índice de Desempenho Físico (IDF) | Farol IDF | % Previsto Ponderado | % Concluído Ponderado | Farol de Início | Responsável | Código do Contrato |
| --- | --- | --- | --- | --- | --- | --- | --- | --- | --- | --- | --- | --- | --- | --- | --- | --- | --- | --- | --- | --- | --- | --- | --- | --- |
| 1227 | 2.3.13.3.4 | **Elaboração do Projeto Executivo** |  | 146d | 2019-12-19 | 2020-07-23 |  | 2019-12-19 | 2020-07-23 | 146d |  |  | 771d |  | Verde | Verde | 0% | 0% | Verde | 0% | 0% |  |  |  |
| 1228 | 2.3.13.3.4.1 | Elaborar Projeto Executivo |  | 76d | 2019-12-19 | 2020-04-13 | 1224 | 2019-12-19 | 2020-04-13 | 76d |  |  | 771d | 0d | Verde | Verde | 0% | 0% | Verde | 0% | 0% | Verde |  |  |
| 1229 | 2.3.13.3.4.2 | Projeto executivo apresentado ao banco | milestone | 0d | 2020-04-13 | 2020-04-13 | 1228 | 2020-04-13 | 2020-04-13 | 0d |  |  | 771d | 0d | Verde | Verde | 0% | 0% | Verde | 0% | 0% | Verde |  |  |
| 1230 | 2.3.13.3.4.3 | Analisar projeto executivo |  | 21d | 2020-04-14 | 2020-05-14 | 1229 | 2020-04-14 | 2020-05-14 | 21d |  |  | 771d | 0d | Verde | Verde | 0% | 0% | Verde | 0% | 0% | Verde |  |  |
| 1231 | 2.3.13.3.4.4 | Adequar/revisar projeto executivo |  | 21d | 2020-05-15 | 2020-06-15 | 1230 | 2020-05-15 | 2020-06-15 | 21d |  |  | 771d | 0d | Verde | Verde | 0% | 0% | Verde | 0% | 0% | Verde |  |  |
| 1232 | 2.3.13.3.4.5 | Analisar projeto executivo - final |  | 23d | 2020-06-16 | 2020-07-16 | 1231 | 2020-06-16 | 2020-07-16 | 23d |  |  | 771d | 0d | Verde | Verde | 0% | 0% | Verde | 0% | 0% | Verde |  |  |
| 1233 | 2.3.13.3.4.6 | Projeto executivo concluído | milestone | 0d | 2020-07-16 | 2020-07-16 | 1232, 1226, 1225 | 2020-07-16 | 2020-07-16 | 0d |  |  | 771d | 0d | Verde | Verde | 0% | 0% | Verde | 0% | 0% | Verde |  |  |
| 1234 | 2.3.13.3.4.7 | Recurso do projeto executivo do pleito FETESPJ02 repassado | milestone | 0d | 2020-07-23 | 2020-07-23 | 1233FS+5d | 2020-07-23 | 2020-07-23 | 0d |  |  | 1141d | 0d | Verde | Verde | 0% | 0% | Verde | 0% | 0% | Verde |  |  |
| 1235 | 2.3.13.3.5 | Pleito FETESPJ02 concluído | milestone | 0d | 2020-07-23 | 2020-07-23 | 1234 | 2020-07-23 | 2020-07-23 | 0d |  |  | 1141d | 370d | Verde | Verde | 0% | 0% | Verde | 0% | 0% | Verde |  |  |
| 1236 | 2.3.13.4 | **Pleito FETESOB01 - Obras de adequação e complementação da rede coletora da sede.** |  | 375d | 2020-07-16 | 2022-01-17 |  | 2020-07-16 | 2022-01-17 | 375d |  |  | 771d |  | Verde | Verde | 0% | 0% | Verde | 0% | 0% |  |  |  |
| 1237 | 2.3.13.4.1 | **Licitação da obra** |  | 58d | 2020-07-16 | 2020-10-07 |  | 2020-07-16 | 2020-10-07 | 58d |  |  | 771d |  | Verde | Verde | 0% | 0% | Verde | 0% | 0% |  |  |  |
| 1238 | 2.3.13.4.1.1 | Licitação da obra autorizada pelo banco | milestone | 0d | 2020-07-16 | 2020-07-16 | 1233 | 2020-07-16 | 2020-07-16 | 0d |  |  | 771d | 0d | Verde | Verde | 0% | 0% | Verde | 0% | 0% | Verde |  |  |
| 1239 | 2.3.13.4.1.2 | Licitar obra |  | 44d | 2020-07-17 | 2020-09-17 | 1238 | 2020-07-17 | 2020-09-17 | 44d | 2019-08-30 | 2019-12-28 | 771d | 0d | Verde | Verde | 0% | 0% | Verde | 0% | 0% | Verde | 02 - Execução | PG 031 |
| 1240 | 2.3.13.4.1.3 | Analisar e emitir resultado da licitação da obra |  | 14d | 2020-09-18 | 2020-10-07 | 1239 | 2020-09-18 | 2020-10-07 | 14d |  |  | 771d | 0d | Verde | Verde | 0% | 0% | Verde | 0% | 0% | Verde |  |  |
| 1241 | 2.3.13.4.1.4 | Licitação da obra concluída | milestone | 0d | 2020-10-07 | 2020-10-07 | 1240 | 2020-10-07 | 2020-10-07 | 0d |  |  | 771d | 0d | Verde | Verde | 0% | 0% | Verde | 0% | 0% | Verde |  |  |
| 1242 | 2.3.13.4.2 | Executar obra |  | 164d | 2020-11-09 | 2021-07-07 | 1241FS+20d | 2020-11-09 | 2021-07-07 | 164d |  |  | 771d | 0d | Verde | Verde | 0% | 0% | Verde | 0% | 0% | Verde |  |  |
| 1243 | 2.3.13.4.3 | Realizar processo de pré-operação |  | 128d | 2021-07-08 | 2022-01-10 | 1242 | 2021-07-08 | 2022-01-10 | 128d | 2020-07-05 | 2021-03-02 | 771d | 0d | Verde | Verde | 0% | 0% | Verde | 0% | 0% | Verde | 02 - Execução | PG 031 |
| 1244 | 2.3.13.4.4 | Recurso da obra parcelado repassado | milestone | 0d | 2022-01-17 | 2022-01-17 | 1243FS+5d | 2022-01-17 | 2022-01-17 | 0d |  |  | 771d | 0d | Verde | Verde | 0% | 0% | Verde | 0% | 0% | Verde |  |  |
| 1245 | 2.3.13.4.5 | Pleito FETESOB01 concluído | milestone | 0d | 2022-01-17 | 2022-01-17 | 1244 | 2022-01-17 | 2022-01-17 | 0d |  |  | 771d | 0d | Verde | Verde | 0% | 0% | Verde | 0% | 0% | Verde |  |  |
| 1246 | 2.3.13.5 | **Pleito de Fernandes Tourinho a definir - Obra de reforma da ETE da sede do município** |  | 362d | 2019-05-31 | 2020-11-12 |  | 2019-05-31 | 2020-11-12 | 362d |  |  | 1064d |  | Verde | Verde | 0% | 0% | Verde | 0% | 0% |  |  |  |
| 1247 | 2.3.13.5.1 | Pleito aprovado | milestone | 0d | 2019-05-31 | 2019-05-31 | 206FS+115d | 2019-05-31 | 2019-05-31 | 0d |  |  | 1064d | 0d | Verde | Verde | 0% | 0% | Verde | 0% | 0% | Verde |  |  |
| 1248 | 2.3.13.5.2 | **Licitação da obra** |  | 79d | 2019-06-14 | 2019-10-07 |  | 2019-06-14 | 2019-10-07 | 79d |  |  | 1064d |  | Verde | Verde | 0% | 0% | Verde | 0% | 0% |  |  |  |
| 1249 | 2.3.13.5.2.1 | Licitação da obra autorizada pelo banco | milestone | 0d | 2019-06-14 | 2019-06-14 | 1247FS+10d | 2019-06-14 | 2019-06-14 | 0d |  |  | 1064d | 0d | Verde | Verde | 0% | 0% | Verde | 0% | 0% | Verde |  |  |
| 1250 | 2.3.13.5.2.2 | Licitar obra |  | 65d | 2019-06-17 | 2019-09-17 | 1249 | 2019-06-17 | 2019-09-17 | 65d |  |  | 1064d | 0d | Verde | Verde | 0% | 0% | Verde | 0% | 0% | Verde |  |  |
| 1251 | 2.3.13.5.2.3 | Analisar e emitir resultado da licitação da obra |  | 14d | 2019-09-18 | 2019-10-07 | 1250 | 2019-09-18 | 2019-10-07 | 14d |  |  | 1064d | 0d | Verde | Verde | 0% | 0% | Verde | 0% | 0% | Verde |  |  |
| 1252 | 2.3.13.5.2.4 | Licitação da obra concluída | milestone | 0d | 2019-10-07 | 2019-10-07 | 1251 | 2019-10-07 | 2019-10-07 | 0d |  |  | 1064d | 0d | Verde | Verde | 0% | 0% | Verde | 0% | 0% | Verde |  |  |
| 1253 | 2.3.13.5.3 | Executar obra |  | 120d | 2019-11-05 | 2020-05-05 | 1252FS+20d | 2019-11-05 | 2020-05-05 | 120d |  |  | 1064d | 0d | Verde | Verde | 0% | 0% | Verde | 0% | 0% | Verde |  |  |
| 1254 | 2.3.13.5.4 | Realizar processo de pré-operação |  | 128d | 2020-05-06 | 2020-11-05 | 1253 | 2020-05-06 | 2020-11-05 | 128d |  |  | 1064d | 0d | Verde | Verde | 0% | 0% | Verde | 0% | 0% | Verde |  |  |
| 1255 | 2.3.13.5.5 | Recurso da obra parcelado repassado | milestone | 0d | 2020-11-12 | 2020-11-12 | 1254FS+5d | 2020-11-12 | 2020-11-12 | 0d |  |  | 1064d | 0d | Verde | Verde | 0% | 0% | Verde | 0% | 0% | Verde |  |  |
| 1256 | 2.3.13.5.6 | Pleito a definir concluído | milestone | 0d | 2020-11-12 | 2020-11-12 | 1255 | 2020-11-12 | 2020-11-12 | 0d |  |  | 1064d | 293d | Verde | Verde | 0% | 0% | Verde | 0% | 0% | Verde |  |  |

| ID | WBS | Task | Type | Duration | Start | Finish | Predecessors | Complete | Remaining | Baseline start | Baseline finish | Baseline duration | Baseline 1 start | Baseline 1 finish | Total slack | Free slack | Farol de Atraso | Farol Marcos | % Previsto Tempo | % Concluída Numérico | % Previsto Tempo Numérico | Índice de Desempenho Físico (IDF) | IDF Numérico | Farol IDF | % Previsto Ponderado | % Concluído Ponderado | % Previsto Ponderado Numérico | % Concluído Ponderado Numérico | Farol de Início | Responsável | Código do Contrato |
| --- | --- | --- | --- | --- | --- | --- | --- | --- | --- | --- | --- | --- | --- | --- | --- | --- | --- | --- | --- | --- | --- | --- | --- | --- | --- | --- | --- | --- | --- | --- | --- |
| 1257 | 2.3.13.6 | **Pleito FETRSPM01 - Elaboração de estudos de viabilidade para concepção dos serviços de infraestrutura de sistemas integrados de destinação final de resíduos sólidos urbanos, assim como educação ambiental e programas de coleta seletiva** |  | 437d | 2018-06-15 A | 2020-03-11 |  | 45% | 241.47d | 2018-06-15 | 2020-03-11 | 437d |  |  | 1233d |  | Verde | Verde | 50% | 45 | 50 | 67% | 67 | Vermelho | 6% | 4% |  |  |  |  |  |
| 1258 | 2.3.13.6.1 | **Licitação de Empresa para Estudo de Viabilidade** |  | 283d | 2018-06-15 A | 2019-07-26 |  | 75% | 71.39d | 2018-06-15 | 2019-07-26 | 283d |  |  | 1233d |  | Verde | Verde | 78% | 75 | 78 | 62% | 62 | Vermelho | 53% | 33% | 53 | 33 |  |  |  |
| 1259 | 2.3.13.6.1.1 | Licitação da empresa para Estudo de Viabilidade autorizada pelo banco | milestone | 0d | 2018-06-15 A | 2018-06-15 A | 313 | 100% |  | 2018-06-15 | 2018-06-15 | 0d |  |  |  |  | Verde | Verde | 100% | 100 | 100 | 0% |  | Vermelho | 100% | 0% | 100 |  | Verde |  |  |
| 1260 | 2.3.13.6.1.2 | Licitar empresa para Estudo de Viabilidade |  | 208d | 2018-09-03 A | 2019-07-01 | 1259FS+56d | 80% | 42d | 2018-09-03 | 2019-07-01 | 208d |  |  | 1233d | 0d | Verde | Verde | 79% | 80 | 79 | 63% | 63 | Vermelho | 79% | 50% | 79 | 50 | Verde |  |  |
| 1261 | 2.3.13.6.1.3 | Documentação de licitação apresentada ao banco | milestone | 0d | 2019-07-08 | 2019-07-08 | 1260FS+5d |  |  | 2019-07-08 | 2019-07-08 | 0d |  |  | 1233d | 0d | Verde | Verde | 0% |  |  | 0% |  | Verde | 0% | 0% |  |  | Verde |  |  |
| 1262 | 2.3.13.6.1.4 | Analisar e emitir resultado da licitação da empresa para Estudo de Viabilidade |  | 14d | 2019-07-09 | 2019-07-26 | 1261 |  |  | 2019-07-09 | 2019-07-26 | 14d |  |  | 1233d | 0d | Verde | Verde | 0% |  |  | 0% |  | Verde | 0% | 0% |  |  | Verde |  |  |
| 1263 | 2.3.13.6.1.5 | Licitação da empresa para Estudo de Viabilidade concluída | milestone | 0d | 2019-07-26 | 2019-07-26 | 1262 |  |  | 2019-07-26 | 2019-07-26 | 0d |  |  | 1233d | 0d | Verde | Verde | 0% |  |  | 0% |  | Verde | 0% | 0% |  |  | Verde |  |  |
| 1264 | 2.3.13.6.2 | **Elaboração do estudo de viabilidade** |  | 149d | 2019-07-29 | 2020-03-04 |  |  |  | 2019-07-29 | 2020-03-04 | 149d |  |  | 1233d |  | Verde | Verde | 0% |  |  | 0% |  | Verde | 0% | 0% |  |  |  |  |  |
| 1265 | 2.3.13.6.2.1 | Elaborar estudo de viabilidade |  | 88d | 2019-07-29 | 2019-11-29 | 1263 |  |  | 2019-07-29 | 2019-11-29 | 88d |  |  | 1233d | 0d | Verde | Verde | 0% |  |  | 0% |  | Verde | 0% | 0% |  |  | Verde |  |  |
| 1266 | 2.3.13.6.2.2 | Analisar estudo |  | 20d | 2019-12-02 | 2020-01-02 | 1265 |  |  | 2019-12-02 | 2020-01-02 | 20d |  |  | 1233d | 0d | Verde | Verde | 0% |  |  | 0% |  | Verde | 0% | 0% |  |  | Verde |  |  |
| 1267 | 2.3.13.6.2.3 | Adequar/revisar estudo |  | 22d | 2020-01-03 | 2020-02-03 | 1266 |  |  | 2020-01-03 | 2020-02-03 | 22d |  |  | 1233d | 0d | Verde | Verde | 0% |  |  | 0% |  | Verde | 0% | 0% |  |  | Verde |  |  |
| 1268 | 2.3.13.6.2.4 | Analisar estudo - final |  | 19d | 2020-02-04 | 2020-03-04 | 1267 |  |  | 2020-02-04 | 2020-03-04 | 19d |  |  | 1233d | 0d | Verde | Verde | 0% |  |  | 0% |  | Verde | 0% | 0% |  |  | Verde |  |  |
| 1269 | 2.3.13.6.2.5 | Estudo concluído | milestone | 0d | 2020-03-04 | 2020-03-04 | 1268 |  |  | 2020-03-04 | 2020-03-04 | 0d |  |  | 1233d | 0d | Verde | Verde | 0% |  |  | 0% |  | Verde | 0% | 0% |  |  | Verde |  |  |
| 1270 | 2.3.13.6.3 | Recurso do serviço repassado | milestone | 0d | 2020-03-11 | 2020-03-11 | 1269FS+5d |  |  | 2020-03-11 | 2020-03-11 | 0d |  |  | 1233d | 0d | Verde | Verde | 0% |  |  | 0% |  | Verde | 0% | 0% |  |  | Verde |  |  |
| 1271 | 2.3.13.6.4 | Pleito FETRSPM01 concluído | milestone | 0d | 2020-03-11 | 2020-03-11 | 1270 |  |  | 2020-03-11 | 2020-03-11 | 0d |  |  | 1233d | 462d | Verde | Verde | 0% |  |  | 0% |  | Verde | 0% | 0% |  |  | Verde |  |  |
| 1272 | 2.3.13.7 | Recursos de Fernandes Tourinho repassados | milestone | 0d | 2022-01-17 | 2022-01-17 | 1271, 1256, 1245, 1235, 1211, 1201 |  |  | 2022-01-17 | 2022-01-17 | 0d | 2019-06-01 | 2021-03-01 | 771d |  | Verde | Verde | 0% |  |  | 0% |  | Verde | 0% | 0% |  |  | Verde | 02 - Execução | PG 031 |
| 1273 | 2.3.14 | **Galiléia** |  | 925d | 2018-06-15 A | 2022-02-22 |  | 12% | 818.37d | 2018-06-15 | 2022-02-22 | 925d | 2018-10-23 | 2021-07-27 | 745d |  | Verde | Verde | 24% | 12 | 24 | 0% |  | Vermelho | 1% | 0% |  |  |  |  |  |
| 1274 | 2.3.14.1 | **Pleito GALESPJ01 - Elaboração de projetos de sistema de esgotamento sanitário da sede do município.** |  | 320d | 2018-12-04 | 2020-03-18 |  |  |  | 2018-12-04 | 2020-03-18 | 320d |  |  | 745d |  | Verde | Verde | 31% |  | 31 | 0% |  | Vermelho | 3% | 0% |  |  |  |  |  |
| 1275 | 2.3.14.1.1 | **Licitação do Projeto** |  | 121d | 2018-12-04 | 2019-05-30 |  |  |  | 2018-12-04 | 2019-05-30 | 121d |  |  | 745d |  | Verde | Verde | 82% |  | 82 | 0% |  | Vermelho | 49% | 0% | 49 |  |  |  |  |
| 1276 | 2.3.14.1.1.1 | Licitar Projeto |  | 102d | 2018-12-04 | 2019-05-03 | 206FS-7d |  |  | 2018-12-04 | 2019-05-03 | 102d |  |  | 745d | 0d | Verde | Verde | 98% |  | 98 | 0% |  | Vermelho | 98% | 0% | 98 |  | Verde |  |  |
| 1277 | 2.3.14.1.1.2 | Documentação de licitação apresentada ao banco | milestone | 0d | 2019-05-10 | 2019-05-10 | 1276FS+5d |  |  | 2019-05-10 | 2019-05-10 | 0d |  |  | 745d | 0d | Verde | Verde | 0% |  |  | 0% |  | Verde | 0% | 0% |  |  | Verde |  |  |
| 1278 | 2.3.14.1.1.3 | Analisar e emitir resultado da licitação do projeto |  | 14d | 2019-05-13 | 2019-05-30 | 1277 |  |  | 2019-05-13 | 2019-05-30 | 14d |  |  | 745d | 0d | Verde | Verde | 0% |  |  | 0% |  | Verde | 0% | 0% |  |  | Verde |  |  |
| 1279 | 2.3.14.1.1.4 | Licitação do projeto concluída | milestone | 0d | 2019-05-30 | 2019-05-30 | 1278 |  |  | 2019-05-30 | 2019-05-30 | 0d |  |  | 745d | 0d | Verde | Verde | 0% |  |  | 0% |  | Verde | 0% | 0% |  |  | Verde |  |  |
| 1280 | 2.3.14.1.2 | **Elaboração do Projeto Básico** |  | 138d | 2019-05-31 | 2019-12-16 |  |  |  | 2019-05-31 | 2019-12-16 | 138d |  |  | 745d |  | Verde | Verde | 0% |  |  | 0% |  | Verde | 0% | 0% |  |  |  |  |  |
| 1281 | 2.3.14.1.2.1 | Elaborar Projeto Básico |  | 65d | 2019-05-31 | 2019-09-02 | 1279 |  |  | 2019-05-31 | 2019-09-02 | 65d | 2019-03-03 | 2019-06-01 | 745d | 0d | Verde | Verde | 0% |  |  | 0% |  | Verde | 0% | 0% |  |  | Verde | 02 - Execução | PG 031 |
| 1282 | 2.3.14.1.2.2 | Projeto básico apresentado ao banco | milestone | 0d | 2019-09-02 | 2019-09-02 | 1281 |  |  | 2019-09-02 | 2019-09-02 | 0d |  |  | 745d | 0d | Verde | Verde | 0% |  |  | 0% |  | Verde | 0% | 0% |  |  | Verde |  |  |
| 1283 | 2.3.14.1.2.3 | Analisar projeto básico |  | 22d | 2019-09-03 | 2019-10-02 | 1282 |  |  | 2019-09-03 | 2019-10-02 | 22d |  |  | 745d | 0d | Verde | Verde | 0% |  |  | 0% |  | Verde | 0% | 0% |  |  | Verde |  |  |
| 1284 | 2.3.14.1.2.4 | Adequar/revisar projeto básico |  | 24d | 2019-10-03 | 2019-11-05 | 1283 |  |  | 2019-10-03 | 2019-11-05 | 24d |  |  | 825d | 0d | Verde | Verde | 0% |  |  | 0% |  | Verde | 0% | 0% |  |  | Verde |  |  |
| 1285 | 2.3.14.1.2.5 | Analisar projeto básico - final |  | 22d | 2019-11-06 | 2019-12-06 | 1284 |  |  | 2019-11-06 | 2019-12-06 | 22d |  |  | 825d | 0d | Verde | Verde | 0% |  |  | 0% |  | Verde | 0% | 0% |  |  | Verde |  |  |
| 1286 | 2.3.14.1.2.6 | Projeto básico concluído | milestone | 0d | 2019-12-06 | 2019-12-06 | 1285 |  |  | 2019-12-06 | 2019-12-06 | 0d |  |  | 825d | 0d | Verde | Verde | 0% |  |  | 0% |  | Verde | 0% | 0% |  |  | Verde |  |  |
| 1287 | 2.3.14.1.2.7 | Recurso do projeto básico do pleito GALESPJ01 repassado | milestone | 0d | 2019-12-16 | 2019-12-16 | 1286FS+5d |  |  | 2019-12-16 | 2019-12-16 | 0d |  |  | 825d | 56d | Verde | Verde | 0% |  |  | 0% |  | Verde | 0% | 0% |  |  | Verde |  |  |
| 1288 | 2.3.14.1.3 | Realizar Licenciamento Ambiental |  | 129d | 2019-09-03 | 2020-03-11 | 1282 |  |  | 2019-09-03 | 2020-03-11 | 129d | 2019-06-01 | 2019-11-28 | 769d | 0d | Verde | Verde | 0% |  |  | 0% |  | Verde | 0% | 0% |  |  | Verde | 02 - Execução | PG 031 |

Notes:
- 1260: Em 29/04/2019: atualizado como agendado
- 1272: Valor de recurso destinado ao munícipio: R$2.661.115,58
- 1273: Galileia pediu 89,4% (R$4.226.993,07) dos 90% de recursos destinado para Esgotamento Sanitário e teve todo o pleito aprovado, conforme Deliberação 75. / O município teve 0,8%, dos 10% do valor teto destinado a Resíduos Sólidos aprovado (R$37.131,34).
- 1276: Em 29/04/2019: atualizado como agendado

| ID | WBS | Task | Type | Duration | Start | Finish | Predecessors | Baseline start | Baseline finish | Baseline duration | Baseline 1 start | Baseline 1 finish | Total slack | Free slack | Farol de Atraso | Farol Marcos | % Previsto Tempo | Índice de Desempenho Físico (IDF) | Farol IDF | % Previsto Ponderado | % Concluído Ponderado | Responsável | Código do Contrato | Farol de Início |
| --- | --- | --- | --- | --- | --- | --- | --- | --- | --- | --- | --- | --- | --- | --- | --- | --- | --- | --- | --- | --- | --- | --- | --- | --- |
| 1289 | 2.3.14.1.4 | **Elaboração do Projeto Executivo** |  | 134d | 2019-09-03 | 2020-03-18 |  | 2019-09-03 | 2020-03-18 | 134d |  |  | 769d |  | Verde | Verde | 0% | 0% | Verde | 0% | 0% |  |  |  |
| 1290 | 2.3.14.1.4.1 | Elaborar Projeto Executivo |  | 66d | 2019-09-03 | 2019-12-04 | 1281 | 2019-09-03 | 2019-12-04 | 66d | 2019-06-01 | 2019-09-29 | 769d | 0d | Verde | Verde | 0% | 0% | Verde | 0% | 0% | 02 - Execução | PG 031 | Verde |
| 1291 | 2.3.14.1.4.2 | Projeto executivo apresentado ao banco | milestone | 0d | 2019-12-04 | 2019-12-04 | 1290 | 2019-12-04 | 2019-12-04 | 0d |  |  | 769d | 0d | Verde | Verde | 0% | 0% | Verde | 0% | 0% |  |  | Verde |
| 1292 | 2.3.14.1.4.3 | Analisar projeto executivo |  | 20d | 2019-12-05 | 2020-01-07 | 1291 | 2019-12-05 | 2020-01-07 | 20d |  |  | 769d | 0d | Verde | Verde | 0% | 0% | Verde | 0% | 0% |  |  | Verde |
| 1293 | 2.3.14.1.4.4 | Adequar/revisar projeto executivo |  | 24d | 2020-01-08 | 2020-02-10 | 1292 | 2020-01-08 | 2020-02-10 | 24d |  |  | 769d | 0d | Verde | Verde | 0% | 0% | Verde | 0% | 0% |  |  | Verde |
| 1294 | 2.3.14.1.4.5 | Analisar projeto executivo - final |  | 19d | 2020-02-11 | 2020-03-11 | 1293 | 2020-02-11 | 2020-03-11 | 19d |  |  | 769d | 0d | Verde | Verde | 0% | 0% | Verde | 0% | 0% |  |  | Verde |
| 1295 | 2.3.14.1.4.6 | Projeto executivo concluído | milestone | 0d | 2020-03-11 | 2020-03-11 | 1294, 1288, 1287 | 2020-03-11 | 2020-03-11 | 0d |  |  | 769d | 0d | Verde | Verde | 0% | 0% | Verde | 0% | 0% |  |  | Verde |
| 1296 | 2.3.14.1.4.7 | Recurso do projeto executivo do pleito GALESPJ01 repassado | milestone | 0d | 2020-03-18 | 2020-03-18 | 1295FS+5d | 2020-03-18 | 2020-03-18 | 0d |  |  | 769d | 0d | Verde | Verde | 0% | 0% | Verde | 0% | 0% |  |  | Verde |
| 1297 | 2.3.14.1.5 | Pleito GALESPJ01 concluído | milestone | 0d | 2020-03-18 | 2020-03-18 | 1296 | 2020-03-18 | 2020-03-18 | 0d |  |  | 769d | 24d | Verde | Verde | 0% | 0% | Verde | 0% | 0% |  |  | Verde |
| 1298 | 2.3.14.2 | **Pleito GALESCT01 - Aquisição de terrenos para implantação do sistema de esgotamento sanitário da sede do município** |  | 122d | 2019-10-23 | 2020-04-23 |  | 2019-10-23 | 2020-04-23 | 122d |  |  | 745d |  | Verde | Verde | 0% | 0% | Verde | 0% | 0% |  |  |  |
| 1299 | 2.3.14.2.1 | **Aquisição de Terreno** |  | 122d | 2019-10-23 | 2020-04-23 |  | 2019-10-23 | 2020-04-23 | 122d |  |  | 745d |  | Verde | Verde | 0% | 0% | Verde | 0% | 0% |  |  |  |
| 1300 | 2.3.14.2.1.1 | Regularizar terreno e apresentar escritura ao banco |  | 76d | 2019-10-23 | 2020-02-12 | 1283FS+14d | 2019-10-23 | 2020-02-12 | 76d |  |  | 745d | 0d | Verde | Verde | 0% | 0% | Verde | 0% | 0% |  |  | Verde |
| 1301 | 2.3.14.2.1.2 | Analisar documentação do terreno |  | 10d | 2020-02-13 | 2020-03-02 | 1300 | 2020-02-13 | 2020-03-02 | 10d |  |  | 776d | 0d | Verde | Verde | 0% | 0% | Verde | 0% | 0% |  |  | Verde |
| 1302 | 2.3.14.2.1.3 | 50% do valor do imóvel repassado (1) | milestone | 0d | 2020-03-09 | 2020-03-09 | 1301FS+5d | 2020-03-09 | 2020-03-09 | 0d |  |  | 776d | 31d | Verde | Verde | 0% | 0% | Verde | 0% | 0% |  |  | Verde |
| 1303 | 2.3.14.2.1.4 | Registrar imóvel e apresentar documentação ao banco |  | 31d | 2020-02-13 | 2020-03-31 | 1300 | 2020-02-13 | 2020-03-31 | 31d |  |  | 745d | 0d | Verde | Verde | 0% | 0% | Verde | 0% | 0% |  |  | Verde |
| 1304 | 2.3.14.2.1.5 | Analisar documentação do terreno |  | 10d | 2020-04-01 | 2020-04-15 | 1303 | 2020-04-01 | 2020-04-15 | 10d |  |  | 745d | 0d | Verde | Verde | 0% | 0% | Verde | 0% | 0% |  |  | Verde |
| 1305 | 2.3.14.2.1.6 | 50% do valor do imóvel repassado (2) | milestone | 0d | 2020-04-23 | 2020-04-23 | 1304FS+5d | 2020-04-23 | 2020-04-23 | 0d |  |  | 745d | 0d | Verde | Verde | 0% | 0% | Verde | 0% | 0% |  |  | Verde |
| 1306 | 2.3.14.2.1.7 | Aquisição de terreno concluída | milestone | 0d | 2020-04-23 | 2020-04-23 | 1305, 1302 | 2020-04-23 | 2020-04-23 | 0d |  |  | 745d | 0d | Verde | Verde | 0% | 0% | Verde | 0% | 0% |  |  | Verde |
| 1307 | 2.3.14.2.2 | Pleito GALESCT01 concluído | milestone | 0d | 2020-04-23 | 2020-04-23 | 1306 | 2020-04-23 | 2020-04-23 | 0d |  |  | 745d | 0d | Verde | Verde | 0% | 0% | Verde | 0% | 0% |  |  | Verde |
| 1308 | 2.3.14.3 | **Pleito GALESOB01 - Implantação do sistema de esgotamento sanitário da sede do município** |  | 459d | 2020-04-23 | 2022-02-22 |  | 2020-04-23 | 2022-02-22 | 459d |  |  | 745d |  | Verde | Verde | 0% | 0% | Verde | 0% | 0% |  |  |  |
| 1309 | 2.3.14.3.1 | **Licitação da Obra** |  | 56d | 2020-04-23 | 2020-07-14 |  | 2020-04-23 | 2020-07-14 | 56d |  |  | 745d |  | Verde | Verde | 0% | 0% | Verde | 0% | 0% |  |  |  |
| 1310 | 2.3.14.3.1.1 | Licitação da obra autorizada pelo banco | milestone | 0d | 2020-04-23 | 2020-04-23 | 1297, 1307 | 2020-04-23 | 2020-04-23 | 0d |  |  | 745d | 0d | Verde | Verde | 0% | 0% | Verde | 0% | 0% |  |  | Verde |
| 1311 | 2.3.14.3.1.2 | Licitar Obra |  | 42d | 2020-04-24 | 2020-06-24 | 1310 | 2020-04-24 | 2020-06-24 | 42d | 2019-09-29 | 2020-01-27 | 745d | 0d | Verde | Verde | 0% | 0% | Verde | 0% | 0% | 02 - Execução | PG 031 | Verde |
| 1312 | 2.3.14.3.1.3 | Analisar e emitir resultado da licitação da obra |  | 14d | 2020-06-25 | 2020-07-14 | 1311 | 2020-06-25 | 2020-07-14 | 14d |  |  | 745d | 0d | Verde | Verde | 0% | 0% | Verde | 0% | 0% |  |  | Verde |
| 1313 | 2.3.14.3.1.4 | Licitação da obra concluída | milestone | 0d | 2020-07-14 | 2020-07-14 | 1312 | 2020-07-14 | 2020-07-14 | 0d |  |  | 745d | 0d | Verde | Verde | 0% | 0% | Verde | 0% | 0% |  |  | Verde |
| 1314 | 2.3.14.3.2 | Executar obra |  | 250d | 2020-08-12 | 2021-08-12 | 1313FS+20d | 2020-08-12 | 2021-08-12 | 250d |  |  | 745d | 0d | Verde | Verde | 0% | 0% | Verde | 0% | 0% |  |  | Verde |
| 1315 | 2.3.14.3.3 | Realizar processo de pré-operação |  | 128d | 2021-08-13 | 2022-02-15 | 1314 | 2021-08-13 | 2022-02-15 | 128d | 2021-01-28 | 2021-07-27 | 745d | 0d | Verde | Verde | 0% | 0% | Verde | 0% | 0% | 02 - Execução | PG 031 | Verde |
| 1316 | 2.3.14.3.4 | Recurso da obra parcelado repassado | milestone | 0d | 2022-02-22 | 2022-02-22 | 1315FS+5d | 2022-02-22 | 2022-02-22 | 0d |  |  | 745d | 0d | Verde | Verde | 0% | 0% | Verde | 0% | 0% |  |  | Verde |
| 1317 | 2.3.14.3.5 | Pleito GALESOB01 concluído | milestone | 0d | 2022-02-22 | 2022-02-22 | 1316 | 2022-02-22 | 2022-02-22 | 0d |  |  | 745d | 0d | Verde | Verde | 0% | 0% | Verde | 0% | 0% |  |  | Verde |

| ID | WBS | Task | Type | Duration | Start | Finish | Predecessors | Complete | Remaining | Baseline start | Baseline finish | Baseline duration | Baseline 1 start | Baseline 1 finish | Total slack | Free slack | Constraint | Farol de Atraso | Farol Marcos | % Previsto Tempo | Índice de Desempenho Físico (IDF) | Farol IDF | % Previsto Ponderado | % Concluído Ponderado | Farol de Início | % Concluída Numérico | % Previsto Tempo Numérico | IDF Numérico | % Previsto Ponderado Numérico | % Concluído Ponderado Numérico | Responsável | Código do Contrato |
| --- | --- | --- | --- | --- | --- | --- | --- | --- | --- | --- | --- | --- | --- | --- | --- | --- | --- | --- | --- | --- | --- | --- | --- | --- | --- | --- | --- | --- | --- | --- | --- | --- |
| 1318 | 2.3.14.4 | **Pleito GALESPJ02 - Contratação de empresa para adequação de projeto relacionado à regularização ambiental da obra do SES da sede municipal** |  | 172d | 2019-07-03 | 2020-03-11 |  |  |  | 2019-07-03 | 2020-03-11 | 172d |  |  | 1233d |  |  | Verde | Verde | 0% | 0% | Verde | 0% | 0% |  |  |  |  |  |  |  |  |
| 1319 | 2.3.14.4.1 | Analisar pleito |  | 1d | 2019-07-03 | 2019-07-03 | 1288SS-43d |  |  | 2019-07-03 | 2019-07-03 | 1d |  |  | 1404d | 171d |  | Verde | Verde | 0% | 0% | Verde | 0% | 0% | Verde |  |  |  |  |  |  |  |
| 1320 | 2.3.14.4.2 | Pleito GALESPJ02 concluído | milestone | 0d | 2020-03-11 | 2020-03-11 | 1288, 1319 |  |  | 2020-03-11 | 2020-03-11 | 0d |  |  | 1233d | 488d |  | Verde | Verde | 0% | 0% | Verde | 0% | 0% | Verde |  |  |  |  |  |  |  |
| 1321 | 2.3.14.5 | **Pleito GALRSPM01 - Elaboração de estudos de viabiliadade para concepção dos serviços de infraestrutura de sistemas integrados de destinação final de resíduos sólidos urbanos, bem como educação ambiental e programas de coleta seletiva** |  | 437d | 2018-06-15 A | 2020-03-11 |  | 45% | 241.47d | 2018-06-15 | 2020-03-11 | 437d |  |  | 1233d |  |  | Verde | Verde | 50% | 80% | Vermelho | 5% | 4% |  | 45 | 50 | 80 |  |  |  |  |
| 1322 | 2.3.14.5.1 | **Licitação de Empresa para Estudo de Viabilidade** |  | 283d | 2018-06-15 A | 2019-07-26 |  | 75% | 71.39d | 2018-06-15 | 2019-07-26 | 283d |  |  | 1233d |  |  | Verde | Verde | 78% | 85% | Vermelho | 59% | 50% |  | 75 | 78 | 85 | 59 | 50 |  |  |
| 1323 | 2.3.14.5.1.1 | Licitação da empresa para Estudo de Viabilidade autorizada pelo banco | milestone | 0d | 2018-06-15 A | 2018-06-15 A | 313 | 100% |  | 2018-06-15 | 2018-06-15 | 0d |  |  |  |  |  | Verde | Verde | 100% | 0% | Vermelho | 100% | 0% | Verde | 100 | 100 |  | 100 |  |  |  |
| 1324 | 2.3.14.5.1.2 | Licitar empresa para Estudo de Viabilidade |  | 208d | 2018-09-03 A | 2019-07-01 | 1323FS+56d | 80% | 42d | 2018-09-03 | 2019-07-01 | 208d |  |  | 1233d | 0d |  | Verde | Verde | 79% | 85% | Vermelho | 79% | 67% | Verde | 80 | 79 | 85 | 79 | 67 |  |  |
| 1325 | 2.3.14.5.1.3 | Documentação de licitação apresentada ao banco | milestone | 0d | 2019-07-08 | 2019-07-08 | 1324FS+5d |  |  | 2019-07-08 | 2019-07-08 | 0d |  |  | 1233d | 0d |  | Verde | Verde | 0% | 0% | Verde | 0% | 0% | Verde |  |  |  |  |  |  |  |
| 1326 | 2.3.14.5.1.4 | Analisar e emitir resultado da licitação da empresa para Estudo de Viabilidade |  | 14d | 2019-07-09 | 2019-07-26 | 1325 |  |  | 2019-07-09 | 2019-07-26 | 14d |  |  | 1233d | 0d |  | Verde | Verde | 0% | 0% | Verde | 0% | 0% | Verde |  |  |  |  |  |  |  |
| 1327 | 2.3.14.5.1.5 | Licitação da empresa para Estudo de Viabilidade concluída | milestone | 0d | 2019-07-26 | 2019-07-26 | 1326 |  |  | 2019-07-26 | 2019-07-26 | 0d |  |  | 1233d | 0d |  | Verde | Verde | 0% | 0% | Verde | 0% | 0% | Verde |  |  |  |  |  |  |  |
| 1328 | 2.3.14.5.2 | **Elaboração do estudo de viabilidade** |  | 149d | 2019-07-29 | 2020-03-04 |  |  |  | 2019-07-29 | 2020-03-04 | 149d |  |  | 1233d |  |  | Verde | Verde | 0% | 0% | Verde | 0% | 0% |  |  |  |  |  |  |  |  |
| 1329 | 2.3.14.5.2.1 | Elaborar estudo de viabilidade |  | 88d | 2019-07-29 | 2019-11-29 | 1327 |  |  | 2019-07-29 | 2019-11-29 | 88d |  |  | 1233d | 0d |  | Verde | Verde | 0% | 0% | Verde | 0% | 0% | Verde |  |  |  |  |  |  |  |
| 1330 | 2.3.14.5.2.2 | Analisar estudo |  | 20d | 2019-12-02 | 2020-01-02 | 1329 |  |  | 2019-12-02 | 2020-01-02 | 20d |  |  | 1233d | 0d |  | Verde | Verde | 0% | 0% | Verde | 0% | 0% | Verde |  |  |  |  |  |  |  |
| 1331 | 2.3.14.5.2.3 | Adequar/revisar estudo |  | 22d | 2020-01-03 | 2020-02-03 | 1330 |  |  | 2020-01-03 | 2020-02-03 | 22d |  |  | 1233d | 0d |  | Verde | Verde | 0% | 0% | Verde | 0% | 0% | Verde |  |  |  |  |  |  |  |
| 1332 | 2.3.14.5.2.4 | Analisar estudo - final |  | 19d | 2020-02-04 | 2020-03-04 | 1331 |  |  | 2020-02-04 | 2020-03-04 | 19d |  |  | 1233d | 0d |  | Verde | Verde | 0% | 0% | Verde | 0% | 0% | Verde |  |  |  |  |  |  |  |
| 1333 | 2.3.14.5.2.5 | Estudo concluído | milestone | 0d | 2020-03-04 | 2020-03-04 | 1332 |  |  | 2020-03-04 | 2020-03-04 | 0d |  |  | 1233d | 0d |  | Verde | Verde | 0% | 0% | Verde | 0% | 0% | Verde |  |  |  |  |  |  |  |
| 1334 | 2.3.14.5.3 | Recurso do serviço repassado | milestone | 0d | 2020-03-11 | 2020-03-11 | 1333FS+5d |  |  | 2020-03-11 | 2020-03-11 | 0d |  |  | 1233d | 0d |  | Verde | Verde | 0% | 0% | Verde | 0% | 0% | Verde |  |  |  |  |  |  |  |
| 1335 | 2.3.14.5.4 | Pleito GALRSPM01 concluído | milestone | 0d | 2020-03-11 | 2020-03-11 | 1334 |  |  | 2020-03-11 | 2020-03-11 | 0d |  |  | 1233d | 488d |  | Verde | Verde | 0% | 0% | Verde | 0% | 0% | Verde |  |  |  |  |  |  |  |
| 1336 | 2.3.14.6 | Recursos de Galileia repassados | milestone | 0d | 2022-02-22 | 2022-02-22 | 1297, 1307, 1317, 1320, 1335 |  |  | 2022-02-22 | 2022-02-22 | 0d | 2019-07-01 | 2021-07-27 | 745d |  |  | Verde | Verde | 0% | 0% | Verde | 0% | 0% | Verde |  |  |  |  |  | 02 - Execução | PG 031 |
| 1337 | 2.3.15 | **Governador Valadares** |  | 1395d | 2018-06-15 A | 2024-01-18 |  | 5% | 1321.58d | 2018-06-15 | 2024-01-18 | 1395d | 2019-02-09 | 2023-01-19 | 275d |  |  | Verde | Verde | 15% | 0% | Vermelho | 0% | 0% |  |  | 15 |  |  |  |  |  |
| 1338 | 2.3.15.1 | **Pleito de Governador Valadares a definir - Obra ETE Santos Dumont** |  | 936d | 2019-05-31 | 2023-03-06 |  |  |  | 2019-05-31 | 2023-03-06 | 936d |  |  | 0d |  |  | Verde | Verde | 0% | 0% | Verde | 0% | 0% |  |  |  |  |  |  |  |  |
| 1339 | 2.3.15.1.1 | Pleito aprovado | milestone | 0d | 2019-05-31 | 2019-05-31 |  |  |  | 2019-05-31 | 2019-05-31 | 0d |  |  | 0d |  | must start on 2019-05-31 | Verde | Verde | 0% | 0% | Verde | 0% | 0% | Verde |  |  |  |  |  |  |  |
| 1340 | 2.3.15.1.2 | **Apresentação do Projeto Executivo** |  | 68d | 2019-05-31 | 2019-09-05 |  |  |  | 2019-05-31 | 2019-09-05 | 68d | 2019-10-07 | 2020-04-04 | 491d |  |  | Verde | Verde | 0% | 0% | Verde | 0% | 0% |  |  |  |  |  |  | 02 - Execução | PG 031 |
| 1341 | 2.3.15.1.2.1 | Projeto executivo apresentado ao banco | milestone | 0d | 2019-05-31 | 2019-05-31 | 1339 |  |  | 2019-05-31 | 2019-05-31 | 0d |  |  | 491d | 0d |  | Verde | Verde | 0% | 0% | Verde | 0% | 0% | Verde |  |  |  |  |  |  |  |
| 1342 | 2.3.15.1.2.2 | Analisar projeto executivo |  | 21d | 2019-05-31 | 2019-07-01 | 1341 |  |  | 2019-05-31 | 2019-07-01 | 21d |  |  | 491d | 0d |  | Verde | Verde | 0% | 0% | Verde | 0% | 0% | Verde |  |  |  |  |  |  |  |
| 1343 | 2.3.15.1.2.3 | Adequar/revisar projeto executivo |  | 24d | 2019-07-02 | 2019-08-02 | 1342 |  |  | 2019-07-02 | 2019-08-02 | 24d |  |  | 491d | 0d |  | Verde | Verde | 0% | 0% | Verde | 0% | 0% | Verde |  |  |  |  |  |  |  |
| 1344 | 2.3.15.1.2.4 | Analisar projeto executivo - final |  | 23d | 2019-08-05 | 2019-09-05 | 1343 |  |  | 2019-08-05 | 2019-09-05 | 23d |  |  | 491d | 0d |  | Verde | Verde | 0% | 0% | Verde | 0% | 0% | Verde |  |  |  |  |  |  |  |
| 1345 | 2.3.15.1.2.5 | Projeto executivo concluído | milestone | 0d | 2019-09-05 | 2019-09-05 | 1344 |  |  | 2019-09-05 | 2019-09-05 | 0d |  |  | 491d | 0d |  | Verde | Verde | 0% | 0% | Verde | 0% | 0% | Verde |  |  |  |  |  |  |  |

Notes:
- 1324: Em 29/04/2019: atualizado como agendado
- 1336: Valor de recurso destinado ao munícipio: R$4.726.993,07
- 1337: Governador Valadares teve todo o pleito de Esgotamento Sanitário negado. / Está em tratativas visando a definição do escopo dos projetos e obras que poderão ser financiadas com estes recursos. Assim que forem concluídas tais tratativas, será elaborada NT para apresentar a análise do pleito ajustado pelo munícipio. / O município teve 0,8%, dos 10% do valor teto destinado a Resíduos Sólidos aprovado (R$502.718,13). / Como ainda não está definido quantas obras serão realizadas, foi considerado o valor total de obras, dividido por 4 para o critério de prazo, de forma a não impactar no prazo final do programa.
- 1338: Em 23/04/2019: / - obra ETE Santos Dumont + comissionamento/operação assistida - 1a etapa ETE Santos Dumont. / - valor: 21.125.771,30 + 308.928,66

| ID | WBS | Task | Type | Duration | Start | Finish | Predecessors | Baseline start | Baseline finish | Baseline duration | Baseline 1 start | Baseline 1 finish | Total slack | Free slack | Constraint | Farol de Atraso | Farol Marcos | % Previsto Tempo | Índice de Desempenho Físico (IDF) | Responsável | Código do Contrato | Farol IDF | % Previsto Ponderado | % Concluído Ponderado | Farol de Início |
| --- | --- | --- | --- | --- | --- | --- | --- | --- | --- | --- | --- | --- | --- | --- | --- | --- | --- | --- | --- | --- | --- | --- | --- | --- | --- |
| 1346 | 2.3.15.1.3 | **Licitação da Obra** |  | 96d | 2019-09-05 | 2020-01-24 |  | 2019-09-05 | 2020-01-24 | 96d | 2020-04-04 | 2020-08-02 | 491d |  |  | Verde | Verde | 0% | 0% | 02 - Execução | PG 031 | Verde | 0% | 0% |  |
| 1347 | 2.3.15.1.3.1 | Licitação da obra autorizada pelo banco | milestone | 0d | 2019-09-05 | 2019-09-05 | 1345 | 2019-09-05 | 2019-09-05 | 0d |  |  | 491d | 0d |  | Verde | Verde | 0% | 0% |  |  | Verde | 0% | 0% | Verde |
| 1348 | 2.3.15.1.3.2 | Licitar Obra |  | 82d | 2019-09-06 | 2020-01-06 | 1347 | 2019-09-06 | 2020-01-06 | 82d |  |  | 491d | 0d |  | Verde | Verde | 0% | 0% |  |  | Verde | 0% | 0% | Verde |
| 1349 | 2.3.15.1.3.3 | Analisar e emitir resultado da licitação da obra |  | 14d | 2020-01-07 | 2020-01-24 | 1348 | 2020-01-07 | 2020-01-24 | 14d |  |  | 491d | 0d |  | Verde | Verde | 0% | 0% |  |  | Verde | 0% | 0% | Verde |
| 1350 | 2.3.15.1.3.4 | Licitação da obra concluída | milestone | 0d | 2020-01-24 | 2020-01-24 | 1349 | 2020-01-24 | 2020-01-24 | 0d |  |  | 491d | 0d |  | Verde | Verde | 0% | 0% |  |  | Verde | 0% | 0% | Verde |
| 1351 | 2.3.15.1.4 | Executar Obra |  | 622d | 2020-02-19 | 2022-08-19 | 1350FS+17d | 2020-02-19 | 2022-08-19 | 622d | 2020-08-02 | 2022-07-23 | 491d | 0d |  | Verde | Verde | 0% | 0% | 02 - Execução | PG 031 | Verde | 0% | 0% | Verde |
| 1352 | 2.3.15.1.5 | Realizar processo de pré-operação |  | 128d | 2022-08-22 | 2023-02-27 | 1351 | 2022-08-22 | 2023-02-27 | 128d | 2022-07-23 | 2023-01-19 | 491d | 0d |  | Verde | Verde | 0% | 0% | 02 - Execução | PG 031 | Verde | 0% | 0% | Verde |
| 1353 | 2.3.15.1.6 | Recurso da obra parcelado repassado | milestone | 0d | 2023-03-06 | 2023-03-06 | 1352FS+5d | 2023-03-06 | 2023-03-06 | 0d |  |  | 491d | 0d |  | Verde | Verde | 0% | 0% |  |  | Verde | 0% | 0% | Verde |
| 1354 | 2.3.15.1.7 | Pleito a definir concluído | milestone | 0d | 2023-03-06 | 2023-03-06 | 1353 | 2023-03-06 | 2023-03-06 | 0d |  |  | 491d | 216d |  | Verde | Verde | 0% | 0% |  |  | Verde | 0% | 0% | Verde |
| 1355 | 2.3.15.2 | **Pleito de Governador Valadares a definir - Projeto de Interligação de Coletores aos Interceptores e laboratório ETE Santos Dumont** |  | 273d | 2019-05-31 | 2020-07-06 |  | 2019-05-31 | 2020-07-06 | 273d |  |  | 0d |  |  | Verde | Verde | 0% | 0% |  |  | Verde | 0% | 0% |  |
| 1356 | 2.3.15.2.1 | Pleito aprovado | milestone | 0d | 2019-05-31 | 2019-05-31 |  | 2019-05-31 | 2019-05-31 | 0d |  |  | 0d |  | must start on 2019-05-31 | Verde | Verde | 0% | 0% |  |  | Verde | 0% | 0% | Verde |
| 1357 | 2.3.15.2.2 | **Licitação do Projeto** |  | 63d | 2019-06-13 | 2019-09-12 |  | 2019-06-13 | 2019-09-12 | 63d |  |  | 1154d |  |  | Verde | Verde | 0% | 0% |  |  | Verde | 0% | 0% |  |
| 1358 | 2.3.15.2.2.1 | Licitação do projeto autorizada pelo banco | milestone | 0d | 2019-06-13 | 2019-06-13 | 1356FS+10d | 2019-06-13 | 2019-06-13 | 0d |  |  | 1154d | 0d |  | Verde | Verde | 0% | 0% |  |  | Verde | 0% | 0% | Verde |
| 1359 | 2.3.15.2.2.2 | Licitar projeto |  | 44d | 2019-06-14 | 2019-08-16 | 1358 | 2019-06-14 | 2019-08-16 | 44d |  |  | 1154d | 0d |  | Verde | Verde | 0% | 0% |  |  | Verde | 0% | 0% | Verde |
| 1360 | 2.3.15.2.2.3 | Documentação de licitação apresentada ao banco | milestone | 0d | 2019-08-23 | 2019-08-23 | 1359FS+5d | 2019-08-23 | 2019-08-23 | 0d |  |  | 1154d | 0d |  | Verde | Verde | 0% | 0% |  |  | Verde | 0% | 0% | Verde |
| 1361 | 2.3.15.2.2.4 | Analisar e emitir resultado da licitação do projeto |  | 14d | 2019-08-26 | 2019-09-12 | 1360 | 2019-08-26 | 2019-09-12 | 14d |  |  | 1154d | 0d |  | Verde | Verde | 0% | 0% |  |  | Verde | 0% | 0% | Verde |
| 1362 | 2.3.15.2.2.5 | Licitação do projeto concluída | milestone | 0d | 2019-09-12 | 2019-09-12 | 1361 | 2019-09-12 | 2019-09-12 | 0d |  |  | 1154d | 0d |  | Verde | Verde | 0% | 0% |  |  | Verde | 0% | 0% | Verde |
| 1363 | 2.3.15.2.3 | **Elaboração do Projeto Básico** |  | 137d | 2019-09-13 | 2020-04-02 |  | 2019-09-13 | 2020-04-02 | 137d |  |  | 1154d |  |  | Verde | Verde | 0% | 0% |  |  | Verde | 0% | 0% |  |
| 1364 | 2.3.15.2.3.1 | Elaborar Projeto Básico |  | 66d | 2019-09-13 | 2019-12-17 | 1362 | 2019-09-13 | 2019-12-17 | 66d |  |  | 1154d | 0d |  | Verde | Verde | 0% | 0% |  |  | Verde | 0% | 0% | Verde |
| 1365 | 2.3.15.2.3.2 | Projeto básico apresentado ao banco | milestone | 0d | 2019-12-17 | 2019-12-17 | 1364 | 2019-12-17 | 2019-12-17 | 0d |  |  | 1154d | 0d |  | Verde | Verde | 0% | 0% |  |  | Verde | 0% | 0% | Verde |
| 1366 | 2.3.15.2.3.3 | Analisar projeto básico |  | 22d | 2019-12-18 | 2020-01-21 | 1365 | 2019-12-18 | 2020-01-21 | 22d |  |  | 1212d | 0d |  | Verde | Verde | 0% | 0% |  |  | Verde | 0% | 0% | Verde |
| 1367 | 2.3.15.2.3.4 | Adequar/revisar projeto básico |  | 22d | 2020-01-22 | 2020-02-20 | 1366 | 2020-01-22 | 2020-02-20 | 22d |  |  | 1212d | 0d |  | Verde | Verde | 0% | 0% |  |  | Verde | 0% | 0% | Verde |
| 1368 | 2.3.15.2.3.5 | Analisar projeto básico - final |  | 22d | 2020-02-21 | 2020-03-26 | 1367 | 2020-02-21 | 2020-03-26 | 22d |  |  | 1212d | 0d |  | Verde | Verde | 0% | 0% |  |  | Verde | 0% | 0% | Verde |
| 1369 | 2.3.15.2.3.6 | Projeto básico concluído | milestone | 0d | 2020-03-26 | 2020-03-26 | 1368 | 2020-03-26 | 2020-03-26 | 0d |  |  | 1212d | 0d |  | Verde | Verde | 0% | 0% |  |  | Verde | 0% | 0% | Verde |
| 1370 | 2.3.15.2.3.7 | Recurso do projeto básico do pleito repassado | milestone | 0d | 2020-04-02 | 2020-04-02 | 1369FS+5d | 2020-04-02 | 2020-04-02 | 0d |  |  | 1212d | 58d |  | Verde | Verde | 0% | 0% |  |  | Verde | 0% | 0% | Verde |

Notes:
- 1351: Em 19/03/19: por solicitação da A&M foi modificada a duração da atividade Acompanhamento de Obras de 720 dias para 711 dias para atendimento à demanda do MP e igualar as datas de término tendência às da definição do programa.
- 1355: Em 23/04/2019: Interligações dos coletores aos interceptores / - bacia ETE Santos Dumond 1a etapa BDMG / - bacia ETE Elvamar / - Gran Duquesa, Centro, Vale Verde (Bacia de Santos Dumond) / - bacia ETE Santos Dumond - complementação da 1a etapa Renova / - bacia Santos Dumond 2a etapa CEF

| ID | WBS | Task | Type | Duration | Start | Finish | Predecessors | Baseline start | Baseline finish | Baseline duration | Total slack | Free slack | Constraint | Farol de Atraso | Farol Marcos | % Previsto Tempo | Índice de Desempenho Físico (IDF) | Farol IDF | % Previsto Ponderado | % Concluído Ponderado | Farol de Início |
| --- | --- | --- | --- | --- | --- | --- | --- | --- | --- | --- | --- | --- | --- | --- | --- | --- | --- | --- | --- | --- | --- |
| 1371 | 2.3.15.2.4 | **Elaboração do Projeto Executivo** |  | 134d | 2019-12-18 | 2020-07-06 |  | 2019-12-18 | 2020-07-06 | 134d | 1154d |  |  | Verde | Verde | 0% | 0% | Verde | 0% | 0% |  |
| 1372 | 2.3.15.2.4.1 | Elaborar Projeto Executivo |  | 62d | 2019-12-18 | 2020-03-20 | 1365 | 2019-12-18 | 2020-03-20 | 62d | 1154d | 0d |  | Verde | Verde | 0% | 0% | Verde | 0% | 0% | Verde |
| 1373 | 2.3.15.2.4.2 | Projeto apresentado ao banco | milestone | 0d | 2020-03-20 | 2020-03-20 | 1372 | 2020-03-20 | 2020-03-20 | 0d | 1154d | 0d |  | Verde | Verde | 0% | 0% | Verde | 0% | 0% | Verde |
| 1374 | 2.3.15.2.4.3 | Analisar projeto executivo |  | 23d | 2020-03-23 | 2020-04-24 | 1373 | 2020-03-23 | 2020-04-24 | 23d | 1154d | 0d |  | Verde | Verde | 0% | 0% | Verde | 0% | 0% | Verde |
| 1375 | 2.3.15.2.4.4 | Adequar/revisar projeto executivo |  | 22d | 2020-04-27 | 2020-05-27 | 1374 | 2020-04-27 | 2020-05-27 | 22d | 1154d | 0d |  | Verde | Verde | 0% | 0% | Verde | 0% | 0% | Verde |
| 1376 | 2.3.15.2.4.5 | Analisar projeto executivo - final |  | 22d | 2020-05-28 | 2020-06-29 | 1375 | 2020-05-28 | 2020-06-29 | 22d | 1154d | 0d |  | Verde | Verde | 0% | 0% | Verde | 0% | 0% | Verde |
| 1377 | 2.3.15.2.4.6 | Projeto executivo concluído | milestone | 0d | 2020-06-29 | 2020-06-29 | 1376, 1370 | 2020-06-29 | 2020-06-29 | 0d | 1154d | 0d |  | Verde | Verde | 0% | 0% | Verde | 0% | 0% | Verde |
| 1378 | 2.3.15.2.4.7 | Recurso do projeto do pleito repassado | milestone | 0d | 2020-07-06 | 2020-07-06 | 1377FS+5d | 2020-07-06 | 2020-07-06 | 0d | 1154d | 0d |  | Verde | Verde | 0% | 0% | Verde | 0% | 0% | Verde |
| 1379 | 2.3.15.2.5 | Pleito a definir concluído | milestone | 0d | 2020-07-06 | 2020-07-06 | 1378 | 2020-07-06 | 2020-07-06 | 0d | 1154d | 879d |  | Verde | Verde | 0% | 0% | Verde | 0% | 0% | Verde |
| 1380 | 2.3.15.3 | **Pleito de Governador Valadares a definir - Obra Interligação de Coletores aos Interceptores e laboratório ETE Santos Dumont** |  | 905d | 2020-05-29 | 2024-01-18 |  | 2020-05-29 | 2024-01-18 | 905d | 0d |  |  | Verde | Verde | 0% | 0% | Verde | 0% | 0% |  |
| 1381 | 2.3.15.3.1 | Pleito aprovado | milestone | 0d | 2020-05-29 | 2020-05-29 |  | 2020-05-29 | 2020-05-29 | 0d | 0d |  | must start on 2020-05-29 | Verde | Verde | 0% | 0% | Verde | 0% | 0% | Verde |
| 1382 | 2.3.15.3.2 | **Licitação da obra** |  | 80d | 2020-06-12 | 2020-10-05 |  | 2020-06-12 | 2020-10-05 | 80d | 275d |  |  | Verde | Verde | 0% | 0% | Verde | 0% | 0% |  |
| 1383 | 2.3.15.3.2.1 | Licitação da obra autorizada pelo banco | milestone | 0d | 2020-06-12 | 2020-06-12 | 1381FS+10d | 2020-06-12 | 2020-06-12 | 0d | 275d | 0d |  | Verde | Verde | 0% | 0% | Verde | 0% | 0% | Verde |
| 1384 | 2.3.15.3.2.2 | Licitar obra |  | 66d | 2020-06-15 | 2020-09-15 | 1383 | 2020-06-15 | 2020-09-15 | 66d | 275d | 0d |  | Verde | Verde | 0% | 0% | Verde | 0% | 0% | Verde |
| 1385 | 2.3.15.3.2.3 | Analisar e emitir resultado da licitação da obra |  | 14d | 2020-09-16 | 2020-10-05 | 1384 | 2020-09-16 | 2020-10-05 | 14d | 275d | 0d |  | Verde | Verde | 0% | 0% | Verde | 0% | 0% | Verde |
| 1386 | 2.3.15.3.2.4 | Licitação da obra concluída | milestone | 0d | 2020-10-05 | 2020-10-05 | 1385 | 2020-10-05 | 2020-10-05 | 0d | 275d | 0d |  | Verde | Verde | 0% | 0% | Verde | 0% | 0% | Verde |
| 1387 | 2.3.15.3.3 | Executar obra |  | 662d | 2020-11-05 | 2023-07-05 | 1386FS+20d | 2020-11-05 | 2023-07-05 | 662d | 275d | 0d |  | Verde | Verde | 0% | 0% | Verde | 0% | 0% | Verde |
| 1388 | 2.3.15.3.4 | Realizar processo de pré-operação |  | 128d | 2023-07-06 | 2024-01-11 | 1387 | 2023-07-06 | 2024-01-11 | 128d | 275d | 0d |  | Verde | Verde | 0% | 0% | Verde | 0% | 0% | Verde |
| 1389 | 2.3.15.3.5 | Recurso da obra parcelado repassado | milestone | 0d | 2024-01-18 | 2024-01-18 | 1388FS+5d | 2024-01-18 | 2024-01-18 | 0d | 275d | 0d |  | Verde | Verde | 0% | 0% | Verde | 0% | 0% | Verde |
| 1390 | 2.3.15.3.6 | Pleito a definir concluído | milestone | 0d | 2024-01-18 | 2024-01-18 | 1389 | 2024-01-18 | 2024-01-18 | 0d | 275d | 0d |  | Verde | Verde | 0% | 0% | Verde | 0% | 0% | Verde |
| 1391 | 2.3.15.4 | **Pleito de Governador Valadares a definir - Obra Interligação de Coletores aos Interceptores da ETE Elvamar** |  | 407d | 2020-05-29 | 2022-01-13 |  | 2020-05-29 | 2022-01-13 | 407d | 0d |  |  | Verde | Verde | 0% | 0% | Verde | 0% | 0% |  |
| 1392 | 2.3.15.4.1 | Pleito aprovado | milestone | 0d | 2020-05-29 | 2020-05-29 |  | 2020-05-29 | 2020-05-29 | 0d | 0d |  | must start on 2020-05-29 | Verde | Verde | 0% | 0% | Verde | 0% | 0% | Verde |
| 1393 | 2.3.15.4.2 | **Licitação da obra** |  | 80d | 2020-06-12 | 2020-10-05 |  | 2020-06-12 | 2020-10-05 | 80d | 773d |  |  | Verde | Verde | 0% | 0% | Verde | 0% | 0% |  |
| 1394 | 2.3.15.4.2.1 | Licitação da obra autorizada pelo banco | milestone | 0d | 2020-06-12 | 2020-06-12 | 1392FS+10d | 2020-06-12 | 2020-06-12 | 0d | 773d | 0d |  | Verde | Verde | 0% | 0% | Verde | 0% | 0% | Verde |
| 1395 | 2.3.15.4.2.2 | Licitar obra |  | 66d | 2020-06-15 | 2020-09-15 | 1394 | 2020-06-15 | 2020-09-15 | 66d | 773d | 0d |  | Verde | Verde | 0% | 0% | Verde | 0% | 0% | Verde |
| 1396 | 2.3.15.4.2.3 | Analisar e emitir resultado da licitação da obra |  | 14d | 2020-09-16 | 2020-10-05 | 1395 | 2020-09-16 | 2020-10-05 | 14d | 773d | 0d |  | Verde | Verde | 0% | 0% | Verde | 0% | 0% | Verde |
| 1397 | 2.3.15.4.2.4 | Licitação da obra concluída | milestone | 0d | 2020-10-05 | 2020-10-05 | 1396 | 2020-10-05 | 2020-10-05 | 0d | 773d | 0d |  | Verde | Verde | 0% | 0% | Verde | 0% | 0% | Verde |
| 1398 | 2.3.15.4.3 | Executar obra |  | 164d | 2020-11-05 | 2021-07-05 | 1397FS+20d | 2020-11-05 | 2021-07-05 | 164d | 773d | 0d |  | Verde | Verde | 0% | 0% | Verde | 0% | 0% | Verde |
| 1399 | 2.3.15.4.4 | Realizar processo de pré-operação |  | 128d | 2021-07-06 | 2022-01-06 | 1398 | 2021-07-06 | 2022-01-06 | 128d | 773d | 0d |  | Verde | Verde | 0% | 0% | Verde | 0% | 0% | Verde |
| 1400 | 2.3.15.4.5 | Recurso da obra parcelado repassado | milestone | 0d | 2022-01-13 | 2022-01-13 | 1399FS+5d | 2022-01-13 | 2022-01-13 | 0d | 773d | 0d |  | Verde | Verde | 0% | 0% | Verde | 0% | 0% | Verde |
| 1401 | 2.3.15.4.6 | Pleito a definir concluído | milestone | 0d | 2022-01-13 | 2022-01-13 | 1400 | 2022-01-13 | 2022-01-13 | 0d | 773d | 498d |  | Verde | Verde | 0% | 0% | Verde | 0% | 0% | Verde |

Notes:
- 1380: Em 23/04/2019: Obra de interligações dos coletores aos interceptores / - Santos Dumond, SIR, Universitário (Bacia ETE Santos Dumont) - 1a etapa BDMG / - Santos Dumond, SIR, Universitário (Bacia ETE Santos Dumont) - complementação 1a etapa Renova / - Santos Dumond, SIR, Universitário (Bacia ETE Santos Dumont) - 2a etapa CEF / - Gran Duquesa, Centro, Vale Verde (Bacia ETE Santos Dumont) / E: / - Complementação sistema santa rita (bacia ETE Santos Dumont) - interceptores, estações elevatórias de esgoto, linhas de recalque. / - Equipamentos/Materiais para laboratório da ETE Santos Dumont e execução da ETE Laboratório Santos Dumont

| ID | WBS | Task | Type | Duration | Start | Finish | Predecessors | Complete | Remaining | Baseline start | Baseline finish | Baseline duration | Baseline 1 start | Baseline 1 finish | Total slack | Free slack | Constraint | Farol de Atraso | Farol Marcos | % Previsto Tempo | Índice de Desempenho Físico (IDF) | Farol IDF | % Previsto Ponderado | % Concluído Ponderado | Farol de Início | % Concluída Numérico | % Previsto Tempo Numérico | IDF Numérico | % Previsto Ponderado Numérico | % Concluído Ponderado Numérico | Responsável | Código do Contrato |
| --- | --- | --- | --- | --- | --- | --- | --- | --- | --- | --- | --- | --- | --- | --- | --- | --- | --- | --- | --- | --- | --- | --- | --- | --- | --- | --- | --- | --- | --- | --- | --- | --- |
| 1402 | 2.3.15.5 | **Pleito de Governador Valadares a definir - Assessoria Licenciamento Ambiental ETE Elvamar** |  | 335d | 2019-05-31 | 2020-10-01 |  |  |  | 2019-05-31 | 2020-10-01 | 335d |  |  | 0d |  |  | Verde | Verde | 0% | 0% | Verde | 0% | 0% |  |  |  |  |  |  |  |  |
| 1403 | 2.3.15.5.1 | Pleito aprovado | milestone | 0d | 2019-05-31 | 2019-05-31 |  |  |  | 2019-05-31 | 2019-05-31 | 0d |  |  | 0d |  | must start on 2019-05-31 | Verde | Verde | 0% | 0% | Verde | 0% | 0% | Verde |  |  |  |  |  |  |  |
| 1404 | 2.3.15.5.2 | **Licitação do Serviço de Assessoria** |  | 63d | 2019-06-13 | 2019-09-12 |  |  |  | 2019-06-13 | 2019-09-12 | 63d |  |  | 1092d |  |  | Verde | Verde | 0% | 0% | Verde | 0% | 0% |  |  |  |  |  |  |  |  |
| 1405 | 2.3.15.5.2.1 | Licitação do serviço autorizada pelo banco | milestone | 0d | 2019-06-13 | 2019-06-13 | 1403FS+10d |  |  | 2019-06-13 | 2019-06-13 | 0d |  |  | 1092d | 0d |  | Verde | Verde | 0% | 0% | Verde | 0% | 0% | Verde |  |  |  |  |  |  |  |
| 1406 | 2.3.15.5.2.2 | Licitar serviço |  | 44d | 2019-06-14 | 2019-08-16 | 1405 |  |  | 2019-06-14 | 2019-08-16 | 44d |  |  | 1092d | 0d |  | Verde | Verde | 0% | 0% | Verde | 0% | 0% | Verde |  |  |  |  |  |  |  |
| 1407 | 2.3.15.5.2.3 | Documentação de licitação apresentada ao banco | milestone | 0d | 2019-08-23 | 2019-08-23 | 1406FS+5d |  |  | 2019-08-23 | 2019-08-23 | 0d |  |  | 1092d | 0d |  | Verde | Verde | 0% | 0% | Verde | 0% | 0% | Verde |  |  |  |  |  |  |  |
| 1408 | 2.3.15.5.2.4 | Analisar e emitir resultado da licitação do serviço |  | 14d | 2019-08-26 | 2019-09-12 | 1407 |  |  | 2019-08-26 | 2019-09-12 | 14d |  |  | 1092d | 0d |  | Verde | Verde | 0% | 0% | Verde | 0% | 0% | Verde |  |  |  |  |  |  |  |
| 1409 | 2.3.15.5.2.5 | Licitação do serviço concluída | milestone | 0d | 2019-09-12 | 2019-09-12 | 1408 |  |  | 2019-09-12 | 2019-09-12 | 0d |  |  | 1092d | 0d |  | Verde | Verde | 0% | 0% | Verde | 0% | 0% | Verde |  |  |  |  |  |  |  |
| 1410 | 2.3.15.5.3 | Executar serviço |  | 250d | 2019-09-24 | 2020-09-24 | 1409FS+7d |  |  | 2019-09-24 | 2020-09-24 | 250d |  |  | 1092d | 0d |  | Verde | Verde | 0% | 0% | Verde | 0% | 0% | Verde |  |  |  |  |  |  |  |
| 1411 | 2.3.15.5.4 | Recurso do serviço parcelado repassado | milestone | 0d | 2020-10-01 | 2020-10-01 | 1410FS+5d |  |  | 2020-10-01 | 2020-10-01 | 0d |  |  | 1092d | 0d |  | Verde | Verde | 0% | 0% | Verde | 0% | 0% | Verde |  |  |  |  |  |  |  |
| 1412 | 2.3.15.5.5 | Pleito a definir concluído | milestone | 0d | 2020-10-01 | 2020-10-01 | 1411 |  |  | 2020-10-01 | 2020-10-01 | 0d |  |  | 1092d | 817d |  | Verde | Verde | 0% | 0% | Verde | 0% | 0% | Verde |  |  |  |  |  |  |  |
| 1413 | 2.3.15.6 | **Pleito GOVRSPM01 - Elaboração de estudos de viabilidade para concepção dos serviços de infraestrutura de sistemas integrados de destinação final de resíduos sólidos urbanos, assim como educação ambiental e programas de coleta seletiva** |  | 437d | 2018-06-15 A | 2020-03-11 |  | 45% | 241.47d | 2018-06-15 | 2020-03-11 | 437d |  |  | 1233d |  |  | Verde | Verde | 50% | 100% | Verde | 4% | 4% |  | 45 | 50 | 100 |  |  |  |  |
| 1414 | 2.3.15.6.1 | **Licitação de Empresa para Estudo de Viabilidade** |  | 283d | 2018-06-15 A | 2019-07-26 |  | 75% | 71.39d | 2018-06-15 | 2019-07-26 | 283d |  |  | 1233d |  |  | Verde | Verde | 78% | 98% | Vermelho | 63% | 62% |  | 75 | 78 | 98 | 63 | 62 |  |  |
| 1415 | 2.3.15.6.1.1 | Licitação da empresa para Estudo de Viabilidade autorizada pelo banco | milestone | 0d | 2018-06-15 A | 2018-06-15 A | 313 | 100% |  | 2018-06-15 | 2018-06-15 | 0d |  |  |  |  |  | Verde | Verde | 100% | 0% | Vermelho | 100% | 0% | Verde | 100 | 100 |  | 100 |  |  |  |
| 1416 | 2.3.15.6.1.2 | Licitar empresa para Estudo de Viabilidade |  | 208d | 2018-09-03 A | 2019-07-01 | 1415FS+56d | 80% | 42d | 2018-09-03 | 2019-07-01 | 208d |  |  | 1233d | 0d |  | Verde | Verde | 79% | 99% | Vermelho | 79% | 78% | Verde | 80 | 79 | 99 | 79 | 78 |  |  |
| 1417 | 2.3.15.6.1.3 | Documentação de licitação apresentada ao banco | milestone | 0d | 2019-07-08 | 2019-07-08 | 1416FS+5d |  |  | 2019-07-08 | 2019-07-08 | 0d |  |  | 1233d | 0d |  | Verde | Verde | 0% | 0% | Verde | 0% | 0% | Verde |  |  |  |  |  |  |  |
| 1418 | 2.3.15.6.1.4 | Analisar e emitir resultado da licitação da empresa para Estudo de Viabilidade |  | 14d | 2019-07-09 | 2019-07-26 | 1417 |  |  | 2019-07-09 | 2019-07-26 | 14d |  |  | 1233d | 0d |  | Verde | Verde | 0% | 0% | Verde | 0% | 0% | Verde |  |  |  |  |  |  |  |
| 1419 | 2.3.15.6.1.5 | Licitação da empresa para Estudo de Viabilidade concluída | milestone | 0d | 2019-07-26 | 2019-07-26 | 1418 |  |  | 2019-07-26 | 2019-07-26 | 0d |  |  | 1233d | 0d |  | Verde | Verde | 0% | 0% | Verde | 0% | 0% | Verde |  |  |  |  |  |  |  |
| 1420 | 2.3.15.6.2 | **Elaboração do estudo de viabilidade** |  | 149d | 2019-07-29 | 2020-03-04 |  |  |  | 2019-07-29 | 2020-03-04 | 149d |  |  | 1233d |  |  | Verde | Verde | 0% | 0% | Verde | 0% | 0% |  |  |  |  |  |  |  |  |
| 1421 | 2.3.15.6.2.1 | Elaborar estudo de viabilidade |  | 88d | 2019-07-29 | 2019-11-29 | 1419 |  |  | 2019-07-29 | 2019-11-29 | 88d |  |  | 1233d | 0d |  | Verde | Verde | 0% | 0% | Verde | 0% | 0% | Verde |  |  |  |  |  |  |  |
| 1422 | 2.3.15.6.2.2 | Analisar estudo |  | 20d | 2019-12-02 | 2020-01-02 | 1421 |  |  | 2019-12-02 | 2020-01-02 | 20d |  |  | 1233d | 0d |  | Verde | Verde | 0% | 0% | Verde | 0% | 0% | Verde |  |  |  |  |  |  |  |
| 1423 | 2.3.15.6.2.3 | Adequar/revisar estudo |  | 22d | 2020-01-03 | 2020-02-03 | 1422 |  |  | 2020-01-03 | 2020-02-03 | 22d |  |  | 1233d | 0d |  | Verde | Verde | 0% | 0% | Verde | 0% | 0% | Verde |  |  |  |  |  |  |  |
| 1424 | 2.3.15.6.2.4 | Analisar estudo - final |  | 19d | 2020-02-04 | 2020-03-04 | 1423 |  |  | 2020-02-04 | 2020-03-04 | 19d |  |  | 1233d | 0d |  | Verde | Verde | 0% | 0% | Verde | 0% | 0% | Verde |  |  |  |  |  |  |  |
| 1425 | 2.3.15.6.2.5 | Estudo concluído | milestone | 0d | 2020-03-04 | 2020-03-04 | 1424 |  |  | 2020-03-04 | 2020-03-04 | 0d |  |  | 1233d | 0d |  | Verde | Verde | 0% | 0% | Verde | 0% | 0% | Verde |  |  |  |  |  |  |  |
| 1426 | 2.3.15.6.3 | Recurso do serviço repassado | milestone | 0d | 2020-03-11 | 2020-03-11 | 1425FS+5d |  |  | 2020-03-11 | 2020-03-11 | 0d |  |  | 1233d | 0d |  | Verde | Verde | 0% | 0% | Verde | 0% | 0% | Verde |  |  |  |  |  |  |  |
| 1427 | 2.3.15.6.4 | Pleito GOVRSPM01 concluído | milestone | 0d | 2020-03-11 | 2020-03-11 | 1426 |  |  | 2020-03-11 | 2020-03-11 | 0d |  |  | 1233d | 958d |  | Verde | Verde | 0% | 0% | Verde | 0% | 0% | Verde |  |  |  |  |  |  |  |
| 1428 | 2.3.15.7 | Recursos de Governador Valadares repassados | milestone | 0d | 2024-01-18 | 2024-01-18 | 1354, 1379, 1390, 1401, 1412, 1427 |  |  | 2024-01-18 | 2024-01-18 | 0d | 2019-11-06 | 2023-01-19 | 275d |  |  | Verde | Verde | 0% | 0% | Verde | 0% | 0% | Verde |  |  |  |  |  | 02 - Execução | PG 031 |

Notes:
- 1416: Em 29/04/2019: atualizado como agendado
- 1428: Valor de recurso destinado ao munícipio: R$68.532.492,00 / Em 19/03/19: por solicitação da A&M foi modificada a duração da atividade Governador Valadares de 1170 dias para 1161 dias para atendimento à demanda do MP e igualar as datas de término tendência às da definição do programa.

| ID | WBS | Task | Type | Duration | Start | Finish | Predecessors | Complete | Remaining | Baseline start | Baseline finish | Baseline duration | Baseline 1 start | Baseline 1 finish | Total slack | Free slack | Farol de Atraso | Farol Marcos | % Previsto Tempo | % Previsto Tempo Numérico | Índice de Desempenho Físico (IDF) | IDF Numérico | Farol IDF | % Previsto Ponderado | % Concluído Ponderado | % Concluída Numérico | % Previsto Ponderado Numérico | Farol de Início |
| --- | --- | --- | --- | --- | --- | --- | --- | --- | --- | --- | --- | --- | --- | --- | --- | --- | --- | --- | --- | --- | --- | --- | --- | --- | --- | --- | --- | --- |
| 1429 | 2.3.16 | **Iapu** |  | 697d | 2018-12-03 A | 2021-09-20 |  | 9% | 631.23d | 2018-12-03 | 2021-09-20 | 697d | 2019-01-03 | 2021-01-22 | 852d |  | Verde | Verde | 14% | 14 | 50% | 50 | Vermelho | 2% | 1% |  |  |  |
| 1430 | 2.3.16.1 | **Pleito IAPRSPM01 - Elaboração de estudos ambientais** |  | 214d | 2018-12-03 A | 2019-10-09 |  | 50% | 108.05d | 2018-12-03 | 2019-10-09 | 214d |  |  | 1335d |  | Verde | Verde | 47% | 47 | 0% |  | Vermelho | 14% | 0% | 50 | 14 |  |
| 1431 | 2.3.16.1.1 | **Licitação de Empresa para Licenciamento Ambiental** |  | 161d | 2018-12-03 A | 2019-07-25 |  | 65% | 56.76d | 2018-12-03 | 2019-07-25 | 161d |  |  | 941d |  | Verde | Verde | 62% | 62 | 0% |  | Vermelho | 36% | 0% | 65 | 36 |  |
| 1432 | 2.3.16.1.1.1 | Licitação da empresa para Licenciamento Ambiental autorizada pelo banco | milestone | 0d | 2018-12-03 A | 2018-12-03 A | 544 | 100% |  | 2018-12-03 | 2018-12-03 | 0d |  |  |  |  | Verde | Verde | 100% | 100 | 0% |  | Vermelho | 100% | 0% | 100 | 100 | Verde |
| 1433 | 2.3.16.1.1.2 | Licitar empresa para Licenciamento Ambiental |  | 142d | 2018-12-03 A | 2019-06-28 | 1432 | 71% | 41d | 2018-12-03 | 2019-06-28 | 142d |  |  | 941d | 0d | Verde | Verde | 71% | 71 | 0% |  | Vermelho | 71% | 0% | 71 | 71 | Verde |
| 1434 | 2.3.16.1.1.3 | Documentação de licitação apresentada ao banco | milestone | 0d | 2019-07-05 | 2019-07-05 | 1433FS+5d |  |  | 2019-07-05 | 2019-07-05 | 0d |  |  | 941d | 0d | Verde | Verde | 0% |  | 0% |  | Verde | 0% | 0% |  |  | Verde |
| 1435 | 2.3.16.1.1.4 | Analisar e emitir resultado da licitação do empresa para Licenciamento Ambiental |  | 14d | 2019-07-08 | 2019-07-25 | 1434 |  |  | 2019-07-08 | 2019-07-25 | 14d |  |  | 941d | 0d | Verde | Verde | 0% |  | 0% |  | Verde | 0% | 0% |  |  | Verde |
| 1436 | 2.3.16.1.1.5 | Licitação da empresa para Licenciamento Ambiental concluída | milestone | 0d | 2019-07-25 | 2019-07-25 | 1435 |  |  | 2019-07-25 | 2019-07-25 | 0d |  |  | 941d | 0d | Verde | Verde | 0% |  | 0% |  | Verde | 0% | 0% |  |  | Verde |
| 1437 | 2.3.16.1.2 | Executar o Licenciamento Ambiental |  | 48d | 2019-07-26 | 2019-10-02 | 1436 |  |  | 2019-07-26 | 2019-10-02 | 48d |  |  | 941d | 0d | Verde | Verde | 0% |  | 0% |  | Verde | 0% | 0% |  |  | Verde |
| 1438 | 2.3.16.1.3 | Recurso do serviço parcelado repassado | milestone | 0d | 2019-10-09 | 2019-10-09 | 1437FS+5d |  |  | 2019-10-09 | 2019-10-09 | 0d |  |  | 1335d | 0d | Verde | Verde | 0% |  | 0% |  | Verde | 0% | 0% |  |  | Verde |
| 1439 | 2.3.16.1.4 | Pleito IAPRSPM01 concluído | milestone | 0d | 2019-10-09 | 2019-10-09 | 1438 |  |  | 2019-10-09 | 2019-10-09 | 0d |  |  | 1335d | 395d | Verde | Verde | 0% |  | 0% |  | Verde | 0% | 0% |  |  | Verde |
| 1440 | 2.3.16.2 | **Pleito IAPRSOB02 - Implantação de aterro sanitário** |  | 467d | 2019-06-28 | 2021-05-17 |  |  |  | 2019-06-28 | 2021-05-17 | 467d |  |  | 940d |  | Verde | Verde | 0% |  | 0% |  | Verde | 0% | 0% |  |  |  |
| 1441 | 2.3.16.2.1 | **Aprovação do Projeto Executivo** |  | 68d | 2019-06-28 | 2019-10-03 |  |  |  | 2019-06-28 | 2019-10-03 | 68d |  |  | 940d |  | Verde | Verde | 0% |  | 0% |  | Verde | 0% | 0% |  |  |  |
| 1442 | 2.3.16.2.1.1 | Projeto apresentado ao banco | milestone | 0d | 2019-06-28 | 2019-06-28 | 554 |  |  | 2019-06-28 | 2019-06-28 | 0d |  |  | 940d | 0d | Verde | Verde | 0% |  | 0% |  | Verde | 0% | 0% |  |  | Verde |
| 1443 | 2.3.16.2.1.2 | Analisar projeto |  | 22d | 2019-07-01 | 2019-07-30 | 1442 |  |  | 2019-07-01 | 2019-07-30 | 22d |  |  | 940d | 0d | Verde | Verde | 0% |  | 0% |  | Verde | 0% | 0% |  |  | Verde |
| 1444 | 2.3.16.2.1.3 | Adequar/revisar projeto |  | 23d | 2019-07-31 | 2019-09-02 | 1443 |  |  | 2019-07-31 | 2019-09-02 | 23d |  |  | 940d | 0d | Verde | Verde | 0% |  | 0% |  | Verde | 0% | 0% |  |  | Verde |
| 1445 | 2.3.16.2.1.4 | Analisar projeto - final |  | 23d | 2019-09-03 | 2019-10-03 | 1444 |  |  | 2019-09-03 | 2019-10-03 | 23d |  |  | 940d | 0d | Verde | Verde | 0% |  | 0% |  | Verde | 0% | 0% |  |  | Verde |
| 1446 | 2.3.16.2.1.5 | Projeto concluído | milestone | 0d | 2019-10-03 | 2019-10-03 | 1445, 1437 |  |  | 2019-10-03 | 2019-10-03 | 0d |  |  | 940d | 0d | Verde | Verde | 0% |  | 0% |  | Verde | 0% | 0% |  |  | Verde |
| 1447 | 2.3.16.2.2 | **Licitação da obra** |  | 80d | 2019-10-03 | 2020-01-30 |  |  |  | 2019-10-03 | 2020-01-30 | 80d |  |  | 940d |  | Verde | Verde | 0% |  | 0% |  | Verde | 0% | 0% |  |  |  |
| 1448 | 2.3.16.2.2.1 | Licitação da obra autorizada pelo banco | milestone | 0d | 2019-10-03 | 2019-10-03 | 1446 |  |  | 2019-10-03 | 2019-10-03 | 0d |  |  | 940d | 0d | Verde | Verde | 0% |  | 0% |  | Verde | 0% | 0% |  |  | Verde |
| 1449 | 2.3.16.2.2.2 | Licitar obra |  | 66d | 2019-10-04 | 2020-01-10 | 1448 |  |  | 2019-10-04 | 2020-01-10 | 66d |  |  | 940d | 0d | Verde | Verde | 0% |  | 0% |  | Verde | 0% | 0% |  |  | Verde |
| 1450 | 2.3.16.2.2.3 | Analisar e emitir resultado da licitação da obra |  | 14d | 2020-01-13 | 2020-01-30 | 1449 |  |  | 2020-01-13 | 2020-01-30 | 14d |  |  | 940d | 0d | Verde | Verde | 0% |  | 0% |  | Verde | 0% | 0% |  |  | Verde |
| 1451 | 2.3.16.2.2.4 | Licitação da obra concluída | milestone | 0d | 2020-01-30 | 2020-01-30 | 1450 |  |  | 2020-01-30 | 2020-01-30 | 0d |  |  | 940d | 0d | Verde | Verde | 0% |  | 0% |  | Verde | 0% | 0% |  |  | Verde |
| 1452 | 2.3.16.2.3 | Executar obra |  | 168d | 2020-03-02 | 2020-10-29 | 1451FS+18d |  |  | 2020-03-02 | 2020-10-29 | 168d |  |  | 940d | 0d | Verde | Verde | 0% |  | 0% |  | Verde | 0% | 0% |  |  | Verde |
| 1453 | 2.3.16.2.4 | Realizar processo de pré-operação |  | 128d | 2020-10-30 | 2021-05-10 | 1452 |  |  | 2020-10-30 | 2021-05-10 | 128d |  |  | 940d | 0d | Verde | Verde | 0% |  | 0% |  | Verde | 0% | 0% |  |  | Verde |
| 1454 | 2.3.16.2.5 | Recurso da obra parcelado repassado | milestone | 0d | 2021-05-17 | 2021-05-17 | 1453FS+5d |  |  | 2021-05-17 | 2021-05-17 | 0d |  |  | 940d | 0d | Verde | Verde | 0% |  | 0% |  | Verde | 0% | 0% |  |  | Verde |
| 1455 | 2.3.16.2.6 | Pleito IAPRSOB02 concluído | milestone | 0d | 2021-05-17 | 2021-05-17 | 1454 |  |  | 2021-05-17 | 2021-05-17 | 0d |  |  | 940d | 0d | Verde | Verde | 0% |  | 0% |  | Verde | 0% | 0% |  |  | Verde |

Notes:
- 1429: Iapu solicitou mudança de pleito e foi autorizado pelo CIF na NT21. / Iapu teve 87,3% (R$5.502.219,94) dos recursos destinado para Esgotamento Sanitário aprovado, conforme Deliberação 75. / O pleito de resíduos sólido (10% do total do recurso destinado ao munícipio, R$630.265,74), foi aprovado na NT20.
- 1433: Em 29/04/2019: atualizado como agendado

| ID | WBS | Task | Type | Duration | Start | Finish | Predecessors | Complete | Remaining | Baseline start | Baseline finish | Baseline duration | Baseline 1 start | Baseline 1 finish | Total slack | Free slack | Constraint | Farol de Atraso | Farol Marcos | % Previsto Tempo | Índice de Desempenho Físico (IDF) | IDF Numérico | Farol IDF | % Previsto Ponderado | % Concluído Ponderado | % Concluída Numérico | % Previsto Tempo Numérico | % Previsto Ponderado Numérico | Farol de Início | % Concluído Ponderado Numérico | Responsável | Código do Contrato |
| --- | --- | --- | --- | --- | --- | --- | --- | --- | --- | --- | --- | --- | --- | --- | --- | --- | --- | --- | --- | --- | --- | --- | --- | --- | --- | --- | --- | --- | --- | --- | --- | --- |
| 1456 | 2.3.16.3 | **Pleito IAPESOB03 - Implantação de sistema de coleta e tratamento de esgoto sanitário** |  | 618d | 2019-03-28 A | 2021-09-20 |  | 2% | 606.84d | 2019-03-28 | 2021-09-20 | 618d |  |  | 852d |  |  | Verde | Verde | 3% | 100% | 100 | Verde | 1% | 1% |  |  |  |  |  |  |  |
| 1457 | 2.3.16.3.1 | Alteração do pleito aprovada | milestone | 0d | 2019-03-28 A | 2019-03-28 A |  | 100% |  | 2019-03-28 | 2019-03-28 | 0d |  |  |  |  | must start on 2019-03-28 | Verde | Verde | 100% | 0% |  | Vermelho | 100% | 0% | 100 | 100 | 100 | Verde |  |  |  |
| 1458 | 2.3.16.3.2 | **Aprovação do Projeto Executivo** |  | 65d | 2019-04-15 A | 2019-07-19 |  | 14% | 56d | 2019-04-15 | 2019-07-19 | 65d |  |  | 852d |  |  | Verde | Verde | 13% | 100% | 100 | Verde | 16% | 16% | 14 | 13 | 16 |  | 16 |  |  |
| 1459 | 2.3.16.3.2.1 | Projeto apresentado ao banco | milestone | 0d | 2019-04-15 A | 2019-04-15 A | 1457FS+13d | 100% |  | 2019-04-15 | 2019-04-15 | 0d |  |  |  |  |  | Verde | Verde | 100% | 0% |  | Vermelho | 100% | 0% | 100 | 100 | 100 | Verde |  |  |  |
| 1460 | 2.3.16.3.2.2 | Analisar projeto |  | 19d | 2019-04-16 A | 2019-05-15 | 1459 | 47% | 10d | 2019-04-16 | 2019-05-15 | 19d |  |  | 852d | 0d |  | Verde | Verde | 47% | 100% | 100 | Verde | 47% | 47% | 47 | 47 | 47 | Verde | 47 |  |  |
| 1461 | 2.3.16.3.2.3 | Adequar/revisar projeto |  | 24d | 2019-05-16 | 2019-06-18 | 1460 |  |  | 2019-05-16 | 2019-06-18 | 24d |  |  | 852d | 0d |  | Verde | Verde | 0% | 0% |  | Verde | 0% | 0% |  |  |  | Verde |  |  |  |
| 1462 | 2.3.16.3.2.4 | Analisar projeto - final |  | 22d | 2019-06-19 | 2019-07-19 | 1461 |  |  | 2019-06-19 | 2019-07-19 | 22d |  |  | 852d | 0d |  | Verde | Verde | 0% | 0% |  | Verde | 0% | 0% |  |  |  | Verde |  |  |  |
| 1463 | 2.3.16.3.2.5 | Projeto concluído | milestone | 0d | 2019-07-19 | 2019-07-19 | 1462 |  |  | 2019-07-19 | 2019-07-19 | 0d |  |  | 852d | 0d |  | Verde | Verde | 0% | 0% |  | Verde | 0% | 0% |  |  |  | Verde |  |  |  |
| 1464 | 2.3.16.3.3 | Realizar Licenciamento Ambiental |  | 29d | 2019-04-29 A | 2019-06-07 | 1459FS+7d | 7% | 27d | 2019-04-29 | 2019-06-07 | 29d |  |  | 881d | 29d |  | Verde | Verde | 6% | 83% | 83 | Vermelho | 6% | 5% |  |  |  | Verde |  |  |  |
| 1465 | 2.3.16.3.4 | **Licitação da obra** |  | 80d | 2019-07-19 | 2019-11-11 |  |  |  | 2019-07-19 | 2019-11-11 | 80d |  |  | 852d |  |  | Verde | Verde | 0% | 0% |  | Verde | 0% | 0% |  |  |  |  |  |  |  |
| 1466 | 2.3.16.3.4.1 | Licitação da obra autorizada pelo banco | milestone | 0d | 2019-07-19 | 2019-07-19 | 1463, 1464, 1483 |  |  | 2019-07-19 | 2019-07-19 | 0d |  |  | 852d | 0d |  | Verde | Verde | 0% | 0% |  | Verde | 0% | 0% |  |  |  | Verde |  |  |  |
| 1467 | 2.3.16.3.4.2 | Licitar obra |  | 66d | 2019-07-22 | 2019-10-22 | 1466 |  |  | 2019-07-22 | 2019-10-22 | 66d |  |  | 852d | 0d |  | Verde | Verde | 0% | 0% |  | Verde | 0% | 0% |  |  |  | Verde |  |  |  |
| 1468 | 2.3.16.3.4.3 | Analisar e emitir resultado da licitação da obra |  | 14d | 2019-10-23 | 2019-11-11 | 1467 |  |  | 2019-10-23 | 2019-11-11 | 14d |  |  | 852d | 0d |  | Verde | Verde | 0% | 0% |  | Verde | 0% | 0% |  |  |  | Verde |  |  |  |
| 1469 | 2.3.16.3.4.4 | Licitação da obra concluída | milestone | 0d | 2019-11-11 | 2019-11-11 | 1468 |  |  | 2019-11-11 | 2019-11-11 | 0d |  |  | 852d | 0d |  | Verde | Verde | 0% | 0% |  | Verde | 0% | 0% |  |  |  | Verde |  |  |  |
| 1470 | 2.3.16.3.5 | Executar obra |  | 307d | 2019-12-11 | 2021-03-11 | 1469FS+20d |  |  | 2019-12-11 | 2021-03-11 | 307d |  |  | 852d | 0d |  | Verde | Verde | 0% | 0% |  | Verde | 0% | 0% |  |  |  | Verde |  |  |  |
| 1471 | 2.3.16.3.6 | Realizar processo de pré-operação |  | 128d | 2021-03-12 | 2021-09-13 | 1470 |  |  | 2021-03-12 | 2021-09-13 | 128d | 2020-07-26 | 2021-01-22 | 852d | 0d |  | Verde | Verde | 0% | 0% |  | Verde | 0% | 0% |  |  |  | Verde |  | 02 - Execução | PG 031 |
| 1472 | 2.3.16.3.7 | Recurso da obra parcelado repassado | milestone | 0d | 2021-09-20 | 2021-09-20 | 1471FS+5d |  |  | 2021-09-20 | 2021-09-20 | 0d |  |  | 852d | 0d |  | Verde | Verde | 0% | 0% |  | Verde | 0% | 0% |  |  |  | Verde |  |  |  |
| 1473 | 2.3.16.3.8 | Pleito IAPESOB03 concluído | milestone | 0d | 2021-09-20 | 2021-09-20 | 1472 |  |  | 2021-09-20 | 2021-09-20 | 0d |  |  | 852d | 0d |  | Verde | Verde | 0% | 0% |  | Verde | 0% | 0% |  |  |  | Verde |  |  |  |
| 1474 | 2.3.16.4 | **Pleito IAPESCT01 - Aquisição de terreno para implantação de estação de tratamento de esgoto** |  | 62d | 2019-03-28 A | 2019-06-27 |  | 21% | 48.95d | 2019-03-28 | 2019-06-27 | 62d |  |  | 1408d |  |  | Verde | Verde | 35% | 82% | 82 | Vermelho | 22% | 18% | 21 | 35 | 22 |  | 18 |  |  |
| 1475 | 2.3.16.4.1 | Pleito aprovado | milestone | 0d | 2019-03-28 A | 2019-03-28 A |  | 100% |  | 2019-03-28 | 2019-03-28 | 0d |  |  |  |  | must start on 2019-03-28 | Verde | Verde | 100% | 0% |  | Vermelho | 100% | 0% | 100 | 100 | 100 | Verde |  |  |  |
| 1476 | 2.3.16.4.2 | **Aquisição de Terreno** |  | 52d | 2019-04-11 A | 2019-06-27 |  | 21% | 41.05d | 2019-04-11 | 2019-06-27 | 52d |  |  | 868d |  |  | Verde | Verde | 23% | 82% | 82 | Vermelho | 22% | 18% | 21 | 23 | 22 |  | 18 |  |  |
| 1477 | 2.3.16.4.2.1 | Regularizar terreno e apresentar escritura ao banco |  | 25d | 2019-04-11 A | 2019-05-20 | 1475FS+10d | 48% | 13d | 2019-04-11 | 2019-05-20 | 25d |  |  | 868d | 0d |  | Verde | Verde | 48% | 83% | 83 | Vermelho | 48% | 40% | 48 | 48 | 48 | Verde | 40 |  |  |
| 1478 | 2.3.16.4.2.2 | Analisar documentação do terreno |  | 10d | 2019-05-21 | 2019-06-03 | 1477 |  |  | 2019-05-21 | 2019-06-03 | 10d |  |  | 880d | 0d |  | Verde | Verde | 0% | 0% |  | Verde | 0% | 0% |  |  |  | Verde |  |  |  |
| 1479 | 2.3.16.4.2.3 | 50% do valor do imóvel repassado (1) | milestone | 0d | 2019-06-10 | 2019-06-10 | 1478FS+5d |  |  | 2019-06-10 | 2019-06-10 | 0d |  |  | 880d | 12d |  | Verde | Verde | 0% | 0% |  | Verde | 0% | 0% |  |  |  | Verde |  |  |  |
| 1480 | 2.3.16.4.2.4 | Registrar imóvel e apresentar documentação ao banco |  | 12d | 2019-05-21 | 2019-06-05 | 1477 |  |  | 2019-05-21 | 2019-06-05 | 12d |  |  | 868d | 0d |  | Verde | Verde | 0% | 0% |  | Verde | 0% | 0% |  |  |  | Verde |  |  |  |
| 1481 | 2.3.16.4.2.5 | Analisar documentação do terreno |  | 10d | 2019-06-06 | 2019-06-19 | 1480 |  |  | 2019-06-06 | 2019-06-19 | 10d |  |  | 868d | 0d |  | Verde | Verde | 0% | 0% |  | Verde | 0% | 0% |  |  |  | Verde |  |  |  |
| 1482 | 2.3.16.4.2.6 | 50% do valor do imóvel repassado (2) | milestone | 0d | 2019-06-27 | 2019-06-27 | 1481FS+5d |  |  | 2019-06-27 | 2019-06-27 | 0d |  |  | 868d | 0d |  | Verde | Verde | 0% | 0% |  | Verde | 0% | 0% |  |  |  | Verde |  |  |  |
| 1483 | 2.3.16.4.2.7 | Aquisição de terreno concluída | milestone | 0d | 2019-06-27 | 2019-06-27 | 1482, 1479 |  |  | 2019-06-27 | 2019-06-27 | 0d |  |  | 868d | 0d |  | Verde | Verde | 0% | 0% |  | Verde | 0% | 0% |  |  |  | Verde |  |  |  |
| 1484 | 2.3.16.4.3 | Pleito IAPESCT1 concluído | milestone | 0d | 2019-06-27 | 2019-06-27 | 1483 |  |  | 2019-06-27 | 2019-06-27 | 0d |  |  | 1408d | 556d |  | Verde | Verde | 0% | 0% |  | Verde | 0% | 0% |  |  |  | Verde |  |  |  |
| 1485 | 2.3.16.5 | Recursos de Iapu repassados | milestone | 0d | 2021-09-20 | 2021-09-20 | 1484, 1473, 1455, 1439 |  |  | 2021-09-20 | 2021-09-20 | 0d | 2019-06-02 | 2021-01-22 | 852d |  |  | Verde | Verde | 0% | 0% |  | Verde | 0% | 0% |  |  |  | Verde |  | 02 - Execução | PG 031 |

Notes:
- 1460: Em 29/04/2019: atualizado como agendado
- 1464: Em 29/04/2019: atualizado como agendado
- 1477: Em 29/04/2019: atualizado como agendado
- 1485: Valor de recurso destinado ao munícipio: R$6.302.657,43

| ID | WBS | Task | Type | Duration | Start | Finish | Predecessors | Complete | Remaining | Baseline start | Baseline finish | Baseline duration | Baseline 1 start | Baseline 1 finish | Total slack | Free slack | Farol de Atraso | Farol Marcos | % Previsto Tempo | % Previsto Tempo Numérico | Índice de Desempenho Físico (IDF) | Farol IDF | % Previsto Ponderado | % Concluído Ponderado | Farol de Início | % Concluída Numérico | % Previsto Ponderado Numérico |
| --- | --- | --- | --- | --- | --- | --- | --- | --- | --- | --- | --- | --- | --- | --- | --- | --- | --- | --- | --- | --- | --- | --- | --- | --- | --- | --- | --- |
| 1486 | 2.3.17 | **Ipaba** |  | 971d | 2018-12-03 A | 2022-10-26 |  | 7% | 899.96d | 2018-12-03 | 2022-10-26 | 971d | 2018-09-04 | 2021-05-21 | 578d |  | Verde | Verde | 10% | 10 | 0% | Vermelho | 0% | 0% |  |  |  |
| 1487 | 2.3.17.1 | **Pleito IPBESPJ01 - Elaboração de projeto de sistema de esgotamento sanitário da sede do município e povoado de Boachá** |  | 319d | 2019-03-11 A | 2020-06-22 |  | 5% | 301.82d | 2019-03-11 | 2020-06-22 | 319d |  |  | 578d |  | Verde | Verde | 10% | 10 | 0% | Vermelho | 1% | 0% |  |  |  |
| 1488 | 2.3.17.1.1 | **Licitação do Projeto** |  | 64d | 2019-05-06 | 2019-08-02 |  |  |  | 2019-05-06 | 2019-08-02 | 64d |  |  | 35d |  | Verde | Verde | 0% |  | 0% | Verde | 0% | 0% |  |  |  |
| 1489 | 2.3.17.1.1.1 | Licitar projeto |  | 45d | 2019-05-06 | 2019-07-08 | 206FS+95d |  |  | 2019-05-06 | 2019-07-08 | 45d |  |  | 35d | 0d | Verde | Verde | 0% |  | 0% | Verde | 0% | 0% | Verde |  |  |
| 1490 | 2.3.17.1.1.2 | Documentação de licitação apresentada ao banco | milestone | 0d | 2019-07-15 | 2019-07-15 | 1489FS+5d |  |  | 2019-07-15 | 2019-07-15 | 0d |  |  | 35d | 0d | Verde | Verde | 0% |  | 0% | Verde | 0% | 0% | Verde |  |  |
| 1491 | 2.3.17.1.1.3 | Analisar e emitir resultado da licitação do projeto |  | 14d | 2019-07-16 | 2019-08-02 | 1490 |  |  | 2019-07-16 | 2019-08-02 | 14d |  |  | 35d | 0d | Verde | Verde | 0% |  | 0% | Verde | 0% | 0% | Verde |  |  |
| 1492 | 2.3.17.1.1.4 | Licitação do projeto concluída | milestone | 0d | 2019-08-02 | 2019-08-02 | 1491 |  |  | 2019-08-02 | 2019-08-02 | 0d |  |  | 35d | 0d | Verde | Verde | 0% |  | 0% | Verde | 0% | 0% | Verde |  |  |
| 1493 | 2.3.17.1.2 | **Elaboração do Projeto Básico** |  | 135d | 2019-08-05 | 2020-02-17 |  |  |  | 2019-08-05 | 2020-02-17 | 135d |  |  | 35d |  | Verde | Verde | 0% |  | 0% | Verde | 0% | 0% |  |  |  |
| 1494 | 2.3.17.1.2.1 | Elaborar Projeto Básico |  | 66d | 2019-08-05 | 2019-11-05 | 1492 |  |  | 2019-08-05 | 2019-11-05 | 66d |  |  | 35d | 0d | Verde | Verde | 0% |  | 0% | Verde | 0% | 0% | Verde |  |  |
| 1495 | 2.3.17.1.2.2 | Projeto básico apresentado ao banco | milestone | 0d | 2019-11-05 | 2019-11-05 | 1494 |  |  | 2019-11-05 | 2019-11-05 | 0d |  |  | 35d | 0d | Verde | Verde | 0% |  | 0% | Verde | 0% | 0% | Verde |  |  |
| 1496 | 2.3.17.1.2.3 | Analisar projeto básico |  | 22d | 2019-11-06 | 2019-12-06 | 1495 |  |  | 2019-11-06 | 2019-12-06 | 22d |  |  | 656d | 0d | Verde | Verde | 0% |  | 0% | Verde | 0% | 0% | Verde |  |  |
| 1497 | 2.3.17.1.2.4 | Adequar/revisar projeto básico |  | 20d | 2019-12-09 | 2020-01-09 | 1496 |  |  | 2019-12-09 | 2020-01-09 | 20d |  |  | 656d | 0d | Verde | Verde | 0% |  | 0% | Verde | 0% | 0% | Verde |  |  |
| 1498 | 2.3.17.1.2.5 | Analisar projeto básico - final |  | 22d | 2020-01-10 | 2020-02-10 | 1497 |  |  | 2020-01-10 | 2020-02-10 | 22d |  |  | 656d | 0d | Verde | Verde | 0% |  | 0% | Verde | 0% | 0% | Verde |  |  |
| 1499 | 2.3.17.1.2.6 | Projeto básico concluído | milestone | 0d | 2020-02-10 | 2020-02-10 | 1498 |  |  | 2020-02-10 | 2020-02-10 | 0d |  |  | 656d | 0d | Verde | Verde | 0% |  | 0% | Verde | 0% | 0% | Verde |  |  |
| 1500 | 2.3.17.1.2.7 | Recurso do projeto básico do pleito IPBESOB01 repassado | milestone | 0d | 2020-02-17 | 2020-02-17 | 1499FS+5d |  |  | 2020-02-17 | 2020-02-17 | 0d |  |  | 656d | 78d | Verde | Verde | 0% |  | 0% | Verde | 0% | 0% | Verde |  |  |
| 1501 | 2.3.17.1.3 | Realizar Licenciamento Ambiental |  | 314d | 2019-03-11 A | 2020-06-15 | 1495FS-167d | 11% | 279d | 2019-03-11 | 2020-06-15 | 314d |  |  | 578d | 0d | Verde | Verde | 11% | 11 | 0% | Vermelho | 11% | 0% | Verde | 11 | 11 |
| 1502 | 2.3.17.1.4 | **Elaboração do Projeto Executivo** |  | 152d | 2019-11-06 | 2020-06-22 |  |  |  | 2019-11-06 | 2020-06-22 | 152d |  |  | 578d |  | Verde | Verde | 0% |  | 0% | Verde | 0% | 0% |  |  |  |
| 1503 | 2.3.17.1.4.1 | Elaborar Projeto Executivo |  | 80d | 2019-11-06 | 2020-03-06 | 1494 |  |  | 2019-11-06 | 2020-03-06 | 80d |  |  | 578d | 0d | Verde | Verde | 0% |  | 0% | Verde | 0% | 0% | Verde |  |  |
| 1504 | 2.3.17.1.4.2 | Projeto executivo apresentado ao banco | milestone | 0d | 2020-03-06 | 2020-03-06 | 1503 |  |  | 2020-03-06 | 2020-03-06 | 0d |  |  | 578d | 0d | Verde | Verde | 0% |  | 0% | Verde | 0% | 0% | Verde |  |  |
| 1505 | 2.3.17.1.4.3 | Analisar projeto executivo |  | 24d | 2020-03-09 | 2020-04-09 | 1504 |  |  | 2020-03-09 | 2020-04-09 | 24d |  |  | 578d | 0d | Verde | Verde | 0% |  | 0% | Verde | 0% | 0% | Verde |  |  |
| 1506 | 2.3.17.1.4.4 | Adequar/revisar projeto executivo |  | 21d | 2020-04-13 | 2020-05-13 | 1505 |  |  | 2020-04-13 | 2020-05-13 | 21d |  |  | 578d | 0d | Verde | Verde | 0% |  | 0% | Verde | 0% | 0% | Verde |  |  |
| 1507 | 2.3.17.1.4.5 | Analisar projeto executivo - final |  | 22d | 2020-05-14 | 2020-06-15 | 1506 |  |  | 2020-05-14 | 2020-06-15 | 22d |  |  | 578d | 0d | Verde | Verde | 0% |  | 0% | Verde | 0% | 0% | Verde |  |  |
| 1508 | 2.3.17.1.4.6 | Projeto executivo concluído | milestone | 0d | 2020-06-15 | 2020-06-15 | 1507, 1500, 1501 |  |  | 2020-06-15 | 2020-06-15 | 0d |  |  | 578d | 0d | Verde | Verde | 0% |  | 0% | Verde | 0% | 0% | Verde |  |  |
| 1509 | 2.3.17.1.4.7 | Recurso do projeto executivo do pleito IPBESOB01 repassado | milestone | 0d | 2020-06-22 | 2020-06-22 | 1508FS+5d |  |  | 2020-06-22 | 2020-06-22 | 0d |  |  | 578d | 0d | Verde | Verde | 0% |  | 0% | Verde | 0% | 0% | Verde |  |  |
| 1510 | 2.3.17.1.5 | Pleito IPBESPJ01 concluído | milestone | 0d | 2020-06-22 | 2020-06-22 | 1509 |  |  | 2020-06-22 | 2020-06-22 | 0d |  |  | 578d | 0d | Verde | Verde | 0% |  | 0% | Verde | 0% | 0% | Verde |  |  |

Notes:
- 1486: Ipaba teve 100% dos pleitos de Esgotamento Sanitário Aprovado, conforme Deliberação 75. / O pleito de resíduos sólido (10% do total do recurso destinado ao munícipio, R$945.398,61) foi aprovado na NT20. / Aderiu à ata de registro de preço.
- 1489: Em 30/04/2019: prazo redefinido para município finalizar a licitação do projeto
- 1501: Em 29/04/2019: atualizado como agendado

| ID | WBS | Task | Type | Duration | Start | Finish | Predecessors | Complete | Remaining | Baseline start | Baseline finish | Baseline duration | Baseline 1 start | Baseline 1 finish | Total slack | Free slack | Farol de Atraso | Farol Marcos | % Previsto Tempo | Índice de Desempenho Físico (IDF) | Farol IDF | % Previsto Ponderado | % Concluído Ponderado | Farol de Início | Responsável | Código do Contrato | % Concluída Numérico | % Previsto Tempo Numérico | % Previsto Ponderado Numérico |
| --- | --- | --- | --- | --- | --- | --- | --- | --- | --- | --- | --- | --- | --- | --- | --- | --- | --- | --- | --- | --- | --- | --- | --- | --- | --- | --- | --- | --- | --- |
| 1511 | 2.3.17.2 | **Pleito IPBESOB01 - Implantação de sistema de esgotamento sanitário da sede do município e povoado de Boachá** |  | 586d | 2020-06-22 | 2022-10-26 |  |  |  | 2020-06-22 | 2022-10-26 | 586d |  |  | 578d |  | Verde | Verde | 0% | 0% | Verde | 0% | 0% |  |  |  |  |  |  |
| 1512 | 2.3.17.2.1 | **Licitação da Obra** |  | 60d | 2020-06-22 | 2020-09-15 |  |  |  | 2020-06-22 | 2020-09-15 | 60d |  |  | 578d |  | Verde | Verde | 0% | 0% | Verde | 0% | 0% |  |  |  |  |  |  |
| 1513 | 2.3.17.2.1.1 | Licitação da obra autorizada pelo banco | milestone | 0d | 2020-06-22 | 2020-06-22 | 1510 |  |  | 2020-06-22 | 2020-06-22 | 0d |  |  | 578d | 0d | Verde | Verde | 0% | 0% | Verde | 0% | 0% | Verde |  |  |  |  |  |
| 1514 | 2.3.17.2.1.2 | Licitar Obra |  | 46d | 2020-06-23 | 2020-08-25 | 1513 |  |  | 2020-06-23 | 2020-08-25 | 46d |  |  | 578d | 0d | Verde | Verde | 0% | 0% | Verde | 0% | 0% | Verde |  |  |  |  |  |
| 1515 | 2.3.17.2.1.3 | Analisar e emitir resultado da licitação da obra |  | 14d | 2020-08-26 | 2020-09-15 | 1514 |  |  | 2020-08-26 | 2020-09-15 | 14d |  |  | 578d | 0d | Verde | Verde | 0% | 0% | Verde | 0% | 0% | Verde |  |  |  |  |  |
| 1516 | 2.3.17.2.1.4 | Licitação da obra concluída | milestone | 0d | 2020-09-15 | 2020-09-15 | 1515 |  |  | 2020-09-15 | 2020-09-15 | 0d |  |  | 578d | 0d | Verde | Verde | 0% | 0% | Verde | 0% | 0% | Verde |  |  |  |  |  |
| 1517 | 2.3.17.2.2 | Executar obra |  | 374d | 2020-10-15 | 2022-04-18 | 1516FS+20d |  |  | 2020-10-15 | 2022-04-18 | 374d |  |  | 578d | 0d | Verde | Verde | 0% | 0% | Verde | 0% | 0% | Verde |  |  |  |  |  |
| 1518 | 2.3.17.2.3 | Realizar processo de pré-operação |  | 127d | 2022-04-19 | 2022-10-19 | 1517 |  |  | 2022-04-19 | 2022-10-19 | 127d | 2020-11-22 | 2021-05-21 | 578d | 0d | Verde | Verde | 0% | 0% | Verde | 0% | 0% | Verde | 02 - Execução | PG 031 |  |  |  |
| 1519 | 2.3.17.2.4 | Recurso da obra parcelado repassado | milestone | 0d | 2022-10-26 | 2022-10-26 | 1518FS+5d |  |  | 2022-10-26 | 2022-10-26 | 0d |  |  | 578d | 0d | Verde | Verde | 0% | 0% | Verde | 0% | 0% | Verde |  |  |  |  |  |
| 1520 | 2.3.17.2.5 | Pleito IPBESOB01 concluído | milestone | 0d | 2022-10-26 | 2022-10-26 | 1519 |  |  | 2022-10-26 | 2022-10-26 | 0d |  |  | 578d | 0d | Verde | Verde | 0% | 0% | Verde | 0% | 0% | Verde |  |  |  |  |  |
| 1521 | 2.3.17.3 | **Pleito IPBRSPM01 - Elaboração de estudos ambientais** |  | 214d | 2018-12-03 A | 2019-10-09 |  | 50% | 108.05d | 2018-12-03 | 2019-10-09 | 214d |  |  | 1335d |  | Verde | Verde | 47% | 0% | Vermelho | 14% | 0% |  |  |  | 50 | 47 | 14 |
| 1522 | 2.3.17.3.1 | **Licitação de Empresa para Licenciamento Ambiental** |  | 161d | 2018-12-03 A | 2019-07-25 |  | 65% | 56.76d | 2018-12-03 | 2019-07-25 | 161d |  |  | 941d |  | Verde | Verde | 62% | 0% | Vermelho | 36% | 0% |  |  |  | 65 | 62 | 36 |
| 1523 | 2.3.17.3.1.1 | Licitação da empresa para Licenciamento Ambiental autorizada pelo banco | milestone | 0d | 2018-12-03 A | 2018-12-03 A | 544 | 100% |  | 2018-12-03 | 2018-12-03 | 0d |  |  |  |  | Verde | Verde | 100% | 0% | Vermelho | 100% | 0% | Verde |  |  | 100 | 100 | 100 |
| 1524 | 2.3.17.3.1.2 | Licitar empresa para Licenciamento Ambiental |  | 142d | 2018-12-03 A | 2019-06-28 | 1523 | 71% | 41d | 2018-12-03 | 2019-06-28 | 142d |  |  | 941d | 0d | Verde | Verde | 71% | 0% | Vermelho | 71% | 0% | Verde |  |  | 71 | 71 | 71 |
| 1525 | 2.3.17.3.1.3 | Documentação de licitação apresentada ao banco | milestone | 0d | 2019-07-05 | 2019-07-05 | 1524FS+5d |  |  | 2019-07-05 | 2019-07-05 | 0d |  |  | 941d | 0d | Verde | Verde | 0% | 0% | Verde | 0% | 0% | Verde |  |  |  |  |  |
| 1526 | 2.3.17.3.1.4 | Analisar e emitir resultado da licitação do empresa para Licenciamento Ambiental |  | 14d | 2019-07-08 | 2019-07-25 | 1525 |  |  | 2019-07-08 | 2019-07-25 | 14d |  |  | 941d | 0d | Verde | Verde | 0% | 0% | Verde | 0% | 0% | Verde |  |  |  |  |  |
| 1527 | 2.3.17.3.1.5 | Licitação da empresa para Licenciamento Ambiental concluída | milestone | 0d | 2019-07-25 | 2019-07-25 | 1526 |  |  | 2019-07-25 | 2019-07-25 | 0d |  |  | 941d | 0d | Verde | Verde | 0% | 0% | Verde | 0% | 0% | Verde |  |  |  |  |  |
| 1528 | 2.3.17.3.2 | Executar o Licenciamento Ambiental |  | 48d | 2019-07-26 | 2019-10-02 | 1527 |  |  | 2019-07-26 | 2019-10-02 | 48d |  |  | 941d | 0d | Verde | Verde | 0% | 0% | Verde | 0% | 0% | Verde |  |  |  |  |  |
| 1529 | 2.3.17.3.3 | Recurso do serviço parcelado repassado | milestone | 0d | 2019-10-09 | 2019-10-09 | 1528FS+5d |  |  | 2019-10-09 | 2019-10-09 | 0d |  |  | 1335d | 0d | Verde | Verde | 0% | 0% | Verde | 0% | 0% | Verde |  |  |  |  |  |
| 1530 | 2.3.17.3.4 | Pleito IPBRSPM01 concluído | milestone | 0d | 2019-10-09 | 2019-10-09 | 1529 |  |  | 2019-10-09 | 2019-10-09 | 0d |  |  | 1335d | 395d | Verde | Verde | 0% | 0% | Verde | 0% | 0% | Verde |  |  |  |  |  |
| 1531 | 2.3.17.4 | **Pleito IPBRSOB02 - Implantação de aterro sanitário** |  | 467d | 2019-06-28 | 2021-05-17 |  |  |  | 2019-06-28 | 2021-05-17 | 467d |  |  | 940d |  | Verde | Verde | 0% | 0% | Verde | 0% | 0% |  |  |  |  |  |  |
| 1532 | 2.3.17.4.1 | **Aprovação do Projeto Executivo** |  | 68d | 2019-06-28 | 2019-10-03 |  |  |  | 2019-06-28 | 2019-10-03 | 68d |  |  | 940d |  | Verde | Verde | 0% | 0% | Verde | 0% | 0% |  |  |  |  |  |  |
| 1533 | 2.3.17.4.1.1 | Projeto apresentado ao banco | milestone | 0d | 2019-06-28 | 2019-06-28 | 554 |  |  | 2019-06-28 | 2019-06-28 | 0d |  |  | 940d | 0d | Verde | Verde | 0% | 0% | Verde | 0% | 0% | Verde |  |  |  |  |  |
| 1534 | 2.3.17.4.1.2 | Analisar projeto |  | 22d | 2019-07-01 | 2019-07-30 | 1533 |  |  | 2019-07-01 | 2019-07-30 | 22d |  |  | 940d | 0d | Verde | Verde | 0% | 0% | Verde | 0% | 0% | Verde |  |  |  |  |  |
| 1535 | 2.3.17.4.1.3 | Adequar/revisar projeto |  | 23d | 2019-07-31 | 2019-09-02 | 1534 |  |  | 2019-07-31 | 2019-09-02 | 23d |  |  | 940d | 0d | Verde | Verde | 0% | 0% | Verde | 0% | 0% | Verde |  |  |  |  |  |
| 1536 | 2.3.17.4.1.4 | Analisar projeto - final |  | 23d | 2019-09-03 | 2019-10-03 | 1535 |  |  | 2019-09-03 | 2019-10-03 | 23d |  |  | 940d | 0d | Verde | Verde | 0% | 0% | Verde | 0% | 0% | Verde |  |  |  |  |  |
| 1537 | 2.3.17.4.1.5 | Projeto concluído | milestone | 0d | 2019-10-03 | 2019-10-03 | 1536, 1528 |  |  | 2019-10-03 | 2019-10-03 | 0d |  |  | 940d | 0d | Verde | Verde | 0% | 0% | Verde | 0% | 0% | Verde |  |  |  |  |  |

Notes:
- 1524: Em 29/04/2019: atualizado como agendado

| ID | WBS | Task | Type | Duration | Start | Finish | Predecessors | Complete | Remaining | Baseline start | Baseline finish | Baseline duration | Baseline 1 start | Baseline 1 finish | Total slack | Free slack | Farol de Atraso | Farol Marcos | % Previsto Tempo | Índice de Desempenho Físico (IDF) | Farol IDF | % Previsto Ponderado | % Concluído Ponderado | Farol de Início | Responsável | Código do Contrato | % Previsto Tempo Numérico | IDF Numérico | % Concluída Numérico | % Previsto Ponderado Numérico | % Concluído Ponderado Numérico |
| --- | --- | --- | --- | --- | --- | --- | --- | --- | --- | --- | --- | --- | --- | --- | --- | --- | --- | --- | --- | --- | --- | --- | --- | --- | --- | --- | --- | --- | --- | --- | --- |
| 1538 | 2.3.17.4.2 | **Licitação da obra** |  | 80d | 2019-10-03 | 2020-01-30 |  |  |  | 2019-10-03 | 2020-01-30 | 80d |  |  | 940d |  | Verde | Verde | 0% | 0% | Verde | 0% | 0% |  |  |  |  |  |  |  |  |
| 1539 | 2.3.17.4.2.1 | Licitação da obra autorizada pelo banco | milestone | 0d | 2019-10-03 | 2019-10-03 | 1537 |  |  | 2019-10-03 | 2019-10-03 | 0d |  |  | 940d | 0d | Verde | Verde | 0% | 0% | Verde | 0% | 0% | Verde |  |  |  |  |  |  |  |
| 1540 | 2.3.17.4.2.2 | Licitar obra |  | 66d | 2019-10-04 | 2020-01-10 | 1539 |  |  | 2019-10-04 | 2020-01-10 | 66d |  |  | 940d | 0d | Verde | Verde | 0% | 0% | Verde | 0% | 0% | Verde |  |  |  |  |  |  |  |
| 1541 | 2.3.17.4.2.3 | Analisar e emitir resultado da licitação da obra |  | 14d | 2020-01-13 | 2020-01-30 | 1540 |  |  | 2020-01-13 | 2020-01-30 | 14d |  |  | 940d | 0d | Verde | Verde | 0% | 0% | Verde | 0% | 0% | Verde |  |  |  |  |  |  |  |
| 1542 | 2.3.17.4.2.4 | Licitação da obra concluída | milestone | 0d | 2020-01-30 | 2020-01-30 | 1541 |  |  | 2020-01-30 | 2020-01-30 | 0d |  |  | 940d | 0d | Verde | Verde | 0% | 0% | Verde | 0% | 0% | Verde |  |  |  |  |  |  |  |
| 1543 | 2.3.17.4.3 | Executar obra |  | 168d | 2020-03-02 | 2020-10-29 | 1542FS+18d |  |  | 2020-03-02 | 2020-10-29 | 168d |  |  | 940d | 0d | Verde | Verde | 0% | 0% | Verde | 0% | 0% | Verde |  |  |  |  |  |  |  |
| 1544 | 2.3.17.4.4 | Realizar processo de pré-operação |  | 128d | 2020-10-30 | 2021-05-10 | 1543 |  |  | 2020-10-30 | 2021-05-10 | 128d |  |  | 940d | 0d | Verde | Verde | 0% | 0% | Verde | 0% | 0% | Verde |  |  |  |  |  |  |  |
| 1545 | 2.3.17.4.5 | Recurso da obra parcelado repassado | milestone | 0d | 2021-05-17 | 2021-05-17 | 1544FS+5d |  |  | 2021-05-17 | 2021-05-17 | 0d |  |  | 940d | 0d | Verde | Verde | 0% | 0% | Verde | 0% | 0% | Verde |  |  |  |  |  |  |  |
| 1546 | 2.3.17.4.6 | Pleito IPBRSOB02 concluído | milestone | 0d | 2021-05-17 | 2021-05-17 | 1545 |  |  | 2021-05-17 | 2021-05-17 | 0d |  |  | 940d | 0d | Verde | Verde | 0% | 0% | Verde | 0% | 0% | Verde |  |  |  |  |  |  |  |
| 1547 | 2.3.17.5 | Recursos de Ipaba repassados | milestone | 0d | 2022-10-26 | 2022-10-26 | 1546, 1530, 1520, 1510 |  |  | 2022-10-26 | 2022-10-26 | 0d | 2019-04-02 | 2021-05-21 | 578d |  | Verde | Verde | 0% | 0% | Verde | 0% | 0% | Verde | 02 - Execução | PG 031 |  |  |  |  |  |
| 1548 | 2.3.18 | **Ipatinga** |  | 1230d | 2018-08-22 A | 2023-07-27 |  | 2% | 1203.16d | 2018-08-22 | 2023-07-27 | 1230d | 2018-12-04 | 2022-01-24 | 392d |  | Verde | Verde | 14% | 100% | Verde | 1% | 1% |  |  |  | 14 | 100 |  |  |  |
| 1549 | 2.3.18.1 | **Pleito IPAESOB01 - Ampliação do sistema de coleta e tratamento de esgoto da sede do município - Bairros Vila Celeste, Barra Alegre, Horto, Vila Militar e Forquilha** |  | 1088d | 2019-03-01 A | 2023-07-20 |  | 3% | 1056.79d | 2019-03-01 | 2023-07-20 | 1088d |  |  | 397d |  | Verde | Verde | 3% | 100% | Verde | 1% | 1% |  |  |  |  | 100 |  |  |  |
| 1550 | 2.3.18.1.1 | **Licitação do Projeto** |  | 85d | 2019-03-01 A | 2019-07-09 |  | 45% | 46.86d | 2019-03-01 | 2019-07-09 | 85d |  |  | 397d |  | Verde | Verde | 43% | 95% | Vermelho | 44% | 42% |  |  |  | 43 | 95 | 45 | 44 | 42 |
| 1551 | 2.3.18.1.1.1 | Licitação do projeto autorizada pelo banco | milestone | 0d | 2019-03-01 A | 2019-03-01 A | 206FS+56d | 100% |  | 2019-03-01 | 2019-03-01 | 0d |  |  |  |  | Verde | Verde | 100% | 0% | Vermelho | 100% | 0% | Verde |  |  | 100 |  | 100 | 100 |  |
| 1552 | 2.3.18.1.1.2 | Licitar projeto |  | 64d | 2019-03-11 A | 2019-06-11 | 1551FS+2d | 55% | 29d | 2019-03-11 | 2019-06-11 | 64d | 2018-12-04 | 2019-04-03 | 397d | 0d | Verde | Verde | 54% | 96% | Vermelho | 54% | 52% | Verde | 02 - Execução | PG 031 | 54 | 96 | 55 | 54 | 52 |
| 1553 | 2.3.18.1.1.3 | Documentação de licitação apresentada ao banco | milestone | 0d | 2019-06-18 | 2019-06-18 | 1552FS+5d |  |  | 2019-06-18 | 2019-06-18 | 0d |  |  | 397d | 0d | Verde | Verde | 0% | 0% | Verde | 0% | 0% | Verde |  |  |  |  |  |  |  |
| 1554 | 2.3.18.1.1.4 | Analisar e emitir resultado da licitação do projeto |  | 14d | 2019-06-19 | 2019-07-09 | 1553 |  |  | 2019-06-19 | 2019-07-09 | 14d |  |  | 397d | 0d | Verde | Verde | 0% | 0% | Verde | 0% | 0% | Verde |  |  |  |  |  |  |  |
| 1555 | 2.3.18.1.1.5 | Licitação do projeto concluída | milestone | 0d | 2019-07-09 | 2019-07-09 | 1554 |  |  | 2019-07-09 | 2019-07-09 | 0d |  |  | 397d | 0d | Verde | Verde | 0% | 0% | Verde | 0% | 0% | Verde |  |  |  |  |  |  |  |
| 1556 | 2.3.18.1.2 | **Elaboração do Projeto Básico** |  | 113d | 2019-07-10 | 2019-12-18 |  |  |  | 2019-07-10 | 2019-12-18 | 113d |  |  | 397d |  | Verde | Verde | 0% | 0% | Verde | 0% | 0% |  |  |  |  |  |  |  |  |
| 1557 | 2.3.18.1.2.1 | Elaborar Projeto Básico |  | 44d | 2019-07-10 | 2019-09-10 | 1555 |  |  | 2019-07-10 | 2019-09-10 | 44d | 2019-04-03 | 2019-07-02 | 397d | 0d | Verde | Verde | 0% | 0% | Verde | 0% | 0% | Verde | 02 - Execução | PG 031 |  |  |  |  |  |
| 1558 | 2.3.18.1.2.2 | Projeto básico apresentado ao banco | milestone | 0d | 2019-09-10 | 2019-09-10 | 1557 |  |  | 2019-09-10 | 2019-09-10 | 0d |  |  | 432d | 0d | Verde | Verde | 0% | 0% | Verde | 0% | 0% | Verde |  |  |  |  |  |  |  |
| 1559 | 2.3.18.1.2.3 | Analisar projeto básico |  | 22d | 2019-09-11 | 2019-10-10 | 1558 |  |  | 2019-09-11 | 2019-10-10 | 22d |  |  | 432d | 0d | Verde | Verde | 0% | 0% | Verde | 0% | 0% | Verde |  |  |  |  |  |  |  |
| 1560 | 2.3.18.1.2.4 | Adequar/revisar projeto básico |  | 22d | 2019-10-11 | 2019-11-11 | 1559 |  |  | 2019-10-11 | 2019-11-11 | 22d |  |  | 432d | 0d | Verde | Verde | 0% | 0% | Verde | 0% | 0% | Verde |  |  |  |  |  |  |  |
| 1561 | 2.3.18.1.2.5 | Analisar projeto básico - final |  | 20d | 2019-11-12 | 2019-12-10 | 1560 |  |  | 2019-11-12 | 2019-12-10 | 20d |  |  | 432d | 0d | Verde | Verde | 0% | 0% | Verde | 0% | 0% | Verde |  |  |  |  |  |  |  |
| 1562 | 2.3.18.1.2.6 | Projeto básico concluído | milestone | 0d | 2019-12-10 | 2019-12-10 | 1561 |  |  | 2019-12-10 | 2019-12-10 | 0d |  |  | 432d | 0d | Verde | Verde | 0% | 0% | Verde | 0% | 0% | Verde |  |  |  |  |  |  |  |
| 1563 | 2.3.18.1.2.7 | Recurso do projeto básico do pleito IPAESOB01 repassado | milestone | 0d | 2019-12-18 | 2019-12-18 | 1562FS+5d |  |  | 2019-12-18 | 2019-12-18 | 0d |  |  | 432d | 35d | Verde | Verde | 0% | 0% | Verde | 0% | 0% | Verde |  |  |  |  |  |  |  |
| 1564 | 2.3.18.1.3 | Realizar Licenciamento Ambiental |  | 104d | 2019-09-11 | 2020-02-10 | 1557 |  |  | 2019-09-11 | 2020-02-10 | 104d | 2019-07-02 | 2020-03-28 | 397d | 0d | Verde | Verde | 0% | 0% | Verde | 0% | 0% | Verde | 02 - Execução | PG 031 |  |  |  |  |  |

Notes:
- 1547: Valor de recurso destinado ao munícipio: R$9.453.986,14
- 1548: Ipatinga solicitou pediu 82,5% (R%14.640.770,57) dos 90% de recursos destinado para Esgotamento Sanitário e teve todo o pleito aprovado, conforme Deliberação 75. / O município teve 2,5%, dos 10% do valor teto destinado a Resíduos Sólidos aprovado (R$450.000,00). / Como ainda não está definido quantas obras seram realizadas, foi considerado o valor total de obras, dividido por 3 / para o critério de prazo, de forma a não impactar no prazo final do programa.
- 1552: 19/12/18 - Apoio Técnico está dando suporte na elaboração da planilha orçamentária (data prevista para 31/01/19) / 25/01/19 - Oficio 006 17/01/19 - Solicitou alteração de pleito de projeto de rede coletora da sede. (2 meses para a aprovação da mudança de pleito + 1 mês para a adesão a ATA de registro de preço e aprovação do banco) / Em 29/04/2019: atualizado como agendado

| ID | WBS | Task | Type | Duration | Start | Finish | Predecessors | Baseline start | Baseline finish | Baseline duration | Baseline 1 start | Baseline 1 finish | Total slack | Free slack | Farol de Atraso | Farol Marcos | % Previsto Tempo | Índice de Desempenho Físico (IDF) | Farol IDF | % Previsto Ponderado | % Concluído Ponderado | Responsável | Código do Contrato | Farol de Início | % Previsto Tempo Numérico | % Previsto Ponderado Numérico |
| --- | --- | --- | --- | --- | --- | --- | --- | --- | --- | --- | --- | --- | --- | --- | --- | --- | --- | --- | --- | --- | --- | --- | --- | --- | --- | --- |
| 1565 | 2.3.18.1.4 | **Elaboração do Projeto Executivo** |  | 109d | 2019-09-11 | 2020-02-17 |  | 2019-09-11 | 2020-02-17 | 109d |  |  | 397d |  | Verde | Verde | 0% | 0% | Verde | 0% | 0% |  |  |  |  |  |
| 1566 | 2.3.18.1.4.1 | Elaborar Projeto Executivo |  | 44d | 2019-09-11 | 2019-11-11 | 1557 | 2019-09-11 | 2019-11-11 | 44d | 2019-07-02 | 2019-12-29 | 397d | 0d | Verde | Verde | 0% | 0% | Verde | 0% | 0% | 02 - Execução | PG 031 | Verde |  |  |
| 1567 | 2.3.18.1.4.2 | Projeto executivo apresentado ao banco | milestone | 0d | 2019-11-11 | 2019-11-11 | 1566 | 2019-11-11 | 2019-11-11 | 0d |  |  | 397d | 0d | Verde | Verde | 0% | 0% | Verde | 0% | 0% |  |  | Verde |  |  |
| 1568 | 2.3.18.1.4.3 | Analisar projeto executivo |  | 20d | 2019-11-12 | 2019-12-10 | 1567 | 2019-11-12 | 2019-12-10 | 20d |  |  | 397d | 0d | Verde | Verde | 0% | 0% | Verde | 0% | 0% |  |  | Verde |  |  |
| 1569 | 2.3.18.1.4.4 | Adequar/revisar projeto executivo |  | 19d | 2019-12-11 | 2020-01-10 | 1568 | 2019-12-11 | 2020-01-10 | 19d |  |  | 397d | 0d | Verde | Verde | 0% | 0% | Verde | 0% | 0% |  |  | Verde |  |  |
| 1570 | 2.3.18.1.4.5 | Analisar projeto executivo - final |  | 21d | 2020-01-13 | 2020-02-10 | 1569 | 2020-01-13 | 2020-02-10 | 21d |  |  | 397d | 0d | Verde | Verde | 0% | 0% | Verde | 0% | 0% |  |  | Verde |  |  |
| 1571 | 2.3.18.1.4.6 | Projeto executivo concluído | milestone | 0d | 2020-02-10 | 2020-02-10 | 1570, 1564, 1563 | 2020-02-10 | 2020-02-10 | 0d |  |  | 397d | 0d | Verde | Verde | 0% | 0% | Verde | 0% | 0% |  |  | Verde |  |  |
| 1572 | 2.3.18.1.4.7 | Recurso do projeto executivo do pleito IPAESOB01 repassado | milestone | 0d | 2020-02-17 | 2020-02-17 | 1571FS+5d | 2020-02-17 | 2020-02-17 | 0d |  |  | 397d | 0d | Verde | Verde | 0% | 0% | Verde | 0% | 0% |  |  | Verde |  |  |
| 1573 | 2.3.18.1.5 | **Licitação da obra** |  | 73d | 2020-02-17 | 2020-06-05 |  | 2020-02-17 | 2020-06-05 | 73d |  |  | 397d |  | Verde | Verde | 0% | 0% | Verde | 0% | 0% |  |  |  |  |  |
| 1574 | 2.3.18.1.5.1 | Licitação da obra autorizada pelo banco | milestone | 0d | 2020-02-17 | 2020-02-17 | 1572 | 2020-02-17 | 2020-02-17 | 0d |  |  | 397d | 0d | Verde | Verde | 0% | 0% | Verde | 0% | 0% |  |  | Verde |  |  |
| 1575 | 2.3.18.1.5.2 | Licitar Obra |  | 59d | 2020-02-18 | 2020-05-18 | 1574 | 2020-02-18 | 2020-05-18 | 59d | 2019-12-29 | 2020-04-27 | 397d | 0d | Verde | Verde | 0% | 0% | Verde | 0% | 0% | 02 - Execução | PG 031 | Verde |  |  |
| 1576 | 2.3.18.1.5.3 | Analisar e emitir resultado da licitação da obra |  | 14d | 2020-05-19 | 2020-06-05 | 1575 | 2020-05-19 | 2020-06-05 | 14d |  |  | 397d | 0d | Verde | Verde | 0% | 0% | Verde | 0% | 0% |  |  | Verde |  |  |
| 1577 | 2.3.18.1.5.4 | Licitação da obra concluída | milestone | 0d | 2020-06-05 | 2020-06-05 | 1576 | 2020-06-05 | 2020-06-05 | 0d |  |  | 397d | 0d | Verde | Verde | 0% | 0% | Verde | 0% | 0% |  |  | Verde |  |  |
| 1578 | 2.3.18.1.6 | Executar obra |  | 625d | 2020-07-06 | 2023-01-05 | 1577FS+19d | 2020-07-06 | 2023-01-05 | 625d |  |  | 397d | 0d | Verde | Verde | 0% | 0% | Verde | 0% | 0% |  |  | Verde |  |  |
| 1579 | 2.3.18.1.7 | Realizar processo de pré-operação |  | 128d | 2023-01-06 | 2023-07-13 | 1578 | 2023-01-06 | 2023-07-13 | 128d | 2021-07-28 | 2022-01-24 | 397d | 0d | Verde | Verde | 0% | 0% | Verde | 0% | 0% | 02 - Execução | PG 031 | Verde |  |  |
| 1580 | 2.3.18.1.8 | Recurso da obra parcelado repassado | milestone | 0d | 2023-07-20 | 2023-07-20 | 1579FS+5d | 2023-07-20 | 2023-07-20 | 0d |  |  | 397d | 0d | Verde | Verde | 0% | 0% | Verde | 0% | 0% |  |  | Verde |  |  |
| 1581 | 2.3.18.1.9 | Pleito IPAESOB01 concluído | milestone | 0d | 2023-07-20 | 2023-07-20 | 1580 | 2023-07-20 | 2023-07-20 | 0d |  |  | 397d | 5d | Verde | Verde | 0% | 0% | Verde | 0% | 0% |  |  | Verde |  |  |
| 1582 | 2.3.18.2 | **Pleito IPARSPM01 - Elaboração do estudo de viabilidade e indicação de área para implantação de aterro sanitário** |  | 393d | 2018-08-22 | 2020-03-17 |  | 2018-08-22 | 2020-03-17 | 393d |  |  | 1229d |  | Verde | Verde | 44% | 0% | Vermelho | 3% | 0% |  |  |  | 44 |  |
| 1583 | 2.3.18.2.1 | **Licitação de Empresa para Estudo de Viabilidade** |  | 388d | 2018-08-22 | 2020-03-10 |  | 2018-08-22 | 2020-03-10 | 388d |  |  | 1229d |  | Verde | Verde | 44% | 0% | Vermelho | 3% | 0% |  |  |  | 44 |  |
| 1584 | 2.3.18.2.1.1 | Licitação da empresa para Estudo de Viabilidade autorizada pelo banco | milestone | 0d | 2018-08-22 | 2018-08-22 | 206FS-81d | 2018-08-22 | 2018-08-22 | 0d |  |  | 1229d | 0d | Verde | Verde | 100% | 0% | Vermelho | 100% | 0% |  |  | Verde | 100 | 100 |
| 1585 | 2.3.18.2.1.2 | Licitar empresa para Estudo de Viabilidade |  | 215d | 2018-08-22 | 2019-06-28 | 1584 | 2018-08-22 | 2019-06-28 | 215d |  |  | 1229d | 0d | Verde | Verde | 80% | 0% | Vermelho | 80% | 0% |  |  | Verde | 80 | 80 |
| 1586 | 2.3.18.2.1.3 | Documentação de licitação apresentada ao banco | milestone | 0d | 2019-07-05 | 2019-07-05 | 1585FS+5d | 2019-07-05 | 2019-07-05 | 0d |  |  | 1229d | 0d | Verde | Verde | 0% | 0% | Verde | 0% | 0% |  |  | Verde |  |  |
| 1587 | 2.3.18.2.1.4 | Analisar e emitir resultado da licitação da empresa para Estudo de Viabilidade |  | 14d | 2019-07-08 | 2019-07-25 | 1586 | 2019-07-08 | 2019-07-25 | 14d |  |  | 1229d | 0d | Verde | Verde | 0% | 0% | Verde | 0% | 0% |  |  | Verde |  |  |
| 1588 | 2.3.18.2.1.5 | Licitação da empresa para Estudo de Viabilidade concluída | milestone | 0d | 2019-07-25 | 2019-07-25 | 1587 | 2019-07-25 | 2019-07-25 | 0d |  |  | 1229d | 0d | Verde | Verde | 0% | 0% | Verde | 0% | 0% |  |  | Verde |  |  |

Notes:
- 1584: Em 24/04/2019: a licitação foi autorizada pelo banco no dia 22/08/2018 conforme planilha de controle gerencial renova
- 1585: Em 29/04/2019: atualizado como agendado

| ID | WBS | Task | Type | Duration | Start | Finish | Predecessors | Complete | Remaining | Baseline start | Baseline finish | Baseline duration | Baseline 1 start | Baseline 1 finish | Total slack | Free slack | Constraint | Farol de Atraso | Farol Marcos | % Previsto Tempo | Índice de Desempenho Físico (IDF) | Farol IDF | % Previsto Ponderado | % Concluído Ponderado | Farol de Início | Responsável | Código do Contrato | % Concluída Numérico | % Previsto Tempo Numérico | % Previsto Ponderado Numérico |
| --- | --- | --- | --- | --- | --- | --- | --- | --- | --- | --- | --- | --- | --- | --- | --- | --- | --- | --- | --- | --- | --- | --- | --- | --- | --- | --- | --- | --- | --- | --- |
| 1589 | 2.3.18.2.1.6 | **Elaboração do estudo de viabilidade** |  | 154d | 2019-07-26 | 2020-03-10 |  |  |  | 2019-07-26 | 2020-03-10 | 154d |  |  | 1229d |  |  | Verde | Verde | 0% | 0% | Verde | 0% | 0% |  |  |  |  |  |  |
| 1590 | 2.3.18.2.1.6.1 | Elaborar estudo de viabilidade |  | 88d | 2019-07-26 | 2019-11-28 | 1588 |  |  | 2019-07-26 | 2019-11-28 | 88d |  |  | 1229d | 0d |  | Verde | Verde | 0% | 0% | Verde | 0% | 0% | Verde |  |  |  |  |  |
| 1591 | 2.3.18.2.1.6.2 | Analisar estudo |  | 22d | 2019-11-29 | 2020-01-03 | 1590 |  |  | 2019-11-29 | 2020-01-03 | 22d |  |  | 1229d | 0d |  | Verde | Verde | 0% | 0% | Verde | 0% | 0% | Verde |  |  |  |  |  |
| 1592 | 2.3.18.2.1.6.3 | Adequar/revisar estudo |  | 22d | 2020-01-06 | 2020-02-04 | 1591 |  |  | 2020-01-06 | 2020-02-04 | 22d |  |  | 1229d | 0d |  | Verde | Verde | 0% | 0% | Verde | 0% | 0% | Verde |  |  |  |  |  |
| 1593 | 2.3.18.2.1.6.4 | Analisar estudo - final |  | 22d | 2020-02-05 | 2020-03-10 | 1592 |  |  | 2020-02-05 | 2020-03-10 | 22d |  |  | 1229d | 0d |  | Verde | Verde | 0% | 0% | Verde | 0% | 0% | Verde |  |  |  |  |  |
| 1594 | 2.3.18.2.1.6.5 | Estudo concluído | milestone | 0d | 2020-03-10 | 2020-03-10 | 1593 |  |  | 2020-03-10 | 2020-03-10 | 0d |  |  | 1229d | 0d |  | Verde | Verde | 0% | 0% | Verde | 0% | 0% | Verde |  |  |  |  |  |
| 1595 | 2.3.18.2.2 | Recurso do serviço parcelado repassado | milestone | 0d | 2020-03-17 | 2020-03-17 | 1594FS+5d |  |  | 2020-03-17 | 2020-03-17 | 0d |  |  | 1229d | 0d |  | Verde | Verde | 0% | 0% | Verde | 0% | 0% | Verde |  |  |  |  |  |
| 1596 | 2.3.18.2.3 | Pleito IPARSPM01 concluído | milestone | 0d | 2020-03-17 | 2020-03-17 | 1595 |  |  | 2020-03-17 | 2020-03-17 | 0d |  |  | 1229d | 837d |  | Verde | Verde | 0% | 0% | Verde | 0% | 0% | Verde |  |  |  |  |  |
| 1597 | 2.3.18.3 | **Pleito de Ipatinga de Resíduos Sólidos a definir - Projeto e Obra** |  | 971d | 2019-08-30 | 2023-07-27 |  |  |  | 2019-08-30 | 2023-07-27 | 971d |  |  | 392d |  |  | Verde | Verde | 0% | 0% | Verde | 0% | 0% |  |  |  |  |  |  |
| 1598 | 2.3.18.3.1 | Pleito aprovado | milestone | 0d | 2019-08-30 | 2019-08-30 | 206FS+178d |  |  | 2019-08-30 | 2019-08-30 | 0d |  |  | 392d | 0d |  | Verde | Verde | 0% | 0% | Verde | 0% | 0% | Verde |  |  |  |  |  |
| 1599 | 2.3.18.3.2 | Iniciar pleito |  | 1d | 2019-09-02 | 2019-09-02 | 1598 |  |  | 2019-09-02 | 2019-09-02 | 1d |  |  | 392d | 0d |  | Verde | Verde | 0% | 0% | Verde | 0% | 0% | Verde |  |  |  |  |  |
| 1600 | 2.3.18.3.3 | Pleito concluído | milestone | 0d | 2023-07-27 | 2023-07-27 | 1599FS+970d |  |  | 2023-07-27 | 2023-07-27 | 0d |  |  | 392d | 0d |  | Verde | Verde | 0% | 0% | Verde | 0% | 0% | Verde |  |  |  |  |  |
| 1601 | 2.3.18.4 | Recursos de Ipatinga repassados | milestone | 0d | 2023-07-27 | 2023-07-27 | 1581, 1596, 1600 |  |  | 2023-07-27 | 2023-07-27 | 0d | 2019-08-01 | 2022-01-24 | 392d |  |  | Verde | Verde | 0% | 0% | Verde | 0% | 0% | Verde | 02 - Execução | PG 031 |  |  |  |
| 1602 | 2.3.19 | **Itueta** |  | 698d | 2019-03-28 A | 2022-01-14 |  | 2% | 687.2d | 2019-03-28 | 2022-01-14 | 698d | 2019-01-29 | 2021-02-26 | 772d |  |  | Verde | Verde | 3% | 0% | Vermelho | 0% | 0% |  |  |  |  |  |  |
| 1603 | 2.3.19.1 | **Pleito ITUESPJ02 - Contratação de empresa especializada de engenharia para elaboração de projetos básicos e executivos para ampliação do sistema de esgotamento sanitário nos distritos de Vila Nietzel e Quatituba** |  | 261d | 2019-03-28 A | 2020-04-15 |  | 3% | 252.44d | 2019-03-28 | 2020-04-15 | 261d |  |  | 1209d |  |  | Verde | Verde | 8% | 0% | Vermelho | 1% | 0% |  |  |  |  |  |  |
| 1604 | 2.3.19.1.1 | Alteração do pleito aprovada | milestone | 0d | 2019-03-28 A | 2019-03-28 A |  | 100% |  | 2019-03-28 | 2019-03-28 | 0d |  |  |  |  | must start on 2019-03-28 | Verde | Verde | 100% | 0% | Vermelho | 100% | 0% | Verde |  |  | 100 | 100 | 100 |
| 1605 | 2.3.19.1.2 | **Licitação do Projeto** |  | 59d | 2019-04-08 A | 2019-07-04 |  | 26% | 43.7d | 2019-04-08 | 2019-07-04 | 59d |  |  | 862d |  |  | Verde | Verde | 23% | 0% | Vermelho | 18% | 0% |  |  |  | 26 | 23 | 18 |
| 1606 | 2.3.19.1.2.1 | Licitação do projeto autorizada pelo banco | milestone | 0d | 2019-04-08 A | 2019-04-08 A | 1604FS+8d | 100% |  | 2019-04-08 | 2019-04-08 | 0d |  |  |  |  |  | Verde | Verde | 100% | 0% | Vermelho | 100% | 0% | Verde |  |  | 100 | 100 | 100 |
| 1607 | 2.3.19.1.2.2 | Licitar projeto |  | 40d | 2019-04-09 A | 2019-06-06 | 1606 | 35% | 26d | 2019-04-09 | 2019-06-06 | 40d | 2019-01-29 | 2019-04-29 | 862d | 0d |  | Verde | Verde | 35% | 0% | Vermelho | 35% | 0% | Verde | 02 - Execução | PG 031 | 35 | 35 | 35 |
| 1608 | 2.3.19.1.2.3 | Documentação de licitação apresentada ao banco | milestone | 0d | 2019-06-13 | 2019-06-13 | 1607FS+5d |  |  | 2019-06-13 | 2019-06-13 | 0d |  |  | 862d | 0d |  | Verde | Verde | 0% | 0% | Verde | 0% | 0% | Verde |  |  |  |  |  |
| 1609 | 2.3.19.1.2.4 | Analisar e emitir resultado da licitação do projeto |  | 14d | 2019-06-14 | 2019-07-04 | 1608 |  |  | 2019-06-14 | 2019-07-04 | 14d |  |  | 862d | 0d |  | Verde | Verde | 0% | 0% | Verde | 0% | 0% | Verde |  |  |  |  |  |
| 1610 | 2.3.19.1.2.5 | Licitação do projeto concluída | milestone | 0d | 2019-07-04 | 2019-07-04 | 1609 |  |  | 2019-07-04 | 2019-07-04 | 0d |  |  | 862d | 0d |  | Verde | Verde | 0% | 0% | Verde | 0% | 0% | Verde |  |  |  |  |  |
| 1611 | 2.3.19.1.3 | **Elaboração do Projeto Básico** |  | 132d | 2019-07-05 | 2020-01-14 |  |  |  | 2019-07-05 | 2020-01-14 | 132d |  |  | 862d |  |  | Verde | Verde | 0% | 0% | Verde | 0% | 0% |  |  |  |  |  |  |
| 1612 | 2.3.19.1.3.1 | Elaborar Projeto Básico |  | 65d | 2019-07-05 | 2019-10-04 | 1610 |  |  | 2019-07-05 | 2019-10-04 | 65d | 2019-04-29 | 2019-06-28 | 862d | 0d |  | Verde | Verde | 0% | 0% | Verde | 0% | 0% | Verde | 02 - Execução | PG 031 |  |  |  |
| 1613 | 2.3.19.1.3.2 | Projeto básico apresentado ao banco | milestone | 0d | 2019-10-04 | 2019-10-04 | 1612 |  |  | 2019-10-04 | 2019-10-04 | 0d |  |  | 919d | 0d |  | Verde | Verde | 0% | 0% | Verde | 0% | 0% | Verde |  |  |  |  |  |
| 1614 | 2.3.19.1.3.3 | Analisar projeto básico |  | 23d | 2019-10-07 | 2019-11-06 | 1613 |  |  | 2019-10-07 | 2019-11-06 | 23d |  |  | 919d | 0d |  | Verde | Verde | 0% | 0% | Verde | 0% | 0% | Verde |  |  |  |  |  |
| 1615 | 2.3.19.1.3.4 | Adequar/revisar projeto básico |  | 20d | 2019-11-07 | 2019-12-05 | 1614 |  |  | 2019-11-07 | 2019-12-05 | 20d |  |  | 919d | 0d |  | Verde | Verde | 0% | 0% | Verde | 0% | 0% | Verde |  |  |  |  |  |
| 1616 | 2.3.19.1.3.5 | Analisar projeto básico - final |  | 19d | 2019-12-06 | 2020-01-07 | 1615 |  |  | 2019-12-06 | 2020-01-07 | 19d |  |  | 919d | 0d |  | Verde | Verde | 0% | 0% | Verde | 0% | 0% | Verde |  |  |  |  |  |
| 1617 | 2.3.19.1.3.6 | Projeto básico concluído | milestone | 0d | 2020-01-07 | 2020-01-07 | 1616 |  |  | 2020-01-07 | 2020-01-07 | 0d |  |  | 919d | 0d |  | Verde | Verde | 0% | 0% | Verde | 0% | 0% | Verde |  |  |  |  |  |
| 1618 | 2.3.19.1.3.7 | Recurso do projeto básico do pleito repassado | milestone | 0d | 2020-01-14 | 2020-01-14 | 1617FS+5d |  |  | 2020-01-14 | 2020-01-14 | 0d |  |  | 919d | 57d |  | Verde | Verde | 0% | 0% | Verde | 0% | 0% | Verde |  |  |  |  |  |
| 1619 | 2.3.19.1.4 | Realizar Licenciamento Ambiental |  | 124d | 2019-10-07 | 2020-04-07 | 1612 |  |  | 2019-10-07 | 2020-04-07 | 124d | 2019-06-28 | 2019-12-25 | 862d | 0d |  | Verde | Verde | 0% | 0% | Verde | 0% | 0% | Verde | 02 - Execução | PG 031 |  |  |  |

Notes:
- 1598: Em 24/09/2019: pleito aprovado no dia 30/08/2019 conforme NT 33 e premissa de que o município enviará pleito entre junho e julho para ser avaliado.
- 1600: Em 24/09/2019: considerado a soma dos valores para resíduos sólidos de cada município parcipante do consórcio CIMVA 2 menos o valor do pleito de Ipatinga de estudo de viabilidade para definição da duração do pleito.
- 1601: Valor de recurso destinado ao munícipio: R$17.740.770,56
- 1602: Itueta teve 58,2% dos pleitos de Esgotamento Sanitário aprovado (R$1.550.000,00), conforme Deliberação 75. / O município teve o pleito de resíduos sólidos negado (R$266.111,56), equivalente a 10% do total do recurso,). / Itueta solicitou mudança de pleito, mas ainda não foi autorizado pelo CIF. / ·Alteração do pleito que beneficiava o distrito de Vila Neitzel com SES, uma vez que o mesmo não possui sistema de abastecimento de água. Desta forma o SES seria ineficiente. / ·Solicitaram alteração da obrigatoriedade de direcionamento de 10% da recurso em Resíduos Sólidos para utilizar 100% dos recursos na área de Esgotamento Sanítário no distrito de Quatituba.
- 1604: Em 21/04/2019: pleito foi aprovado na deliberação 269 pelo CIF no dia 28/03/2019
- 1607: 22/01/19 - Fazendo adequação de projeto com recurso próprio e fazendo alteração de pleito / Em 29/04/2019: atualizado como agendado

| ID | WBS | Task | Type | Duration | Start | Finish | Predecessors | Complete | Remaining | Baseline start | Baseline finish | Baseline duration | Baseline 1 start | Baseline 1 finish | Total slack | Free slack | Constraint | Farol de Atraso | Farol Marcos | % Previsto Tempo | Índice de Desempenho Físico (IDF) | Farol IDF | % Previsto Ponderado | % Concluído Ponderado | Responsável | Código do Contrato | Farol de Início | % Concluída Numérico | % Previsto Tempo Numérico | % Previsto Ponderado Numérico |
| --- | --- | --- | --- | --- | --- | --- | --- | --- | --- | --- | --- | --- | --- | --- | --- | --- | --- | --- | --- | --- | --- | --- | --- | --- | --- | --- | --- | --- | --- | --- |
| 1620 | 2.3.19.1.5 | **Elaboração do Projeto Executivo** |  | 127d | 2019-10-09 | 2020-04-15 |  |  |  | 2019-10-09 | 2020-04-15 | 127d |  |  | 862d |  |  | Verde | Verde | 0% | 0% | Verde | 0% | 0% |  |  |  |  |  |  |
| 1621 | 2.3.19.1.5.1 | Elaborar Projeto Executivo |  | 60d | 2019-10-09 | 2020-01-07 | 1612FS+2d |  |  | 2019-10-09 | 2020-01-07 | 60d | 2019-06-28 | 2019-09-26 | 862d | 0d |  | Verde | Verde | 0% | 0% | Verde | 0% | 0% | 02 - Execução | PG 031 | Verde |  |  |  |
| 1622 | 2.3.19.1.5.2 | Projeto executivo apresentado ao banco | milestone | 0d | 2020-01-07 | 2020-01-07 | 1621 |  |  | 2020-01-07 | 2020-01-07 | 0d |  |  | 862d | 0d |  | Verde | Verde | 0% | 0% | Verde | 0% | 0% |  |  | Verde |  |  |  |
| 1623 | 2.3.19.1.5.3 | Analisar projeto executivo |  | 22d | 2020-01-08 | 2020-02-06 | 1622 |  |  | 2020-01-08 | 2020-02-06 | 22d |  |  | 862d | 0d |  | Verde | Verde | 0% | 0% | Verde | 0% | 0% |  |  | Verde |  |  |  |
| 1624 | 2.3.19.1.5.4 | Adequar/revisar projeto executivo |  | 17d | 2020-02-07 | 2020-03-05 | 1623 |  |  | 2020-02-07 | 2020-03-05 | 17d |  |  | 862d | 0d |  | Verde | Verde | 0% | 0% | Verde | 0% | 0% |  |  | Verde |  |  |  |
| 1625 | 2.3.19.1.5.5 | Analisar projeto executivo - final |  | 23d | 2020-03-06 | 2020-04-07 | 1624 |  |  | 2020-03-06 | 2020-04-07 | 23d |  |  | 862d | 0d |  | Verde | Verde | 0% | 0% | Verde | 0% | 0% |  |  | Verde |  |  |  |
| 1626 | 2.3.19.1.5.6 | Projeto executivo concluído | milestone | 0d | 2020-04-07 | 2020-04-07 | 1625, 1619, 1618 |  |  | 2020-04-07 | 2020-04-07 | 0d |  |  | 862d | 0d |  | Verde | Verde | 0% | 0% | Verde | 0% | 0% |  |  | Verde |  |  |  |
| 1627 | 2.3.19.1.5.7 | Recurso do projeto executivo do pleito ITUESPJ02 repassado | milestone | 0d | 2020-04-15 | 2020-04-15 | 1626FS+5d |  |  | 2020-04-15 | 2020-04-15 | 0d |  |  | 1209d | 0d |  | Verde | Verde | 0% | 0% | Verde | 0% | 0% |  |  | Verde |  |  |  |
| 1628 | 2.3.19.1.6 | Pleito ITUESPJ02 concluído | milestone | 0d | 2020-04-15 | 2020-04-15 | 1627 |  |  | 2020-04-15 | 2020-04-15 | 0d |  |  | 1209d | 437d |  | Verde | Verde | 0% | 0% | Verde | 0% | 0% |  |  | Verde |  |  |  |
| 1629 | 2.3.19.2 | **Pleito ITUESOB03 - Contratação de empresa para execução de obras de reformas e melhorias na área da estação de tratamento de esgotos e nas estações elevatórias de esgoto da Sede e distrito de Quatituba** |  | 352d | 2020-04-07 | 2021-09-03 |  |  |  | 2020-04-07 | 2021-09-03 | 352d |  |  | 862d |  |  | Verde | Verde | 0% | 0% | Verde | 0% | 0% |  |  |  |  |  |  |
| 1630 | 2.3.19.2.1 | **Licitação da Obra** |  | 75d | 2020-04-07 | 2020-07-27 |  |  |  | 2020-04-07 | 2020-07-27 | 75d |  |  | 862d |  |  | Verde | Verde | 0% | 0% | Verde | 0% | 0% |  |  |  |  |  |  |
| 1631 | 2.3.19.2.1.1 | Licitação da obra autorizada pelo banco | milestone | 0d | 2020-04-07 | 2020-04-07 | 1626 |  |  | 2020-04-07 | 2020-04-07 | 0d |  |  | 862d | 0d |  | Verde | Verde | 0% | 0% | Verde | 0% | 0% |  |  | Verde |  |  |  |
| 1632 | 2.3.19.2.1.2 | Licitar Obra |  | 61d | 2020-04-08 | 2020-07-07 | 1631 |  |  | 2020-04-08 | 2020-07-07 | 61d | 2019-09-26 | 2019-12-25 | 862d | 0d |  | Verde | Verde | 0% | 0% | Verde | 0% | 0% | 02 - Execução | PG 031 | Verde |  |  |  |
| 1633 | 2.3.19.2.1.3 | Analisar e emitir resultado da licitação da obra |  | 14d | 2020-07-08 | 2020-07-27 | 1632 |  |  | 2020-07-08 | 2020-07-27 | 14d |  |  | 862d | 0d |  | Verde | Verde | 0% | 0% | Verde | 0% | 0% |  |  | Verde |  |  |  |
| 1634 | 2.3.19.2.1.4 | Licitação da obra concluída | milestone | 0d | 2020-07-27 | 2020-07-27 | 1633 |  |  | 2020-07-27 | 2020-07-27 | 0d |  |  | 862d | 0d |  | Verde | Verde | 0% | 0% | Verde | 0% | 0% |  |  | Verde |  |  |  |
| 1635 | 2.3.19.2.2 | Executar obra |  | 123d | 2020-08-26 | 2021-02-25 | 1634FS+21d |  |  | 2020-08-26 | 2021-02-25 | 123d |  |  | 862d | 0d |  | Verde | Verde | 0% | 0% | Verde | 0% | 0% |  |  | Verde |  |  |  |
| 1636 | 2.3.19.2.3 | Realizar processo de pré-operação |  | 128d | 2021-02-26 | 2021-08-27 | 1635 |  |  | 2021-02-26 | 2021-08-27 | 128d | 2020-07-01 | 2021-02-26 | 862d | 0d |  | Verde | Verde | 0% | 0% | Verde | 0% | 0% | 02 - Execução | PG 031 | Verde |  |  |  |
| 1637 | 2.3.19.2.4 | Recurso da obra parcelado repassado | milestone | 0d | 2021-09-03 | 2021-09-03 | 1636FS+5d |  |  | 2021-09-03 | 2021-09-03 | 0d |  |  | 862d | 0d |  | Verde | Verde | 0% | 0% | Verde | 0% | 0% |  |  | Verde |  |  |  |
| 1638 | 2.3.19.2.5 | Pleito ITUESOB03 concluído | milestone | 0d | 2021-09-03 | 2021-09-03 | 1637 |  |  | 2021-09-03 | 2021-09-03 | 0d |  |  | 862d | 90d |  | Verde | Verde | 0% | 0% | Verde | 0% | 0% |  |  | Verde |  |  |  |
| 1639 | 2.3.19.3 | **Pleito ITUESOB04 - Contratação de empresa para execução de obras para ampliação da rede coletora de esgoto na sede do município** |  | 361d | 2019-03-28 A | 2020-09-08 |  | 4% | 345.48d | 2019-03-28 | 2020-09-08 | 361d |  |  | 1109d |  |  | Verde | Verde | 6% | 0% | Vermelho | 7% | 0% |  |  |  |  |  |  |
| 1640 | 2.3.19.3.1 | Alteração do pleito aprovada | milestone | 0d | 2019-03-28 A | 2019-03-28 A |  | 100% |  | 2019-03-28 | 2019-03-28 | 0d |  |  |  |  | must start on 2019-03-28 | Verde | Verde | 100% | 0% | Vermelho | 100% | 0% |  |  | Verde | 100 | 100 | 100 |
| 1641 | 2.3.19.3.2 | **Aprovação do Projeto Executivo** |  | 61d | 2019-04-05 A | 2019-07-05 |  | 25% | 46d | 2019-04-05 | 2019-07-05 | 61d |  |  | 1109d |  |  | Verde | Verde | 24% | 0% | Vermelho | 29% | 0% |  |  |  | 25 | 24 | 29 |
| 1642 | 2.3.19.3.2.1 | Projeto executivo apresentado ao banco | milestone | 0d | 2019-04-05 A | 2019-04-05 A | 1640FS+7d | 100% |  | 2019-04-05 | 2019-04-05 | 0d |  |  |  |  |  | Verde | Verde | 100% | 0% | Vermelho | 100% | 0% |  |  | Verde | 100 | 100 | 100 |
| 1643 | 2.3.19.3.2.2 | Analisar projeto executivo |  | 17d | 2019-04-08 A | 2019-05-03 | 1642 | 88% | 2d | 2019-04-08 | 2019-05-03 | 17d |  |  | 1109d | 0d |  | Verde | Verde | 88% | 0% | Vermelho | 88% | 0% |  |  | Verde | 88 | 88 | 88 |
| 1644 | 2.3.19.3.2.3 | Adequar/revisar projeto executivo |  | 23d | 2019-05-06 | 2019-06-05 | 1643 |  |  | 2019-05-06 | 2019-06-05 | 23d |  |  | 1109d | 0d |  | Verde | Verde | 0% | 0% | Verde | 0% | 0% |  |  | Verde |  |  |  |
| 1645 | 2.3.19.3.2.4 | Analisar projeto executivo - final |  | 21d | 2019-06-06 | 2019-07-05 | 1644 |  |  | 2019-06-06 | 2019-07-05 | 21d |  |  | 1109d | 0d |  | Verde | Verde | 0% | 0% | Verde | 0% | 0% |  |  | Verde |  |  |  |
| 1646 | 2.3.19.3.2.5 | Projeto executivo aprovado | milestone | 0d | 2019-07-05 | 2019-07-05 | 1645 |  |  | 2019-07-05 | 2019-07-05 | 0d |  |  | 1109d | 0d |  | Verde | Verde | 0% | 0% | Verde | 0% | 0% |  |  | Verde |  |  |  |

Notes:
- 1643: Em 29/04/2019: atualizado como agendado

| ID | WBS | Task | Type | Duration | Start | Finish | Predecessors | Baseline start | Baseline finish | Baseline duration | Total slack | Free slack | Farol de Atraso | Farol Marcos | % Previsto Tempo | Índice de Desempenho Físico (IDF) | Farol IDF | % Previsto Ponderado | % Concluído Ponderado | Farol de Início |
| --- | --- | --- | --- | --- | --- | --- | --- | --- | --- | --- | --- | --- | --- | --- | --- | --- | --- | --- | --- | --- |
| 1647 | 2.3.19.3.3 | **Licitação da Obra** |  | 35d | 2019-07-05 | 2019-08-26 |  | 2019-07-05 | 2019-08-26 | 35d | 1109d |  | Verde | Verde | 0% | 0% | Verde | 0% | 0% |  |
| 1648 | 2.3.19.3.3.1 | Licitação da obra autorizada pelo banco | milestone | 0d | 2019-07-05 | 2019-07-05 | 1646 | 2019-07-05 | 2019-07-05 | 0d | 1109d | 0d | Verde | Verde | 0% | 0% | Verde | 0% | 0% | Verde |
| 1649 | 2.3.19.3.3.2 | Licitar Obra |  | 21d | 2019-07-08 | 2019-08-05 | 1648 | 2019-07-08 | 2019-08-05 | 21d | 1109d | 0d | Verde | Verde | 0% | 0% | Verde | 0% | 0% | Verde |
| 1650 | 2.3.19.3.3.3 | Analisar e emitir resultado da licitação da obra |  | 14d | 2019-08-06 | 2019-08-26 | 1649 | 2019-08-06 | 2019-08-26 | 14d | 1109d | 0d | Verde | Verde | 0% | 0% | Verde | 0% | 0% | Verde |
| 1651 | 2.3.19.3.3.4 | Licitação da obra concluída | milestone | 0d | 2019-08-26 | 2019-08-26 | 1650 | 2019-08-26 | 2019-08-26 | 0d | 1109d | 0d | Verde | Verde | 0% | 0% | Verde | 0% | 0% | Verde |
| 1652 | 2.3.19.3.4 | Executar obra |  | 125d | 2019-08-27 | 2020-02-27 | 1651 | 2019-08-27 | 2020-02-27 | 125d | 1109d | 0d | Verde | Verde | 0% | 0% | Verde | 0% | 0% | Verde |
| 1653 | 2.3.19.3.5 | Realizar processo de pré-operação |  | 128d | 2020-02-28 | 2020-08-31 | 1652 | 2020-02-28 | 2020-08-31 | 128d | 1109d | 0d | Verde | Verde | 0% | 0% | Verde | 0% | 0% | Verde |
| 1654 | 2.3.19.3.6 | Recurso da obra parcelado repassado | milestone | 0d | 2020-09-08 | 2020-09-08 | 1653FS+5d | 2020-09-08 | 2020-09-08 | 0d | 1109d | 0d | Verde | Verde | 0% | 0% | Verde | 0% | 0% | Verde |
| 1655 | 2.3.19.3.7 | Pleito ITUESOB04 concluído | milestone | 0d | 2020-09-08 | 2020-09-08 | 1654 | 2020-09-08 | 2020-09-08 | 0d | 1109d | 407d | Verde | Verde | 0% | 0% | Verde | 0% | 0% | Verde |
| 1656 | 2.3.19.4 | **Pleito ITURSOB02 - Manutenção do aterro sanitário consorciado em Resplendor** |  | 497d | 2019-05-08 | 2021-05-07 |  | 2019-05-08 | 2021-05-07 | 497d | 946d |  | Verde | Verde | 0% | 0% | Verde | 0% | 0% |  |
| 1657 | 2.3.19.4.1 | **Aprovação do Projeto Executivo** |  | 68d | 2019-05-08 | 2019-08-13 |  | 2019-05-08 | 2019-08-13 | 68d | 1023d |  | Verde | Verde | 0% | 0% | Verde | 0% | 0% |  |
| 1658 | 2.3.19.4.1.1 | Projeto apresentado ao banco | milestone | 0d | 2019-05-08 | 2019-05-08 | 2249 | 2019-05-08 | 2019-05-08 | 0d | 1023d | 0d | Verde | Verde | 0% | 0% | Verde | 0% | 0% | Verde |
| 1659 | 2.3.19.4.1.2 | Analisar projeto |  | 24d | 2019-05-09 | 2019-06-11 | 1658 | 2019-05-09 | 2019-06-11 | 24d | 1023d | 0d | Verde | Verde | 0% | 0% | Verde | 0% | 0% | Verde |
| 1660 | 2.3.19.4.1.3 | Adequar/revisar projeto |  | 22d | 2019-06-12 | 2019-07-12 | 1659 | 2019-06-12 | 2019-07-12 | 22d | 1023d | 0d | Verde | Verde | 0% | 0% | Verde | 0% | 0% | Verde |
| 1661 | 2.3.19.4.1.4 | Analisar projeto - final |  | 22d | 2019-07-15 | 2019-08-13 | 1660 | 2019-07-15 | 2019-08-13 | 22d | 1023d | 0d | Verde | Verde | 0% | 0% | Verde | 0% | 0% | Verde |
| 1662 | 2.3.19.4.1.5 | Projeto concluído | milestone | 0d | 2019-08-13 | 2019-08-13 | 1661 | 2019-08-13 | 2019-08-13 | 0d | 1023d | 0d | Verde | Verde | 0% | 0% | Verde | 0% | 0% | Verde |
| 1663 | 2.3.19.4.2 | **Licitação da obra** |  | 77d | 2019-08-13 | 2019-12-02 |  | 2019-08-13 | 2019-12-02 | 77d | 1023d |  | Verde | Verde | 0% | 0% | Verde | 0% | 0% |  |
| 1664 | 2.3.19.4.2.1 | Licitação da obra autorizada pelo banco | milestone | 0d | 2019-08-13 | 2019-08-13 | 1662 | 2019-08-13 | 2019-08-13 | 0d | 1023d | 0d | Verde | Verde | 0% | 0% | Verde | 0% | 0% | Verde |
| 1665 | 2.3.19.4.2.2 | Licitar obra |  | 63d | 2019-08-14 | 2019-11-11 | 1664 | 2019-08-14 | 2019-11-11 | 63d | 1023d | 0d | Verde | Verde | 0% | 0% | Verde | 0% | 0% | Verde |
| 1666 | 2.3.19.4.2.3 | Analisar e emitir resultado da licitação da obra |  | 14d | 2019-11-12 | 2019-12-02 | 1665 | 2019-11-12 | 2019-12-02 | 14d | 1023d | 0d | Verde | Verde | 0% | 0% | Verde | 0% | 0% | Verde |
| 1667 | 2.3.19.4.2.4 | Licitação da obra concluída | milestone | 0d | 2019-12-02 | 2019-12-02 | 1666 | 2019-12-02 | 2019-12-02 | 0d | 1023d | 0d | Verde | Verde | 0% | 0% | Verde | 0% | 0% | Verde |
| 1668 | 2.3.19.4.3 | Executar obra |  | 127d | 2020-01-06 | 2020-07-09 | 1667FS+20d | 2020-01-06 | 2020-07-09 | 127d | 1023d | 0d | Verde | Verde | 0% | 0% | Verde | 0% | 0% | Verde |
| 1669 | 2.3.19.4.4 | Realizar processo de pré-operação |  | 128d | 2020-07-10 | 2021-01-13 | 1668 | 2020-07-10 | 2021-01-13 | 128d | 1023d | 77d | Verde | Verde | 0% | 0% | Verde | 0% | 0% | Verde |
| 1670 | 2.3.19.4.5 | Recurso da obra parcelado repassado | milestone | 0d | 2021-05-07 | 2021-05-07 | 1669, 2261FS+5d | 2021-05-07 | 2021-05-07 | 0d | 946d | 0d | Verde | Verde | 0% | 0% | Verde | 0% | 0% | Verde |
| 1671 | 2.3.19.4.6 | Pleito ITURSOB02 concluído | milestone | 0d | 2021-05-07 | 2021-05-07 | 1670 | 2021-05-07 | 2021-05-07 | 0d | 946d | 174d | Verde | Verde | 0% | 0% | Verde | 0% | 0% | Verde |

| ID | WBS | Task | Type | Duration | Start | Finish | Predecessors | Complete | Remaining | Baseline start | Baseline finish | Baseline duration | Baseline 1 start | Baseline 1 finish | Total slack | Free slack | Farol de Atraso | Farol Marcos | % Previsto Tempo | Índice de Desempenho Físico (IDF) | Farol IDF | % Previsto Ponderado | % Concluído Ponderado | Farol de Início | Responsável | Código do Contrato | % Concluída Numérico | IDF Numérico | % Previsto Tempo Numérico | % Previsto Ponderado Numérico | % Concluído Ponderado Numérico |
| --- | --- | --- | --- | --- | --- | --- | --- | --- | --- | --- | --- | --- | --- | --- | --- | --- | --- | --- | --- | --- | --- | --- | --- | --- | --- | --- | --- | --- | --- | --- | --- |
| 1672 | 2.3.19.5 | **Pleito de Itueta a definir - Obra Vila Nietzel ou Quatituba** |  | 407d | 2020-05-29 | 2022-01-14 |  |  |  | 2020-05-29 | 2022-01-14 | 407d |  |  | 772d |  | Verde | Verde | 0% | 0% | Verde | 0% | 0% |  |  |  |  |  |  |  |  |
| 1673 | 2.3.19.5.1 | Pleito aprovado | milestone | 0d | 2020-05-29 | 2020-05-29 | 206FS+362d |  |  | 2020-05-29 | 2020-05-29 | 0d |  |  | 772d | 0d | Verde | Verde | 0% | 0% | Verde | 0% | 0% | Verde |  |  |  |  |  |  |  |
| 1674 | 2.3.19.5.2 | **Licitação da Obra** |  | 80d | 2020-06-15 | 2020-10-06 |  |  |  | 2020-06-15 | 2020-10-06 | 80d |  |  | 772d |  | Verde | Verde | 0% | 0% | Verde | 0% | 0% |  |  |  |  |  |  |  |  |
| 1675 | 2.3.19.5.2.1 | Licitação da obra autorizada pelo banco | milestone | 0d | 2020-06-15 | 2020-06-15 | 1673FS+10d |  |  | 2020-06-15 | 2020-06-15 | 0d |  |  | 772d | 0d | Verde | Verde | 0% | 0% | Verde | 0% | 0% | Verde |  |  |  |  |  |  |  |
| 1676 | 2.3.19.5.2.2 | Licitar Obra |  | 66d | 2020-06-16 | 2020-09-16 | 1675 |  |  | 2020-06-16 | 2020-09-16 | 66d |  |  | 772d | 0d | Verde | Verde | 0% | 0% | Verde | 0% | 0% | Verde |  |  |  |  |  |  |  |
| 1677 | 2.3.19.5.2.3 | Analisar e emitir resultado da licitação da obra |  | 14d | 2020-09-17 | 2020-10-06 | 1676 |  |  | 2020-09-17 | 2020-10-06 | 14d |  |  | 772d | 0d | Verde | Verde | 0% | 0% | Verde | 0% | 0% | Verde |  |  |  |  |  |  |  |
| 1678 | 2.3.19.5.2.4 | Licitação da obra concluída | milestone | 0d | 2020-10-06 | 2020-10-06 | 1677 |  |  | 2020-10-06 | 2020-10-06 | 0d |  |  | 772d | 0d | Verde | Verde | 0% | 0% | Verde | 0% | 0% | Verde |  |  |  |  |  |  |  |
| 1679 | 2.3.19.5.3 | Executar obra |  | 164d | 2020-11-06 | 2021-07-06 | 1678FS+20d |  |  | 2020-11-06 | 2021-07-06 | 164d |  |  | 772d | 0d | Verde | Verde | 0% | 0% | Verde | 0% | 0% | Verde |  |  |  |  |  |  |  |
| 1680 | 2.3.19.5.4 | Realizar processo de pré-operação |  | 128d | 2021-07-07 | 2022-01-07 | 1679 |  |  | 2021-07-07 | 2022-01-07 | 128d |  |  | 772d | 0d | Verde | Verde | 0% | 0% | Verde | 0% | 0% | Verde |  |  |  |  |  |  |  |
| 1681 | 2.3.19.5.5 | Recurso da obra parcelado repassado | milestone | 0d | 2022-01-14 | 2022-01-14 | 1680FS+5d |  |  | 2022-01-14 | 2022-01-14 | 0d |  |  | 772d | 0d | Verde | Verde | 0% | 0% | Verde | 0% | 0% | Verde |  |  |  |  |  |  |  |
| 1682 | 2.3.19.5.6 | Pleito a definir concluído | milestone | 0d | 2022-01-14 | 2022-01-14 | 1681 |  |  | 2022-01-14 | 2022-01-14 | 0d |  |  | 772d | 0d | Verde | Verde | 0% | 0% | Verde | 0% | 0% | Verde |  |  |  |  |  |  |  |
| 1683 | 2.3.19.6 | Recursos de Itueta repassados | milestone | 0d | 2022-01-14 | 2022-01-14 | 1628, 1638, 1671, 1682 |  |  | 2022-01-14 | 2022-01-14 | 0d | 2019-07-29 | 2021-07-15 | 772d |  | Verde | Verde | 0% | 0% | Verde | 0% | 0% | Verde | 02 - Execução | PG 031 |  |  |  |  |  |
| 1684 | 2.3.20 | **Linhares** |  | 1089d | 2019-03-14 A | 2023-07-28 |  | 10% | 984.17d | 2019-03-14 | 2023-07-28 | 1089d | 2018-12-04 | 2022-06-23 | 391d |  | Verde | Verde | 2% | 100% | Verde | 2% | 2% |  |  |  | 10 | 100 |  |  |  |
| 1685 | 2.3.20.1 | **Pleito LINESOB01 - Outras obras complementares - SES do distrito de Povoação (obra iniciada e paralisada em 2012)** |  | 382d | 2019-03-25 A | 2020-10-02 |  | 11% | 339.93d | 2019-03-25 | 2020-10-02 | 382d |  |  | 1091d |  | Verde | Verde | 6% | 50% | Vermelho | 2% | 1% |  |  |  | 11 | 50 |  |  |  |
| 1686 | 2.3.20.1.1 | Alteração do pleito aprovada | milestone | 0d | 2019-05-31 | 2019-05-31 | 206FS+115d |  |  | 2019-05-31 | 2019-05-31 | 0d |  |  | 24d | 0d | Verde | Verde | 0% | 0% | Verde | 0% | 0% | Verde |  |  |  |  |  |  |  |
| 1687 | 2.3.20.1.2 | **Aprovação do Projeto** |  | 35d | 2019-05-06 | 2019-06-24 |  |  |  | 2019-05-06 | 2019-06-24 | 35d |  |  | 1091d |  | Verde | Verde | 0% | 0% | Verde | 0% | 0% |  |  |  |  |  |  |  |  |
| 1688 | 2.3.20.1.2.1 | Informações complementares do projeto protocoladas no banco | milestone | 0d | 2019-05-06 | 2019-05-06 | 1686FS-20d |  |  | 2019-05-06 | 2019-05-06 | 0d |  |  | 1104d | 0d | Verde | Verde | 0% | 0% | Verde | 0% | 0% | Verde |  |  |  |  |  |  |  |
| 1689 | 2.3.20.1.2.2 | Analisar projeto |  | 22d | 2019-05-06 | 2019-06-04 | 1688 |  |  | 2019-05-06 | 2019-06-04 | 22d |  |  | 1104d | 13d | Verde | Verde | 0% | 0% | Verde | 0% | 0% | Verde |  |  |  |  |  |  |  |
| 1690 | 2.3.20.1.2.3 | Projeto aprovado | milestone | 0d | 2019-06-24 | 2019-06-24 | 1689, 1692, 1691 |  |  | 2019-06-24 | 2019-06-24 | 0d |  |  | 1091d | 0d | Verde | Verde | 0% | 0% | Verde | 0% | 0% | Verde |  |  |  |  |  |  |  |
| 1691 | 2.3.20.1.3 | Regularizar terreno |  | 62d | 2019-03-25 A | 2019-06-24 | 1686FS-46d | 40% | 37d | 2019-03-25 | 2019-06-24 | 62d |  |  | 1091d | 0d | Verde | Verde | 40% | 72% | Vermelho | 40% | 29% | Verde |  |  | 40 | 72 | 40 | 40 | 29 |
| 1692 | 2.3.20.1.4 | Realizar Licenciamento Ambiental |  | 62d | 2019-03-25 A | 2019-06-24 | 1686FS-46d | 40% | 37d | 2019-03-25 | 2019-06-24 | 62d |  |  | 1091d | 0d | Verde | Verde | 40% | 82% | Vermelho | 40% | 33% | Verde |  |  | 40 | 82 | 40 | 40 | 33 |
| 1693 | 2.3.20.1.5 | **Licitação da Obra** |  | 35d | 2019-05-06 | 2019-06-24 |  |  |  | 2019-05-06 | 2019-06-24 | 35d |  |  | 1091d |  | Verde | Verde | 0% | 0% | Verde | 0% | 0% |  |  |  |  |  |  |  |  |
| 1694 | 2.3.20.1.5.1 | Licitação da obra apresentada ao banco | milestone | 0d | 2019-05-06 | 2019-05-06 | 1688 |  |  | 2019-05-06 | 2019-05-06 | 0d |  |  | 1112d | 0d | Verde | Verde | 0% | 0% | Verde | 0% | 0% | Verde |  |  |  |  |  |  |  |
| 1695 | 2.3.20.1.5.2 | Analisar e emitir resultado da licitação do projeto |  | 14d | 2019-05-06 | 2019-05-23 | 1694 |  |  | 2019-05-06 | 2019-05-23 | 14d |  |  | 1112d | 21d | Verde | Verde | 0% | 0% | Verde | 0% | 0% | Verde |  |  |  |  |  |  |  |
| 1696 | 2.3.20.1.5.3 | Licitação da obra concluída | milestone | 0d | 2019-06-24 | 2019-06-24 | 1695, 1690 |  |  | 2019-06-24 | 2019-06-24 | 0d |  |  | 1091d | 0d | Verde | Verde | 0% | 0% | Verde | 0% | 0% | Verde |  |  |  |  |  |  |  |
| 1697 | 2.3.20.1.6 | Executar obra |  | 167d | 2019-07-24 | 2020-03-25 | 1696FS+21d |  |  | 2019-07-24 | 2020-03-25 | 167d |  |  | 1091d | 0d | Verde | Verde | 0% | 0% | Verde | 0% | 0% | Verde |  |  |  |  |  |  |  |
| 1698 | 2.3.20.1.7 | Realizar processo de pré-operação |  | 127d | 2020-03-26 | 2020-09-25 | 1697 |  |  | 2020-03-26 | 2020-09-25 | 127d |  |  | 1091d | 0d | Verde | Verde | 0% | 0% | Verde | 0% | 0% | Verde |  |  |  |  |  |  |  |
| 1699 | 2.3.20.1.8 | Recurso da obra parcelado repassado | milestone | 0d | 2020-10-02 | 2020-10-02 | 1698FS+5d |  |  | 2020-10-02 | 2020-10-02 | 0d |  |  | 1091d | 0d | Verde | Verde | 0% | 0% | Verde | 0% | 0% | Verde |  |  |  |  |  |  |  |
| 1700 | 2.3.20.1.9 | Pleito LINESOB01 concluído | milestone | 0d | 2020-10-02 | 2020-10-02 | 1699 |  |  | 2020-10-02 | 2020-10-02 | 0d |  |  | 1091d | 700d | Verde | Verde | 0% | 0% | Verde | 0% | 0% | Verde |  |  |  |  |  |  |  |

Notes:
- 1673: Em 23/04/2019: o município poderá enviar pleito de obra após protocolo do projeto executivo no banco (07/01/20) e conforme cronograma da NT 33 o pleito só será analisado em maio.
- 1683: Valor de recurso destinado ao munícipio: R$2.661.115,58
- 1684: Linhares solicitou pediu 51,6% (R$24.628.767,59) dos 90% de recursos destinado para Esgotamento Sanitário e teve todo o pleito aprovado, conforme Deliberação 75. / O pleito de resíduos sólido (10% do total do recurso destinado ao munícipio) foi aprovado.
- 1686: Em 23/04/2019: O ofício de pleito será analisado na próxima CT e CIF sendo aprovado apenas dia 31/05/2019
- 1691: Em 29/04/2019: atualizado como agendado
- 1692: Em 29/04/2019: atualizado como agendado
- 1697: Em 24/04/2019: valor da obra R$ 2,5 milhões

| ID | WBS | Task | Type | Duration | Start | Finish | Predecessors | Complete | Remaining | Baseline start | Baseline finish | Baseline duration | Total slack | Free slack | Farol de Atraso | Farol Marcos | % Previsto Tempo | % Concluída Numérico | Índice de Desempenho Físico (IDF) | IDF Numérico | Farol IDF | % Previsto Ponderado | % Concluído Ponderado | Farol de Início | % Previsto Tempo Numérico | % Previsto Ponderado Numérico | % Concluído Ponderado Numérico |
| --- | --- | --- | --- | --- | --- | --- | --- | --- | --- | --- | --- | --- | --- | --- | --- | --- | --- | --- | --- | --- | --- | --- | --- | --- | --- | --- | --- |
| 1701 | 2.3.20.2 | **Pleito LINESOB02 - Outras obras complementares - SES do distrito de Regência (obra iniciada e paralisada em 2012)** |  | 382d | 2019-03-25 A | 2020-10-02 |  | 11% | 339.93d | 2019-03-25 | 2020-10-02 | 382d | 1091d |  | Verde | Verde | 6% | 11 | 100% | 100 | Verde | 2% | 2% |  |  |  |  |
| 1702 | 2.3.20.2.1 | Alteração do pleito aprovada | milestone | 0d | 2019-05-31 | 2019-05-31 | 1686 |  |  | 2019-05-31 | 2019-05-31 | 0d | 24d | 0d | Verde | Verde | 0% |  | 0% |  | Verde | 0% | 0% | Verde |  |  |  |
| 1703 | 2.3.20.2.2 | **Aprovação do Projeto** |  | 35d | 2019-05-06 | 2019-06-24 |  |  |  | 2019-05-06 | 2019-06-24 | 35d | 1091d |  | Verde | Verde | 0% |  | 0% |  | Verde | 0% | 0% |  |  |  |  |
| 1704 | 2.3.20.2.2.1 | Informações complementares do projeto protocoladas no banco | milestone | 0d | 2019-05-06 | 2019-05-06 | 1702FS-20d |  |  | 2019-05-06 | 2019-05-06 | 0d | 1104d | 0d | Verde | Verde | 0% |  | 0% |  | Verde | 0% | 0% | Verde |  |  |  |
| 1705 | 2.3.20.2.2.2 | Analisar projeto |  | 22d | 2019-05-06 | 2019-06-04 | 1704 |  |  | 2019-05-06 | 2019-06-04 | 22d | 1104d | 13d | Verde | Verde | 0% |  | 0% |  | Verde | 0% | 0% | Verde |  |  |  |
| 1706 | 2.3.20.2.2.3 | Projeto aprovado | milestone | 0d | 2019-06-24 | 2019-06-24 | 1705, 1708, 1707 |  |  | 2019-06-24 | 2019-06-24 | 0d | 1091d | 0d | Verde | Verde | 0% |  | 0% |  | Verde | 0% | 0% | Verde |  |  |  |
| 1707 | 2.3.20.2.3 | Regularizar terreno |  | 62d | 2019-03-25 A | 2019-06-24 | 1702FS-46d | 40% | 37d | 2019-03-25 | 2019-06-24 | 62d | 1091d | 0d | Verde | Verde | 40% | 40 | 95% | 95 | Vermelho | 40% | 38% | Verde | 40 | 40 | 38 |
| 1708 | 2.3.20.2.4 | Realizar Licenciamento Ambiental |  | 62d | 2019-03-25 A | 2019-06-24 | 1702FS-46d | 40% | 37d | 2019-03-25 | 2019-06-24 | 62d | 1091d | 0d | Verde | Verde | 40% | 40 | 95% | 95 | Vermelho | 40% | 38% | Verde | 40 | 40 | 38 |
| 1709 | 2.3.20.2.5 | **Licitação da Obra** |  | 35d | 2019-05-06 | 2019-06-24 |  |  |  | 2019-05-06 | 2019-06-24 | 35d | 1091d |  | Verde | Verde | 0% |  | 0% |  | Verde | 0% | 0% |  |  |  |  |
| 1710 | 2.3.20.2.5.1 | Licitação da obra apresentada ao banco | milestone | 0d | 2019-05-06 | 2019-05-06 | 1704 |  |  | 2019-05-06 | 2019-05-06 | 0d | 1112d | 0d | Verde | Verde | 0% |  | 0% |  | Verde | 0% | 0% | Verde |  |  |  |
| 1711 | 2.3.20.2.5.2 | Analisar e emitir resultado da licitação do projeto |  | 14d | 2019-05-06 | 2019-05-23 | 1710 |  |  | 2019-05-06 | 2019-05-23 | 14d | 1112d | 21d | Verde | Verde | 0% |  | 0% |  | Verde | 0% | 0% | Verde |  |  |  |
| 1712 | 2.3.20.2.5.3 | Licitação da obra concluída | milestone | 0d | 2019-06-24 | 2019-06-24 | 1711, 1706 |  |  | 2019-06-24 | 2019-06-24 | 0d | 1091d | 0d | Verde | Verde | 0% |  | 0% |  | Verde | 0% | 0% | Verde |  |  |  |
| 1713 | 2.3.20.2.6 | Executar obra |  | 167d | 2019-07-24 | 2020-03-25 | 1712FS+21d |  |  | 2019-07-24 | 2020-03-25 | 167d | 1091d | 0d | Verde | Verde | 0% |  | 0% |  | Verde | 0% | 0% | Verde |  |  |  |
| 1714 | 2.3.20.2.7 | Realizar processo de pré-operação |  | 127d | 2020-03-26 | 2020-09-25 | 1713 |  |  | 2020-03-26 | 2020-09-25 | 127d | 1091d | 0d | Verde | Verde | 0% |  | 0% |  | Verde | 0% | 0% | Verde |  |  |  |
| 1715 | 2.3.20.2.8 | Recurso da obra parcelado repassado | milestone | 0d | 2020-10-02 | 2020-10-02 | 1714FS+5d |  |  | 2020-10-02 | 2020-10-02 | 0d | 1091d | 0d | Verde | Verde | 0% |  | 0% |  | Verde | 0% | 0% | Verde |  |  |  |
| 1716 | 2.3.20.2.9 | Pleito LINESOB02 concluído | milestone | 0d | 2020-10-02 | 2020-10-02 | 1715 |  |  | 2020-10-02 | 2020-10-02 | 0d | 1091d | 700d | Verde | Verde | 0% |  | 0% |  | Verde | 0% | 0% | Verde |  |  |  |
| 1717 | 2.3.20.3 | **Pleito LINESOB07 - Contratação de empresa para conclusão da implantação e recuperação das obras já executadas do SES do distrito de Pontal do Ipiranga** |  | 382d | 2019-03-25 A | 2020-10-02 |  | 11% | 339.93d | 2019-03-25 | 2020-10-02 | 382d | 1091d |  | Verde | Verde | 6% | 11 | 100% | 100 | Verde | 2% | 2% |  |  |  |  |
| 1718 | 2.3.20.3.1 | Alteração do pleito aprovada | milestone | 0d | 2019-05-31 | 2019-05-31 | 1686 |  |  | 2019-05-31 | 2019-05-31 | 0d | 24d | 0d | Verde | Verde | 0% |  | 0% |  | Verde | 0% | 0% | Verde |  |  |  |
| 1719 | 2.3.20.3.2 | **Aprovação do Projeto** |  | 35d | 2019-05-06 | 2019-06-24 |  |  |  | 2019-05-06 | 2019-06-24 | 35d | 1091d |  | Verde | Verde | 0% |  | 0% |  | Verde | 0% | 0% |  |  |  |  |
| 1720 | 2.3.20.3.2.1 | Informações complementares do projeto protocoladas no banco | milestone | 0d | 2019-05-06 | 2019-05-06 | 1718FS-20d |  |  | 2019-05-06 | 2019-05-06 | 0d | 1104d | 0d | Verde | Verde | 0% |  | 0% |  | Verde | 0% | 0% | Verde |  |  |  |
| 1721 | 2.3.20.3.2.2 | Analisar projeto |  | 22d | 2019-05-06 | 2019-06-04 | 1720 |  |  | 2019-05-06 | 2019-06-04 | 22d | 1104d | 13d | Verde | Verde | 0% |  | 0% |  | Verde | 0% | 0% | Verde |  |  |  |
| 1722 | 2.3.20.3.2.3 | Projeto aprovado | milestone | 0d | 2019-06-24 | 2019-06-24 | 1721, 1723, 1724 |  |  | 2019-06-24 | 2019-06-24 | 0d | 1091d | 0d | Verde | Verde | 0% |  | 0% |  | Verde | 0% | 0% | Verde |  |  |  |
| 1723 | 2.3.20.3.3 | Regularizar terreno |  | 62d | 2019-03-25 A | 2019-06-24 | 1718FS-46d | 40% | 37d | 2019-03-25 | 2019-06-24 | 62d | 1091d | 0d | Verde | Verde | 40% | 40 | 100% | 100 | Verde | 40% | 40% | Verde | 40 | 40 | 40 |
| 1724 | 2.3.20.3.4 | Realizar Licenciamento Ambiental |  | 62d | 2019-03-25 A | 2019-06-24 | 1718FS-46d | 40% | 37d | 2019-03-25 | 2019-06-24 | 62d | 1091d | 0d | Verde | Verde | 40% | 40 | 100% | 100 | Verde | 40% | 40% | Verde | 40 | 40 | 40 |

Notes:
- 1707: Em 29/04/2019: atualizado como agendado
- 1708: Em 29/04/2019: atualizado como agendado
- 1723: Em 29/04/2019: atualizado como agendado
- 1724: Em 29/04/2019: atualizado como agendado

| ID | WBS | Task | Type | Duration | Start | Finish | Predecessors | Complete | Remaining | Baseline start | Baseline finish | Baseline duration | Total slack | Free slack | Farol de Atraso | Farol Marcos | % Previsto Tempo | Índice de Desempenho Físico (IDF) | Farol IDF | % Previsto Ponderado | % Concluído Ponderado | Farol de Início | % Concluída Numérico | IDF Numérico | % Previsto Tempo Numérico | % Previsto Ponderado Numérico | % Concluído Ponderado Numérico |
| --- | --- | --- | --- | --- | --- | --- | --- | --- | --- | --- | --- | --- | --- | --- | --- | --- | --- | --- | --- | --- | --- | --- | --- | --- | --- | --- | --- |
| 1725 | 2.3.20.3.5 | **Licitação da Obra** |  | 35d | 2019-05-06 | 2019-06-24 |  |  |  | 2019-05-06 | 2019-06-24 | 35d | 1091d |  | Verde | Verde | 0% | 0% | Verde | 0% | 0% |  |  |  |  |  |  |
| 1726 | 2.3.20.3.5.1 | Licitação da obra apresentada ao banco | milestone | 0d | 2019-05-06 | 2019-05-06 | 1720 |  |  | 2019-05-06 | 2019-05-06 | 0d | 1112d | 0d | Verde | Verde | 0% | 0% | Verde | 0% | 0% | Verde |  |  |  |  |  |
| 1727 | 2.3.20.3.5.2 | Analisar e emitir resultado da licitação do projeto |  | 14d | 2019-05-06 | 2019-05-23 | 1726 |  |  | 2019-05-06 | 2019-05-23 | 14d | 1112d | 21d | Verde | Verde | 0% | 0% | Verde | 0% | 0% | Verde |  |  |  |  |  |
| 1728 | 2.3.20.3.5.3 | Licitação da obra concluída | milestone | 0d | 2019-06-24 | 2019-06-24 | 1727, 1722 |  |  | 2019-06-24 | 2019-06-24 | 0d | 1091d | 0d | Verde | Verde | 0% | 0% | Verde | 0% | 0% | Verde |  |  |  |  |  |
| 1729 | 2.3.20.3.6 | Executar obra |  | 167d | 2019-07-24 | 2020-03-25 | 1728FS+21d |  |  | 2019-07-24 | 2020-03-25 | 167d | 1091d | 0d | Verde | Verde | 0% | 0% | Verde | 0% | 0% | Verde |  |  |  |  |  |
| 1730 | 2.3.20.3.7 | Realizar processo de pré-operação |  | 127d | 2020-03-26 | 2020-09-25 | 1729 |  |  | 2020-03-26 | 2020-09-25 | 127d | 1091d | 0d | Verde | Verde | 0% | 0% | Verde | 0% | 0% | Verde |  |  |  |  |  |
| 1731 | 2.3.20.3.8 | Recurso da obra parcelado repassado | milestone | 0d | 2020-10-02 | 2020-10-02 | 1730FS+5d |  |  | 2020-10-02 | 2020-10-02 | 0d | 1091d | 0d | Verde | Verde | 0% | 0% | Verde | 0% | 0% | Verde |  |  |  |  |  |
| 1732 | 2.3.20.3.9 | Pleito LINESOB07 concluído | milestone | 0d | 2020-10-02 | 2020-10-02 | 1731 |  |  | 2020-10-02 | 2020-10-02 | 0d | 1091d | 700d | Verde | Verde | 0% | 0% | Verde | 0% | 0% | Verde |  |  |  |  |  |
| 1733 | 2.3.20.4 | **Pleito de Linhares a definir - Obra na sede, Bagueira, Humaitá, Pontal do Ouro e Quartel** |  | 1035d | 2019-05-31 | 2023-07-28 |  |  |  | 2019-05-31 | 2023-07-28 | 1035d | 391d |  | Verde | Verde | 0% | 0% | Verde | 0% | 0% |  |  |  |  |  |  |
| 1734 | 2.3.20.4.1 | Pleito aprovado | milestone | 0d | 2019-05-31 | 2019-05-31 | 206FS+115d |  |  | 2019-05-31 | 2019-05-31 | 0d | 391d | 0d | Verde | Verde | 0% | 0% | Verde | 0% | 0% | Verde |  |  |  |  |  |
| 1735 | 2.3.20.4.2 | Iniciar pleito |  | 1d | 2019-06-17 | 2019-06-17 | 1734FS+10d |  |  | 2019-06-17 | 2019-06-17 | 1d | 391d | 0d | Verde | Verde | 0% | 0% | Verde | 0% | 0% | Verde |  |  |  |  |  |
| 1736 | 2.3.20.4.3 | Pleito concluído | milestone | 0d | 2023-07-28 | 2023-07-28 | 1735FS+1024d |  |  | 2023-07-28 | 2023-07-28 | 0d | 391d | 0d | Verde | Verde | 0% | 0% | Verde | 0% | 0% | Verde |  |  |  |  |  |
| 1737 | 2.3.20.5 | **Pleito LINESOB03 - Outras obras complementares - ampliação do SES da sede municipal - construção de ETE, no bairro Aviso** |  | 396d | 2019-03-25 A | 2020-10-23 |  | 11% | 352.39d | 2019-03-25 | 2020-10-23 | 396d | 1077d |  | Verde | Verde | 6% | 100% | Verde | 2% | 2% |  | 11 | 100 |  |  |  |
| 1738 | 2.3.20.5.1 | Alteração do pleito aprovada | milestone | 0d | 2019-05-31 | 2019-05-31 | 1686 |  |  | 2019-05-31 | 2019-05-31 | 0d | 24d | 0d | Verde | Verde | 0% | 0% | Verde | 0% | 0% | Verde |  |  |  |  |  |
| 1739 | 2.3.20.5.2 | **Aprovação do Projeto** |  | 35d | 2019-05-06 | 2019-06-24 |  |  |  | 2019-05-06 | 2019-06-24 | 35d | 1077d |  | Verde | Verde | 0% | 0% | Verde | 0% | 0% |  |  |  |  |  |  |
| 1740 | 2.3.20.5.2.1 | Informações complementares do projeto protocoladas no banco | milestone | 0d | 2019-05-06 | 2019-05-06 | 1738FS-20d |  |  | 2019-05-06 | 2019-05-06 | 0d | 1090d | 0d | Verde | Verde | 0% | 0% | Verde | 0% | 0% | Verde |  |  |  |  |  |
| 1741 | 2.3.20.5.2.2 | Analisar projeto |  | 22d | 2019-05-06 | 2019-06-04 | 1740 |  |  | 2019-05-06 | 2019-06-04 | 22d | 1090d | 13d | Verde | Verde | 0% | 0% | Verde | 0% | 0% | Verde |  |  |  |  |  |
| 1742 | 2.3.20.5.2.3 | Projeto aprovado | milestone | 0d | 2019-06-24 | 2019-06-24 | 1741, 1743, 1744 |  |  | 2019-06-24 | 2019-06-24 | 0d | 1077d | 0d | Verde | Verde | 0% | 0% | Verde | 0% | 0% | Verde |  |  |  |  |  |
| 1743 | 2.3.20.5.3 | Regularizar terreno |  | 62d | 2019-03-25 A | 2019-06-24 | 1738FS-46d | 40% | 37d | 2019-03-25 | 2019-06-24 | 62d | 1077d | 0d | Verde | Verde | 40% | 95% | Vermelho | 40% | 38% | Verde | 40 | 95 | 40 | 40 | 38 |
| 1744 | 2.3.20.5.4 | Realizar Licenciamento Ambiental |  | 62d | 2019-03-25 A | 2019-06-24 | 1738FS-46d | 40% | 37d | 2019-03-25 | 2019-06-24 | 62d | 1077d | 0d | Verde | Verde | 40% | 98% | Vermelho | 40% | 39% | Verde | 40 | 98 | 40 | 40 | 39 |
| 1745 | 2.3.20.5.5 | **Licitação da Obra** |  | 14d | 2019-06-24 | 2019-07-12 |  |  |  | 2019-06-24 | 2019-07-12 | 14d | 1077d |  | Verde | Verde | 0% | 0% | Verde | 0% | 0% |  |  |  |  |  |  |
| 1746 | 2.3.20.5.5.1 | Licitação da obra apresentada ao banco | milestone | 0d | 2019-06-24 | 2019-06-24 | 1740, 1742 |  |  | 2019-06-24 | 2019-06-24 | 0d | 1077d | 0d | Verde | Verde | 0% | 0% | Verde | 0% | 0% | Verde |  |  |  |  |  |
| 1747 | 2.3.20.5.5.2 | Analisar e emitir resultado da licitação do projeto |  | 14d | 2019-06-25 | 2019-07-12 | 1746 |  |  | 2019-06-25 | 2019-07-12 | 14d | 1077d | 0d | Verde | Verde | 0% | 0% | Verde | 0% | 0% | Verde |  |  |  |  |  |
| 1748 | 2.3.20.5.5.3 | Licitação da obra concluída | milestone | 0d | 2019-07-12 | 2019-07-12 | 1747 |  |  | 2019-07-12 | 2019-07-12 | 0d | 1077d | 0d | Verde | Verde | 0% | 0% | Verde | 0% | 0% | Verde |  |  |  |  |  |
| 1749 | 2.3.20.5.6 | Executar obra |  | 167d | 2019-08-13 | 2020-04-15 | 1748FS+21d |  |  | 2019-08-13 | 2020-04-15 | 167d | 1077d | 0d | Verde | Verde | 0% | 0% | Verde | 0% | 0% | Verde |  |  |  |  |  |
| 1750 | 2.3.20.5.7 | Realizar processo de pré-operação |  | 127d | 2020-04-16 | 2020-10-16 | 1749 |  |  | 2020-04-16 | 2020-10-16 | 127d | 1077d | 0d | Verde | Verde | 0% | 0% | Verde | 0% | 0% | Verde |  |  |  |  |  |
| 1751 | 2.3.20.5.8 | Recurso da obra parcelado repassado | milestone | 0d | 2020-10-23 | 2020-10-23 | 1750FS+5d |  |  | 2020-10-23 | 2020-10-23 | 0d | 1077d | 0d | Verde | Verde | 0% | 0% | Verde | 0% | 0% | Verde |  |  |  |  |  |
| 1752 | 2.3.20.5.9 | Pleito LINESOB03 concluído | milestone | 0d | 2020-10-23 | 2020-10-23 | 1751 |  |  | 2020-10-23 | 2020-10-23 | 0d | 1077d | 686d | Verde | Verde | 0% | 0% | Verde | 0% | 0% | Verde |  |  |  |  |  |

Notes:
- 1734: Em 25/04/2019: ofício de pleito foi enviado a CT conforme informado pelo município. Não foi apresentado a Renova e por isso foi considerado apenas início e fim do pleito. O pleito será aprovado na próxima CT/CIF dia 31/05/2019.
- 1736: Em 25/04/2019: considerado o valor da obra de R$ 12 milhões com licitação e licenciamento.
- 1743: Em 29/04/2019: atualizado como agendado
- 1744: Em 29/04/2019: atualizado como agendado

| ID | WBS | Task | Type | Duration | Start | Finish | Predecessors | Complete | Remaining | Baseline start | Baseline finish | Baseline duration | Baseline 1 start | Baseline 1 finish | Total slack | Free slack | Farol de Atraso | Farol Marcos | % Previsto Tempo | Índice de Desempenho Físico (IDF) | IDF Numérico | Farol IDF | % Previsto Ponderado | % Previsto Ponderado Numérico | % Concluído Ponderado | % Concluído Ponderado Numérico | % Concluída Numérico | % Previsto Tempo Numérico | Farol de Início | Responsável | Código do Contrato |
| --- | --- | --- | --- | --- | --- | --- | --- | --- | --- | --- | --- | --- | --- | --- | --- | --- | --- | --- | --- | --- | --- | --- | --- | --- | --- | --- | --- | --- | --- | --- | --- |
| 1753 | 2.3.20.6 | **Pleito LINRSOB01 - O município fez opção por alocar os recursos no montante de R$ 4.775.582,44 para viabilizar a solução consorciada, com objetivo de executar as obras para a implantação da Central de Tratamento de Resíduos – CTR Colatina, apesar de não f** |  | 625d | 2019-03-14 A | 2021-09-15 |  | 5% | 590.99d | 2019-03-14 | 2021-09-15 | 625d |  |  | 855d |  | Verde | Verde | 5% | 100% | 100 | Verde | 10% | 10 | 10% | 10 |  |  |  |  |  |
| 1754 | 2.3.20.6.1 | **Licitação da obra** |  | 52d | 2019-03-14 A | 2019-05-29 |  | 70% | 15.83d | 2019-03-14 | 2019-05-29 | 52d |  |  | 855d |  | Verde | Verde | 61% | 100% | 100 | Verde | 67% | 67 | 67% | 67 | 70 | 61 |  |  |  |
| 1755 | 2.3.20.6.1.1 | Licitação da obra autorizada pelo banco | milestone | 0d | 2019-03-14 A | 2019-03-14 A | 358 | 100% |  | 2019-03-14 | 2019-03-14 | 0d |  |  |  |  | Verde | Verde | 100% | 0% |  | Vermelho | 100% | 100 | 0% |  | 100 | 100 | Verde |  |  |
| 1756 | 2.3.20.6.1.2 | Licitar obra |  | 38d | 2019-03-14 A | 2019-05-09 | 1755 | 84% | 6d | 2019-03-14 | 2019-05-09 | 38d |  |  | 855d | 0d | Verde | Verde | 84% | 100% | 100 | Verde | 84% | 84 | 84% | 84 | 84 | 84 | Verde |  |  |
| 1757 | 2.3.20.6.1.3 | Analisar e emitir resultado da licitação da obra |  | 8d | 2019-05-20 | 2019-05-29 | 1756FS+6d |  |  | 2019-05-20 | 2019-05-29 | 8d |  |  | 855d | 0d | Verde | Verde | 0% | 0% |  | Verde | 0% |  | 0% |  |  |  | Verde |  |  |
| 1758 | 2.3.20.6.1.4 | Licitação da obra concluída | milestone | 0d | 2019-05-29 | 2019-05-29 | 1757 |  |  | 2019-05-29 | 2019-05-29 | 0d |  |  | 855d | 0d | Verde | Verde | 0% | 0% |  | Verde | 0% |  | 0% |  |  |  | Verde |  |  |
| 1759 | 2.3.20.6.2 | Executar obra |  | 414d | 2019-07-08 | 2021-03-08 | 1758FS+26d |  |  | 2019-07-08 | 2021-03-08 | 414d |  |  | 855d | 0d | Verde | Verde | 0% | 0% |  | Verde | 0% |  | 0% |  |  |  | Verde |  |  |
| 1760 | 2.3.20.6.3 | Realizar processo de pré-operação |  | 128d | 2021-03-09 | 2021-09-08 | 1759 |  |  | 2021-03-09 | 2021-09-08 | 128d |  |  | 855d | 0d | Verde | Verde | 0% | 0% |  | Verde | 0% |  | 0% |  |  |  | Verde |  |  |
| 1761 | 2.3.20.6.4 | Recurso da obra parcelado repassado | milestone | 0d | 2021-09-15 | 2021-09-15 | 1760FS+5d |  |  | 2021-09-15 | 2021-09-15 | 0d |  |  | 855d | 0d | Verde | Verde | 0% | 0% |  | Verde | 0% |  | 0% |  |  |  | Verde |  |  |
| 1762 | 2.3.20.6.5 | Pleito LINRSOB01 concluído | milestone | 0d | 2021-09-15 | 2021-09-15 | 1761 |  |  | 2021-09-15 | 2021-09-15 | 0d |  |  | 855d | 464d | Verde | Verde | 0% | 0% |  | Verde | 0% |  | 0% |  |  |  | Verde |  |  |
| 1763 | 2.3.20.7 | **Pleito LINESPJ01 - Elaboração de projetos de obras de infraestrutura urbana no município de linhares (em fase de licitação); elaboração de projetos de SES dos distritos de Rio Quartel, Bagueira, Guaxe, Chapadão das Palminhas, Humaitá; e construção de emis** |  | 1d | 2019-06-03 | 2019-06-03 |  |  |  | 2019-06-03 | 2019-06-03 | 1d |  |  | 1425d |  | Verde | Verde | 0% | 0% |  | Verde | 0% |  | 0% |  |  |  |  |  |  |
| 1764 | 2.3.20.7.1 | Avaliar pleito |  | 1d | 2019-06-03 | 2019-06-03 | 206FS+115d |  |  | 2019-06-03 | 2019-06-03 | 1d |  |  | 1425d | 0d | Verde | Verde | 0% | 0% |  | Verde | 0% |  | 0% |  |  |  | Verde |  |  |
| 1765 | 2.3.20.7.2 | Pleito LINESPJ01 concluído | milestone | 0d | 2019-06-03 | 2019-06-03 | 1764 |  |  | 2019-06-03 | 2019-06-03 | 0d |  |  | 1425d | 1034d | Verde | Verde | 0% | 0% |  | Verde | 0% |  | 0% |  |  |  | Verde |  |  |
| 1766 | 2.3.20.8 | **Pleito LINESOB04 - Construção de EEEB - bairro Canivete** |  | 1d | 2019-06-03 | 2019-06-03 |  |  |  | 2019-06-03 | 2019-06-03 | 1d |  |  | 1425d |  | Verde | Verde | 0% | 0% |  | Verde | 0% |  | 0% |  |  |  |  |  |  |
| 1767 | 2.3.20.8.1 | Avaliar pleito |  | 1d | 2019-06-03 | 2019-06-03 | 206FS+115d |  |  | 2019-06-03 | 2019-06-03 | 1d |  |  | 1425d | 0d | Verde | Verde | 0% | 0% |  | Verde | 0% |  | 0% |  |  |  | Verde |  |  |
| 1768 | 2.3.20.8.2 | Pleito LINESOB04 concluído | milestone | 0d | 2019-06-03 | 2019-06-03 | 1767 |  |  | 2019-06-03 | 2019-06-03 | 0d |  |  | 1425d | 1034d | Verde | Verde | 0% | 0% |  | Verde | 0% |  | 0% |  |  |  | Verde |  |  |
| 1769 | 2.3.20.9 | **Pleito LINESOB05 - Construção de EEEB - bairro Aviso** |  | 1d | 2019-06-03 | 2019-06-03 |  |  |  | 2019-06-03 | 2019-06-03 | 1d |  |  | 1425d |  | Verde | Verde | 0% | 0% |  | Verde | 0% |  | 0% |  |  |  |  |  |  |
| 1770 | 2.3.20.9.1 | Avaliar pleito |  | 1d | 2019-06-03 | 2019-06-03 | 206FS+115d |  |  | 2019-06-03 | 2019-06-03 | 1d |  |  | 1425d | 0d | Verde | Verde | 0% | 0% |  | Verde | 0% |  | 0% |  |  |  | Verde |  |  |
| 1771 | 2.3.20.9.2 | Pleito LINESOB05 concluído | milestone | 0d | 2019-06-03 | 2019-06-03 | 1770 |  |  | 2019-06-03 | 2019-06-03 | 0d |  |  | 1425d | 1034d | Verde | Verde | 0% | 0% |  | Verde | 0% |  | 0% |  |  |  | Verde |  |  |
| 1772 | 2.3.20.10 | **Pleito LINESOB06 - Implantação de biodigestor para tratamento de esgoto (beneficiará 210 agricultores)** |  | 1d | 2019-06-03 | 2019-06-03 |  |  |  | 2019-06-03 | 2019-06-03 | 1d |  |  | 1425d |  | Verde | Verde | 0% | 0% |  | Verde | 0% |  | 0% |  |  |  |  |  |  |
| 1773 | 2.3.20.10.1 | Avaliar pleito |  | 1d | 2019-06-03 | 2019-06-03 | 206FS+115d |  |  | 2019-06-03 | 2019-06-03 | 1d |  |  | 1425d | 0d | Verde | Verde | 0% | 0% |  | Verde | 0% |  | 0% |  |  |  | Verde |  |  |
| 1774 | 2.3.20.10.2 | Pleito LINESOB06 concluído | milestone | 0d | 2019-06-03 | 2019-06-03 | 1773 |  |  | 2019-06-03 | 2019-06-03 | 0d |  |  | 1425d | 1034d | Verde | Verde | 0% | 0% |  | Verde | 0% |  | 0% |  |  |  | Verde |  |  |
| 1775 | 2.3.20.11 | **Pleito LINESOB08 - Reforma das 65 EEEBs** |  | 1d | 2019-06-03 | 2019-06-03 |  |  |  | 2019-06-03 | 2019-06-03 | 1d |  |  | 1425d |  | Verde | Verde | 0% | 0% |  | Verde | 0% |  | 0% |  |  |  |  |  |  |
| 1776 | 2.3.20.11.1 | Avaliar pleito |  | 1d | 2019-06-03 | 2019-06-03 | 206FS+115d |  |  | 2019-06-03 | 2019-06-03 | 1d |  |  | 1425d | 0d | Verde | Verde | 0% | 0% |  | Verde | 0% |  | 0% |  |  |  | Verde |  |  |
| 1777 | 2.3.20.11.2 | Pleito LINESOB08 concluído | milestone | 0d | 2019-06-03 | 2019-06-03 | 1776 |  |  | 2019-06-03 | 2019-06-03 | 0d |  |  | 1425d | 1034d | Verde | Verde | 0% | 0% |  | Verde | 0% |  | 0% |  |  |  | Verde |  |  |
| 1778 | 2.3.20.12 | Recurso de Linhares repassados | milestone | 0d | 2023-07-28 | 2023-07-28 | 1765, 1732, 1700, 1716, 1752, 1768, 1771, 1774, 1777, 1762, 1736 |  |  | 2023-07-28 | 2023-07-28 | 0d | 2019-05-08 | 2022-06-23 | 391d |  | Verde | Verde | 0% | 0% |  | Verde | 0% |  | 0% |  |  |  | Verde | 02 - Execução | PG 031 |

Notes:
- 1756: Em 29/04/2019: atualizado como agendado
- 1764: Em 25/04/2019: o ofício de cancelamento de pleito foi enviado dia 13/03/2019. Considerado que na próxima reunião do CIF o pleito será cancelado dia 31/05/2019.
- 1767: Em 25/04/2019: o ofício de cancelamento de pleito foi enviado dia 13/03/2019. Considerado que na próxima reunião do CIF o pleito será cancelado dia 31/05/2019.
- 1770: Em 25/04/2019: o ofício de cancelamento de pleito foi enviado dia 13/03/2019. Considerado que na próxima reunião do CIF o pleito será cancelado dia 31/05/2019.
- 1773: Em 25/04/2019: o ofício de cancelamento de pleito foi enviado dia 13/03/2019. Considerado que na próxima reunião do CIF o pleito será cancelado dia 31/05/2019.
- 1776: Em 25/04/2019: o ofício de cancelamento de pleito foi enviado dia 13/03/2019. Considerado que na próxima reunião do CIF o pleito será cancelado dia 31/05/2019.
- 1778: Valor de recurso destinado ao munícipio: R$47.755.824,41

| ID | WBS | Task | Type | Duration | Start | Finish | Predecessors | Complete | Remaining | Baseline start | Baseline finish | Baseline duration | Baseline 1 start | Baseline 1 finish | Total slack | Free slack | Constraint | Farol de Atraso | Farol Marcos | % Previsto Tempo | Índice de Desempenho Físico (IDF) | Farol IDF | % Previsto Ponderado | % Concluído Ponderado | IDF Numérico | % Concluída Numérico | % Previsto Tempo Numérico | % Previsto Ponderado Numérico | Farol de Início | % Concluído Ponderado Numérico |
| --- | --- | --- | --- | --- | --- | --- | --- | --- | --- | --- | --- | --- | --- | --- | --- | --- | --- | --- | --- | --- | --- | --- | --- | --- | --- | --- | --- | --- | --- | --- |
| 1779 | 2.3.21 | **Mariana** |  | 1226d | 2019-02-19 A | 2024-01-29 |  | 3% | 1183.13d | 2019-02-19 | 2024-01-29 | 1226d | 2018-09-12 | 2022-03-25 | 268d |  |  | Verde | Verde | 3% | 0% | Vermelho | 0% | 0% |  |  |  |  |  |  |
| 1780 | 2.3.21.1 | **Pleito MRNESPJ03 - Elaboração de projetos de engenharia Distritos de Rita Durão, Monsenhor Horta, Bandeirantes, Cláudio Manoel, Furquim, Barroca e Passagem de Mariana, incluindo o bairro Liberdade e os subdistritos de Mainart, Barro Branco e Águas Claras** |  | 317d | 2019-03-28 A | 2020-07-07 |  | 5% | 302.45d | 2019-03-28 | 2020-07-07 | 317d |  |  | 1153d |  |  | Verde | Verde | 6% | 100% | Verde | 1% | 1% | 100 |  |  |  |  |  |
| 1781 | 2.3.21.1.1 | Pleito aprovado | milestone | 0d | 2019-03-28 A | 2019-03-28 A |  | 100% |  | 2019-03-28 | 2019-03-28 | 0d |  |  |  |  | must start on 2019-03-28 | Verde | Verde | 100% | 0% | Vermelho | 100% | 0% |  | 100 | 100 | 100 | Verde |  |
| 1782 | 2.3.21.1.2 | **Licitação do Projeto** |  | 56d | 2019-04-08 A | 2019-07-01 |  | 25% | 42d | 2019-04-08 | 2019-07-01 | 56d |  |  | 1153d |  |  | Verde | Verde | 25% | 63% | Vermelho | 27% | 17% | 63 | 25 | 25 | 27 |  | 17 |
| 1783 | 2.3.21.1.2.1 | Licitação do projeto autorizada pelo banco | milestone | 0d | 2019-04-08 A | 2019-04-08 A | 1781FS+8d | 100% |  | 2019-04-08 | 2019-04-08 | 0d |  |  |  |  |  | Verde | Verde | 100% | 0% | Vermelho | 100% | 0% |  | 100 | 100 | 100 | Verde |  |
| 1784 | 2.3.21.1.2.2 | Licitar projeto |  | 42d | 2019-04-09 A | 2019-06-10 | 1783 | 33% | 28d | 2019-04-09 | 2019-06-10 | 42d |  |  | 1153d | 0d |  | Verde | Verde | 33% | 61% | Vermelho | 33% | 20% | 61 | 33 | 33 | 33 | Verde | 20 |
| 1785 | 2.3.21.1.2.3 | Documentação de licitação apresentada ao banco | milestone | 0d | 2019-06-10 | 2019-06-10 | 1784 |  |  | 2019-06-10 | 2019-06-10 | 0d |  |  | 1153d | 0d |  | Verde | Verde | 0% | 0% | Verde | 0% | 0% |  |  |  |  | Verde |  |
| 1786 | 2.3.21.1.2.4 | Analisar e emitir resultado da licitação do projeto |  | 14d | 2019-06-11 | 2019-07-01 | 1785 |  |  | 2019-06-11 | 2019-07-01 | 14d |  |  | 1153d | 0d |  | Verde | Verde | 0% | 0% | Verde | 0% | 0% |  |  |  |  | Verde |  |
| 1787 | 2.3.21.1.2.5 | Licitação do projeto concluída | milestone | 0d | 2019-07-01 | 2019-07-01 | 1786 |  |  | 2019-07-01 | 2019-07-01 | 0d |  |  | 1153d | 0d |  | Verde | Verde | 0% | 0% | Verde | 0% | 0% |  |  |  |  | Verde |  |
| 1788 | 2.3.21.1.3 | **Elaboração do Projeto Básico** |  | 154d | 2019-07-02 | 2020-02-10 |  |  |  | 2019-07-02 | 2020-02-10 | 154d |  |  | 1153d |  |  | Verde | Verde | 0% | 0% | Verde | 0% | 0% |  |  |  |  |  |  |
| 1789 | 2.3.21.1.3.1 | Elaborar projeto básico |  | 84d | 2019-07-02 | 2019-10-28 | 1787 |  |  | 2019-07-02 | 2019-10-28 | 84d |  |  | 1153d | 0d |  | Verde | Verde | 0% | 0% | Verde | 0% | 0% |  |  |  |  | Verde |  |
| 1790 | 2.3.21.1.3.2 | Projeto Básico apresentado ao banco | milestone | 0d | 2019-10-28 | 2019-10-28 | 1789 |  |  | 2019-10-28 | 2019-10-28 | 0d |  |  | 1247d | 0d |  | Verde | Verde | 0% | 0% | Verde | 0% | 0% |  |  |  |  | Verde |  |
| 1791 | 2.3.21.1.3.3 | Analisar projeto básico |  | 22d | 2019-10-29 | 2019-11-28 | 1790 |  |  | 2019-10-29 | 2019-11-28 | 22d |  |  | 1247d | 0d |  | Verde | Verde | 0% | 0% | Verde | 0% | 0% |  |  |  |  | Verde |  |
| 1792 | 2.3.21.1.3.4 | Adequar/revisar projeto básico |  | 22d | 2019-11-29 | 2020-01-03 | 1791 |  |  | 2019-11-29 | 2020-01-03 | 22d |  |  | 1247d | 0d |  | Verde | Verde | 0% | 0% | Verde | 0% | 0% |  |  |  |  | Verde |  |
| 1793 | 2.3.21.1.3.5 | Analisar projeto básico - final |  | 21d | 2020-01-06 | 2020-02-03 | 1792 |  |  | 2020-01-06 | 2020-02-03 | 21d |  |  | 1247d | 0d |  | Verde | Verde | 0% | 0% | Verde | 0% | 0% |  |  |  |  | Verde |  |
| 1794 | 2.3.21.1.3.6 | Projeto básico concluído | milestone | 0d | 2020-02-03 | 2020-02-03 | 1793 |  |  | 2020-02-03 | 2020-02-03 | 0d |  |  | 1247d | 0d |  | Verde | Verde | 0% | 0% | Verde | 0% | 0% |  |  |  |  | Verde |  |
| 1795 | 2.3.21.1.3.7 | Recurso do projeto básico do pleito MRNESPJ03 repassado | milestone | 0d | 2020-02-10 | 2020-02-10 | 1794FS+5d |  |  | 2020-02-10 | 2020-02-10 | 0d |  |  | 1247d | 94d |  | Verde | Verde | 0% | 0% | Verde | 0% | 0% |  |  |  |  | Verde |  |
| 1796 | 2.3.21.1.4 | **Elaboração do Projeto Executivo** |  | 105d | 2020-02-03 | 2020-07-07 |  |  |  | 2020-02-03 | 2020-07-07 | 105d |  |  | 1153d |  |  | Verde | Verde | 0% | 0% | Verde | 0% | 0% |  |  |  |  |  |  |
| 1797 | 2.3.21.1.4.1 | Elaborar de projeto executivo |  | 42d | 2020-02-03 | 2020-04-03 | 1789FS+64d |  |  | 2020-02-03 | 2020-04-03 | 42d |  |  | 1153d | 0d |  | Verde | Verde | 0% | 0% | Verde | 0% | 0% |  |  |  |  | Verde |  |
| 1798 | 2.3.21.1.4.2 | Projeto Executivo apresentado ao banco | milestone | 0d | 2020-04-03 | 2020-04-03 | 1797 |  |  | 2020-04-03 | 2020-04-03 | 0d |  |  | 1153d | 0d |  | Verde | Verde | 0% | 0% | Verde | 0% | 0% |  |  |  |  | Verde |  |
| 1799 | 2.3.21.1.4.3 | Analisar projeto executivo |  | 19d | 2020-04-06 | 2020-05-05 | 1798 |  |  | 2020-04-06 | 2020-05-05 | 19d |  |  | 1153d | 0d |  | Verde | Verde | 0% | 0% | Verde | 0% | 0% |  |  |  |  | Verde |  |
| 1800 | 2.3.21.1.4.4 | Adequar/rever o projeto |  | 21d | 2020-05-06 | 2020-06-03 | 1799 |  |  | 2020-05-06 | 2020-06-03 | 21d |  |  | 1153d | 0d |  | Verde | Verde | 0% | 0% | Verde | 0% | 0% |  |  |  |  | Verde |  |
| 1801 | 2.3.21.1.4.5 | Analisar projeto executivo - final |  | 18d | 2020-06-04 | 2020-06-30 | 1800 |  |  | 2020-06-04 | 2020-06-30 | 18d |  |  | 1153d | 0d |  | Verde | Verde | 0% | 0% | Verde | 0% | 0% |  |  |  |  | Verde |  |
| 1802 | 2.3.21.1.4.6 | Projeto executivo concluído | milestone | 0d | 2020-06-30 | 2020-06-30 | 1801, 1795 |  |  | 2020-06-30 | 2020-06-30 | 0d |  |  | 1153d | 0d |  | Verde | Verde | 0% | 0% | Verde | 0% | 0% |  |  |  |  | Verde |  |
| 1803 | 2.3.21.1.4.7 | Recurso do projeto executivo do pleito MRNESPJ03 repassado | milestone | 0d | 2020-07-07 | 2020-07-07 | 1802FS+5d |  |  | 2020-07-07 | 2020-07-07 | 0d |  |  | 1153d | 0d |  | Verde | Verde | 0% | 0% | Verde | 0% | 0% |  |  |  |  | Verde |  |
| 1804 | 2.3.21.1.5 | Pleito MRNESPJ03 concluído | milestone | 0d | 2020-07-07 | 2020-07-07 | 1803 |  |  | 2020-07-07 | 2020-07-07 | 0d |  |  | 1153d | 451d |  | Verde | Verde | 0% | 0% | Verde | 0% | 0% |  |  |  |  | Verde |  |

Notes:
- 1779: Mariana solicitou 96,8% do total de recurso destinado ao munícipio para Esgotamento Sanitário, mas foi aprovado 90% do valor teto para este fim (R$64.166.980,38), conforme Deliberação 75. / O município teve o pleito de resíduos sólidos negado (R$7.129.664,49), equivalente a 10% do total do recurso). / Aderiu à ata de registro de preço. / Como ainda não está definido quantas obras seram realizadas, foi considerado o valor total de obras, dividido por 6 para o critério de prazo, de forma a não impactar no prazo final do programa.
- 1781: Em 24/04/2019: pleito foi aprovado na deliberação 269 no dia 28/03/2019
- 1783: Em 24/04/2019: considerando que alteração do pleito foi aprovada em 28/03/2019 e desconsiderando o processo licitatório apresentado anteriormente.
- 1784: Em 29/04/2019: atualizado como agendado

| ID | WBS | Task | Type | Duration | Start | Finish | Predecessors | Complete | Remaining | Baseline start | Baseline finish | Baseline duration | Total slack | Free slack | Constraint | Farol de Atraso | Farol Marcos | % Previsto Tempo | Índice de Desempenho Físico (IDF) | IDF Numérico | Farol IDF | % Previsto Ponderado | % Concluído Ponderado | % Concluída Numérico | % Previsto Tempo Numérico | % Previsto Ponderado Numérico | Farol de Início | % Concluído Ponderado Numérico |
| --- | --- | --- | --- | --- | --- | --- | --- | --- | --- | --- | --- | --- | --- | --- | --- | --- | --- | --- | --- | --- | --- | --- | --- | --- | --- | --- | --- | --- |
| 1805 | 2.3.21.2 | **Pleito MRNESPJ04 - Adequação dos projetos básicos e elaboração dos projetos executivos dos SES de Padre Viegas e Cachoeira do Brumado** |  | 264d | 2019-03-28 A | 2020-04-20 |  | 6% | 248.98d | 2019-03-28 | 2020-04-20 | 264d | 702d |  |  | Verde | Verde | 8% | 80% | 80 | Vermelho | 5% | 4% |  |  |  |  |  |
| 1806 | 2.3.21.2.1 | Alteração do pleito aprovada | milestone | 0d | 2019-03-28 A | 2019-03-28 A |  | 100% |  | 2019-03-28 | 2019-03-28 | 0d |  |  | must start on 2019-03-28 | Verde | Verde | 100% | 0% |  | Vermelho | 100% | 0% | 100 | 100 | 100 | Verde |  |
| 1807 | 2.3.21.2.2 | **Licitação do Projeto** |  | 62d | 2019-04-08 A | 2019-07-09 |  | 25% | 46.77d | 2019-04-08 | 2019-07-09 | 62d | 702d |  |  | Verde | Verde | 22% | 92% | 92 | Vermelho | 25% | 23% | 25 | 22 | 25 |  | 23 |
| 1808 | 2.3.21.2.2.1 | Licitação do projeto autorizada pelo banco | milestone | 0d | 2019-04-08 A | 2019-04-08 A | 1806FS+8d | 100% |  | 2019-04-08 | 2019-04-08 | 0d |  |  |  | Verde | Verde | 100% | 0% |  | Vermelho | 100% | 0% | 100 | 100 | 100 | Verde |  |
| 1809 | 2.3.21.2.2.2 | Licitar projeto |  | 43d | 2019-04-09 A | 2019-06-11 | 1808 | 33% | 29d | 2019-04-09 | 2019-06-11 | 43d | 702d | 0d |  | Verde | Verde | 32% | 94% | 94 | Vermelho | 32% | 30% | 33 | 32 | 32 | Verde | 30 |
| 1810 | 2.3.21.2.2.3 | Documentação de licitação apresentada ao banco | milestone | 0d | 2019-06-18 | 2019-06-18 | 1809FS+5d |  |  | 2019-06-18 | 2019-06-18 | 0d | 702d | 0d |  | Verde | Verde | 0% | 0% |  | Verde | 0% | 0% |  |  |  | Verde |  |
| 1811 | 2.3.21.2.2.4 | Analisar e emitir resultado da licitação do projeto |  | 14d | 2019-06-19 | 2019-07-09 | 1810 |  |  | 2019-06-19 | 2019-07-09 | 14d | 702d | 0d |  | Verde | Verde | 0% | 0% |  | Verde | 0% | 0% |  |  |  | Verde |  |
| 1812 | 2.3.21.2.2.5 | Licitação do projeto concluída | milestone | 0d | 2019-07-09 | 2019-07-09 | 1811 |  |  | 2019-07-09 | 2019-07-09 | 0d | 702d | 0d |  | Verde | Verde | 0% | 0% |  | Verde | 0% | 0% |  |  |  | Verde |  |
| 1813 | 2.3.21.2.3 | **Elaboração do Projeto Executivo** |  | 194d | 2019-07-10 | 2020-04-20 |  |  |  | 2019-07-10 | 2020-04-20 | 194d | 702d |  |  | Verde | Verde | 0% | 0% |  | Verde | 0% | 0% |  |  |  |  |  |
| 1814 | 2.3.21.2.3.1 | Elaborar projeto executivo |  | 125d | 2019-07-10 | 2020-01-08 | 1812 |  |  | 2019-07-10 | 2020-01-08 | 125d | 702d | 0d |  | Verde | Verde | 0% | 0% |  | Verde | 0% | 0% |  |  |  | Verde |  |
| 1815 | 2.3.21.2.3.2 | Projeto Executivo apresentado ao banco | milestone | 0d | 2020-01-08 | 2020-01-08 | 1814 |  |  | 2020-01-08 | 2020-01-08 | 0d | 702d | 0d |  | Verde | Verde | 0% | 0% |  | Verde | 0% | 0% |  |  |  | Verde |  |
| 1816 | 2.3.21.2.3.3 | Analisar projeto executivo |  | 23d | 2020-01-09 | 2020-02-10 | 1815 |  |  | 2020-01-09 | 2020-02-10 | 23d | 702d | 0d |  | Verde | Verde | 0% | 0% |  | Verde | 0% | 0% |  |  |  | Verde |  |
| 1817 | 2.3.21.2.3.4 | Adequar/revisar projeto executivo |  | 19d | 2020-02-11 | 2020-03-11 | 1816 |  |  | 2020-02-11 | 2020-03-11 | 19d | 702d | 0d |  | Verde | Verde | 0% | 0% |  | Verde | 0% | 0% |  |  |  | Verde |  |
| 1818 | 2.3.21.2.3.5 | Analisar projeto executivo - final |  | 22d | 2020-03-12 | 2020-04-13 | 1817 |  |  | 2020-03-12 | 2020-04-13 | 22d | 702d | 0d |  | Verde | Verde | 0% | 0% |  | Verde | 0% | 0% |  |  |  | Verde |  |
| 1819 | 2.3.21.2.3.6 | Projeto executivo concluído | milestone | 0d | 2020-04-13 | 2020-04-13 | 1818 |  |  | 2020-04-13 | 2020-04-13 | 0d | 702d | 0d |  | Verde | Verde | 0% | 0% |  | Verde | 0% | 0% |  |  |  | Verde |  |
| 1820 | 2.3.21.2.3.7 | Recurso do projeto executivo do pleito MRNESPJ05 repassado | milestone | 0d | 2020-04-20 | 2020-04-20 | 1819FS+5d |  |  | 2020-04-20 | 2020-04-20 | 0d | 702d | 0d |  | Verde | Verde | 0% | 0% |  | Verde | 0% | 0% |  |  |  | Verde |  |
| 1821 | 2.3.21.2.4 | Pleito MRNESPJ04 concluído | milestone | 0d | 2020-04-20 | 2020-04-20 | 1820 |  |  | 2020-04-20 | 2020-04-20 | 0d | 702d | 0d |  | Verde | Verde | 0% | 0% |  | Verde | 0% | 0% |  |  |  | Verde |  |
| 1822 | 2.3.21.3 | **Pleito MRNESPJ05 - Adequação de projetos de engenharia, referente à licenciamento, para Distritos de Padre Viegas e Cachoeira do Brumado** |  | 268d | 2019-02-19 A | 2020-03-20 |  | 19% | 217.91d | 2019-02-19 | 2020-03-20 | 268d | 1226d |  |  | Verde | Verde | 17% | 56% | 56 | Vermelho | 18% | 10% | 19 | 17 | 18 |  | 10 |
| 1823 | 2.3.21.3.1 | Pleito aprovado | milestone | 0d | 2019-03-28 A | 2019-03-28 A |  | 100% |  | 2019-03-28 | 2019-03-28 | 0d |  |  | must start on 2019-03-28 | Verde | Verde | 100% | 0% |  | Vermelho | 100% | 0% | 100 | 100 | 100 | Verde |  |
| 1824 | 2.3.21.3.2 | **Licitação de Empresa para Licenciamento Ambiental** |  | 63d | 2019-04-08 A | 2019-07-10 |  | 24% | 47.79d | 2019-04-08 | 2019-07-10 | 63d | 46d |  |  | Verde | Verde | 22% | 0% |  | Vermelho | 21% | 0% | 24 | 22 | 21 |  |  |
| 1825 | 2.3.21.3.2.1 | Licitação da empresa para Licenciamento Ambiental autorizada pelo banco | milestone | 0d | 2019-04-08 A | 2019-04-08 A | 1823FS+8d | 100% |  | 2019-04-08 | 2019-04-08 | 0d |  |  |  | Verde | Verde | 100% | 0% |  | Vermelho | 100% | 0% | 100 | 100 | 100 | Verde |  |
| 1826 | 2.3.21.3.2.2 | Licitar empresa para Licenciamento Ambiental |  | 44d | 2019-04-09 A | 2019-06-12 | 1825 | 32% | 30d | 2019-04-09 | 2019-06-12 | 44d | 46d | 0d |  | Verde | Verde | 31% | 0% |  | Vermelho | 31% | 0% | 32 | 31 | 31 | Verde |  |
| 1827 | 2.3.21.3.2.3 | Documentação de licitação apresentada ao banco | milestone | 0d | 2019-06-19 | 2019-06-19 | 1826FS+5d |  |  | 2019-06-19 | 2019-06-19 | 0d | 46d | 0d |  | Verde | Verde | 0% | 0% |  | Verde | 0% | 0% |  |  |  | Verde |  |
| 1828 | 2.3.21.3.2.4 | Analisar e emitir resultado da licitação do empresa para Licenciamento Ambiental |  | 14d | 2019-06-21 | 2019-07-10 | 1827 |  |  | 2019-06-21 | 2019-07-10 | 14d | 46d | 0d |  | Verde | Verde | 0% | 0% |  | Verde | 0% | 0% |  |  |  | Verde |  |
| 1829 | 2.3.21.3.2.5 | Licitação da empresa para Licenciamento Ambiental concluída | milestone | 0d | 2019-07-10 | 2019-07-10 | 1828 |  |  | 2019-07-10 | 2019-07-10 | 0d | 46d | 0d |  | Verde | Verde | 0% | 0% |  | Verde | 0% | 0% |  |  |  | Verde |  |
| 1830 | 2.3.21.3.3 | Executar o Licenciamento Ambiental |  | 263d | 2019-02-19 A | 2020-03-13 | 1829FS-95d | 17% | 217d | 2019-02-19 | 2020-03-13 | 263d | 1226d | 0d |  | Verde | Verde | 17% | 82% | 82 | Vermelho | 17% | 14% | 17 | 17 | 17 | Verde | 14 |
| 1831 | 2.3.21.3.4 | Recurso do serviço parcelado repassado | milestone | 0d | 2020-03-20 | 2020-03-20 | 1830FS+5d |  |  | 2020-03-20 | 2020-03-20 | 0d | 1226d | 0d |  | Verde | Verde | 0% | 0% |  | Verde | 0% | 0% |  |  |  | Verde |  |
| 1832 | 2.3.21.3.5 | Pleito MRNESPJ05 concluído | milestone | 0d | 2020-03-20 | 2020-03-20 | 1831 |  |  | 2020-03-20 | 2020-03-20 | 0d | 1226d | 524d |  | Verde | Verde | 0% | 0% |  | Verde | 0% | 0% |  |  |  | Verde |  |

Notes:
- 1809: Em 29/04/2019: atualizado como agendado
- 1826: Em 29/04/2019: atualizado como agendado

| ID | WBS | Task | Type | Duration | Start | Finish | Predecessors | Complete | Remaining | Baseline start | Baseline finish | Baseline duration | Total slack | Free slack | Constraint | Farol de Atraso | Farol Marcos | % Previsto Tempo | Índice de Desempenho Físico (IDF) | Farol IDF | % Previsto Ponderado | % Concluído Ponderado | Farol de Início | IDF Numérico | % Concluída Numérico | % Previsto Tempo Numérico | % Previsto Ponderado Numérico | % Concluído Ponderado Numérico |
| --- | --- | --- | --- | --- | --- | --- | --- | --- | --- | --- | --- | --- | --- | --- | --- | --- | --- | --- | --- | --- | --- | --- | --- | --- | --- | --- | --- | --- |
| 1833 | 2.3.21.4 | **Pleito MRNESOB06 - Execução de obras de implantação do SES para distrito de Cachoeira do Brumado** |  | 504d | 2020-04-20 | 2022-04-29 |  |  |  | 2020-04-20 | 2022-04-29 | 504d | 702d |  |  | Verde | Verde | 0% | 0% | Verde | 0% | 0% |  |  |  |  |  |  |
| 1834 | 2.3.21.4.1 | **Licitação da obra** |  | 102d | 2020-04-20 | 2020-09-15 |  |  |  | 2020-04-20 | 2020-09-15 | 102d | 702d |  |  | Verde | Verde | 0% | 0% | Verde | 0% | 0% |  |  |  |  |  |  |
| 1835 | 2.3.21.4.1.1 | Licitação da obra autorizada pelo banco | milestone | 0d | 2020-04-20 | 2020-04-20 | 1821 |  |  | 2020-04-20 | 2020-04-20 | 0d | 702d | 0d |  | Verde | Verde | 0% | 0% | Verde | 0% | 0% | Verde |  |  |  |  |  |
| 1836 | 2.3.21.4.1.2 | Licitar Obra |  | 87d | 2020-04-22 | 2020-08-24 | 1835 |  |  | 2020-04-22 | 2020-08-24 | 87d | 702d | 0d |  | Verde | Verde | 0% | 0% | Verde | 0% | 0% | Verde |  |  |  |  |  |
| 1837 | 2.3.21.4.1.3 | Analisar e emitir resultado da licitação da obra |  | 15d | 2020-08-25 | 2020-09-15 | 1836 |  |  | 2020-08-25 | 2020-09-15 | 15d | 702d | 0d |  | Verde | Verde | 0% | 0% | Verde | 0% | 0% | Verde |  |  |  |  |  |
| 1838 | 2.3.21.4.1.4 | Licitação da obra concluída | milestone | 0d | 2020-09-15 | 2020-09-15 | 1837 |  |  | 2020-09-15 | 2020-09-15 | 0d | 702d | 0d |  | Verde | Verde | 0% | 0% | Verde | 0% | 0% | Verde |  |  |  |  |  |
| 1839 | 2.3.21.4.2 | Executar obra |  | 249d | 2020-10-15 | 2021-10-14 | 1838FS+20d |  |  | 2020-10-15 | 2021-10-14 | 249d | 702d | 0d |  | Verde | Verde | 0% | 0% | Verde | 0% | 0% | Verde |  |  |  |  |  |
| 1840 | 2.3.21.4.3 | Realizar processo de pré-operação |  | 128d | 2021-10-15 | 2022-04-22 | 1839 |  |  | 2021-10-15 | 2022-04-22 | 128d | 702d | 0d |  | Verde | Verde | 0% | 0% | Verde | 0% | 0% | Verde |  |  |  |  |  |
| 1841 | 2.3.21.4.4 | Recurso da obra parcelado repassado | milestone | 0d | 2022-04-29 | 2022-04-29 | 1840FS+5d |  |  | 2022-04-29 | 2022-04-29 | 0d | 702d | 0d |  | Verde | Verde | 0% | 0% | Verde | 0% | 0% | Verde |  |  |  |  |  |
| 1842 | 2.3.21.4.5 | Pleito MRNESOB06 concluído | milestone | 0d | 2022-04-29 | 2022-04-29 | 1841 |  |  | 2022-04-29 | 2022-04-29 | 0d | 702d | 0d |  | Verde | Verde | 0% | 0% | Verde | 0% | 0% | Verde |  |  |  |  |  |
| 1843 | 2.3.21.5 | **Pleito MRNESOB05 - Execução de obras de implantação do SES para o distrito Padre Viegas** |  | 420d | 2020-04-20 | 2021-12-27 |  |  |  | 2020-04-20 | 2021-12-27 | 420d | 786d |  |  | Verde | Verde | 0% | 0% | Verde | 0% | 0% |  |  |  |  |  |  |
| 1844 | 2.3.21.5.1 | **Licitação da obra** |  | 102d | 2020-04-20 | 2020-09-15 |  |  |  | 2020-04-20 | 2020-09-15 | 102d | 786d |  |  | Verde | Verde | 0% | 0% | Verde | 0% | 0% |  |  |  |  |  |  |
| 1845 | 2.3.21.5.1.1 | Licitação da obra autorizada pelo banco | milestone | 0d | 2020-04-20 | 2020-04-20 | 1821 |  |  | 2020-04-20 | 2020-04-20 | 0d | 786d | 0d |  | Verde | Verde | 0% | 0% | Verde | 0% | 0% | Verde |  |  |  |  |  |
| 1846 | 2.3.21.5.1.2 | Licitar Obra |  | 87d | 2020-04-22 | 2020-08-24 | 1845 |  |  | 2020-04-22 | 2020-08-24 | 87d | 786d | 0d |  | Verde | Verde | 0% | 0% | Verde | 0% | 0% | Verde |  |  |  |  |  |
| 1847 | 2.3.21.5.1.3 | Analisar e emitir resultado da licitação da obra |  | 15d | 2020-08-25 | 2020-09-15 | 1846 |  |  | 2020-08-25 | 2020-09-15 | 15d | 786d | 0d |  | Verde | Verde | 0% | 0% | Verde | 0% | 0% | Verde |  |  |  |  |  |
| 1848 | 2.3.21.5.1.4 | Licitação da obra concluída | milestone | 0d | 2020-09-15 | 2020-09-15 | 1847 |  |  | 2020-09-15 | 2020-09-15 | 0d | 786d | 0d |  | Verde | Verde | 0% | 0% | Verde | 0% | 0% | Verde |  |  |  |  |  |
| 1849 | 2.3.21.5.2 | Executar obra |  | 165d | 2020-10-15 | 2021-06-16 | 1848FS+20d |  |  | 2020-10-15 | 2021-06-16 | 165d | 786d | 0d |  | Verde | Verde | 0% | 0% | Verde | 0% | 0% | Verde |  |  |  |  |  |
| 1850 | 2.3.21.5.3 | Realizar processo de pré-operação |  | 128d | 2021-06-17 | 2021-12-17 | 1849 |  |  | 2021-06-17 | 2021-12-17 | 128d | 786d | 0d |  | Verde | Verde | 0% | 0% | Verde | 0% | 0% | Verde |  |  |  |  |  |
| 1851 | 2.3.21.5.4 | Recurso da obra parcelado repassado | milestone | 0d | 2021-12-27 | 2021-12-27 | 1850FS+5d |  |  | 2021-12-27 | 2021-12-27 | 0d | 786d | 0d |  | Verde | Verde | 0% | 0% | Verde | 0% | 0% | Verde |  |  |  |  |  |
| 1852 | 2.3.21.5.5 | Pleito MRNESOB05 concluído | milestone | 0d | 2021-12-27 | 2021-12-27 | 1851 |  |  | 2021-12-27 | 2021-12-27 | 0d | 786d | 84d |  | Verde | Verde | 0% | 0% | Verde | 0% | 0% | Verde |  |  |  |  |  |
| 1853 | 2.3.21.6 | **Pleito MRNESPJ06 - Elaboração de projetos de engenharia para a Sede de Mariana, a ser utilizada na complementação dos projetos executivos já existentes e na elaboração de projetos básicos e executivos dos demais itens que compôem o sistema de coleta e tra** |  | 264d | 2019-03-28 A | 2020-04-20 |  | 6% | 248.98d | 2019-03-28 | 2020-04-20 | 264d | 1206d |  |  | Verde | Verde | 8% | 100% | Verde | 5% | 5% |  | 100 |  |  |  |  |
| 1854 | 2.3.21.6.1 | Alteração do pleito aprovada | milestone | 0d | 2019-03-28 A | 2019-03-28 A |  | 100% |  | 2019-03-28 | 2019-03-28 | 0d |  |  | must start on 2019-03-28 | Verde | Verde | 100% | 0% | Vermelho | 100% | 0% | Verde |  | 100 | 100 | 100 |  |
| 1855 | 2.3.21.6.2 | **Licitação do Projeto** |  | 62d | 2019-04-08 A | 2019-07-09 |  | 25% | 46.77d | 2019-04-08 | 2019-07-09 | 62d | 706d |  |  | Verde | Verde | 22% | 92% | Vermelho | 26% | 24% |  | 92 | 25 | 22 | 26 | 24 |
| 1856 | 2.3.21.6.2.1 | Licitação do projeto autorizada pelo banco | milestone | 0d | 2019-04-08 A | 2019-04-08 A | 1854FS+8d | 100% |  | 2019-04-08 | 2019-04-08 | 0d |  |  |  | Verde | Verde | 100% | 0% | Vermelho | 100% | 0% | Verde |  | 100 | 100 | 100 |  |
| 1857 | 2.3.21.6.2.2 | Licitar projeto |  | 43d | 2019-04-09 A | 2019-06-11 | 1856 | 33% | 29d | 2019-04-09 | 2019-06-11 | 43d | 706d | 0d |  | Verde | Verde | 32% | 91% | Vermelho | 32% | 29% | Verde | 91 | 33 | 32 | 32 | 29 |
| 1858 | 2.3.21.6.2.3 | Documentação de licitação apresentada ao banco | milestone | 0d | 2019-06-18 | 2019-06-18 | 1857FS+5d |  |  | 2019-06-18 | 2019-06-18 | 0d | 706d | 0d |  | Verde | Verde | 0% | 0% | Verde | 0% | 0% | Verde |  |  |  |  |  |
| 1859 | 2.3.21.6.2.4 | Analisar e emitir resultado da licitação do projeto |  | 14d | 2019-06-19 | 2019-07-09 | 1858 |  |  | 2019-06-19 | 2019-07-09 | 14d | 706d | 0d |  | Verde | Verde | 0% | 0% | Verde | 0% | 0% | Verde |  |  |  |  |  |
| 1860 | 2.3.21.6.2.5 | Licitação do projeto concluída | milestone | 0d | 2019-07-09 | 2019-07-09 | 1859 |  |  | 2019-07-09 | 2019-07-09 | 0d | 706d | 0d |  | Verde | Verde | 0% | 0% | Verde | 0% | 0% | Verde |  |  |  |  |  |

Notes:
- 1839: Em 24/04/2019: valor da obra R$ 3.045.229,52
- 1849: Em 24/04/2019: valor da obra R$ 1,9 milhões
- 1857: Em 29/04/2019: atualizado como agendado

| ID | WBS | Task | Type | Duration | Start | Finish | Predecessors | Baseline start | Baseline finish | Baseline duration | Total slack | Free slack | Farol de Atraso | Farol Marcos | % Previsto Tempo | Índice de Desempenho Físico (IDF) | Farol IDF | % Previsto Ponderado | % Concluído Ponderado | Farol de Início |
| --- | --- | --- | --- | --- | --- | --- | --- | --- | --- | --- | --- | --- | --- | --- | --- | --- | --- | --- | --- | --- |
| 1861 | 2.3.21.6.3 | **Elaboração do Projeto Executivo** |  | 194d | 2019-07-10 | 2020-04-20 |  | 2019-07-10 | 2020-04-20 | 194d | 706d |  | Verde | Verde | 0% | 0% | Verde | 0% | 0% |  |
| 1862 | 2.3.21.6.3.1 | Elaborar projeto executivo |  | 125d | 2019-07-10 | 2020-01-08 | 1860 | 2019-07-10 | 2020-01-08 | 125d | 706d | 0d | Verde | Verde | 0% | 0% | Verde | 0% | 0% | Verde |
| 1863 | 2.3.21.6.3.2 | Projeto executivo apresentado ao banco | milestone | 0d | 2020-01-08 | 2020-01-08 | 1862 | 2020-01-08 | 2020-01-08 | 0d | 706d | 0d | Verde | Verde | 0% | 0% | Verde | 0% | 0% | Verde |
| 1864 | 2.3.21.6.3.3 | Analisar projeto executivo |  | 23d | 2020-01-09 | 2020-02-10 | 1863 | 2020-01-09 | 2020-02-10 | 23d | 706d | 0d | Verde | Verde | 0% | 0% | Verde | 0% | 0% | Verde |
| 1865 | 2.3.21.6.3.4 | Adequar/revisar projeto executivo |  | 19d | 2020-02-11 | 2020-03-11 | 1864 | 2020-02-11 | 2020-03-11 | 19d | 706d | 0d | Verde | Verde | 0% | 0% | Verde | 0% | 0% | Verde |
| 1866 | 2.3.21.6.3.5 | Analisar projeto executivo - final |  | 22d | 2020-03-12 | 2020-04-13 | 1865 | 2020-03-12 | 2020-04-13 | 22d | 706d | 0d | Verde | Verde | 0% | 0% | Verde | 0% | 0% | Verde |
| 1867 | 2.3.21.6.3.6 | Projeto executivo concluído | milestone | 0d | 2020-04-13 | 2020-04-13 | 1866 | 2020-04-13 | 2020-04-13 | 0d | 706d | 0d | Verde | Verde | 0% | 0% | Verde | 0% | 0% | Verde |
| 1868 | 2.3.21.6.3.7 | Recurso do projeto executivo do pleito MRNESPJ06 repassado | milestone | 0d | 2020-04-20 | 2020-04-20 | 1867FS+5d | 2020-04-20 | 2020-04-20 | 0d | 1206d | 0d | Verde | Verde | 0% | 0% | Verde | 0% | 0% | Verde |
| 1869 | 2.3.21.6.4 | Pleito MRNESPJ06 comcluído | milestone | 0d | 2020-04-20 | 2020-04-20 | 1868 | 2020-04-20 | 2020-04-20 | 0d | 1206d | 504d | Verde | Verde | 0% | 0% | Verde | 0% | 0% | Verde |
| 1870 | 2.3.21.7 | **Pleito MRNESOB04 - Execução de obras de implantação do SES para a cidade de Mariana** |  | 505d | 2020-04-13 | 2022-04-25 |  | 2020-04-13 | 2022-04-25 | 505d | 706d |  | Verde | Verde | 0% | 0% | Verde | 0% | 0% |  |
| 1871 | 2.3.21.7.1 | **Licitação da obra** |  | 102d | 2020-04-13 | 2020-09-08 |  | 2020-04-13 | 2020-09-08 | 102d | 706d |  | Verde | Verde | 0% | 0% | Verde | 0% | 0% |  |
| 1872 | 2.3.21.7.1.1 | Licitação da obra autorizada pelo banco | milestone | 0d | 2020-04-13 | 2020-04-13 | 1867 | 2020-04-13 | 2020-04-13 | 0d | 706d | 0d | Verde | Verde | 0% | 0% | Verde | 0% | 0% | Verde |
| 1873 | 2.3.21.7.1.2 | Licitar Obra |  | 87d | 2020-04-14 | 2020-08-17 | 1872 | 2020-04-14 | 2020-08-17 | 87d | 706d | 0d | Verde | Verde | 0% | 0% | Verde | 0% | 0% | Verde |
| 1874 | 2.3.21.7.1.3 | Analisar e emitir resultado da licitação da obra |  | 15d | 2020-08-18 | 2020-09-08 | 1873 | 2020-08-18 | 2020-09-08 | 15d | 706d | 0d | Verde | Verde | 0% | 0% | Verde | 0% | 0% | Verde |
| 1875 | 2.3.21.7.1.4 | Licitação da obra concluída | milestone | 0d | 2020-09-08 | 2020-09-08 | 1874 | 2020-09-08 | 2020-09-08 | 0d | 706d | 0d | Verde | Verde | 0% | 0% | Verde | 0% | 0% | Verde |
| 1876 | 2.3.21.7.2 | Executar obra |  | 250d | 2020-10-07 | 2021-10-07 | 1875FS+20d | 2020-10-07 | 2021-10-07 | 250d | 706d | 0d | Verde | Verde | 0% | 0% | Verde | 0% | 0% | Verde |
| 1877 | 2.3.21.7.3 | Realizar processo de pré-operação |  | 128d | 2021-10-08 | 2022-04-14 | 1876 | 2021-10-08 | 2022-04-14 | 128d | 706d | 0d | Verde | Verde | 0% | 0% | Verde | 0% | 0% | Verde |
| 1878 | 2.3.21.7.4 | Recurso da obra parcelado repassado | milestone | 0d | 2022-04-25 | 2022-04-25 | 1877FS+5d | 2022-04-25 | 2022-04-25 | 0d | 706d | 0d | Verde | Verde | 0% | 0% | Verde | 0% | 0% | Verde |
| 1879 | 2.3.21.7.5 | Pleito MRNESOB04 concluído | milestone | 0d | 2022-04-25 | 2022-04-25 | 1878 | 2022-04-25 | 2022-04-25 | 0d | 706d | 4d | Verde | Verde | 0% | 0% | Verde | 0% | 0% | Verde |
| 1880 | 2.3.21.8 | **Pleito MRNESCT01 - Indenização pela desapropriação da área local onde será implantada a ETE no distrito Sede de Mariana** |  | 143d | 2020-02-11 | 2020-09-08 |  | 2020-02-11 | 2020-09-08 | 143d | 1109d |  | Verde | Verde | 0% | 0% | Verde | 0% | 0% |  |
| 1881 | 2.3.21.8.1 | **Aquisição de Terreno** |  | 143d | 2020-02-11 | 2020-09-08 |  | 2020-02-11 | 2020-09-08 | 143d | 1109d |  | Verde | Verde | 0% | 0% | Verde | 0% | 0% |  |
| 1882 | 2.3.21.8.1.1 | Regularizar terreno e apresentar escritura ao banco |  | 82d | 2020-02-11 | 2020-06-12 | 1864 | 2020-02-11 | 2020-06-12 | 82d | 1109d | 0d | Verde | Verde | 0% | 0% | Verde | 0% | 0% | Verde |
| 1883 | 2.3.21.8.1.2 | Analisar documentação do terreno |  | 10d | 2020-06-15 | 2020-06-26 | 1882 | 2020-06-15 | 2020-06-26 | 10d | 1155d | 0d | Verde | Verde | 0% | 0% | Verde | 0% | 0% | Verde |
| 1884 | 2.3.21.8.1.3 | 50% do valor do imóvel repassado (1) | milestone | 0d | 2020-07-03 | 2020-07-03 | 1883FS+5d | 2020-07-03 | 2020-07-03 | 0d | 1155d | 46d | Verde | Verde | 0% | 0% | Verde | 0% | 0% | Verde |
| 1885 | 2.3.21.8.1.4 | Registrar imóvel e apresentar documentação ao banco |  | 46d | 2020-06-15 | 2020-08-17 | 1882 | 2020-06-15 | 2020-08-17 | 46d | 1109d | 0d | Verde | Verde | 0% | 0% | Verde | 0% | 0% | Verde |
| 1886 | 2.3.21.8.1.5 | Analisar documentação do terreno |  | 10d | 2020-08-18 | 2020-08-31 | 1885 | 2020-08-18 | 2020-08-31 | 10d | 1109d | 0d | Verde | Verde | 0% | 0% | Verde | 0% | 0% | Verde |
| 1887 | 2.3.21.8.1.6 | 50% do valor do imóvel repassado (2) | milestone | 0d | 2020-09-08 | 2020-09-08 | 1886FS+5d | 2020-09-08 | 2020-09-08 | 0d | 1109d | 0d | Verde | Verde | 0% | 0% | Verde | 0% | 0% | Verde |
| 1888 | 2.3.21.8.1.7 | Aquisição de Terreno concluída | milestone | 0d | 2020-09-08 | 2020-09-08 | 1887, 1884 | 2020-09-08 | 2020-09-08 | 0d | 1109d | 0d | Verde | Verde | 0% | 0% | Verde | 0% | 0% | Verde |
| 1889 | 2.3.21.8.2 | Pleito MRNESCT01 concluído | milestone | 0d | 2020-09-08 | 2020-09-08 | 1888 | 2020-09-08 | 2020-09-08 | 0d | 1109d | 407d | Verde | Verde | 0% | 0% | Verde | 0% | 0% | Verde |

Notes:
- 1876: Em 24/04/2019: valor da obra R$ 3 milhões

| ID | WBS | Task | Type | Duration | Start | Finish | Predecessors | Baseline start | Baseline finish | Baseline duration | Baseline 1 start | Baseline 1 finish | Total slack | Free slack | Farol de Atraso | Farol Marcos | % Previsto Tempo | Índice de Desempenho Físico (IDF) | Farol IDF | % Previsto Ponderado | % Concluído Ponderado | Farol de Início | Responsável | Código do Contrato |
| --- | --- | --- | --- | --- | --- | --- | --- | --- | --- | --- | --- | --- | --- | --- | --- | --- | --- | --- | --- | --- | --- | --- | --- | --- |
| 1890 | 2.3.21.9 | **Pleito MRNESCT02 - Indenização pela desapropriação de área, local onde será implantada a EEE do Ribeirão do Carmo para o SES do distrito Sede de Mariana** |  | 143d | 2020-02-11 | 2020-09-08 |  | 2020-02-11 | 2020-09-08 | 143d |  |  | 1109d |  | Verde | Verde | 0% | 0% | Verde | 0% | 0% |  |  |  |
| 1891 | 2.3.21.9.1 | **Aquisição de Terreno** |  | 143d | 2020-02-11 | 2020-09-08 |  | 2020-02-11 | 2020-09-08 | 143d |  |  | 1109d |  | Verde | Verde | 0% | 0% | Verde | 0% | 0% |  |  |  |
| 1892 | 2.3.21.9.1.1 | Regularizar terreno e apresentar escritura ao banco |  | 82d | 2020-02-11 | 2020-06-12 | 1864 | 2020-02-11 | 2020-06-12 | 82d |  |  | 1109d | 0d | Verde | Verde | 0% | 0% | Verde | 0% | 0% | Verde |  |  |
| 1893 | 2.3.21.9.1.2 | Analisar documentação do terreno |  | 10d | 2020-06-15 | 2020-06-26 | 1892 | 2020-06-15 | 2020-06-26 | 10d |  |  | 1155d | 0d | Verde | Verde | 0% | 0% | Verde | 0% | 0% | Verde |  |  |
| 1894 | 2.3.21.9.1.3 | 50% do valor do imóvel repassado (1) | milestone | 0d | 2020-07-03 | 2020-07-03 | 1893FS+5d | 2020-07-03 | 2020-07-03 | 0d |  |  | 1155d | 46d | Verde | Verde | 0% | 0% | Verde | 0% | 0% | Verde |  |  |
| 1895 | 2.3.21.9.1.4 | Registrar imóvel e apresentar documentação ao banco |  | 46d | 2020-06-15 | 2020-08-17 | 1892 | 2020-06-15 | 2020-08-17 | 46d |  |  | 1109d | 0d | Verde | Verde | 0% | 0% | Verde | 0% | 0% | Verde |  |  |
| 1896 | 2.3.21.9.1.5 | Analisar documentação do terreno |  | 10d | 2020-08-18 | 2020-08-31 | 1895 | 2020-08-18 | 2020-08-31 | 10d |  |  | 1109d | 0d | Verde | Verde | 0% | 0% | Verde | 0% | 0% | Verde |  |  |
| 1897 | 2.3.21.9.1.6 | 50% do valor do imóvel repassado (2) | milestone | 0d | 2020-09-08 | 2020-09-08 | 1896FS+5d | 2020-09-08 | 2020-09-08 | 0d |  |  | 1109d | 0d | Verde | Verde | 0% | 0% | Verde | 0% | 0% | Verde |  |  |
| 1898 | 2.3.21.9.1.7 | Aquisição de Terreno concluída | milestone | 0d | 2020-09-08 | 2020-09-08 | 1897, 1894 | 2020-09-08 | 2020-09-08 | 0d |  |  | 1109d | 0d | Verde | Verde | 0% | 0% | Verde | 0% | 0% | Verde |  |  |
| 1899 | 2.3.21.9.2 | Pleito MRNESCT02 concluído | milestone | 0d | 2020-09-08 | 2020-09-08 | 1898 | 2020-09-08 | 2020-09-08 | 0d |  |  | 1109d | 407d | Verde | Verde | 0% | 0% | Verde | 0% | 0% | Verde |  |  |
| 1900 | 2.3.21.10 | **Pleito MRNESCT03 - Indenização pela desapropriação de área onde será implantada EEE do Córrego Santana** |  | 143d | 2020-02-11 | 2020-09-08 |  | 2020-02-11 | 2020-09-08 | 143d |  |  | 1109d |  | Verde | Verde | 0% | 0% | Verde | 0% | 0% |  |  |  |
| 1901 | 2.3.21.10.1 | **Aquisição de Terreno** |  | 143d | 2020-02-11 | 2020-09-08 |  | 2020-02-11 | 2020-09-08 | 143d |  |  | 1109d |  | Verde | Verde | 0% | 0% | Verde | 0% | 0% |  |  |  |
| 1902 | 2.3.21.10.1.1 | Regularizar terreno e apresentar escritura ao banco |  | 82d | 2020-02-11 | 2020-06-12 | 1864 | 2020-02-11 | 2020-06-12 | 82d |  |  | 1109d | 0d | Verde | Verde | 0% | 0% | Verde | 0% | 0% | Verde |  |  |
| 1903 | 2.3.21.10.1.2 | Analisar documentação do terreno |  | 10d | 2020-06-15 | 2020-06-26 | 1902 | 2020-06-15 | 2020-06-26 | 10d |  |  | 1155d | 0d | Verde | Verde | 0% | 0% | Verde | 0% | 0% | Verde |  |  |
| 1904 | 2.3.21.10.1.3 | 50% do valor do imóvel repassado (1) | milestone | 0d | 2020-07-03 | 2020-07-03 | 1903FS+5d | 2020-07-03 | 2020-07-03 | 0d |  |  | 1155d | 46d | Verde | Verde | 0% | 0% | Verde | 0% | 0% | Verde |  |  |
| 1905 | 2.3.21.10.1.4 | Registrar imóvel e apresentar documentação ao banco |  | 46d | 2020-06-15 | 2020-08-17 | 1902 | 2020-06-15 | 2020-08-17 | 46d |  |  | 1109d | 0d | Verde | Verde | 0% | 0% | Verde | 0% | 0% | Verde |  |  |
| 1906 | 2.3.21.10.1.5 | Analisar documentação do terreno |  | 10d | 2020-08-18 | 2020-08-31 | 1905 | 2020-08-18 | 2020-08-31 | 10d |  |  | 1109d | 0d | Verde | Verde | 0% | 0% | Verde | 0% | 0% | Verde |  |  |
| 1907 | 2.3.21.10.1.6 | 50% do valor do imóvel repassado (2) | milestone | 0d | 2020-09-08 | 2020-09-08 | 1906FS+5d | 2020-09-08 | 2020-09-08 | 0d |  |  | 1109d | 0d | Verde | Verde | 0% | 0% | Verde | 0% | 0% | Verde |  |  |
| 1908 | 2.3.21.10.1.7 | Aquisição de Terreno concluída | milestone | 0d | 2020-09-08 | 2020-09-08 | 1907, 1904 | 2020-09-08 | 2020-09-08 | 0d |  |  | 1109d | 0d | Verde | Verde | 0% | 0% | Verde | 0% | 0% | Verde |  |  |
| 1909 | 2.3.21.10.2 | Pleito MRNESCT03 concluído | milestone | 0d | 2020-09-08 | 2020-09-08 | 1908 | 2020-09-08 | 2020-09-08 | 0d |  |  | 1109d | 407d | Verde | Verde | 0% | 0% | Verde | 0% | 0% | Verde |  |  |
| 1910 | 2.3.21.11 | **Pleito Mariana de Resíduos Sólidos a definir** |  | 1096d | 2019-08-30 | 2024-01-29 |  | 2019-08-30 | 2024-01-29 | 1096d |  |  | 268d |  | Verde | Verde | 0% | 0% | Verde | 0% | 0% |  |  |  |
| 1911 | 2.3.21.11.1 | Pleito aprovado | milestone | 0d | 2019-08-30 | 2019-08-30 | 393 | 2019-08-30 | 2019-08-30 | 0d |  |  | 268d | 0d | Verde | Verde | 0% | 0% | Verde | 0% | 0% | Verde |  |  |
| 1912 | 2.3.21.11.2 | Iniciar pleito |  | 1d | 2019-08-30 | 2019-08-30 | 1911 | 2019-08-30 | 2019-08-30 | 1d |  |  | 268d | 0d | Verde | Verde | 0% | 0% | Verde | 0% | 0% | Verde |  |  |
| 1913 | 2.3.21.11.3 | Pleito concluído | milestone | 0d | 2024-01-29 | 2024-01-29 | 1912FS+1095d | 2024-01-29 | 2024-01-29 | 0d |  |  | 268d | 0d | Verde | Verde | 0% | 0% | Verde | 0% | 0% | Verde |  |  |
| 1914 | 2.3.21.12 | Recursos de Mariana repassados | milestone | 0d | 2024-01-29 | 2024-01-29 | 1804, 1821, 1832, 1842, 1852, 1869, 1889, 1899, 1909, 1913 | 2024-01-29 | 2024-01-29 | 0d | 2019-07-09 | 2022-03-25 | 268d |  | Verde | Verde | 0% | 0% | Verde | 0% | 0% | Verde | 02 - Execução | PG 031 |

Notes:
- 1914: Valor de recurso destinado ao munícipio: R$71.296.644,86

| ID | WBS | Task | Type | Duration | Start | Finish | Predecessors | Complete | Remaining | Baseline start | Baseline finish | Baseline duration | Baseline 1 start | Baseline 1 finish | Total slack | Free slack | Farol de Atraso | Farol Marcos | % Previsto Tempo | Índice de Desempenho Físico (IDF) | IDF Numérico | Farol IDF | % Previsto Ponderado | % Concluído Ponderado | % Previsto Tempo Numérico | % Concluída Numérico | % Previsto Ponderado Numérico | Farol de Início | Responsável | Código do Contrato |
| --- | --- | --- | --- | --- | --- | --- | --- | --- | --- | --- | --- | --- | --- | --- | --- | --- | --- | --- | --- | --- | --- | --- | --- | --- | --- | --- | --- | --- | --- | --- |
| 1915 | 2.3.22 | **Marilândia** |  | 786d | 2019-02-26 A | 2022-04-29 |  | 2% | 768.37d | 2019-02-26 | 2022-04-29 | 786d | 2018-11-06 | 2021-09-28 | 702d |  | Verde | Verde | 5% | 100% | 100 | Verde | 1% | 1% |  |  |  |  |  |  |
| 1916 | 2.3.22.1 | **Pleito MRLESPJ07 - Adequação e elaboração de projetos dos sistemas de esgotamento sanitário das localidadesde São Marcos, Monte Sinai, Patrão Mor, Brejal, Alto Liberdade e da Sede Municipal** |  | 265d | 2019-02-26 A | 2020-03-25 |  |  | 265d | 2019-02-26 | 2020-03-25 | 265d |  |  | 1223d |  | Verde | Verde | 15% | 0% |  | Vermelho | 0% | 0% | 15 |  |  |  |  |  |
| 1917 | 2.3.22.1.1 | Pleito aprovado | milestone | 0d | 2019-02-26 A | 2019-02-26 A | 206FS+53d | 100% |  | 2019-02-26 | 2019-02-26 | 0d |  |  |  |  | Verde | Verde | 100% | 0% |  | Vermelho | 100% | 0% | 100 | 100 | 100 | Verde |  |  |
| 1918 | 2.3.22.1.2 | **Licitação do Projeto** |  | 55d | 2019-06-03 | 2019-08-21 |  |  |  | 2019-06-03 | 2019-08-21 | 55d |  |  | 702d |  | Verde | Verde | 0% | 0% |  | Verde | 0% | 0% |  |  |  |  |  |  |
| 1919 | 2.3.22.1.2.1 | Licitação do projeto autorizada pelo banco | milestone | 0d | 2019-06-03 | 2019-06-03 | 1917FS+63d |  |  | 2019-06-03 | 2019-06-03 | 0d |  |  | 702d | 0d | Verde | Verde | 0% | 0% |  | Verde | 0% | 0% |  |  |  | Verde |  |  |
| 1920 | 2.3.22.1.2.2 | Licitar projeto |  | 42d | 2019-06-04 | 2019-08-01 | 1919 |  |  | 2019-06-04 | 2019-08-01 | 42d | 2018-11-06 | 2019-02-04 | 702d | 0d | Verde | Verde | 0% | 0% |  | Verde | 0% | 0% |  |  |  | Verde | 02 - Execução | PG031 |
| 1921 | 2.3.22.1.2.3 | Documentação de licitação apresentada ao banco | milestone | 0d | 2019-08-13 | 2019-08-13 | 1920FS+8d |  |  | 2019-08-13 | 2019-08-13 | 0d |  |  | 702d | 0d | Verde | Verde | 0% | 0% |  | Verde | 0% | 0% |  |  |  | Verde |  |  |
| 1922 | 2.3.22.1.2.4 | Analisar e emitir resultado da licitação do projeto |  | 5d | 2019-08-14 | 2019-08-21 | 1921 |  |  | 2019-08-14 | 2019-08-21 | 5d |  |  | 702d | 0d | Verde | Verde | 0% | 0% |  | Verde | 0% | 0% |  |  |  | Verde |  |  |
| 1923 | 2.3.22.1.2.5 | Licitação concluída | milestone | 0d | 2019-08-21 | 2019-08-21 | 1922 |  |  | 2019-08-21 | 2019-08-21 | 0d |  |  | 702d | 0d | Verde | Verde | 0% | 0% |  | Verde | 0% | 0% |  |  |  | Verde |  |  |
| 1924 | 2.3.22.1.3 | **Elaboração do Projeto** |  | 147d | 2019-08-22 | 2020-03-25 |  |  |  | 2019-08-22 | 2020-03-25 | 147d |  |  | 702d |  | Verde | Verde | 0% | 0% |  | Verde | 0% | 0% |  |  |  |  |  |  |
| 1925 | 2.3.22.1.3.1 | Elaborar Projeto |  | 75d | 2019-08-22 | 2019-12-05 | 1923 |  |  | 2019-08-22 | 2019-12-05 | 75d | 2019-02-04 | 2019-05-05 | 702d | 0d | Verde | Verde | 0% | 0% |  | Verde | 0% | 0% |  |  |  | Verde | 02 - Execução | PG031 |
| 1926 | 2.3.22.1.3.2 | Projeto apresentado ao banco | milestone | 0d | 2019-12-05 | 2019-12-05 | 1925 |  |  | 2019-12-05 | 2019-12-05 | 0d |  |  | 702d | 0d | Verde | Verde | 0% | 0% |  | Verde | 0% | 0% |  |  |  | Verde |  |  |
| 1927 | 2.3.22.1.3.3 | Analisar projeto |  | 19d | 2019-12-06 | 2020-01-07 | 1926 |  |  | 2019-12-06 | 2020-01-07 | 19d |  |  | 702d | 0d | Verde | Verde | 0% | 0% |  | Verde | 0% | 0% |  |  |  | Verde |  |  |
| 1928 | 2.3.22.1.3.4 | Adequar/revisar projeto |  | 24d | 2020-01-08 | 2020-02-10 | 1927 |  |  | 2020-01-08 | 2020-02-10 | 24d |  |  | 702d | 0d | Verde | Verde | 0% | 0% |  | Verde | 0% | 0% |  |  |  | Verde |  |  |
| 1929 | 2.3.22.1.3.5 | Analisar projeto - final |  | 19d | 2020-02-11 | 2020-03-11 | 1928 |  |  | 2020-02-11 | 2020-03-11 | 19d |  |  | 702d | 0d | Verde | Verde | 0% | 0% |  | Verde | 0% | 0% |  |  |  | Verde |  |  |
| 1930 | 2.3.22.1.3.6 | Projeto concluído | milestone | 0d | 2020-03-18 | 2020-03-18 | 1929, 1932, 1933 |  |  | 2020-03-18 | 2020-03-18 | 0d |  |  | 1223d | 0d | Verde | Verde | 0% | 0% |  | Verde | 0% | 0% |  |  |  | Verde |  |  |
| 1931 | 2.3.22.1.3.7 | Recurso do projeto do pleito MRLESPJ07 repassado | milestone | 0d | 2020-03-25 | 2020-03-25 | 1930FS+5d |  |  | 2020-03-25 | 2020-03-25 | 0d |  |  | 1223d | 0d | Verde | Verde | 0% | 0% |  | Verde | 0% | 0% |  |  |  | Verde |  |  |
| 1932 | 2.3.22.1.4 | Realizar Licenciamento Ambiental |  | 79d | 2019-11-20 | 2020-03-18 | 1925SS+63d |  |  | 2019-11-20 | 2020-03-18 | 79d | 2019-05-05 | 2019-11-01 | 1223d | 0d | Verde | Verde | 0% | 0% |  | Verde | 0% | 0% |  |  |  | Verde | 02 - Execução | PG031 |
| 1933 | 2.3.22.1.5 | Aquisição de Terreno |  | 79d | 2019-11-20 | 2020-03-18 | 1925SS+63d |  |  | 2019-11-20 | 2020-03-18 | 79d |  |  | 1223d | 0d | Verde | Verde | 0% | 0% |  | Verde | 0% | 0% |  |  |  | Verde |  |  |
| 1934 | 2.3.22.1.6 | Pleito MRLESPJ07 concluído | milestone | 0d | 2020-03-25 | 2020-03-25 | 1931 |  |  | 2020-03-25 | 2020-03-25 | 0d |  |  | 1223d | 0d | Verde | Verde | 0% | 0% |  | Verde | 0% | 0% |  |  |  | Verde |  |  |
| 1935 | 2.3.22.2 | **Pleito de Marilândia a definir - Obra da Sede** |  | 528d | 2020-03-16 | 2022-04-29 |  |  |  | 2020-03-16 | 2022-04-29 | 528d |  |  | 702d |  | Verde | Verde | 0% | 0% |  | Verde | 0% | 0% |  |  |  |  |  |  |
| 1936 | 2.3.22.2.1 | Pleito aprovado | milestone | 0d | 2020-03-16 | 2020-03-16 | 1929FS+3d |  |  | 2020-03-16 | 2020-03-16 | 0d |  |  | 702d | 0d | Verde | Verde | 0% | 0% |  | Verde | 0% | 0% |  |  |  | Verde |  |  |
| 1937 | 2.3.22.2.2 | **Licitação da Obra** |  | 55d | 2020-03-24 | 2020-06-15 |  |  |  | 2020-03-24 | 2020-06-15 | 55d |  |  | 702d |  | Verde | Verde | 0% | 0% |  | Verde | 0% | 0% |  |  |  |  |  |  |
| 1938 | 2.3.22.2.2.1 | Licitação da obra autorizada pelo banco | milestone | 0d | 2020-03-24 | 2020-03-24 | 1936FS+6d |  |  | 2020-03-24 | 2020-03-24 | 0d |  |  | 702d | 0d | Verde | Verde | 0% | 0% |  | Verde | 0% | 0% |  |  |  | Verde |  |  |
| 1939 | 2.3.22.2.2.2 | Licitar Obra |  | 41d | 2020-03-25 | 2020-05-25 | 1938 |  |  | 2020-03-25 | 2020-05-25 | 41d |  |  | 702d | 0d | Verde | Verde | 0% | 0% |  | Verde | 0% | 0% |  |  |  | Verde |  |  |
| 1940 | 2.3.22.2.2.3 | Analisar e emitir resultado da licitação da obra |  | 14d | 2020-05-26 | 2020-06-15 | 1939 |  |  | 2020-05-26 | 2020-06-15 | 14d |  |  | 702d | 0d | Verde | Verde | 0% | 0% |  | Verde | 0% | 0% |  |  |  | Verde |  |  |
| 1941 | 2.3.22.2.2.4 | Licitação da obra concluída | milestone | 0d | 2020-06-15 | 2020-06-15 | 1940 |  |  | 2020-06-15 | 2020-06-15 | 0d |  |  | 702d | 0d | Verde | Verde | 0% | 0% |  | Verde | 0% | 0% |  |  |  | Verde |  |  |
| 1942 | 2.3.22.2.3 | Executar obra |  | 314d | 2020-07-14 | 2021-10-14 | 1941FS+20d |  |  | 2020-07-14 | 2021-10-14 | 314d |  |  | 702d | 0d | Verde | Verde | 0% | 0% |  | Verde | 0% | 0% |  |  |  | Verde |  |  |
| 1943 | 2.3.22.2.4 | Realizar processo de pré-operação |  | 128d | 2021-10-15 | 2022-04-22 | 1942 |  |  | 2021-10-15 | 2022-04-22 | 128d |  |  | 702d | 0d | Verde | Verde | 0% | 0% |  | Verde | 0% | 0% |  |  |  | Verde |  |  |
| 1944 | 2.3.22.2.5 | Recurso da obra parcelado repassado | milestone | 0d | 2022-04-29 | 2022-04-29 | 1943FS+5d |  |  | 2022-04-29 | 2022-04-29 | 0d |  |  | 702d | 0d | Verde | Verde | 0% | 0% |  | Verde | 0% | 0% |  |  |  | Verde |  |  |
| 1945 | 2.3.22.2.6 | Pleito a definir concluído | milestone | 0d | 2022-04-29 | 2022-04-29 | 1944 |  |  | 2022-04-29 | 2022-04-29 | 0d |  |  | 702d | 0d | Verde | Verde | 0% | 0% |  | Verde | 0% | 0% |  |  |  | Verde |  |  |

Notes:
- 1915: Marilândia fez o pleito de apenas R$270.000,00 (correspondente a apenas 4,3% do valor total para SES destinado ao munícipio), para execução de projetos e foi aprovado conforme Deliberação 75. Somente após o projeto, será feito o pleito para as obras. / O pleito de resíduos sólido (10% do total do recurso destinado ao munícipio) foi aprovado. / O munícipio informou que vai solicitar alteração de pleito ao CIF de R$270.000,00 para R$400.000,00
- 1920: 18/12/2018 - Minuta do edital de licitação foi finalizada, faltando definir o orçamento da pré-operação.
- 1942: Em 24/04/2019: valor da obra igual a 90% do teto menos pleito de projeto

| ID | WBS | Task | Type | Duration | Start | Finish | Predecessors | Complete | Remaining | Baseline start | Baseline finish | Baseline duration | Baseline 1 start | Baseline 1 finish | Total slack | Free slack | Constraint | Farol de Atraso | Farol Marcos | % Previsto Tempo | Índice de Desempenho Físico (IDF) | IDF Numérico | Farol IDF | % Previsto Ponderado | % Previsto Ponderado Numérico | % Concluído Ponderado | % Concluída Numérico | % Previsto Tempo Numérico | % Concluído Ponderado Numérico | Farol de Início | Responsável | Código do Contrato |
| --- | --- | --- | --- | --- | --- | --- | --- | --- | --- | --- | --- | --- | --- | --- | --- | --- | --- | --- | --- | --- | --- | --- | --- | --- | --- | --- | --- | --- | --- | --- | --- | --- |
| 1946 | 2.3.22.3 | **Pleito MRLRSOB01 - O município de Marilândia é membro do Consórcio Público para tratamento e destinação final adequada de resíduos sólidos da região doce oeste do Estado do Espírito Santo – CONDOESTE, e fez opção por alocar o montante de R$ 630.265,74 par** |  | 625d | 2019-03-14 A | 2021-09-15 |  | 5% | 590.99d | 2019-03-14 | 2021-09-15 | 625d |  |  | 855d |  |  | Verde | Verde | 5% | 90% | 90 | Vermelho | 10% | 10 | 9% |  |  |  |  |  |  |
| 1947 | 2.3.22.3.1 | **Licitação da obra** |  | 52d | 2019-03-14 A | 2019-05-29 |  | 70% | 15.83d | 2019-03-14 | 2019-05-29 | 52d |  |  | 855d |  |  | Verde | Verde | 61% | 90% | 90 | Vermelho | 67% | 67 | 60% | 70 | 61 | 60 |  |  |  |
| 1948 | 2.3.22.3.1.1 | Licitação da obra autorizada pelo banco | milestone | 0d | 2019-03-14 A | 2019-03-14 A | 358 | 100% |  | 2019-03-14 | 2019-03-14 | 0d |  |  |  |  |  | Verde | Verde | 100% | 0% |  | Vermelho | 100% | 100 | 0% | 100 | 100 |  | Verde |  |  |
| 1949 | 2.3.22.3.1.2 | Licitar obra |  | 38d | 2019-03-14 A | 2019-05-09 | 1948 | 84% | 6d | 2019-03-14 | 2019-05-09 | 38d |  |  | 855d | 0d |  | Verde | Verde | 84% | 89% | 89 | Vermelho | 84% | 84 | 75% | 84 | 84 | 75 | Verde |  |  |
| 1950 | 2.3.22.3.1.3 | Analisar e emitir resultado da licitação da obra |  | 8d | 2019-05-20 | 2019-05-29 | 1949FS+6d |  |  | 2019-05-20 | 2019-05-29 | 8d |  |  | 855d | 0d |  | Verde | Verde | 0% | 0% |  | Verde | 0% |  | 0% |  |  |  | Verde |  |  |
| 1951 | 2.3.22.3.1.4 | Licitação da obra concluída | milestone | 0d | 2019-05-29 | 2019-05-29 | 1950 |  |  | 2019-05-29 | 2019-05-29 | 0d |  |  | 855d | 0d |  | Verde | Verde | 0% | 0% |  | Verde | 0% |  | 0% |  |  |  | Verde |  |  |
| 1952 | 2.3.22.3.2 | Executar obra |  | 414d | 2019-07-08 | 2021-03-08 | 1951FS+26d |  |  | 2019-07-08 | 2021-03-08 | 414d |  |  | 855d | 0d |  | Verde | Verde | 0% | 0% |  | Verde | 0% |  | 0% |  |  |  | Verde |  |  |
| 1953 | 2.3.22.3.3 | Realizar processo de pré-operação |  | 128d | 2021-03-09 | 2021-09-08 | 1952 |  |  | 2021-03-09 | 2021-09-08 | 128d |  |  | 855d | 0d |  | Verde | Verde | 0% | 0% |  | Verde | 0% |  | 0% |  |  |  | Verde |  |  |
| 1954 | 2.3.22.3.4 | Recurso da obra parcelado repassado | milestone | 0d | 2021-09-15 | 2021-09-15 | 1953FS+5d |  |  | 2021-09-15 | 2021-09-15 | 0d |  |  | 855d | 0d |  | Verde | Verde | 0% | 0% |  | Verde | 0% |  | 0% |  |  |  | Verde |  |  |
| 1955 | 2.3.22.3.5 | Pleito MRLRSOB01 concluído | milestone | 0d | 2021-09-15 | 2021-09-15 | 1954 |  |  | 2021-09-15 | 2021-09-15 | 0d |  |  | 855d | 153d |  | Verde | Verde | 0% | 0% |  | Verde | 0% |  | 0% |  |  |  | Verde |  |  |
| 1956 | 2.3.22.4 | Recursos de Marilândia repassados | milestone | 0d | 2022-04-29 | 2022-04-29 | 1934, 1955, 1945 |  |  | 2022-04-29 | 2022-04-29 | 0d | 2019-06-04 | 2021-09-28 | 702d |  |  | Verde | Verde | 0% | 0% |  | Verde | 0% |  | 0% |  |  |  | Verde | 02 - Execução | PG 031 |
| 1957 | 2.3.23 | **Marliéria** |  | 697d | 2019-02-21 A | 2021-12-13 |  | 8% | 639.61d | 2019-02-21 | 2021-12-13 | 697d | 2019-02-02 | 2021-08-27 | 795d |  |  | Verde | Verde | 6% | 0% |  | Vermelho | 0% |  | 0% |  |  |  |  |  |  |
| 1958 | 2.3.23.1 | **Pleito MREESPJ01 - Elaboração de projeto do sistema de esgotamento sanitário do distrito de Cava Grande** |  | 252d | 2019-02-21 A | 2020-03-02 |  | 22% | 196.22d | 2019-02-21 | 2020-03-02 | 252d |  |  | 1240d |  |  | Verde | Verde | 17% | 41% | 41 | Vermelho | 17% | 17 | 7% | 22 | 17 |  |  |  |  |
| 1959 | 2.3.23.1.1 | **Licitação do Projeto** |  | 48d | 2019-02-21 A | 2019-05-07 |  | 91% | 4.47d | 2019-02-21 | 2019-05-07 | 48d |  |  | 795d |  |  | Verde | Verde | 91% | 58% | 58 | Vermelho | 86% | 86 | 50% | 91 | 91 | 50 |  |  |  |
| 1960 | 2.3.23.1.1.1 | Licitar projeto |  | 29d | 2019-02-21 A | 2019-04-05 A |  | 100% |  | 2019-02-21 | 2019-04-05 | 29d | 2019-02-02 | 2019-05-03 |  |  | must start on 2019-02-21 | Verde | Verde | 100% | 100% | 100 | Verde | 100% | 100 | 100% | 100 | 100 | 100 | Verde |  |  |
| 1961 | 2.3.23.1.1.2 | Documentação de licitação apresentada ao banco | milestone | 0d | 2019-04-12 A | 2019-04-12 A | 1960FS+5d | 100% |  | 2019-04-12 | 2019-04-12 | 0d |  |  |  |  |  | Verde | Verde | 100% | 0% |  | Vermelho | 100% | 100 | 0% | 100 | 100 |  | Verde |  |  |
| 1962 | 2.3.23.1.1.3 | Analisar e emitir resultado da licitação do projeto |  | 14d | 2019-04-15 A | 2019-05-07 | 1961 | 71% | 4d | 2019-04-15 | 2019-05-07 | 14d |  |  | 795d | 0d |  | Verde | Verde | 71% | 0% |  | Vermelho | 71% | 71 | 0% | 71 | 71 |  | Verde |  |  |
| 1963 | 2.3.23.1.1.4 | Licitação do projeto concluída | milestone | 0d | 2019-05-07 | 2019-05-07 | 1962 |  |  | 2019-05-07 | 2019-05-07 | 0d |  |  | 795d | 0d |  | Verde | Verde | 0% | 0% |  | Verde | 0% |  | 0% |  |  |  | Verde |  |  |
| 1964 | 2.3.23.1.2 | **Elaboração do Projeto Básico** |  | 134d | 2019-05-08 | 2019-11-13 |  |  |  | 2019-05-08 | 2019-11-13 | 134d |  |  | 795d |  |  | Verde | Verde | 0% | 0% |  | Verde | 0% |  | 0% |  |  |  |  |  |  |
| 1965 | 2.3.23.1.2.1 | Elaborar Projeto Básico |  | 64d | 2019-05-08 | 2019-08-06 | 1963 |  |  | 2019-05-08 | 2019-08-06 | 64d | 2019-05-03 | 2019-07-02 | 795d | 0d |  | Verde | Verde | 0% | 0% |  | Verde | 0% |  | 0% |  |  |  | Verde | 02 - Execução | PG 031 |
| 1966 | 2.3.23.1.2.2 | Projeto básico apresentado ao banco | milestone | 0d | 2019-08-06 | 2019-08-06 | 1965 |  |  | 2019-08-06 | 2019-08-06 | 0d |  |  | 795d | 0d |  | Verde | Verde | 0% | 0% |  | Verde | 0% |  | 0% |  |  |  | Verde |  |  |
| 1967 | 2.3.23.1.2.3 | Analisar projeto básico |  | 23d | 2019-08-07 | 2019-09-09 | 1966 |  |  | 2019-08-07 | 2019-09-09 | 23d |  |  | 860d | 0d |  | Verde | Verde | 0% | 0% |  | Verde | 0% |  | 0% |  |  |  | Verde |  |  |
| 1968 | 2.3.23.1.2.4 | Adequar/revisar projeto básico |  | 20d | 2019-09-10 | 2019-10-07 | 1967 |  |  | 2019-09-10 | 2019-10-07 | 20d |  |  | 860d | 0d |  | Verde | Verde | 0% | 0% |  | Verde | 0% |  | 0% |  |  |  | Verde |  |  |
| 1969 | 2.3.23.1.2.5 | Analisar projeto básico - final |  | 22d | 2019-10-08 | 2019-11-06 | 1968 |  |  | 2019-10-08 | 2019-11-06 | 22d |  |  | 860d | 0d |  | Verde | Verde | 0% | 0% |  | Verde | 0% |  | 0% |  |  |  | Verde |  |  |
| 1970 | 2.3.23.1.2.6 | Projeto básico concluído | milestone | 0d | 2019-11-06 | 2019-11-06 | 1969 |  |  | 2019-11-06 | 2019-11-06 | 0d |  |  | 860d | 0d |  | Verde | Verde | 0% | 0% |  | Verde | 0% |  | 0% |  |  |  | Verde |  |  |
| 1971 | 2.3.23.1.2.7 | Recurso do projeto básico do pleito MREESPJ01 repassado | milestone | 0d | 2019-11-13 | 2019-11-13 | 1970FS+5d |  |  | 2019-11-13 | 2019-11-13 | 0d |  |  | 860d | 65d |  | Verde | Verde | 0% | 0% |  | Verde | 0% |  | 0% |  |  |  | Verde |  |  |
| 1972 | 2.3.23.1.3 | Realizar Licenciamento Ambiental |  | 68d | 2019-02-21 A | 2019-06-04 | 1960SS | 65% | 24d | 2019-02-21 | 2019-06-04 | 68d | 2019-07-02 | 2019-12-29 | 974d | 179d |  | Verde | Verde | 64% | 0% |  | Vermelho | 64% | 64 | 0% | 65 | 64 |  | Verde | 02 - Execução | PG 031 |

Notes:
- 1949: Em 29/04/2019: atualizado como agendado
- 1956: Valor de recurso destinado ao munícipio: R$6.302.657,43
- 1957: Marliéria teve 100% dos pleitos de Esgotamento Sanitário aprovado (R$4.254.293,76), conforme Deliberação 75. / O município teve 0,53%, dos 10% do valor teto destinado a Resíduos Sólidos aprovado (R$24.889,97).
- 1960: Em 24/09/2019: considerada a data da reunião junto aos municípios de estabelecimento de cronograma como data de início
- 1962: Em 29/04/2019: atualizado como agendado
- 1972: Em 29/04/2019: atualizado como agendado

| ID | WBS | Task | Type | Duration | Start | Finish | Predecessors | Baseline start | Baseline finish | Baseline duration | Baseline 1 start | Baseline 1 finish | Total slack | Free slack | Farol de Atraso | Farol Marcos | % Previsto Tempo | Índice de Desempenho Físico (IDF) | Farol IDF | % Previsto Ponderado | % Concluído Ponderado | Responsável | Código do Contrato | Farol de Início |
| --- | --- | --- | --- | --- | --- | --- | --- | --- | --- | --- | --- | --- | --- | --- | --- | --- | --- | --- | --- | --- | --- | --- | --- | --- |
| 1973 | 2.3.23.1.4 | **Elaboração do Projeto Executivo** |  | 140d | 2019-08-07 | 2020-03-02 |  | 2019-08-07 | 2020-03-02 | 140d |  |  | 795d |  | Verde | Verde | 0% | 0% | Verde | 0% | 0% |  |  |  |
| 1974 | 2.3.23.1.4.1 | Elaborar Projeto Executivo |  | 66d | 2019-08-07 | 2019-11-07 | 1966 | 2019-08-07 | 2019-11-07 | 66d | 2019-07-02 | 2019-10-30 | 795d | 0d | Verde | Verde | 0% | 0% | Verde | 0% | 0% | 02 - Execução | PG 031 | Verde |
| 1975 | 2.3.23.1.4.2 | Projeto executivo apresentado ao banco | milestone | 0d | 2019-11-07 | 2019-11-07 | 1974 | 2019-11-07 | 2019-11-07 | 0d |  |  | 795d | 0d | Verde | Verde | 0% | 0% | Verde | 0% | 0% |  |  | Verde |
| 1976 | 2.3.23.1.4.3 | Analisar projeto executivo |  | 23d | 2019-11-08 | 2019-12-11 | 1975 | 2019-11-08 | 2019-12-11 | 23d |  |  | 795d | 0d | Verde | Verde | 0% | 0% | Verde | 0% | 0% |  |  | Verde |
| 1977 | 2.3.23.1.4.4 | Adequar/revisar projeto executivo |  | 23d | 2019-12-13 | 2020-01-17 | 1976 | 2019-12-13 | 2020-01-17 | 23d |  |  | 795d | 0d | Verde | Verde | 0% | 0% | Verde | 0% | 0% |  |  | Verde |
| 1978 | 2.3.23.1.4.5 | Analisar projeto executivo - final |  | 23d | 2020-01-20 | 2020-02-19 | 1977 | 2020-01-20 | 2020-02-19 | 23d |  |  | 795d | 0d | Verde | Verde | 0% | 0% | Verde | 0% | 0% |  |  | Verde |
| 1979 | 2.3.23.1.4.6 | Projeto executivo concluído | milestone | 0d | 2020-02-19 | 2020-02-19 | 1978, 1971, 1972 | 2020-02-19 | 2020-02-19 | 0d |  |  | 795d | 0d | Verde | Verde | 0% | 0% | Verde | 0% | 0% |  |  | Verde |
| 1980 | 2.3.23.1.4.7 | Recurso do projeto executivo do pleito MREESPJ01 repassado | milestone | 0d | 2020-03-02 | 2020-03-02 | 1979FS+5d | 2020-03-02 | 2020-03-02 | 0d |  |  | 1240d | 0d | Verde | Verde | 0% | 0% | Verde | 0% | 0% |  |  | Verde |
| 1981 | 2.3.23.1.5 | Pleito MREESPJ01 concluído | milestone | 0d | 2020-03-02 | 2020-03-02 | 1980 | 2020-03-02 | 2020-03-02 | 0d |  |  | 1240d | 445d | Verde | Verde | 0% | 0% | Verde | 0% | 0% |  |  | Verde |
| 1982 | 2.3.23.2 | **Pleito MREESOB01 - Implantação do sistema de esgotamento sanitário do distrito de Cava Grande** |  | 450d | 2020-02-19 | 2021-12-13 |  | 2020-02-19 | 2021-12-13 | 450d |  |  | 795d |  | Verde | Verde | 0% | 0% | Verde | 0% | 0% |  |  |  |
| 1983 | 2.3.23.2.1 | **Licitação da Obra** |  | 41d | 2020-02-19 | 2020-04-23 |  | 2020-02-19 | 2020-04-23 | 41d |  |  | 795d |  | Verde | Verde | 0% | 0% | Verde | 0% | 0% |  |  |  |
| 1984 | 2.3.23.2.1.1 | Licitação da obra autorizada pelo banco | milestone | 0d | 2020-02-19 | 2020-02-19 | 1979 | 2020-02-19 | 2020-02-19 | 0d |  |  | 795d | 0d | Verde | Verde | 0% | 0% | Verde | 0% | 0% |  |  | Verde |
| 1985 | 2.3.23.2.1.2 | Licitar Obra |  | 26d | 2020-02-20 | 2020-03-31 | 1984 | 2020-02-20 | 2020-03-31 | 26d | 2019-10-30 | 2020-02-27 | 795d | 0d | Verde | Verde | 0% | 0% | Verde | 0% | 0% | 02 - Execução | PG 031 | Verde |
| 1986 | 2.3.23.2.1.3 | Analisar e emitir resultado da licitação da obra |  | 15d | 2020-04-01 | 2020-04-23 | 1985 | 2020-04-01 | 2020-04-23 | 15d |  |  | 795d | 0d | Verde | Verde | 0% | 0% | Verde | 0% | 0% |  |  | Verde |
| 1987 | 2.3.23.2.1.4 | Licitação da obra concluída | milestone | 0d | 2020-04-23 | 2020-04-23 | 1986 | 2020-04-23 | 2020-04-23 | 0d |  |  | 795d | 0d | Verde | Verde | 0% | 0% | Verde | 0% | 0% |  |  | Verde |
| 1988 | 2.3.23.2.2 | Executar obra |  | 257d | 2020-05-22 | 2021-06-02 | 1987FS+19d | 2020-05-22 | 2021-06-02 | 257d |  |  | 795d | 0d | Verde | Verde | 0% | 0% | Verde | 0% | 0% |  |  | Verde |
| 1989 | 2.3.23.2.3 | Realizar processo de pré-operação |  | 128d | 2021-06-04 | 2021-12-06 | 1988 | 2021-06-04 | 2021-12-06 | 128d | 2021-02-28 | 2021-08-27 | 795d | 0d | Verde | Verde | 0% | 0% | Verde | 0% | 0% | 02 - Execução | PG 031 | Verde |
| 1990 | 2.3.23.2.4 | Recurso da obra parcelado repassado | milestone | 0d | 2021-12-13 | 2021-12-13 | 1989FS+5d | 2021-12-13 | 2021-12-13 | 0d |  |  | 795d | 0d | Verde | Verde | 0% | 0% | Verde | 0% | 0% |  |  | Verde |
| 1991 | 2.3.23.2.5 | Pleito MREESOB01 concluído | milestone | 0d | 2021-12-13 | 2021-12-13 | 1990 | 2021-12-13 | 2021-12-13 | 0d |  |  | 795d | 0d | Verde | Verde | 0% | 0% | Verde | 0% | 0% |  |  | Verde |
| 1992 | 2.3.23.3 | **Pleito MRERSPM01 - Estudos de viabilidade p/ implantação de aterro sanitário regional.** |  | 217d | 2019-05-03 | 2020-03-17 |  | 2019-05-03 | 2020-03-17 | 217d |  |  | 1229d |  | Verde | Verde | 0% | 0% | Verde | 0% | 0% |  |  |  |
| 1993 | 2.3.23.3.1 | **Licitação de Empresa para Estudo de Viabilidade** |  | 63d | 2019-05-03 | 2019-08-01 |  | 2019-05-03 | 2019-08-01 | 63d |  |  | 1229d |  | Verde | Verde | 0% | 0% | Verde | 0% | 0% |  |  |  |
| 1994 | 2.3.23.3.1.1 | Licitação da empresa para Estudo de Viabilidade autorizada pelo banco | milestone | 0d | 2019-05-03 | 2019-05-03 | 1133 | 2019-05-03 | 2019-05-03 | 0d |  |  | 1229d | 0d | Verde | Verde | 0% | 0% | Verde | 0% | 0% |  |  | Verde |
| 1995 | 2.3.23.3.1.2 | Licitar empresa para Estudo de Viabilidade |  | 44d | 2019-05-06 | 2019-07-05 | 1994 | 2019-05-06 | 2019-07-05 | 44d |  |  | 1229d | 0d | Verde | Verde | 0% | 0% | Verde | 0% | 0% |  |  | Verde |
| 1996 | 2.3.23.3.1.3 | Documentação de licitação apresentada ao banco | milestone | 0d | 2019-07-12 | 2019-07-12 | 1995FS+5d | 2019-07-12 | 2019-07-12 | 0d |  |  | 1229d | 0d | Verde | Verde | 0% | 0% | Verde | 0% | 0% |  |  | Verde |
| 1997 | 2.3.23.3.1.4 | Analisar e emitir resultado da licitação da empresa para Estudo de Viabilidade |  | 14d | 2019-07-15 | 2019-08-01 | 1996 | 2019-07-15 | 2019-08-01 | 14d |  |  | 1229d | 0d | Verde | Verde | 0% | 0% | Verde | 0% | 0% |  |  | Verde |
| 1998 | 2.3.23.3.1.5 | Licitação da empresa para Estudo de Viabilidade concluída | milestone | 0d | 2019-08-01 | 2019-08-01 | 1997 | 2019-08-01 | 2019-08-01 | 0d |  |  | 1229d | 0d | Verde | Verde | 0% | 0% | Verde | 0% | 0% |  |  | Verde |

Notes:
- 1988: Em 24/04/2019: valor da obra R$ 4 milhões

| ID | WBS | Task | Type | Duration | Start | Finish | Predecessors | Complete | Remaining | Baseline start | Baseline finish | Baseline duration | Baseline 1 start | Baseline 1 finish | Total slack | Free slack | Constraint | Farol de Atraso | Farol Marcos | % Previsto Tempo | Índice de Desempenho Físico (IDF) | Farol IDF | % Previsto Ponderado | % Concluído Ponderado | Farol de Início | Responsável | Código do Contrato | % Previsto Tempo Numérico | % Concluída Numérico | % Previsto Ponderado Numérico |
| --- | --- | --- | --- | --- | --- | --- | --- | --- | --- | --- | --- | --- | --- | --- | --- | --- | --- | --- | --- | --- | --- | --- | --- | --- | --- | --- | --- | --- | --- | --- |
| 1999 | 2.3.23.3.2 | **Elaboração do estudo de viabilidade** |  | 149d | 2019-08-02 | 2020-03-10 |  |  |  | 2019-08-02 | 2020-03-10 | 149d |  |  | 1229d |  |  | Verde | Verde | 0% | 0% | Verde | 0% | 0% |  |  |  |  |  |  |
| 2000 | 2.3.23.3.2.1 | Elaborar estudo de viabilidade |  | 88d | 2019-08-02 | 2019-12-05 | 1998 |  |  | 2019-08-02 | 2019-12-05 | 88d |  |  | 1229d | 0d |  | Verde | Verde | 0% | 0% | Verde | 0% | 0% | Verde |  |  |  |  |  |
| 2001 | 2.3.23.3.2.2 | Analisar estudo |  | 20d | 2019-12-06 | 2020-01-08 | 2000 |  |  | 2019-12-06 | 2020-01-08 | 20d |  |  | 1229d | 0d |  | Verde | Verde | 0% | 0% | Verde | 0% | 0% | Verde |  |  |  |  |  |
| 2002 | 2.3.23.3.2.3 | Adequar/revisar estudo |  | 22d | 2020-01-09 | 2020-02-07 | 2001 |  |  | 2020-01-09 | 2020-02-07 | 22d |  |  | 1229d | 0d |  | Verde | Verde | 0% | 0% | Verde | 0% | 0% | Verde |  |  |  |  |  |
| 2003 | 2.3.23.3.2.4 | Analisar estudo - final |  | 19d | 2020-02-10 | 2020-03-10 | 2002 |  |  | 2020-02-10 | 2020-03-10 | 19d |  |  | 1229d | 0d |  | Verde | Verde | 0% | 0% | Verde | 0% | 0% | Verde |  |  |  |  |  |
| 2004 | 2.3.23.3.2.5 | Estudo concluído | milestone | 0d | 2020-03-10 | 2020-03-10 | 2003 |  |  | 2020-03-10 | 2020-03-10 | 0d |  |  | 1229d | 0d |  | Verde | Verde | 0% | 0% | Verde | 0% | 0% | Verde |  |  |  |  |  |
| 2005 | 2.3.23.3.3 | Recurso do serviço repassado | milestone | 0d | 2020-03-17 | 2020-03-17 | 2004FS+5d |  |  | 2020-03-17 | 2020-03-17 | 0d |  |  | 1229d | 0d |  | Verde | Verde | 0% | 0% | Verde | 0% | 0% | Verde |  |  |  |  |  |
| 2006 | 2.3.23.3.4 | Pleito MRERSPM01 concluído | milestone | 0d | 2020-03-17 | 2020-03-17 | 2005 |  |  | 2020-03-17 | 2020-03-17 | 0d |  |  | 1229d | 434d |  | Verde | Verde | 0% | 0% | Verde | 0% | 0% | Verde |  |  |  |  |  |
| 2007 | 2.3.23.4 | Recursos de Marliéria repassados | milestone | 0d | 2021-12-13 | 2021-12-13 | 1991, 1981, 2006 |  |  | 2021-12-13 | 2021-12-13 | 0d | 2019-08-01 | 2021-08-20 | 795d |  |  | Verde | Verde | 0% | 0% | Verde | 0% | 0% | Verde | 02 - Execução | PG 031 |  |  |  |
| 2008 | 2.3.24 | **Naque** |  | 1506d | 2019-02-01 A | 2025-02-24 |  | 5% | 1435.04d | 2019-02-01 | 2025-02-24 | 1506d | 2018-09-25 | 2021-04-27 | 0d |  |  | Verde | Verde | 3% | 0% | Vermelho | 0% | 0% |  |  |  |  |  |  |
| 2009 | 2.3.24.1 | **Pleito NAQESPJ01 - Elaboração de projeto de sistema de esgotamento sanitário da sede do município** |  | 347d | 2019-02-01 A | 2020-06-29 |  | 8% | 320.66d | 2019-02-01 | 2020-06-29 | 347d |  |  | 1159d |  |  | Verde | Verde | 16% | 0% | Vermelho | 2% | 0% |  |  |  | 16 |  |  |
| 2010 | 2.3.24.1.1 | Pleito aprovado | milestone | 0d | 2019-05-31 | 2019-05-31 |  |  |  | 2019-05-31 | 2019-05-31 | 0d |  |  | 0d |  | must start on 2019-05-31 | Verde | Verde | 0% | 0% | Verde | 0% | 0% | Verde |  |  |  |  |  |
| 2011 | 2.3.24.1.2 | **Licitação do Projeto** |  | 63d | 2019-06-13 | 2019-09-12 |  |  |  | 2019-06-13 | 2019-09-12 | 63d |  |  | 675d |  |  | Verde | Verde | 0% | 0% | Verde | 0% | 0% |  |  |  |  |  |  |
| 2012 | 2.3.24.1.2.1 | Licitação do projeto autorizada pelo banco | milestone | 0d | 2019-06-13 | 2019-06-13 | 2010FS+10d |  |  | 2019-06-13 | 2019-06-13 | 0d |  |  | 675d | 0d |  | Verde | Verde | 0% | 0% | Verde | 0% | 0% | Verde |  |  |  |  |  |
| 2013 | 2.3.24.1.2.2 | Licitar projeto |  | 43d | 2019-06-14 | 2019-08-14 | 2012 |  |  | 2019-06-14 | 2019-08-14 | 43d |  |  | 675d | 0d |  | Verde | Verde | 0% | 0% | Verde | 0% | 0% | Verde |  |  |  |  |  |
| 2014 | 2.3.24.1.2.3 | Documentação de licitação apresentada ao banco | milestone | 0d | 2019-08-22 | 2019-08-22 | 2013FS+5d |  |  | 2019-08-22 | 2019-08-22 | 0d |  |  | 675d | 0d |  | Verde | Verde | 0% | 0% | Verde | 0% | 0% | Verde |  |  |  |  |  |
| 2015 | 2.3.24.1.2.4 | Analisar e emitir resultado da licitação do projeto |  | 15d | 2019-08-23 | 2019-09-12 | 2014 |  |  | 2019-08-23 | 2019-09-12 | 15d |  |  | 675d | 0d |  | Verde | Verde | 0% | 0% | Verde | 0% | 0% | Verde |  |  |  |  |  |
| 2016 | 2.3.24.1.2.5 | Licitação do projeto concluída | milestone | 0d | 2019-09-12 | 2019-09-12 | 2015 |  |  | 2019-09-12 | 2019-09-12 | 0d |  |  | 675d | 0d |  | Verde | Verde | 0% | 0% | Verde | 0% | 0% | Verde |  |  |  |  |  |
| 2017 | 2.3.24.1.3 | **Elaboração do Projeto Básico** |  | 134d | 2019-09-13 | 2020-03-30 |  |  |  | 2019-09-13 | 2020-03-30 | 134d |  |  | 675d |  |  | Verde | Verde | 0% | 0% | Verde | 0% | 0% |  |  |  |  |  |  |
| 2018 | 2.3.24.1.3.1 | Elaborar Projeto Básico |  | 64d | 2019-09-13 | 2019-12-13 | 2016 |  |  | 2019-09-13 | 2019-12-13 | 64d |  |  | 675d | 0d |  | Verde | Verde | 0% | 0% | Verde | 0% | 0% | Verde |  |  |  |  |  |
| 2019 | 2.3.24.1.3.2 | Projeto básico apresentado ao banco | milestone | 0d | 2019-12-13 | 2019-12-13 | 2018 |  |  | 2019-12-13 | 2019-12-13 | 0d |  |  | 675d | 0d |  | Verde | Verde | 0% | 0% | Verde | 0% | 0% | Verde |  |  |  |  |  |
| 2020 | 2.3.24.1.3.3 | Analisar projeto básico |  | 21d | 2019-12-16 | 2020-01-16 | 2019 |  |  | 2019-12-16 | 2020-01-16 | 21d |  |  | 731d | 0d |  | Verde | Verde | 0% | 0% | Verde | 0% | 0% | Verde |  |  |  |  |  |
| 2021 | 2.3.24.1.3.4 | Adequar/revisar projeto básico |  | 23d | 2020-01-17 | 2020-02-18 | 2020 |  |  | 2020-01-17 | 2020-02-18 | 23d |  |  | 731d | 0d |  | Verde | Verde | 0% | 0% | Verde | 0% | 0% | Verde |  |  |  |  |  |
| 2022 | 2.3.24.1.3.5 | Analisar projeto básico - final |  | 21d | 2020-02-19 | 2020-03-23 | 2021 |  |  | 2020-02-19 | 2020-03-23 | 21d |  |  | 731d | 0d |  | Verde | Verde | 0% | 0% | Verde | 0% | 0% | Verde |  |  |  |  |  |
| 2023 | 2.3.24.1.3.6 | Projeto básico concluído | milestone | 0d | 2020-03-23 | 2020-03-23 | 2022 |  |  | 2020-03-23 | 2020-03-23 | 0d |  |  | 731d | 0d |  | Verde | Verde | 0% | 0% | Verde | 0% | 0% | Verde |  |  |  |  |  |
| 2024 | 2.3.24.1.3.7 | Recurso do projeto básico do pleito NAQESPJ01 repassado | milestone | 0d | 2020-03-30 | 2020-03-30 | 2023FS+5d |  |  | 2020-03-30 | 2020-03-30 | 0d |  |  | 731d | 56d |  | Verde | Verde | 0% | 0% | Verde | 0% | 0% | Verde |  |  |  |  |  |
| 2025 | 2.3.24.1.4 | Adquirir imóvel |  | 129d | 2019-11-13 | 2020-05-26 | 2018SS+43d |  |  | 2019-11-13 | 2020-05-26 | 129d |  |  | 693d | 18d |  | Verde | Verde | 0% | 0% | Verde | 0% | 0% | Verde |  |  |  |  |  |
| 2026 | 2.3.24.1.5 | Realizar Licenciamento Ambiental |  | 322d | 2019-02-01 A | 2020-05-22 | 190FS+157d | 18% | 264d | 2019-02-01 | 2020-05-22 | 322d |  |  | 695d | 20d |  | Verde | Verde | 18% | 0% | Vermelho | 18% | 0% | Verde |  |  | 18 | 18 | 18 |

Notes:
- 2007: Valor de recurso destinado ao munícipio: R$4.726.993,07
- 2008: Naque teve 100% dos pleitos de Esgotamento Sanitário aprovado (R$4.254.293,76), conforme Deliberação 75. / O município teve o pleito de resíduos sólidos negado (R$472.699,31, equivalente a 10% do total do recurso,). / Naque está pensando em desistir da ata de registro de preço, caso isto aconteça o cronograma vai mudar.
- 2010: 22/01/19 - Município não iniciou o projeto básico devido a indefinição sobre a adesão a ATA de Registro de Preço ou Licitaçao Própria. O município irá solicitar alteração de pleito devido a duplicidade de pleitos para elaboração de projeto, solicitação de PMSB e definição das obras. (Tendo como premissa 3 meses para definição e aprovação do pleito do PMSB junto a CT, 2 meses para licitação e aprovação pelo BDMG, 8 meses para elaboração do PMSB. Após aprovação do PMSB (pela Câmara Municipal do município e BDMG) o município poderá definir os demais pleitos. Em virtude da extensão destas etapas e das indefinições envolvidas, a atividade será adiada 1 ano e 1 mês. / Em 24/04/2019: pleito será protocolado e aprovado pela CT/CIF no dia 31/05
- 2026: Em 29/04/2019: atualizado como agendado

| ID | WBS | Task | Type | Duration | Start | Finish | Predecessors | Baseline start | Baseline finish | Baseline duration | Baseline 1 start | Baseline 1 finish | Total slack | Free slack | Constraint | Farol de Atraso | Farol Marcos | % Previsto Tempo | Índice de Desempenho Físico (IDF) | Farol IDF | % Previsto Ponderado | % Concluído Ponderado | Farol de Início | Responsável | Código do Contrato |
| --- | --- | --- | --- | --- | --- | --- | --- | --- | --- | --- | --- | --- | --- | --- | --- | --- | --- | --- | --- | --- | --- | --- | --- | --- | --- |
| 2027 | 2.3.24.1.6 | **Elaboração do Projeto Executivo** |  | 131d | 2019-12-16 | 2020-06-29 |  | 2019-12-16 | 2020-06-29 | 131d |  |  | 675d |  |  | Verde | Verde | 0% | 0% | Verde | 0% | 0% |  |  |  |
| 2028 | 2.3.24.1.6.1 | Elaborar Projeto Executivo |  | 60d | 2019-12-16 | 2020-03-16 | 2019 | 2019-12-16 | 2020-03-16 | 60d |  |  | 675d | 0d |  | Verde | Verde | 0% | 0% | Verde | 0% | 0% | Verde |  |  |
| 2029 | 2.3.24.1.6.2 | Projeto executivo apresentado ao banco | milestone | 0d | 2020-03-16 | 2020-03-16 | 2028 | 2020-03-16 | 2020-03-16 | 0d |  |  | 675d | 0d |  | Verde | Verde | 0% | 0% | Verde | 0% | 0% | Verde |  |  |
| 2030 | 2.3.24.1.6.3 | Analisar projeto executivo |  | 21d | 2020-03-17 | 2020-04-15 | 2029 | 2020-03-17 | 2020-04-15 | 21d |  |  | 675d | 0d |  | Verde | Verde | 0% | 0% | Verde | 0% | 0% | Verde |  |  |
| 2031 | 2.3.24.1.6.4 | Adequar/revisar projeto executivo |  | 23d | 2020-04-16 | 2020-05-20 | 2030 | 2020-04-16 | 2020-05-20 | 23d |  |  | 675d | 0d |  | Verde | Verde | 0% | 0% | Verde | 0% | 0% | Verde |  |  |
| 2032 | 2.3.24.1.6.5 | Analisar projeto executivo - final |  | 22d | 2020-05-21 | 2020-06-22 | 2031 | 2020-05-21 | 2020-06-22 | 22d |  |  | 675d | 0d |  | Verde | Verde | 0% | 0% | Verde | 0% | 0% | Verde |  |  |
| 2033 | 2.3.24.1.6.6 | Projeto executivo concluído | milestone | 0d | 2020-06-22 | 2020-06-22 | 2032, 2024, 2026, 2025 | 2020-06-22 | 2020-06-22 | 0d |  |  | 675d | 0d |  | Verde | Verde | 0% | 0% | Verde | 0% | 0% | Verde |  |  |
| 2034 | 2.3.24.1.6.7 | Recurso do projeto executivo do pleito NAQESPJ01 repassado | milestone | 0d | 2020-06-29 | 2020-06-29 | 2033FS+5d | 2020-06-29 | 2020-06-29 | 0d |  |  | 1159d | 0d |  | Verde | Verde | 0% | 0% | Verde | 0% | 0% | Verde |  |  |
| 2035 | 2.3.24.1.7 | Pleito NAQESPJ01 concluído | milestone | 0d | 2020-06-29 | 2020-06-29 | 2034 | 2020-06-29 | 2020-06-29 | 0d |  |  | 1159d |  |  | Verde | Verde | 0% | 0% | Verde | 0% | 0% | Verde |  |  |
| 2036 | 2.3.24.2 | **Pleito NAQESAO01 - Contratação de assessoria técnica para apoio na obtenção de licença ambiental** |  | 1d | 2019-08-30 | 2019-08-30 |  | 2019-08-30 | 2019-08-30 | 1d |  |  | 1363d |  |  | Verde | Verde | 0% | 0% | Verde | 0% | 0% |  |  |  |
| 2037 | 2.3.24.2.1 | Avaliar pleito |  | 1d | 2019-08-30 | 2019-08-30 |  | 2019-08-30 | 2019-08-30 | 1d |  |  | 1363d | 0d | start no earlier than 2019-08-30 | Verde | Verde | 0% | 0% | Verde | 0% | 0% | Verde |  |  |
| 2038 | 2.3.24.2.2 | Pleito NAQESAO01 concluído | milestone | 0d | 2019-08-30 | 2019-08-30 | 2037 | 2019-08-30 | 2019-08-30 | 0d |  |  | 1363d |  |  | Verde | Verde | 0% | 0% | Verde | 0% | 0% | Verde |  |  |
| 2039 | 2.3.24.3 | **Pleito NAQESOB01 - Complementação de recursos de contrapartida** |  | 1d | 2019-08-30 | 2019-08-30 |  | 2019-08-30 | 2019-08-30 | 1d |  |  | 0d |  |  | Verde | Verde | 0% | 0% | Verde | 0% | 0% |  |  |  |
| 2040 | 2.3.24.3.1 | Avaliar pleito |  | 1d | 2019-08-30 | 2019-08-30 |  | 2019-08-30 | 2019-08-30 | 1d |  |  | 0d |  | must start on 2019-08-30 | Verde | Verde | 0% | 0% | Verde | 0% | 0% | Verde |  |  |
| 2041 | 2.3.24.3.2 | Pleito NAQESOB01 concluído | milestone | 0d | 2019-08-30 | 2019-08-30 | 2040 | 2019-08-30 | 2019-08-30 | 0d |  |  | 1363d |  |  | Verde | Verde | 0% | 0% | Verde | 0% | 0% | Verde |  |  |
| 2042 | 2.3.24.4 | **Pleito NAQESOB02 - Implantação de SES na sede do município e localidades** |  | 489d | 2020-06-22 | 2022-06-07 |  | 2020-06-22 | 2022-06-07 | 489d |  |  | 675d |  |  | Verde | Verde | 0% | 0% | Verde | 0% | 0% |  |  |  |
| 2043 | 2.3.24.4.1 | **Licitação da obra** |  | 79d | 2020-06-22 | 2020-10-13 |  | 2020-06-22 | 2020-10-13 | 79d |  |  | 675d |  |  | Verde | Verde | 0% | 0% | Verde | 0% | 0% |  |  |  |
| 2044 | 2.3.24.4.1.1 | Licitação da obra autorizada pelo banco | milestone | 0d | 2020-06-22 | 2020-06-22 | 2033 | 2020-06-22 | 2020-06-22 | 0d |  |  | 675d | 0d |  | Verde | Verde | 0% | 0% | Verde | 0% | 0% | Verde |  |  |
| 2045 | 2.3.24.4.1.2 | Licitar Obra |  | 63d | 2020-06-23 | 2020-09-18 | 2044 | 2020-06-23 | 2020-09-18 | 63d | 2019-07-02 | 2019-10-30 | 675d | 0d |  | Verde | Verde | 0% | 0% | Verde | 0% | 0% | Verde | 02 - Execução | PG 031 |
| 2046 | 2.3.24.4.1.3 | Analisar e emitir resultado da licitação da obra |  | 16d | 2020-09-21 | 2020-10-13 | 2045 | 2020-09-21 | 2020-10-13 | 16d |  |  | 675d | 0d |  | Verde | Verde | 0% | 0% | Verde | 0% | 0% | Verde |  |  |
| 2047 | 2.3.24.4.1.4 | Licitação da obra concluída | milestone | 0d | 2020-10-13 | 2020-10-13 | 2046 | 2020-10-13 | 2020-10-13 | 0d |  |  | 675d | 0d |  | Verde | Verde | 0% | 0% | Verde | 0% | 0% | Verde |  |  |
| 2048 | 2.3.24.4.2 | Executar obra |  | 257d | 2020-11-12 | 2021-11-24 | 2047FS+20d | 2020-11-12 | 2021-11-24 | 257d |  |  | 675d | 0d |  | Verde | Verde | 0% | 0% | Verde | 0% | 0% | Verde |  |  |
| 2049 | 2.3.24.4.3 | Realizar processo de pré-operação |  | 128d | 2021-11-25 | 2022-05-31 | 2048 | 2021-11-25 | 2022-05-31 | 128d | 2020-10-29 | 2021-04-27 | 675d | 0d |  | Verde | Verde | 0% | 0% | Verde | 0% | 0% | Verde | 02 - Execução | PG 031 |
| 2050 | 2.3.24.4.4 | Recurso da obra parcelado repassado | milestone | 0d | 2022-06-07 | 2022-06-07 | 2049FS+5d | 2022-06-07 | 2022-06-07 | 0d |  |  | 675d | 0d |  | Verde | Verde | 0% | 0% | Verde | 0% | 0% | Verde |  |  |
| 2051 | 2.3.24.4.5 | Pleito NAQESOB02 concluído | milestone | 0d | 2022-06-07 | 2022-06-07 | 2050 | 2022-06-07 | 2022-06-07 | 0d |  |  | 675d |  |  | Verde | Verde | 0% | 0% | Verde | 0% | 0% | Verde |  |  |

Notes:
- 2037: Em 24/04/2019: foi informado por Sara que o município irá cancelar o pleito, pois acreditam não ser necessário devido ao recebimento de apoio técnico e licenciamento ambiental simplificado. O prazo foi estabelecido com base na nota técnica 33.
- 2040: Em 24/04/2019: considerando o cronograma da NT33 e que município enviará ofício de cancelamento de pleito até o final de julho.
- 2048: Em 24/06/2019: valor da obra R$ 4 milhões

| ID | WBS | Task | Type | Duration | Start | Finish | Predecessors | Complete | Remaining | Baseline start | Baseline finish | Baseline duration | Baseline 1 start | Baseline 1 finish | Total slack | Free slack | Farol de Atraso | Farol Marcos | % Previsto Tempo | Índice de Desempenho Físico (IDF) | Farol IDF | % Previsto Ponderado | % Concluído Ponderado | Farol de Início | Responsável | Código do Contrato | % Previsto Tempo Numérico | IDF Numérico | % Concluída Numérico | % Previsto Ponderado Numérico | % Concluído Ponderado Numérico |
| --- | --- | --- | --- | --- | --- | --- | --- | --- | --- | --- | --- | --- | --- | --- | --- | --- | --- | --- | --- | --- | --- | --- | --- | --- | --- | --- | --- | --- | --- | --- | --- |
| 2052 | 2.3.24.5 | **Pleito de Naque de Resíduos Sólidos a definir** |  | 1364d | 2019-08-30 | 2025-02-24 |  |  |  | 2019-08-30 | 2025-02-24 | 1364d |  |  | 0d |  | Verde | Verde | 0% | 0% | Verde | 0% | 0% |  |  |  |  |  |  |  |  |
| 2053 | 2.3.24.5.1 | Pleito aprovado | milestone | 0d | 2019-08-30 | 2019-08-30 | 440 |  |  | 2019-08-30 | 2019-08-30 | 0d |  |  | 0d |  | Verde | Verde | 0% | 0% | Verde | 0% | 0% | Verde |  |  |  |  |  |  |  |
| 2054 | 2.3.24.5.2 | Iniciar pleito |  | 1d | 2019-08-30 | 2019-08-30 | 2053 |  |  | 2019-08-30 | 2019-08-30 | 1d |  |  | 0d |  | Verde | Verde | 0% | 0% | Verde | 0% | 0% | Verde |  |  |  |  |  |  |  |
| 2055 | 2.3.24.5.3 | Pleito concluído | milestone | 0d | 2025-02-24 | 2025-02-24 | 2054FS+1363d |  |  | 2025-02-24 | 2025-02-24 | 0d |  |  | 0d |  | Verde | Verde | 0% | 0% | Verde | 0% | 0% | Verde |  |  |  |  |  |  |  |
| 2056 | 2.3.24.6 | Recursos de Naque repassados | milestone | 0d | 2025-02-24 | 2025-02-24 | 2035, 2038, 2041, 2051, 2055 |  |  | 2025-02-24 | 2025-02-24 | 0d | 2019-04-03 | 2021-04-22 | 0d |  | Verde | Verde | 0% | 0% | Verde | 0% | 0% | Verde | 02 - Execução | PG 031 |  |  |  |  |  |
| 2057 | 2.3.25 | **Periquito** |  | 1492d | 2019-02-21 A | 2025-02-24 |  | 4% | 1431.77d | 2019-02-21 | 2025-02-24 | 1492d | 2018-11-06 | 2021-06-30 | 0d |  | Verde | Verde | 2% | 0% | Vermelho | 0% | 0% |  |  |  |  |  |  |  |  |
| 2058 | 2.3.25.1 | **Pleito PERESPJ01 - Elaboração de projetos de sistema de esgotamento sanitário da sede do município e distritos São Sebastião do Baixio, Pedra** |  | 293d | 2019-02-21 A | 2020-04-30 |  | 9% | 266.09d | 2019-02-21 | 2020-04-30 | 293d |  |  | 1199d |  | Verde | Verde | 15% | 80% | Vermelho | 5% | 4% |  |  |  | 15 | 80 |  |  |  |
| 2059 | 2.3.25.1.1 | **Licitação do Projeto** |  | 94d | 2019-02-21 A | 2019-07-11 |  | 49% | 47.53d | 2019-02-21 | 2019-07-11 | 94d |  |  | 735d |  | Verde | Verde | 46% | 85% | Vermelho | 39% | 33% |  |  |  | 46 | 85 | 49 | 39 | 33 |
| 2060 | 2.3.25.1.1.1 | Licitar projeto |  | 75d | 2019-02-21 A | 2019-06-13 | 191FS+218ed | 59% | 31d | 2019-02-21 | 2019-06-13 | 75d | 2018-11-06 | 2019-02-04 | 735d | 0d | Verde | Verde | 58% | 86% | Vermelho | 58% | 50% | Verde |  |  | 58 | 86 | 59 | 58 | 50 |
| 2061 | 2.3.25.1.1.2 | Documentação de licitação apresentada ao banco | milestone | 0d | 2019-06-21 | 2019-06-21 | 2060FS+5d |  |  | 2019-06-21 | 2019-06-21 | 0d |  |  | 735d | 0d | Verde | Verde | 0% | 0% | Verde | 0% | 0% | Verde |  |  |  |  |  |  |  |
| 2062 | 2.3.25.1.1.3 | Analisar e emitir resultado da licitação do projeto |  | 14d | 2019-06-24 | 2019-07-11 | 2061 |  |  | 2019-06-24 | 2019-07-11 | 14d |  |  | 735d | 0d | Verde | Verde | 0% | 0% | Verde | 0% | 0% | Verde |  |  |  |  |  |  |  |
| 2063 | 2.3.25.1.1.4 | Licitação do projeto concluída | milestone | 0d | 2019-07-11 | 2019-07-11 | 2062 |  |  | 2019-07-11 | 2019-07-11 | 0d |  |  | 735d | 0d | Verde | Verde | 0% | 0% | Verde | 0% | 0% | Verde |  |  |  |  |  |  |  |
| 2064 | 2.3.25.1.2 | **Elaboração do Projeto Básico** |  | 133d | 2019-07-12 | 2020-01-22 |  |  |  | 2019-07-12 | 2020-01-22 | 133d |  |  | 735d |  | Verde | Verde | 0% | 0% | Verde | 0% | 0% |  |  |  |  |  |  |  |  |
| 2065 | 2.3.25.1.2.1 | Elaborar Projeto Básico |  | 63d | 2019-07-12 | 2019-10-09 | 2063 |  |  | 2019-07-12 | 2019-10-09 | 63d | 2019-02-04 | 2019-05-05 | 735d | 0d | Verde | Verde | 0% | 0% | Verde | 0% | 0% | Verde | 02 - Execução | PG 031 |  |  |  |  |  |
| 2066 | 2.3.25.1.2.2 | Projeto básico apresentado ao banco | milestone | 0d | 2019-10-09 | 2019-10-09 | 2065 |  |  | 2019-10-09 | 2019-10-09 | 0d |  |  | 735d | 0d | Verde | Verde | 0% | 0% | Verde | 0% | 0% | Verde |  |  |  |  |  |  |  |
| 2067 | 2.3.25.1.2.3 | Analisar projeto básico |  | 23d | 2019-10-10 | 2019-11-11 | 2066 |  |  | 2019-10-10 | 2019-11-11 | 23d |  |  | 796d | 0d | Verde | Verde | 0% | 0% | Verde | 0% | 0% | Verde |  |  |  |  |  |  |  |
| 2068 | 2.3.25.1.2.4 | Adequar/revisar projeto básico |  | 21d | 2019-11-12 | 2019-12-11 | 2067 |  |  | 2019-11-12 | 2019-12-11 | 21d |  |  | 796d | 0d | Verde | Verde | 0% | 0% | Verde | 0% | 0% | Verde |  |  |  |  |  |  |  |
| 2069 | 2.3.25.1.2.5 | Analisar projeto básico - final |  | 21d | 2019-12-13 | 2020-01-15 | 2068 |  |  | 2019-12-13 | 2020-01-15 | 21d |  |  | 796d | 0d | Verde | Verde | 0% | 0% | Verde | 0% | 0% | Verde |  |  |  |  |  |  |  |
| 2070 | 2.3.25.1.2.6 | Projeto básico concluído | milestone | 0d | 2020-01-15 | 2020-01-15 | 2069 |  |  | 2020-01-15 | 2020-01-15 | 0d |  |  | 796d | 0d | Verde | Verde | 0% | 0% | Verde | 0% | 0% | Verde |  |  |  |  |  |  |  |
| 2071 | 2.3.25.1.2.7 | Recurso do projeto básico do pleito PERESPJ01 repassado | milestone | 0d | 2020-01-22 | 2020-01-22 | 2070FS+5d |  |  | 2020-01-22 | 2020-01-22 | 0d |  |  | 796d | 61d | Verde | Verde | 0% | 0% | Verde | 0% | 0% | Verde |  |  |  |  |  |  |  |
| 2072 | 2.3.25.1.3 | Realizar Licenciamento Ambiental |  | 131d | 2019-10-10 | 2020-04-23 | 2066 |  |  | 2019-10-10 | 2020-04-23 | 131d | 2019-05-05 | 2019-11-01 | 735d | 0d | Verde | Verde | 0% | 0% | Verde | 0% | 0% | Verde | 02 - Execução | PG 031 |  |  |  |  |  |
| 2073 | 2.3.25.1.4 | **Elaboração do Projeto Executivo** |  | 136d | 2019-10-10 | 2020-04-30 |  |  |  | 2019-10-10 | 2020-04-30 | 136d |  |  | 735d |  | Verde | Verde | 0% | 0% | Verde | 0% | 0% |  |  |  |  |  |  |  |  |
| 2074 | 2.3.25.1.4.1 | Elaborar Projeto Executivo |  | 65d | 2019-10-10 | 2020-01-15 | 2066 |  |  | 2019-10-10 | 2020-01-15 | 65d | 2019-05-05 | 2019-09-02 | 735d | 0d | Verde | Verde | 0% | 0% | Verde | 0% | 0% | Verde | 02 - Execução | PG 031 |  |  |  |  |  |
| 2075 | 2.3.25.1.4.2 | Projeto executivo apresentado ao banco | milestone | 0d | 2020-01-15 | 2020-01-15 | 2074 |  |  | 2020-01-15 | 2020-01-15 | 0d |  |  | 735d | 0d | Verde | Verde | 0% | 0% | Verde | 0% | 0% | Verde |  |  |  |  |  |  |  |
| 2076 | 2.3.25.1.4.3 | Analisar projeto executivo |  | 22d | 2020-01-16 | 2020-02-14 | 2075 |  |  | 2020-01-16 | 2020-02-14 | 22d |  |  | 735d | 0d | Verde | Verde | 0% | 0% | Verde | 0% | 0% | Verde |  |  |  |  |  |  |  |
| 2077 | 2.3.25.1.4.4 | Adequar/revisar projeto executivo |  | 22d | 2020-02-17 | 2020-03-20 | 2076 |  |  | 2020-02-17 | 2020-03-20 | 22d |  |  | 735d | 0d | Verde | Verde | 0% | 0% | Verde | 0% | 0% | Verde |  |  |  |  |  |  |  |
| 2078 | 2.3.25.1.4.5 | Analisar projeto executivo - final |  | 22d | 2020-03-23 | 2020-04-23 | 2077 |  |  | 2020-03-23 | 2020-04-23 | 22d |  |  | 735d | 0d | Verde | Verde | 0% | 0% | Verde | 0% | 0% | Verde |  |  |  |  |  |  |  |
| 2079 | 2.3.25.1.4.6 | Projeto executivo concluído | milestone | 0d | 2020-04-23 | 2020-04-23 | 2078, 2071, 2072, 2091 |  |  | 2020-04-23 | 2020-04-23 | 0d |  |  | 735d | 0d | Verde | Verde | 0% | 0% | Verde | 0% | 0% | Verde |  |  |  |  |  |  |  |
| 2080 | 2.3.25.1.4.7 | Recurso do projeto executivo do pleito PERESPJ01 repassado | milestone | 0d | 2020-04-30 | 2020-04-30 | 2079FS+5d |  |  | 2020-04-30 | 2020-04-30 | 0d |  |  | 1199d | 0d | Verde | Verde | 0% | 0% | Verde | 0% | 0% | Verde |  |  |  |  |  |  |  |
| 2081 | 2.3.25.1.5 | Pleito PERESPJ01 concluído | milestone | 0d | 2020-04-30 | 2020-04-30 | 2080 |  |  | 2020-04-30 | 2020-04-30 | 0d |  |  | 1199d |  | Verde | Verde | 0% | 0% | Verde | 0% | 0% | Verde |  |  |  |  |  |  |  |

Notes:
- 2056: Valor de recurso destinado ao munícipio: R$4.726.993,07
- 2057: Periquito teve 100% dos pleitos de Esgotamento Sanitário aprovado (R$4.254.234,37), conforme Deliberação 75. / O município teve o pleito de resíduos sólidos negado (R$472.699,31, equivalente a 10% do total do recurso,). / Retificado pelo município que está em fase de fechamento da planilha orçamentária do TR.
- 2060: Havia sido informado que o munícipio estava em fase de licitação de projeto (informação passada na planilha para a CT), no entanto em reunião com Apoio Técnico em 04/12 esta informação foi retificada pelo município e informado que está em fase de fechamento da planilha orçamentária do TR. / 22/01/19 - Status continua. / Em 29/04/2019: no dia 15/03 banco cobrou a apresentação do processo licitatório conforme check list enviado. Prazo foi dilatado para finalizar a licitação (validado Sara V.)

| ID | WBS | Task | Type | Duration | Start | Finish | Predecessors | Baseline start | Baseline finish | Baseline duration | Baseline 1 start | Baseline 1 finish | Total slack | Free slack | Constraint | Farol de Atraso | Farol Marcos | % Previsto Tempo | Índice de Desempenho Físico (IDF) | Farol IDF | % Previsto Ponderado | % Concluído Ponderado | Farol de Início | Responsável | Código do Contrato |
| --- | --- | --- | --- | --- | --- | --- | --- | --- | --- | --- | --- | --- | --- | --- | --- | --- | --- | --- | --- | --- | --- | --- | --- | --- | --- |
| 2082 | 2.3.25.2 | **Pleito a definir - Aquisição de imóvel** |  | 151d | 2019-08-30 | 2020-04-08 |  | 2019-08-30 | 2020-04-08 | 151d |  |  | 0d |  |  | Verde | Verde | 0% | 0% | Verde | 0% | 0% |  |  |  |
| 2083 | 2.3.25.2.1 | Pleito aprovado | milestone | 0d | 2019-08-30 | 2019-08-30 |  | 2019-08-30 | 2019-08-30 | 0d |  |  | 0d |  | must start on 2019-08-30 | Verde | Verde | 0% | 0% | Verde | 0% | 0% | Verde |  |  |
| 2084 | 2.3.25.2.2 | **Aquisição de Imóvel** |  | 141d | 2019-09-13 | 2020-04-08 |  | 2019-09-13 | 2020-04-08 | 141d |  |  | 744d |  |  | Verde | Verde | 0% | 0% | Verde | 0% | 0% |  |  |  |
| 2085 | 2.3.25.2.2.1 | Regularizar terreno e apresentar escritura ao banco |  | 82d | 2019-09-13 | 2020-01-13 | 2083FS+10d | 2019-09-13 | 2020-01-13 | 82d |  |  | 744d | 0d |  | Verde | Verde | 0% | 0% | Verde | 0% | 0% | Verde |  |  |
| 2086 | 2.3.25.2.2.2 | Analisar documentação do terreno |  | 10d | 2020-01-14 | 2020-01-27 | 2085 | 2020-01-14 | 2020-01-27 | 10d |  |  | 788d | 0d |  | Verde | Verde | 0% | 0% | Verde | 0% | 0% | Verde |  |  |
| 2087 | 2.3.25.2.2.3 | 50% do valor do imóvel repassado (1) | milestone | 0d | 2020-02-03 | 2020-02-03 | 2086FS+5d | 2020-02-03 | 2020-02-03 | 0d |  |  | 788d | 44d |  | Verde | Verde | 0% | 0% | Verde | 0% | 0% | Verde |  |  |
| 2088 | 2.3.25.2.2.4 | Registrar imóvel e apresentar documentação ao banco |  | 44d | 2020-01-14 | 2020-03-18 | 2085 | 2020-01-14 | 2020-03-18 | 44d |  |  | 744d | 0d |  | Verde | Verde | 0% | 0% | Verde | 0% | 0% | Verde |  |  |
| 2089 | 2.3.25.2.2.5 | Analisar documentação do terreno |  | 10d | 2020-03-19 | 2020-04-01 | 2088 | 2020-03-19 | 2020-04-01 | 10d |  |  | 744d | 0d |  | Verde | Verde | 0% | 0% | Verde | 0% | 0% | Verde |  |  |
| 2090 | 2.3.25.2.2.6 | 50% do valor do imóvel repassado (2) | milestone | 0d | 2020-04-08 | 2020-04-08 | 2089FS+5d | 2020-04-08 | 2020-04-08 | 0d |  |  | 744d | 0d |  | Verde | Verde | 0% | 0% | Verde | 0% | 0% | Verde |  |  |
| 2091 | 2.3.25.2.2.7 | Aquisição do imóvel concluída | milestone | 0d | 2020-04-08 | 2020-04-08 | 2087, 2090 | 2020-04-08 | 2020-04-08 | 0d |  |  | 744d | 0d |  | Verde | Verde | 0% | 0% | Verde | 0% | 0% | Verde |  |  |
| 2092 | 2.3.25.2.3 | Pleito a definir concluído | milestone | 0d | 2020-04-08 | 2020-04-08 | 2091 | 2020-04-08 | 2020-04-08 | 0d |  |  | 1213d |  |  | Verde | Verde | 0% | 0% | Verde | 0% | 0% | Verde |  |  |
| 2093 | 2.3.25.3 | **Pleito PERESOB01 - Implantação de sistema de esgotamento sanitário da sede do município e distritos São Sebastião do Baixio, Pedra Corrida e Serraria.** |  | 469d | 2020-04-23 | 2022-03-11 |  | 2020-04-23 | 2022-03-11 | 469d |  |  | 735d |  |  | Verde | Verde | 0% | 0% | Verde | 0% | 0% |  |  |  |
| 2094 | 2.3.25.3.1 | **Licitação da obra** |  | 79d | 2020-04-23 | 2020-08-14 |  | 2020-04-23 | 2020-08-14 | 79d |  |  | 735d |  |  | Verde | Verde | 0% | 0% | Verde | 0% | 0% |  |  |  |
| 2095 | 2.3.25.3.1.1 | Licitação da obra autorizada pelo banco | milestone | 0d | 2020-04-23 | 2020-04-23 | 2079 | 2020-04-23 | 2020-04-23 | 0d |  |  | 735d | 0d |  | Verde | Verde | 0% | 0% | Verde | 0% | 0% | Verde |  |  |
| 2096 | 2.3.25.3.1.2 | Licitar Obra |  | 63d | 2020-04-24 | 2020-07-23 | 2095 | 2020-04-24 | 2020-07-23 | 63d | 2019-09-02 | 2019-12-31 | 735d | 0d |  | Verde | Verde | 0% | 0% | Verde | 0% | 0% | Verde | 02 - Execução | PG 031 |
| 2097 | 2.3.25.3.1.3 | Analisar e emitir resultado da licitação da obra |  | 16d | 2020-07-24 | 2020-08-14 | 2096 | 2020-07-24 | 2020-08-14 | 16d |  |  | 735d | 0d |  | Verde | Verde | 0% | 0% | Verde | 0% | 0% | Verde |  |  |
| 2098 | 2.3.25.3.1.4 | Licitação da obra concluída | milestone | 0d | 2020-08-14 | 2020-08-14 | 2097 | 2020-08-14 | 2020-08-14 | 0d |  |  | 735d | 0d |  | Verde | Verde | 0% | 0% | Verde | 0% | 0% | Verde |  |  |
| 2099 | 2.3.25.3.2 | Executar obra |  | 257d | 2020-08-17 | 2021-08-26 | 2098 | 2020-08-17 | 2021-08-26 | 257d |  |  | 735d | 0d |  | Verde | Verde | 0% | 0% | Verde | 0% | 0% | Verde |  |  |
| 2100 | 2.3.25.3.3 | Realizar processo de pré-operação |  | 128d | 2021-08-27 | 2022-03-04 | 2099 | 2021-08-27 | 2022-03-04 | 128d | 2021-01-01 | 2021-06-30 | 735d | 0d |  | Verde | Verde | 0% | 0% | Verde | 0% | 0% | Verde | 02 - Execução | PG 031 |
| 2101 | 2.3.25.3.4 | Recurso da obra parcelado repassado | milestone | 0d | 2022-03-11 | 2022-03-11 | 2100FS+5d | 2022-03-11 | 2022-03-11 | 0d |  |  | 735d | 0d |  | Verde | Verde | 0% | 0% | Verde | 0% | 0% | Verde |  |  |
| 2102 | 2.3.25.3.5 | Pleito PERESOB01 concluído | milestone | 0d | 2022-03-11 | 2022-03-11 | 2101 | 2022-03-11 | 2022-03-11 | 0d |  |  | 735d |  |  | Verde | Verde | 0% | 0% | Verde | 0% | 0% | Verde |  |  |
| 2103 | 2.3.25.4 | **Pleito de Periquito Resíduos Sólidos a definir** |  | 1364d | 2019-08-30 | 2025-02-24 |  | 2019-08-30 | 2025-02-24 | 1364d |  |  | 0d |  |  | Verde | Verde | 0% | 0% | Verde | 0% | 0% |  |  |  |
| 2104 | 2.3.25.4.1 | Pleito aprovado | milestone | 0d | 2019-08-30 | 2019-08-30 | 440 | 2019-08-30 | 2019-08-30 | 0d |  |  | 0d |  |  | Verde | Verde | 0% | 0% | Verde | 0% | 0% | Verde |  |  |
| 2105 | 2.3.25.4.2 | Iniciar pleito |  | 1d | 2019-08-30 | 2019-08-30 | 2104 | 2019-08-30 | 2019-08-30 | 1d |  |  | 0d |  |  | Verde | Verde | 0% | 0% | Verde | 0% | 0% | Verde |  |  |
| 2106 | 2.3.25.4.3 | Pleito concluído | milestone | 0d | 2025-02-24 | 2025-02-24 | 2105FS+1363d | 2025-02-24 | 2025-02-24 | 0d |  |  | 0d |  |  | Verde | Verde | 0% | 0% | Verde | 0% | 0% | Verde |  |  |
| 2107 | 2.3.25.5 | Recursos de Periquito repassados | milestone | 0d | 2025-02-24 | 2025-02-24 | 2081, 2092, 2102, 2106 | 2025-02-24 | 2025-02-24 | 0d | 2019-06-04 | 2021-06-23 | 0d |  |  | Verde | Verde | 0% | 0% | Verde | 0% | 0% | Verde | 02 - Execução | PG 031 |

Notes:
- 2083: Em 24/09/2019: município deve apresentar pleito até 30 de julho para atender cronograma da NT 33 e não atrasar o término do projeto executivo e obra.
- 2099: Em 24/04/2019: valor da obra R$ 3,9 milhões
- 2107: Valor de recurso destinado ao munícipio: R$4.726.993,07

| ID | WBS | Task | Type | Duration | Start | Finish | Predecessors | Complete | Remaining | Baseline start | Baseline finish | Baseline duration | Baseline 1 start | Baseline 1 finish | Total slack | Free slack | Constraint | Farol de Atraso | Farol Marcos | % Previsto Tempo | % Previsto Tempo Numérico | Índice de Desempenho Físico (IDF) | Farol IDF | % Previsto Ponderado | % Concluído Ponderado | % Concluída Numérico | % Previsto Ponderado Numérico | Farol de Início | Responsável | Código do Contrato |
| --- | --- | --- | --- | --- | --- | --- | --- | --- | --- | --- | --- | --- | --- | --- | --- | --- | --- | --- | --- | --- | --- | --- | --- | --- | --- | --- | --- | --- | --- | --- |
| 2108 | 2.3.26 | **Pingo D'água** |  | 1615d | 2018-08-31 A | 2025-02-24 |  | 4% | 1551.75d | 2018-08-31 | 2025-02-24 | 1615d | 2018-11-06 | 2021-06-30 | 0d |  |  | Verde | Verde | 10% | 10 | 0% | Vermelho | 0% | 0% |  |  |  |  |  |
| 2109 | 2.3.26.1 | **Pleito PIAESPJ01 - Elaboração de projeto de sistema de esgotamento sanitário para a sede do município.** |  | 467d | 2018-08-31 A | 2020-07-14 |  | 9% | 425.25d | 2018-08-31 | 2020-07-14 | 467d |  |  | 1148d |  |  | Verde | Verde | 35% | 35 | 0% | Vermelho | 7% | 0% |  |  |  |  |  |
| 2110 | 2.3.26.1.1 | **Licitação do Projeto** |  | 191d | 2018-08-31 A | 2019-06-04 |  | 64% | 68.42d | 2018-08-31 | 2019-06-04 | 191d |  |  | 716d |  |  | Verde | Verde | 87% | 87 | 0% | Vermelho | 40% | 0% | 64 | 40 |  |  |  |
| 2111 | 2.3.26.1.1.1 | Licitação do projeto autorizada pelo banco | milestone | 0d | 2018-08-31 A | 2018-08-31 A |  | 100% |  | 2018-08-31 | 2018-08-31 | 0d |  |  |  |  | must start on 2018-08-31 | Verde | Verde | 100% | 100 | 0% | Vermelho | 100% | 0% | 100 | 100 | Verde |  |  |
| 2112 | 2.3.26.1.1.2 | Licitar projeto |  | 53d | 2019-02-21 A | 2019-05-15 | 2111FS+124d | 81% | 10d | 2019-02-21 | 2019-05-15 | 53d | 2018-11-06 | 2019-03-06 | 716d | 0d |  | Verde | Verde | 81% | 81 | 0% | Vermelho | 81% | 0% | 81 | 81 | Verde | 02 - Execução | PG 031 |
| 2113 | 2.3.26.1.1.3 | Documentação de licitação apresentada ao banco | milestone | 0d | 2019-05-15 | 2019-05-15 | 2112 |  |  | 2019-05-15 | 2019-05-15 | 0d |  |  | 716d | 0d |  | Verde | Verde | 0% |  | 0% | Verde | 0% | 0% |  |  | Verde |  |  |
| 2114 | 2.3.26.1.1.4 | Analisar e emitir resultado da licitação do projeto |  | 14d | 2019-05-16 | 2019-06-04 | 2113 |  |  | 2019-05-16 | 2019-06-04 | 14d |  |  | 716d | 0d |  | Verde | Verde | 0% |  | 0% | Verde | 0% | 0% |  |  | Verde |  |  |
| 2115 | 2.3.26.1.1.5 | Licitação do projeto concluída | milestone | 0d | 2019-06-04 | 2019-06-04 | 2114 |  |  | 2019-06-04 | 2019-06-04 | 0d |  |  | 716d | 0d |  | Verde | Verde | 0% |  | 0% | Verde | 0% | 0% |  |  | Verde |  |  |
| 2116 | 2.3.26.1.2 | **Elaboração do Projeto Básico** |  | 135d | 2019-06-05 | 2019-12-16 |  |  |  | 2019-06-05 | 2019-12-16 | 135d |  |  | 716d |  |  | Verde | Verde | 0% |  | 0% | Verde | 0% | 0% |  |  |  |  |  |
| 2117 | 2.3.26.1.2.1 | Elaborar Projeto Básico |  | 64d | 2019-06-05 | 2019-09-04 | 2115 |  |  | 2019-06-05 | 2019-09-04 | 64d | 2019-03-06 | 2019-05-05 | 716d | 0d |  | Verde | Verde | 0% |  | 0% | Verde | 0% | 0% |  |  | Verde | 02 - Execução | PG 031 |
| 2118 | 2.3.26.1.2.2 | Projeto básico apresentado ao banco | milestone | 0d | 2019-09-04 | 2019-09-04 | 2117 |  |  | 2019-09-04 | 2019-09-04 | 0d |  |  | 716d | 0d |  | Verde | Verde | 0% |  | 0% | Verde | 0% | 0% |  |  | Verde |  |  |
| 2119 | 2.3.26.1.2.3 | Analisar projeto básico |  | 22d | 2019-09-05 | 2019-10-04 | 2118 |  |  | 2019-09-05 | 2019-10-04 | 22d |  |  | 716d | 0d |  | Verde | Verde | 0% |  | 0% | Verde | 0% | 0% |  |  | Verde |  |  |
| 2120 | 2.3.26.1.2.4 | Adequar/revisar projeto básico |  | 22d | 2019-10-07 | 2019-11-05 | 2119 |  |  | 2019-10-07 | 2019-11-05 | 22d |  |  | 716d | 0d |  | Verde | Verde | 0% |  | 0% | Verde | 0% | 0% |  |  | Verde |  |  |
| 2121 | 2.3.26.1.2.5 | Analisar projeto básico - final |  | 22d | 2019-11-06 | 2019-12-06 | 2120 |  |  | 2019-11-06 | 2019-12-06 | 22d |  |  | 716d | 0d |  | Verde | Verde | 0% |  | 0% | Verde | 0% | 0% |  |  | Verde |  |  |
| 2122 | 2.3.26.1.2.6 | Projeto básico concluído | milestone | 0d | 2019-12-06 | 2019-12-06 | 2121 |  |  | 2019-12-06 | 2019-12-06 | 0d |  |  | 716d | 0d |  | Verde | Verde | 0% |  | 0% | Verde | 0% | 0% |  |  | Verde |  |  |
| 2123 | 2.3.26.1.2.7 | Recurso do projeto básico do pleito PIAESPJ01 repassado | milestone | 0d | 2019-12-16 | 2019-12-16 | 2122FS+5d |  |  | 2019-12-16 | 2019-12-16 | 0d |  |  | 820d | 136d |  | Verde | Verde | 0% |  | 0% | Verde | 0% | 0% |  |  | Verde |  |  |
| 2124 | 2.3.26.1.3 | Realizar Licenciamento Ambiental |  | 175d | 2019-09-05 | 2020-05-21 | 2117 |  |  | 2019-09-05 | 2020-05-21 | 175d | 2019-05-05 | 2019-11-01 | 716d | 32d |  | Verde | Verde | 0% |  | 0% | Verde | 0% | 0% |  |  | Verde | 02 - Execução | PG 031 |
| 2125 | 2.3.26.1.4 | **Elaboração do Projeto Executivo** |  | 146d | 2019-12-09 | 2020-07-14 |  |  |  | 2019-12-09 | 2020-07-14 | 146d |  |  | 716d |  |  | Verde | Verde | 0% |  | 0% | Verde | 0% | 0% |  |  |  |  |  |
| 2126 | 2.3.26.1.4.1 | Elaborar Projeto Executivo |  | 44d | 2019-12-09 | 2020-02-12 | 2122 |  |  | 2019-12-09 | 2020-02-12 | 44d | 2019-05-05 | 2019-09-02 | 716d | 0d |  | Verde | Verde | 0% |  | 0% | Verde | 0% | 0% |  |  | Verde | 02 - Execução | PG 031 |
| 2127 | 2.3.26.1.4.2 | Projeto executivo apresentado ao banco | milestone | 0d | 2020-02-12 | 2020-02-12 | 2126 |  |  | 2020-02-12 | 2020-02-12 | 0d |  |  | 716d | 0d |  | Verde | Verde | 0% |  | 0% | Verde | 0% | 0% |  |  | Verde |  |  |
| 2128 | 2.3.26.1.4.3 | Analisar projeto executivo |  | 21d | 2020-02-13 | 2020-03-17 | 2127 |  |  | 2020-02-13 | 2020-03-17 | 21d |  |  | 716d | 0d |  | Verde | Verde | 0% |  | 0% | Verde | 0% | 0% |  |  | Verde |  |  |
| 2129 | 2.3.26.1.4.4 | Adequar/revisar projeto executivo |  | 22d | 2020-03-18 | 2020-04-17 | 2128 |  |  | 2020-03-18 | 2020-04-17 | 22d |  |  | 716d | 0d |  | Verde | Verde | 0% |  | 0% | Verde | 0% | 0% |  |  | Verde |  |  |
| 2130 | 2.3.26.1.4.5 | Analisar projeto executivo - final |  | 22d | 2020-04-20 | 2020-05-21 | 2129 |  |  | 2020-04-20 | 2020-05-21 | 22d |  |  | 716d | 32d |  | Verde | Verde | 0% |  | 0% | Verde | 0% | 0% |  |  | Verde |  |  |
| 2131 | 2.3.26.1.4.6 | Projeto executivo concluído | milestone | 0d | 2020-07-07 | 2020-07-07 | 2130, 2123, 2124, 2144 |  |  | 2020-07-07 | 2020-07-07 | 0d |  |  | 684d | 0d |  | Verde | Verde | 0% |  | 0% | Verde | 0% | 0% |  |  | Verde |  |  |
| 2132 | 2.3.26.1.4.7 | Recurso do projeto executivo do pleito PIAESPJ01 repassado | milestone | 0d | 2020-07-14 | 2020-07-14 | 2131FS+5d |  |  | 2020-07-14 | 2020-07-14 | 0d |  |  | 1148d | 0d |  | Verde | Verde | 0% |  | 0% | Verde | 0% | 0% |  |  | Verde |  |  |
| 2133 | 2.3.26.1.5 | Pleito PIAESPJ01 concluído | milestone | 0d | 2020-07-14 | 2020-07-14 | 2124, 2132 |  |  | 2020-07-14 | 2020-07-14 | 0d |  |  | 1148d |  |  | Verde | Verde | 0% |  | 0% | Verde | 0% | 0% |  |  | Verde |  |  |

Notes:
- 2108: Pingo D'água teve 100% dos pleitos de Esgotamento Sanitário aprovado (R$4.254.293,76), conforme Deliberação 75. / O município teve o pleito de resíduos sólidos negado (R$472.699,31, equivalente a 10% do total do recurso).
- 2111: Em 25/04/2019: conforme planilha Controle Gerencial Renova o banco enviou ao município autorização no dia 31/08/2018
- 2112: 18/12/2018 - Município não consegue avançar no preenchimento da planilha oramentária do TR. Apoio técnico irá auxiliar o município com criação da planilha orçamentária, mas por motivo de férias da engenheira em janeiro, o prazo precisou ser extendido. / 25/04/2019: banco cobrou no dia 15/03 o processo licitatório do município. considerado mais 2 meses para apresentação do mesmo em maio de 2019

| ID | WBS | Task | Type | Duration | Start | Finish | Predecessors | Baseline start | Baseline finish | Baseline duration | Baseline 1 start | Baseline 1 finish | Total slack | Free slack | Constraint | Farol de Atraso | Farol Marcos | % Previsto Tempo | Índice de Desempenho Físico (IDF) | Farol IDF | % Previsto Ponderado | % Concluído Ponderado | Farol de Início | Responsável | Código do Contrato |
| --- | --- | --- | --- | --- | --- | --- | --- | --- | --- | --- | --- | --- | --- | --- | --- | --- | --- | --- | --- | --- | --- | --- | --- | --- | --- |
| 2134 | 2.3.26.2 | **Pleito de Pingo D'água a definir - Aquisição de Terreno** |  | 147d | 2019-11-29 | 2020-07-07 |  | 2019-11-29 | 2020-07-07 | 147d |  |  | 0d |  |  | Verde | Verde | 0% | 0% | Verde | 0% | 0% |  |  |  |
| 2135 | 2.3.26.2.1 | Pleito a definir aprovado | milestone | 0d | 2019-11-29 | 2019-11-29 |  | 2019-11-29 | 2019-11-29 | 0d |  |  | 0d |  | must start on 2019-11-29 | Verde | Verde | 0% | 0% | Verde | 0% | 0% | Verde |  |  |
| 2136 | 2.3.26.2.2 | **Aquisição de Terreno** |  | 147d | 2019-11-29 | 2020-07-07 |  | 2019-11-29 | 2020-07-07 | 147d |  |  | 684d |  |  | Verde | Verde | 0% | 0% | Verde | 0% | 0% |  |  |  |
| 2137 | 2.3.26.2.2.1 | Regularizar terreno e apresentar escritura ao banco |  | 88d | 2019-11-29 | 2020-04-09 | 2135, 2119 | 2019-11-29 | 2020-04-09 | 88d |  |  | 684d | 0d |  | Verde | Verde | 0% | 0% | Verde | 0% | 0% | Verde |  |  |
| 2138 | 2.3.26.2.2.2 | Analisar documentação do terreno |  | 10d | 2020-04-13 | 2020-04-27 | 2137 | 2020-04-13 | 2020-04-27 | 10d |  |  | 728d | 0d |  | Verde | Verde | 0% | 0% | Verde | 0% | 0% | Verde |  |  |
| 2139 | 2.3.26.2.2.3 | 50% do valor do imóvel repassado (1) | milestone | 0d | 2020-05-05 | 2020-05-05 | 2138FS+5d | 2020-05-05 | 2020-05-05 | 0d |  |  | 728d | 44d |  | Verde | Verde | 0% | 0% | Verde | 0% | 0% | Verde |  |  |
| 2140 | 2.3.26.2.2.4 | Registrar imóvel e apresentar documentação ao banco |  | 44d | 2020-04-13 | 2020-06-16 | 2137 | 2020-04-13 | 2020-06-16 | 44d |  |  | 684d | 0d |  | Verde | Verde | 0% | 0% | Verde | 0% | 0% | Verde |  |  |
| 2141 | 2.3.26.2.2.5 | Analisar documentação do terreno |  | 10d | 2020-06-17 | 2020-06-30 | 2140 | 2020-06-17 | 2020-06-30 | 10d |  |  | 684d | 0d |  | Verde | Verde | 0% | 0% | Verde | 0% | 0% | Verde |  |  |
| 2142 | 2.3.26.2.2.6 | 50% do valor do imóvel repassado (2) | milestone | 0d | 2020-07-07 | 2020-07-07 | 2141FS+5d | 2020-07-07 | 2020-07-07 | 0d |  |  | 684d | 0d |  | Verde | Verde | 0% | 0% | Verde | 0% | 0% | Verde |  |  |
| 2143 | 2.3.26.2.2.7 | Aquisição de Terreno concluída | milestone | 0d | 2020-07-07 | 2020-07-07 | 2139, 2142 | 2020-07-07 | 2020-07-07 | 0d |  |  | 684d | 0d |  | Verde | Verde | 0% | 0% | Verde | 0% | 0% | Verde |  |  |
| 2144 | 2.3.26.2.3 | Pleito a definir concluído | milestone | 0d | 2020-07-07 | 2020-07-07 | 2143 | 2020-07-07 | 2020-07-07 | 0d |  |  | 684d | 0d |  | Verde | Verde | 0% | 0% | Verde | 0% | 0% | Verde |  |  |
| 2145 | 2.3.26.3 | **Pleito PIAESOB01 - Implantação do sistema de esgotamento sanitário da sede do município** |  | 469d | 2020-07-07 | 2022-05-25 |  | 2020-07-07 | 2022-05-25 | 469d |  |  | 684d |  |  | Verde | Verde | 0% | 0% | Verde | 0% | 0% |  |  |  |
| 2146 | 2.3.26.3.1 | **Licitação da Obra** |  | 79d | 2020-07-07 | 2020-10-28 |  | 2020-07-07 | 2020-10-28 | 79d |  |  | 684d |  |  | Verde | Verde | 0% | 0% | Verde | 0% | 0% |  |  |  |
| 2147 | 2.3.26.3.1.1 | Licitação da obra autorizada pelo banco | milestone | 0d | 2020-07-07 | 2020-07-07 | 2131 | 2020-07-07 | 2020-07-07 | 0d |  |  | 684d | 0d |  | Verde | Verde | 0% | 0% | Verde | 0% | 0% | Verde |  |  |
| 2148 | 2.3.26.3.1.2 | Licitar Obra |  | 65d | 2020-07-08 | 2020-10-07 | 2147 | 2020-07-08 | 2020-10-07 | 65d | 2019-09-02 | 2019-12-31 | 684d | 0d |  | Verde | Verde | 0% | 0% | Verde | 0% | 0% | Verde | 02 - Execução | PG 031 |
| 2149 | 2.3.26.3.1.3 | Analisar e emitir resultado da licitação da obra |  | 14d | 2020-10-08 | 2020-10-28 | 2148 | 2020-10-08 | 2020-10-28 | 14d |  |  | 684d | 0d |  | Verde | Verde | 0% | 0% | Verde | 0% | 0% | Verde |  |  |
| 2150 | 2.3.26.3.1.4 | Licitação da obra concluída | milestone | 0d | 2020-10-28 | 2020-10-28 | 2149 | 2020-10-28 | 2020-10-28 | 0d |  |  | 684d | 0d |  | Verde | Verde | 0% | 0% | Verde | 0% | 0% | Verde |  |  |
| 2151 | 2.3.26.3.2 | Executar obra |  | 257d | 2020-10-29 | 2021-11-10 | 2150 | 2020-10-29 | 2021-11-10 | 257d |  |  | 684d | 0d |  | Verde | Verde | 0% | 0% | Verde | 0% | 0% | Verde |  |  |
| 2152 | 2.3.26.3.3 | Realizar processo de pré-operação |  | 128d | 2021-11-11 | 2022-05-18 | 2151 | 2021-11-11 | 2022-05-18 | 128d | 2021-01-01 | 2021-06-30 | 684d | 0d |  | Verde | Verde | 0% | 0% | Verde | 0% | 0% | Verde | 02 - Execução | PG 031 |
| 2153 | 2.3.26.3.4 | Recurso da obra parcelado repassado | milestone | 0d | 2022-05-25 | 2022-05-25 | 2152FS+5d | 2022-05-25 | 2022-05-25 | 0d |  |  | 684d | 0d |  | Verde | Verde | 0% | 0% | Verde | 0% | 0% | Verde |  |  |
| 2154 | 2.3.26.3.5 | Pleito PIAESOB01 concluído | milestone | 0d | 2022-05-25 | 2022-05-25 | 2153 | 2022-05-25 | 2022-05-25 | 0d |  |  | 684d |  |  | Verde | Verde | 0% | 0% | Verde | 0% | 0% | Verde |  |  |
| 2155 | 2.3.26.4 | **Pleito de Pingo D'agua de Resíduos Sólidos a definir** |  | 1364d | 2019-08-30 | 2025-02-24 |  | 2019-08-30 | 2025-02-24 | 1364d |  |  | 0d |  |  | Verde | Verde | 0% | 0% | Verde | 0% | 0% |  |  |  |
| 2156 | 2.3.26.4.1 | Pleito aprovado | milestone | 0d | 2019-08-30 | 2019-08-30 | 440 | 2019-08-30 | 2019-08-30 | 0d |  |  | 0d |  |  | Verde | Verde | 0% | 0% | Verde | 0% | 0% | Verde |  |  |
| 2157 | 2.3.26.4.2 | Iniciar pleito |  | 1d | 2019-08-30 | 2019-08-30 | 2156 | 2019-08-30 | 2019-08-30 | 1d |  |  | 0d |  |  | Verde | Verde | 0% | 0% | Verde | 0% | 0% | Verde |  |  |
| 2158 | 2.3.26.4.3 | Pleito concluído | milestone | 0d | 2025-02-24 | 2025-02-24 | 2157FS+1363d | 2025-02-24 | 2025-02-24 | 0d |  |  | 0d |  |  | Verde | Verde | 0% | 0% | Verde | 0% | 0% | Verde |  |  |
| 2159 | 2.3.26.5 | Recursos de Pingo D'água repassados | milestone | 0d | 2025-02-24 | 2025-02-24 | 2133, 2154, 2158 | 2025-02-24 | 2025-02-24 | 0d | 2019-06-04 | 2021-06-30 | 0d |  |  | Verde | Verde | 0% | 0% | Verde | 0% | 0% | Verde | 02 - Execução | PG 031 |

Notes:
- 2135: Em 25/04/2019: município mostrou interesse em fazer um pleito de terreno na reunião do dia 21/02/2019. Considerado que o município enviará o pleito e será aprovado no CIF do dia 29/11/2019 conforme NT 33 e após apresentação do projeto básico em setembro.
- 2151: Em 25/04/2019: valor da obra R$ 4 milhões
- 2159: Valor de recurso destinado ao munícipio: R$4.726.993,07

| ID | WBS | Task | Type | Duration | Start | Finish | Predecessors | Complete | Remaining | Baseline start | Baseline finish | Baseline duration | Baseline 1 start | Baseline 1 finish | Total slack | Free slack | Constraint | Farol de Atraso | Farol Marcos | % Previsto Tempo | Índice de Desempenho Físico (IDF) | Farol IDF | % Previsto Ponderado | % Concluído Ponderado | % Previsto Tempo Numérico | IDF Numérico | % Concluída Numérico | % Previsto Ponderado Numérico | Farol de Início | % Concluído Ponderado Numérico | Responsável | Código do Contrato |
| --- | --- | --- | --- | --- | --- | --- | --- | --- | --- | --- | --- | --- | --- | --- | --- | --- | --- | --- | --- | --- | --- | --- | --- | --- | --- | --- | --- | --- | --- | --- | --- | --- |
| 2160 | 2.3.27 | **Raul Soares** |  | 1208d | 2019-03-20 A | 2024-01-29 |  | 2% | 1179.52d | 2019-03-20 | 2024-01-29 | 1208d | 2018-11-25 | 2021-11-19 | 268d |  |  | Verde | Verde | 2% | 0% | Vermelho | 0% | 0% |  |  |  |  |  |  |  |  |
| 2161 | 2.3.27.1 | **Pleito RASESPJ02 - Elaboração de projetos de engenharia de sistemas de esgotamento sanitário para a sede municipal, distritos de São Vicente da Estrela, São Sebastião do Óculo, Santana do Tabuleiro, Vermelho Velho e povoado Cornélio Alves** |  | 220d | 2019-03-20 A | 2020-02-04 |  | 8% | 203.19d | 2019-03-20 | 2020-02-04 | 220d |  |  | 1256d |  |  | Verde | Verde | 12% | 100% | Verde | 4% | 4% | 12 | 100 |  |  |  |  |  |  |
| 2162 | 2.3.27.1.1 | Alteração do pleito aprovada | milestone | 0d | 2019-03-20 A | 2019-03-20 A |  | 100% |  | 2019-03-20 | 2019-03-20 | 0d |  |  |  |  | must start on 2019-03-20 | Verde | Verde | 100% | 0% | Vermelho | 100% | 0% | 100 |  | 100 | 100 | Verde |  |  |  |
| 2163 | 2.3.27.1.2 | **Licitação do Projeto** |  | 60d | 2019-03-27 A | 2019-06-25 |  | 40% | 36d | 2019-03-27 | 2019-06-25 | 60d |  |  | 640d |  |  | Verde | Verde | 36% | 95% | Vermelho | 42% | 40% | 36 | 95 | 40 | 42 |  | 40 |  |  |
| 2164 | 2.3.27.1.2.1 | Licitação do projeto autorizada pelo banco | milestone | 0d | 2019-03-27 A | 2019-03-27 A | 2162FS+6d | 100% |  | 2019-03-27 | 2019-03-27 | 0d |  |  |  |  |  | Verde | Verde | 100% | 0% | Vermelho | 100% | 0% | 100 |  | 100 | 100 | Verde |  |  |  |
| 2165 | 2.3.27.1.2.2 | Licitar projeto |  | 41d | 2019-03-28 A | 2019-05-28 | 2164 | 54% | 19d | 2019-03-28 | 2019-05-28 | 41d |  |  | 640d | 0d |  | Verde | Verde | 53% | 94% | Vermelho | 53% | 50% | 53 | 94 | 54 | 53 | Verde | 50 |  |  |
| 2166 | 2.3.27.1.2.3 | Documentação de licitação apresentada ao banco | milestone | 0d | 2019-06-04 | 2019-06-04 | 2165FS+5d |  |  | 2019-06-04 | 2019-06-04 | 0d |  |  | 640d | 0d |  | Verde | Verde | 0% | 0% | Verde | 0% | 0% |  |  |  |  | Verde |  |  |  |
| 2167 | 2.3.27.1.2.4 | Analisar e emitir resultado da licitação do projeto |  | 14d | 2019-06-05 | 2019-06-25 | 2166 |  |  | 2019-06-05 | 2019-06-25 | 14d |  |  | 640d | 0d |  | Verde | Verde | 0% | 0% | Verde | 0% | 0% |  |  |  |  | Verde |  |  |  |
| 2168 | 2.3.27.1.2.5 | Licitação do projeto concluída | milestone | 0d | 2019-06-25 | 2019-06-25 | 2167 |  |  | 2019-06-25 | 2019-06-25 | 0d |  |  | 640d | 0d |  | Verde | Verde | 0% | 0% | Verde | 0% | 0% |  |  |  |  | Verde |  |  |  |
| 2169 | 2.3.27.1.3 | **Elaboração do Projeto Básico/Executivo** |  | 154d | 2019-06-26 | 2020-02-04 |  |  |  | 2019-06-26 | 2020-02-04 | 154d |  |  | 640d |  |  | Verde | Verde | 0% | 0% | Verde | 0% | 0% |  |  |  |  |  |  |  |  |
| 2170 | 2.3.27.1.3.1 | Elaborar Projeto Básico/Executivo |  | 84d | 2019-06-26 | 2019-10-22 | 2168 |  |  | 2019-06-26 | 2019-10-22 | 84d |  |  | 640d | 0d |  | Verde | Verde | 0% | 0% | Verde | 0% | 0% |  |  |  |  | Verde |  |  |  |
| 2171 | 2.3.27.1.3.2 | Projeto apresentado ao banco | milestone | 0d | 2019-10-22 | 2019-10-22 | 2170 |  |  | 2019-10-22 | 2019-10-22 | 0d |  |  | 640d | 0d |  | Verde | Verde | 0% | 0% | Verde | 0% | 0% |  |  |  |  | Verde |  |  |  |
| 2172 | 2.3.27.1.3.3 | Analisar projeto |  | 21d | 2019-10-23 | 2019-11-21 | 2171 |  |  | 2019-10-23 | 2019-11-21 | 21d |  |  | 1256d | 0d |  | Verde | Verde | 0% | 0% | Verde | 0% | 0% |  |  |  |  | Verde |  |  |  |
| 2173 | 2.3.27.1.3.4 | Adequar/revisar projeto |  | 23d | 2019-11-22 | 2019-12-27 | 2172 |  |  | 2019-11-22 | 2019-12-27 | 23d |  |  | 1256d | 0d |  | Verde | Verde | 0% | 0% | Verde | 0% | 0% |  |  |  |  | Verde |  |  |  |
| 2174 | 2.3.27.1.3.5 | Analisar projeto - final |  | 21d | 2019-12-30 | 2020-01-28 | 2173 |  |  | 2019-12-30 | 2020-01-28 | 21d |  |  | 1256d | 0d |  | Verde | Verde | 0% | 0% | Verde | 0% | 0% |  |  |  |  | Verde |  |  |  |
| 2175 | 2.3.27.1.3.6 | Projeto concluído | milestone | 0d | 2020-01-28 | 2020-01-28 | 2174, 2177 |  |  | 2020-01-28 | 2020-01-28 | 0d |  |  | 1256d | 0d |  | Verde | Verde | 0% | 0% | Verde | 0% | 0% |  |  |  |  | Verde |  |  |  |
| 2176 | 2.3.27.1.3.7 | Recurso do projeto do pleito RASESPJ02 repassado | milestone | 0d | 2020-02-04 | 2020-02-04 | 2175FS+5d |  |  | 2020-02-04 | 2020-02-04 | 0d |  |  | 1256d | 0d |  | Verde | Verde | 0% | 0% | Verde | 0% | 0% |  |  |  |  | Verde |  |  |  |
| 2177 | 2.3.27.1.4 | Realizar Licenciamento Ambiental |  | 84d | 2019-09-26 | 2020-01-28 | 2170SS+65d |  |  | 2019-09-26 | 2020-01-28 | 84d |  |  | 1256d | 0d |  | Verde | Verde | 0% | 0% | Verde | 0% | 0% |  |  |  |  | Verde |  |  |  |
| 2178 | 2.3.27.1.5 | Pleito RASESPJ02 concluído | milestone | 0d | 2020-02-04 | 2020-02-04 | 2176 |  |  | 2020-02-04 | 2020-02-04 | 0d |  |  | 1256d | 988d |  | Verde | Verde | 0% | 0% | Verde | 0% | 0% |  |  |  |  | Verde |  |  |  |
| 2179 | 2.3.27.2 | **Pleito de Raul Soares a definir - Obra** |  | 659d | 2019-11-29 | 2022-07-27 |  |  |  | 2019-11-29 | 2022-07-27 | 659d |  |  | 640d |  |  | Verde | Verde | 0% | 0% | Verde | 0% | 0% |  |  |  |  |  |  |  |  |
| 2180 | 2.3.27.2.1 | Pleito aprovado | milestone | 0d | 2019-11-29 | 2019-11-29 | 2171FS+27d |  |  | 2019-11-29 | 2019-11-29 | 0d |  |  | 640d | 0d |  | Verde | Verde | 0% | 0% | Verde | 0% | 0% |  |  |  |  | Verde |  |  |  |
| 2181 | 2.3.27.2.2 | **Licitação da Obra** |  | 77d | 2019-12-16 | 2020-04-09 |  |  |  | 2019-12-16 | 2020-04-09 | 77d |  |  | 640d |  |  | Verde | Verde | 0% | 0% | Verde | 0% | 0% |  |  |  |  |  |  |  |  |
| 2182 | 2.3.27.2.2.1 | Licitação da obra autorizada pelo banco | milestone | 0d | 2019-12-16 | 2019-12-16 | 2180FS+10d |  |  | 2019-12-16 | 2019-12-16 | 0d |  |  | 640d | 0d |  | Verde | Verde | 0% | 0% | Verde | 0% | 0% |  |  |  |  | Verde |  |  |  |
| 2183 | 2.3.27.2.2.2 | Licitar Obra |  | 63d | 2019-12-17 | 2020-03-20 | 2182 |  |  | 2019-12-17 | 2020-03-20 | 63d | 2019-05-24 | 2019-09-21 | 640d | 0d |  | Verde | Verde | 0% | 0% | Verde | 0% | 0% |  |  |  |  | Verde |  | 02 - Execução | PG 031 |
| 2184 | 2.3.27.2.2.3 | Analisar e emitir resultado da licitação da obra |  | 14d | 2020-03-23 | 2020-04-09 | 2183 |  |  | 2020-03-23 | 2020-04-09 | 14d |  |  | 640d | 0d |  | Verde | Verde | 0% | 0% | Verde | 0% | 0% |  |  |  |  | Verde |  |  |  |
| 2185 | 2.3.27.2.2.4 | Licitação da obra concluída | milestone | 0d | 2020-04-09 | 2020-04-09 | 2184 |  |  | 2020-04-09 | 2020-04-09 | 0d |  |  | 640d | 0d |  | Verde | Verde | 0% | 0% | Verde | 0% | 0% |  |  |  |  | Verde |  |  |  |
| 2186 | 2.3.27.2.3 | Executar obra |  | 439d | 2020-04-13 | 2022-01-13 | 2185 |  |  | 2020-04-13 | 2022-01-13 | 439d |  |  | 640d | 0d |  | Verde | Verde | 0% | 0% | Verde | 0% | 0% |  |  |  |  | Verde |  |  |  |
| 2187 | 2.3.27.2.4 | Realizar processo de pré-operação |  | 128d | 2022-01-14 | 2022-07-20 | 2186 |  |  | 2022-01-14 | 2022-07-20 | 128d | 2021-05-23 | 2021-11-19 | 640d | 0d |  | Verde | Verde | 0% | 0% | Verde | 0% | 0% |  |  |  |  | Verde |  | 02 - Execução | PG 031 |
| 2188 | 2.3.27.2.5 | Recurso da obra parcelado repassado | milestone | 0d | 2022-07-27 | 2022-07-27 | 2187FS+5d |  |  | 2022-07-27 | 2022-07-27 | 0d |  |  | 640d | 0d |  | Verde | Verde | 0% | 0% | Verde | 0% | 0% |  |  |  |  | Verde |  |  |  |
| 2189 | 2.3.27.2.6 | Pleito a definir concluído | milestone | 0d | 2022-07-27 | 2022-07-27 | 2188 |  |  | 2022-07-27 | 2022-07-27 | 0d |  |  | 640d | 372d |  | Verde | Verde | 0% | 0% | Verde | 0% | 0% |  |  |  |  | Verde |  |  |  |

Notes:
- 2160: Raul Soares teve 4,4% dos pleitos de Esgotamento Sanitário aprovado (R$486.705,20), conforme Deliberação 75. / O município teve o pleito de resíduos sólidos negado (R$1.102.965,05), equivalente a 10% do total do recurso). / Aderiu à ata de registro de preço.
- 2162: Em 25/04/2019: pleito aprovado pela renova no dia 20/03/2019 conforme planilha Gestão de Pleitos_V2
- 2165: Em 29/04/2019: atualizado como agendado
- 2180: Em 25/04/2019: considerado que após a apresentação do projeto no banco o município enviará ofício e o pleito será aprovado pela CT/CIF na reunião de novembro.
- 2186: Em 24/05/2019: valor da obra R$ 9,4 milhões (valor teto menos valor do projeto)

| ID | WBS | Task | Type | Duration | Start | Finish | Predecessors | Baseline start | Baseline finish | Baseline duration | Baseline 1 start | Baseline 1 finish | Total slack | Free slack | Farol de Atraso | Farol Marcos | % Previsto Tempo | Índice de Desempenho Físico (IDF) | Farol IDF | % Previsto Ponderado | % Concluído Ponderado | Farol de Início | Responsável | Código do Contrato |
| --- | --- | --- | --- | --- | --- | --- | --- | --- | --- | --- | --- | --- | --- | --- | --- | --- | --- | --- | --- | --- | --- | --- | --- | --- |
| 2190 | 2.3.27.3 | **Pleito de Raul Soares de Resíduos Sólidos a definir** |  | 1096d | 2019-08-30 | 2024-01-29 |  | 2019-08-30 | 2024-01-29 | 1096d |  |  | 268d |  | Verde | Verde | 0% | 0% | Verde | 0% | 0% |  |  |  |
| 2191 | 2.3.27.3.1 | Pleito aprovado | milestone | 0d | 2019-08-30 | 2019-08-30 | 393 | 2019-08-30 | 2019-08-30 | 0d |  |  | 268d | 0d | Verde | Verde | 0% | 0% | Verde | 0% | 0% | Verde |  |  |
| 2192 | 2.3.27.3.2 | Iniciar pleito |  | 1d | 2019-08-30 | 2019-08-30 | 2191 | 2019-08-30 | 2019-08-30 | 1d |  |  | 268d | 0d | Verde | Verde | 0% | 0% | Verde | 0% | 0% | Verde |  |  |
| 2193 | 2.3.27.3.3 | Pleito concluído | milestone | 0d | 2024-01-29 | 2024-01-29 | 2192FS+1095d | 2024-01-29 | 2024-01-29 | 0d |  |  | 268d | 0d | Verde | Verde | 0% | 0% | Verde | 0% | 0% | Verde |  |  |
| 2194 | 2.3.27.4 | Recursos de Raul Soares repassados | milestone | 0d | 2024-01-29 | 2024-01-29 | 2178, 2189, 2193 | 2024-01-29 | 2024-01-29 | 0d | 2019-06-23 | 2022-03-09 | 268d |  | Verde | Verde | 0% | 0% | Verde | 0% | 0% | Verde | 02 - Execução | PG 031 |
| 2195 | 2.3.28 | **Resplendor** |  | 859d | 2019-05-08 | 2022-10-18 |  | 2019-05-08 | 2022-10-18 | 859d | 2018-10-30 | 2022-03-22 | 584d |  | Verde | Verde | 0% | 0% | Verde | 0% | 0% |  |  |  |
| 2196 | 2.3.28.1 | **Pleito de Resplendor a definir - Projeto dos distritos de Calixto, Nicolândia, Campo Alegre e Independência** |  | 270d | 2019-05-31 | 2020-07-02 |  | 2019-05-31 | 2020-07-02 | 270d |  |  | 584d |  | Verde | Verde | 0% | 0% | Verde | 0% | 0% |  |  |  |
| 2197 | 2.3.28.1.1 | Alteração do pleito aprovada | milestone | 0d | 2019-05-31 | 2019-05-31 | 206FS+115d | 2019-05-31 | 2019-05-31 | 0d |  |  | 584d | 0d | Verde | Verde | 0% | 0% | Verde | 0% | 0% | Verde |  |  |
| 2198 | 2.3.28.1.2 | **Licitação do Projeto** |  | 60d | 2019-06-14 | 2019-09-10 |  | 2019-06-14 | 2019-09-10 | 60d |  |  | 584d |  | Verde | Verde | 0% | 0% | Verde | 0% | 0% |  |  |  |
| 2199 | 2.3.28.1.2.1 | Licitação do projeto autorizada pelo banco | milestone | 0d | 2019-06-14 | 2019-06-14 | 2197FS+10d | 2019-06-14 | 2019-06-14 | 0d |  |  | 584d | 0d | Verde | Verde | 0% | 0% | Verde | 0% | 0% | Verde |  |  |
| 2200 | 2.3.28.1.2.2 | Licitar projeto |  | 43d | 2019-06-17 | 2019-08-16 | 2199 | 2019-06-17 | 2019-08-16 | 43d | 2018-10-30 | 2019-02-27 | 584d | 0d | Verde | Verde | 0% | 0% | Verde | 0% | 0% | Verde | 02 - Execução | PG 031 |
| 2201 | 2.3.28.1.2.3 | Documentação de licitação apresentada ao banco | milestone | 0d | 2019-08-23 | 2019-08-23 | 2200FS+5d | 2019-08-23 | 2019-08-23 | 0d |  |  | 584d | 0d | Verde | Verde | 0% | 0% | Verde | 0% | 0% | Verde |  |  |
| 2202 | 2.3.28.1.2.4 | Analisar e emitir resultado da licitação do projeto |  | 12d | 2019-08-26 | 2019-09-10 | 2201 | 2019-08-26 | 2019-09-10 | 12d |  |  | 584d | 0d | Verde | Verde | 0% | 0% | Verde | 0% | 0% | Verde |  |  |
| 2203 | 2.3.28.1.2.5 | Licitação do projeto concluída | milestone | 0d | 2019-09-10 | 2019-09-10 | 2202 | 2019-09-10 | 2019-09-10 | 0d |  |  | 584d | 0d | Verde | Verde | 0% | 0% | Verde | 0% | 0% | Verde |  |  |
| 2204 | 2.3.28.1.3 | **Elaboração do Projeto Básico** |  | 113d | 2019-09-11 | 2020-02-21 |  | 2019-09-11 | 2020-02-21 | 113d |  |  | 584d |  | Verde | Verde | 0% | 0% | Verde | 0% | 0% |  |  |  |
| 2205 | 2.3.28.1.3.1 | Elaborar Projeto Básico |  | 44d | 2019-09-11 | 2019-11-11 | 2203 | 2019-09-11 | 2019-11-11 | 44d | 2019-02-27 | 2019-05-28 | 584d | 0d | Verde | Verde | 0% | 0% | Verde | 0% | 0% | Verde | 02 - Execução | PG 031 |
| 2206 | 2.3.28.1.3.2 | Projeto básico apresentado ao banco | milestone | 0d | 2019-11-11 | 2019-11-11 | 2205 | 2019-11-11 | 2019-11-11 | 0d |  |  | 584d | 0d | Verde | Verde | 0% | 0% | Verde | 0% | 0% | Verde |  |  |
| 2207 | 2.3.28.1.3.3 | Analisar projeto básico |  | 22d | 2019-11-12 | 2019-12-13 | 2206 | 2019-11-12 | 2019-12-13 | 22d |  |  | 584d | 0d | Verde | Verde | 0% | 0% | Verde | 0% | 0% | Verde |  |  |
| 2208 | 2.3.28.1.3.4 | Adequar/revisar projeto básico |  | 23d | 2019-12-16 | 2020-01-20 | 2207 | 2019-12-16 | 2020-01-20 | 23d |  |  | 666d | 0d | Verde | Verde | 0% | 0% | Verde | 0% | 0% | Verde |  |  |
| 2209 | 2.3.28.1.3.5 | Analisar projeto básico - final |  | 19d | 2020-01-21 | 2020-02-14 | 2208 | 2020-01-21 | 2020-02-14 | 19d |  |  | 666d | 0d | Verde | Verde | 0% | 0% | Verde | 0% | 0% | Verde |  |  |
| 2210 | 2.3.28.1.3.6 | Projeto básico concluído | milestone | 0d | 2020-02-14 | 2020-02-14 | 2209 | 2020-02-14 | 2020-02-14 | 0d |  |  | 666d | 0d | Verde | Verde | 0% | 0% | Verde | 0% | 0% | Verde |  |  |
| 2211 | 2.3.28.1.3.7 | Recurso do projeto básico do pleito RESESOB01 repassado | milestone | 0d | 2020-02-21 | 2020-02-21 | 2210FS+5d | 2020-02-21 | 2020-02-21 | 0d |  |  | 666d | 82d | Verde | Verde | 0% | 0% | Verde | 0% | 0% | Verde |  |  |
| 2212 | 2.3.28.1.4 | Adquirir imóvel |  | 129d | 2019-12-16 | 2020-06-25 | 2207 | 2019-12-16 | 2020-06-25 | 129d |  |  | 584d | 0d | Verde | Verde | 0% | 0% | Verde | 0% | 0% | Verde |  |  |
| 2213 | 2.3.28.1.5 | Realizar Licenciamento Ambiental |  | 130d | 2019-11-12 | 2020-05-26 | 2206 | 2019-11-12 | 2020-05-26 | 130d | 2019-05-28 | 2019-11-24 | 605d | 21d | Verde | Verde | 0% | 0% | Verde | 0% | 0% | Verde | 02 - Execução | PG 031 |

Notes:
- 2194: Valor de recurso destinado ao munícipio: R$11.029.650,50
- 2195: Resplendor teve 100% dos pleitos de Esgotamento Sanitário aprovado (R$8.508.587,53), conforme Deliberação 75. / O município teve 5,6%, dos 10% do valor teto destinado a Resíduos Sólidos aprovado (R$529.000,00). / Munícipio vai solicitar mudança de pleito para projetos nos distriitos de Calixto, Nicolândia, Campo Alegre e Independência (ainda não tem o valor do pleito). Posteriormente a aprovação das alternativas de concepção a serem implantadas, deverá ser solicitado recursos para desapropriação e priorização da execução das obras, considerando o saldo de recursos disponíveis.
- 2197: Em 25/04/2019: município pediu a substituição do pleito de obra da sede por meio do ofício 508/2018 e utilização dos recursos para projeto e obra dos distritos de Calixto, Nicolândia, Campo Alegre e Independência. Visto que o pleito não foi julgado no pleito de abril 2019, foi considerado que o pleito será cancelado no próximo CIF de maio (31/05/2019).
- 2200: Munícipio vai mudar o pleito e solicitar projetos. / Município irá definir os novos pleitos em distritos não atendidos pela Copasa, (já possui conceção para a sede). O pleito de RS tbm irá mudar para obras de melhoria no aterro e não projeto de ampliação.

| ID | WBS | Task | Type | Duration | Start | Finish | Predecessors | Baseline start | Baseline finish | Baseline duration | Baseline 1 start | Baseline 1 finish | Total slack | Free slack | Farol de Atraso | Farol Marcos | % Previsto Tempo | Índice de Desempenho Físico (IDF) | Farol IDF | % Previsto Ponderado | % Concluído Ponderado | Responsável | Código do Contrato | Farol de Início |
| --- | --- | --- | --- | --- | --- | --- | --- | --- | --- | --- | --- | --- | --- | --- | --- | --- | --- | --- | --- | --- | --- | --- | --- | --- |
| 2214 | 2.3.28.1.6 | **Elaboração do Projeto Executivo** |  | 156d | 2019-11-12 | 2020-07-02 |  | 2019-11-12 | 2020-07-02 | 156d |  |  | 605d |  | Verde | Verde | 0% | 0% | Verde | 0% | 0% |  |  |  |
| 2215 | 2.3.28.1.6.1 | Elaborar Projeto Executivo |  | 65d | 2019-11-12 | 2020-02-17 | 2205 | 2019-11-12 | 2020-02-17 | 65d | 2019-05-28 | 2019-11-24 | 605d | 0d | Verde | Verde | 0% | 0% | Verde | 0% | 0% | 02 - Execução | PG 031 | Verde |
| 2216 | 2.3.28.1.6.2 | Projeto executivo apresentado ao banco | milestone | 0d | 2020-02-17 | 2020-02-17 | 2215 | 2020-02-17 | 2020-02-17 | 0d |  |  | 605d | 0d | Verde | Verde | 0% | 0% | Verde | 0% | 0% |  |  | Verde |
| 2217 | 2.3.28.1.6.3 | Analisar projeto executivo |  | 22d | 2020-02-18 | 2020-03-23 | 2216 | 2020-02-18 | 2020-03-23 | 22d |  |  | 605d | 0d | Verde | Verde | 0% | 0% | Verde | 0% | 0% |  |  | Verde |
| 2218 | 2.3.28.1.6.4 | Adequar/revisar projeto executivo |  | 21d | 2020-03-24 | 2020-04-23 | 2217 | 2020-03-24 | 2020-04-23 | 21d |  |  | 605d | 0d | Verde | Verde | 0% | 0% | Verde | 0% | 0% |  |  | Verde |
| 2219 | 2.3.28.1.6.5 | Analisar projeto executivo - final |  | 22d | 2020-04-24 | 2020-05-26 | 2218 | 2020-04-24 | 2020-05-26 | 22d |  |  | 605d | 21d | Verde | Verde | 0% | 0% | Verde | 0% | 0% |  |  | Verde |
| 2220 | 2.3.28.1.6.6 | Projeto executivo concluído | milestone | 0d | 2020-06-25 | 2020-06-25 | 2219, 2211, 2213, 2212 | 2020-06-25 | 2020-06-25 | 0d |  |  | 584d | 0d | Verde | Verde | 0% | 0% | Verde | 0% | 0% |  |  | Verde |
| 2221 | 2.3.28.1.6.7 | Recurso do projeto executivo do pleito RESESOB01 repassado | milestone | 0d | 2020-07-02 | 2020-07-02 | 2220FS+5d | 2020-07-02 | 2020-07-02 | 0d |  |  | 1156d | 0d | Verde | Verde | 0% | 0% | Verde | 0% | 0% |  |  | Verde |
| 2222 | 2.3.28.1.7 | Pleito de Resplendor a definir concluído | milestone | 0d | 2020-07-02 | 2020-07-02 | 2221 | 2020-07-02 | 2020-07-02 | 0d |  |  | 1156d | 572d | Verde | Verde | 0% | 0% | Verde | 0% | 0% |  |  | Verde |
| 2223 | 2.3.28.2 | **Pleito de Resplendor a definir - Obra dos distritos de Calixto, Nicolândia, Campo Alegre e Independência** |  | 842d | 2019-05-31 | 2022-10-18 |  | 2019-05-31 | 2022-10-18 | 842d |  |  | 584d |  | Verde | Verde | 0% | 0% | Verde | 0% | 0% |  |  |  |
| 2224 | 2.3.28.2.1 | Alteração de pleito aprovada | milestone | 0d | 2019-05-31 | 2019-05-31 | 206FS+115d | 2019-05-31 | 2019-05-31 | 0d |  |  | 839d | 255d | Verde | Verde | 0% | 0% | Verde | 0% | 0% |  |  | Verde |
| 2225 | 2.3.28.2.2 | **Licitação da Obra** |  | 58d | 2020-06-25 | 2020-09-16 |  | 2020-06-25 | 2020-09-16 | 58d |  |  | 584d |  | Verde | Verde | 0% | 0% | Verde | 0% | 0% |  |  |  |
| 2226 | 2.3.28.2.2.1 | Licitação da obra autorizada pelo banco | milestone | 0d | 2020-06-25 | 2020-06-25 | 2220, 2224FS+10d | 2020-06-25 | 2020-06-25 | 0d |  |  | 584d | 0d | Verde | Verde | 0% | 0% | Verde | 0% | 0% |  |  | Verde |
| 2227 | 2.3.28.2.2.2 | Licitar Obra |  | 43d | 2020-06-26 | 2020-08-25 | 2226 | 2020-06-26 | 2020-08-25 | 43d | 2019-11-24 | 2020-03-23 | 584d | 0d | Verde | Verde | 0% | 0% | Verde | 0% | 0% | 02 - Execução | PG 031 | Verde |
| 2228 | 2.3.28.2.2.3 | Analisar e emitir resultado da licitação da obra |  | 15d | 2020-08-26 | 2020-09-16 | 2227 | 2020-08-26 | 2020-09-16 | 15d |  |  | 584d | 0d | Verde | Verde | 0% | 0% | Verde | 0% | 0% |  |  | Verde |
| 2229 | 2.3.28.2.2.4 | Licitação da obra concluída | milestone | 0d | 2020-09-16 | 2020-09-16 | 2228 | 2020-09-16 | 2020-09-16 | 0d |  |  | 584d | 0d | Verde | Verde | 0% | 0% | Verde | 0% | 0% |  |  | Verde |
| 2230 | 2.3.28.2.3 | Executar obra |  | 386d | 2020-09-17 | 2022-04-06 | 2229 | 2020-09-17 | 2022-04-06 | 386d |  |  | 584d | 0d | Verde | Verde | 0% | 0% | Verde | 0% | 0% |  |  | Verde |
| 2231 | 2.3.28.2.4 | Realizar processo de pré-operação |  | 128d | 2022-04-07 | 2022-10-10 | 2230 | 2022-04-07 | 2022-10-10 | 128d | 2021-09-23 | 2022-03-22 | 584d | 0d | Verde | Verde | 0% | 0% | Verde | 0% | 0% | 02 - Execução | PG 031 | Verde |
| 2232 | 2.3.28.2.5 | Recurso da obra parcelado repassado | milestone | 0d | 2022-10-18 | 2022-10-18 | 2231FS+5d | 2022-10-18 | 2022-10-18 | 0d |  |  | 584d | 0d | Verde | Verde | 0% | 0% | Verde | 0% | 0% |  |  | Verde |
| 2233 | 2.3.28.2.6 | Pleito de Resplendor a definir concluído | milestone | 0d | 2022-10-18 | 2022-10-18 | 2232 | 2022-10-18 | 2022-10-18 | 0d |  |  | 584d | 0d | Verde | Verde | 0% | 0% | Verde | 0% | 0% |  |  | Verde |
| 2234 | 2.3.28.3 | **Pleito RESESOB01 - Construção do sistema de esgotamento sanitário da sede do município.** |  | 1d | 2019-05-31 | 2019-05-31 |  | 2019-05-31 | 2019-05-31 | 1d |  |  | 1426d |  | Verde | Verde | 0% | 0% | Verde | 0% | 0% |  |  |  |
| 2235 | 2.3.28.3.1 | Avaliar pleito |  | 1d | 2019-05-31 | 2019-05-31 | 206FS+114d | 2019-05-31 | 2019-05-31 | 1d |  |  | 1426d | 0d | Verde | Verde | 0% | 0% | Verde | 0% | 0% |  |  | Verde |
| 2236 | 2.3.28.3.2 | Pleito RESESOB01 concluído | milestone | 0d | 2019-05-31 | 2019-05-31 | 2235 | 2019-05-31 | 2019-05-31 | 0d |  |  | 1426d | 842d | Verde | Verde | 0% | 0% | Verde | 0% | 0% |  |  | Verde |
| 2237 | 2.3.28.4 | **Pleito RESRSPM01 - Elaboração de estudos ambientais para a formalização do processo de regularização ambiental junto ao órgão ambiental competente** |  | 116d | 2019-06-11 | 2019-11-25 |  | 2019-06-11 | 2019-11-25 | 116d |  |  | 946d |  | Verde | Verde | 0% | 0% | Verde | 0% | 0% |  |  |  |
| 2238 | 2.3.28.4.1 | **Licitação de Empresa para Licenciamento Ambiental** |  | 63d | 2019-06-11 | 2019-09-10 |  | 2019-06-11 | 2019-09-10 | 63d |  |  | 946d |  | Verde | Verde | 0% | 0% | Verde | 0% | 0% |  |  |  |
| 2239 | 2.3.28.4.1.1 | Licitação da empresa para Licenciamento Ambiental autorizada pelo banco | milestone | 0d | 2019-06-11 | 2019-06-11 | 2250 | 2019-06-11 | 2019-06-11 | 0d |  |  | 946d | 0d | Verde | Verde | 0% | 0% | Verde | 0% | 0% |  |  | Verde |
| 2240 | 2.3.28.4.1.2 | Licitar empresa para Licenciamento Ambiental |  | 44d | 2019-06-12 | 2019-08-13 | 2239 | 2019-06-12 | 2019-08-13 | 44d |  |  | 946d | 0d | Verde | Verde | 0% | 0% | Verde | 0% | 0% |  |  | Verde |
| 2241 | 2.3.28.4.1.3 | Documentação de licitação apresentada ao banco | milestone | 0d | 2019-08-21 | 2019-08-21 | 2240FS+5d | 2019-08-21 | 2019-08-21 | 0d |  |  | 946d | 0d | Verde | Verde | 0% | 0% | Verde | 0% | 0% |  |  | Verde |
| 2242 | 2.3.28.4.1.4 | Analisar e emitir resultado da licitação do empresa para Licenciamento Ambiental |  | 14d | 2019-08-22 | 2019-09-10 | 2241 | 2019-08-22 | 2019-09-10 | 14d |  |  | 946d | 0d | Verde | Verde | 0% | 0% | Verde | 0% | 0% |  |  | Verde |
| 2243 | 2.3.28.4.1.5 | Licitação da empresa para Licenciamento Ambiental concluída | milestone | 0d | 2019-09-10 | 2019-09-10 | 2242 | 2019-09-10 | 2019-09-10 | 0d |  |  | 946d | 0d | Verde | Verde | 0% | 0% | Verde | 0% | 0% |  |  | Verde |
| 2244 | 2.3.28.4.2 | Executar o Licenciamento Ambiental |  | 48d | 2019-09-11 | 2019-11-18 | 2243 | 2019-09-11 | 2019-11-18 | 48d |  |  | 946d | 0d | Verde | Verde | 0% | 0% | Verde | 0% | 0% |  |  | Verde |
| 2245 | 2.3.28.4.3 | Recurso do serviço parcelado repassado | milestone | 0d | 2019-11-25 | 2019-11-25 | 2244FS+5d | 2019-11-25 | 2019-11-25 | 0d |  |  | 1303d | 0d | Verde | Verde | 0% | 0% | Verde | 0% | 0% |  |  | Verde |
| 2246 | 2.3.28.4.4 | Pleito RESRSPM01 concluído | milestone | 0d | 2019-11-25 | 2019-11-25 | 2245 | 2019-11-25 | 2019-11-25 | 0d |  |  | 1303d | 601d | Verde | Verde | 0% | 0% | Verde | 0% | 0% |  |  | Verde |

Notes:
- 2224: Em 25/04/2019: município pediu a substituição do pleito de obra da sede por meio do ofício 508/2018 e utilização dos recursos para projeto e obra dos distritos de Calixto, Nicolândia, Campo Alegre e Independência. Visto que o pleito não foi julgado no pleito de abril 2019, foi considerado que o pleito será cancelado no próximo CIF de maio (31/05/2019).
- 2230: Em 25/04/2019: valor da obra R$ 8 milhões
- 2235: Em 25/04/2019: município pediu a substituição do pleito de obra da sede por meio do ofício 508/2018 e utilização dos recursos para projeto e obra dos distritos de Calixto, Nicolândia, Campo Alegre e Independência. Visto que o pleito não foi julgado no pleito de abril 2019, foi considerado que o pleito será cancelado no próximo CIF de maio (31/05/2019).
- 2239: Em 24/04/2019: foi solicitado ao banco a autorização para licitação da empresa de licenciamento após a primeira análise do projeto a fim de agilizar o processo de licenciamento.

| ID | WBS | Task | Type | Duration | Start | Finish | Predecessors | Complete | Remaining | Baseline start | Baseline finish | Baseline duration | Baseline 1 start | Baseline 1 finish | Total slack | Free slack | Constraint | Farol de Atraso | Farol Marcos | % Previsto Tempo | Índice de Desempenho Físico (IDF) | Farol IDF | % Previsto Ponderado | % Concluído Ponderado | Farol de Início | Responsável | Código do Contrato | % Concluída Numérico | % Previsto Tempo Numérico | IDF Numérico |
| --- | --- | --- | --- | --- | --- | --- | --- | --- | --- | --- | --- | --- | --- | --- | --- | --- | --- | --- | --- | --- | --- | --- | --- | --- | --- | --- | --- | --- | --- | --- |
| 2247 | 2.3.28.5 | **Pleito RESRSOB02 - Execução de obras emergenciais a serem executadas em conformidade com os projetos já aprovados para o empreendimento na fase de concessão da AAF vigente, sendo obras na plataforma em utilização, implantação de sistema de drenagem de per** |  | 492d | 2019-05-08 | 2021-04-30 |  |  |  | 2019-05-08 | 2021-04-30 | 492d |  |  | 946d |  |  | Verde | Verde | 0% | 0% | Verde | 0% | 0% |  |  |  |  |  |  |
| 2248 | 2.3.28.5.1 | **Aprovação do Projeto Executivo** |  | 135d | 2019-05-08 | 2019-11-18 |  |  |  | 2019-05-08 | 2019-11-18 | 135d |  |  | 946d |  |  | Verde | Verde | 0% | 0% | Verde | 0% | 0% |  |  |  |  |  |  |
| 2249 | 2.3.28.5.1.1 | Projeto apresentado ao banco | milestone | 0d | 2019-05-08 | 2019-05-08 | 206FS+98d |  |  | 2019-05-08 | 2019-05-08 | 0d |  |  | 946d | 0d |  | Verde | Verde | 0% | 0% | Verde | 0% | 0% | Verde |  |  |  |  |  |
| 2250 | 2.3.28.5.1.2 | Analisar projeto |  | 24d | 2019-05-09 | 2019-06-11 | 2249 |  |  | 2019-05-09 | 2019-06-11 | 24d |  |  | 946d | 0d |  | Verde | Verde | 0% | 0% | Verde | 0% | 0% | Verde |  |  |  |  |  |
| 2251 | 2.3.28.5.1.3 | Adequar/revisar projeto |  | 22d | 2019-06-12 | 2019-07-12 | 2250 |  |  | 2019-06-12 | 2019-07-12 | 22d |  |  | 1013d | 0d |  | Verde | Verde | 0% | 0% | Verde | 0% | 0% | Verde |  |  |  |  |  |
| 2252 | 2.3.28.5.1.4 | Analisar projeto - final |  | 22d | 2019-07-15 | 2019-08-13 | 2251 |  |  | 2019-07-15 | 2019-08-13 | 22d |  |  | 1013d | 67d |  | Verde | Verde | 0% | 0% | Verde | 0% | 0% | Verde |  |  |  |  |  |
| 2253 | 2.3.28.5.1.5 | Projeto concluído | milestone | 0d | 2019-11-18 | 2019-11-18 | 2252, 2244 |  |  | 2019-11-18 | 2019-11-18 | 0d |  |  | 946d | 0d |  | Verde | Verde | 0% | 0% | Verde | 0% | 0% | Verde |  |  |  |  |  |
| 2254 | 2.3.28.5.2 | **Licitação da obra** |  | 77d | 2019-11-18 | 2020-03-13 |  |  |  | 2019-11-18 | 2020-03-13 | 77d |  |  | 946d |  |  | Verde | Verde | 0% | 0% | Verde | 0% | 0% |  |  |  |  |  |  |
| 2255 | 2.3.28.5.2.1 | Licitação da obra autorizada pelo banco | milestone | 0d | 2019-11-18 | 2019-11-18 | 2253 |  |  | 2019-11-18 | 2019-11-18 | 0d |  |  | 946d | 0d |  | Verde | Verde | 0% | 0% | Verde | 0% | 0% | Verde |  |  |  |  |  |
| 2256 | 2.3.28.5.2.2 | Licitar obra |  | 63d | 2019-11-19 | 2020-02-19 | 2255 |  |  | 2019-11-19 | 2020-02-19 | 63d |  |  | 946d | 0d |  | Verde | Verde | 0% | 0% | Verde | 0% | 0% | Verde |  |  |  |  |  |
| 2257 | 2.3.28.5.2.3 | Analisar e emitir resultado da licitação da obra |  | 14d | 2020-02-20 | 2020-03-13 | 2256 |  |  | 2020-02-20 | 2020-03-13 | 14d |  |  | 946d | 0d |  | Verde | Verde | 0% | 0% | Verde | 0% | 0% | Verde |  |  |  |  |  |
| 2258 | 2.3.28.5.2.4 | Licitação da obra concluída | milestone | 0d | 2020-03-13 | 2020-03-13 | 2257 |  |  | 2020-03-13 | 2020-03-13 | 0d |  |  | 946d | 0d |  | Verde | Verde | 0% | 0% | Verde | 0% | 0% | Verde |  |  |  |  |  |
| 2259 | 2.3.28.5.3 | Executar obra |  | 127d | 2020-04-14 | 2020-10-14 | 2258FS+20d |  |  | 2020-04-14 | 2020-10-14 | 127d |  |  | 946d | 0d |  | Verde | Verde | 0% | 0% | Verde | 0% | 0% | Verde |  |  |  |  |  |
| 2260 | 2.3.28.5.4 | Realizar processo de pré-operação |  | 128d | 2020-10-15 | 2021-04-23 | 2259 |  |  | 2020-10-15 | 2021-04-23 | 128d |  |  | 946d | 0d |  | Verde | Verde | 0% | 0% | Verde | 0% | 0% | Verde |  |  |  |  |  |
| 2261 | 2.3.28.5.5 | Recurso da obra parcelado repassado | milestone | 0d | 2021-04-30 | 2021-04-30 | 2260FS+5d |  |  | 2021-04-30 | 2021-04-30 | 0d |  |  | 946d | 0d |  | Verde | Verde | 0% | 0% | Verde | 0% | 0% | Verde |  |  |  |  |  |
| 2262 | 2.3.28.5.6 | Pleito RESRSOB02 concluído | milestone | 0d | 2021-04-30 | 2021-04-30 | 2261 |  |  | 2021-04-30 | 2021-04-30 | 0d |  |  | 951d | 249d |  | Verde | Verde | 0% | 0% | Verde | 0% | 0% | Verde |  |  |  |  |  |
| 2263 | 2.3.28.6 | Recursos de Resplendor repassados | milestone | 0d | 2022-10-18 | 2022-10-18 | 2236, 2262, 2246, 2233, 2222 |  |  | 2022-10-18 | 2022-10-18 | 0d | 2019-06-27 | 2022-03-22 | 584d |  |  | Verde | Verde | 0% | 0% | Verde | 0% | 0% | Verde | 02 - Execução | PG 031 |  |  |  |
| 2264 | 2.3.29 | **Rio Casca** |  | 1402d | 2018-06-15 A | 2024-01-29 |  | 11% | 1249.94d | 2018-06-15 | 2024-01-29 | 1402d | 2018-11-20 | 2020-12-31 | 508d |  |  | Verde | Verde | 15% | 100% | Verde | 1% | 1% |  |  |  | 11 | 15 | 100 |
| 2265 | 2.3.29.1 | **Pleito de Rio Casca a definir - Projeto da Sede** |  | 192d | 2019-05-31 | 2020-03-09 |  |  |  | 2019-05-31 | 2020-03-09 | 192d |  |  | 1475d |  |  | Verde | Verde | 0% | 0% | Verde | 0% | 0% |  |  |  |  |  |  |
| 2266 | 2.3.29.1.1 | Pleito aprovado | milestone | 0d | 2019-05-31 | 2019-05-31 |  |  |  | 2019-05-31 | 2019-05-31 | 0d |  |  | 1475d | 0d | start no earlier than 2019-05-31 | Verde | Verde | 0% | 0% | Verde | 0% | 0% | Verde |  |  |  |  |  |
| 2267 | 2.3.29.1.2 | **Licitação do Projeto** |  | 66d | 2019-06-13 | 2019-09-17 |  |  |  | 2019-06-13 | 2019-09-17 | 66d |  |  | 1475d |  |  | Verde | Verde | 0% | 0% | Verde | 0% | 0% |  |  |  |  |  |  |
| 2268 | 2.3.29.1.2.1 | Licitação do projeto autorizada pelo banco | milestone | 0d | 2019-06-13 | 2019-06-13 | 2266FS+10d |  |  | 2019-06-13 | 2019-06-13 | 0d |  |  | 1475d | 0d |  | Verde | Verde | 0% | 0% | Verde | 0% | 0% | Verde |  |  |  |  |  |
| 2269 | 2.3.29.1.2.2 | Licitar projeto |  | 43d | 2019-06-14 | 2019-08-14 | 2268 |  |  | 2019-06-14 | 2019-08-14 | 43d |  |  | 1475d | 0d |  | Verde | Verde | 0% | 0% | Verde | 0% | 0% | Verde |  |  |  |  |  |
| 2270 | 2.3.29.1.2.3 | Documentação de licitação apresentada ao banco | milestone | 0d | 2019-08-14 | 2019-08-14 | 2269 |  |  | 2019-08-14 | 2019-08-14 | 0d |  |  | 1475d | 0d |  | Verde | Verde | 0% | 0% | Verde | 0% | 0% | Verde |  |  |  |  |  |
| 2271 | 2.3.29.1.2.4 | Analisar e emitir resultado da licitação do projeto |  | 23d | 2019-08-16 | 2019-09-17 | 2270 |  |  | 2019-08-16 | 2019-09-17 | 23d |  |  | 1475d | 0d |  | Verde | Verde | 0% | 0% | Verde | 0% | 0% | Verde |  |  |  |  |  |
| 2272 | 2.3.29.1.2.5 | Licitação do projeto concluída | milestone | 0d | 2019-09-17 | 2019-09-17 | 2271 |  |  | 2019-09-17 | 2019-09-17 | 0d |  |  | 1475d | 0d |  | Verde | Verde | 0% | 0% | Verde | 0% | 0% | Verde |  |  |  |  |  |

Notes:
- 2249: Em 24/04/2019: banco encaminhará lista de documentos necessários ao município e município em 15 dias encaminhará tudo conforme conversar com Gislaine e Fernanda.
- 2259: Em 24/04/2019: valor da obra R$ 0,9 milhões
- 2263: Valor de recurso destinado ao munícipio: R$9.453.986,14
- 2264: Rio Casca teve 100% dos pleitos de Esgotamento Sanitário aprovado(R$7.087.789,81), conforme Deliberação 75. / O município não fez pleito de resíduos sólidos. / Vai pedir mudança de pleito, devido a uma grande enchente ocorrida no munícipio, que afetou as áreas destinadas à rede interceptora e uma elevatória. Com isto, vai pedir alteração do distrito de jurumirim para sede. / Será necessário fazer alteração de projeto já existente. / Na obra em curso, o recurso da Renova só será empregado após o uso do recurso da FUNASA e como só foi utilizado 20% deste recurso, o munícipio tem um prazo grande para dar entrada com este projeto
- 2266: Em 25/04/2019: o pleito será substituido dos distritos para a sede na próxima CT/CIF de maio dia 31/05/2019. Ofício 199/2019 enviado dia 27/02/2019.

| ID | WBS | Task | Type | Duration | Start | Finish | Predecessors | Baseline start | Baseline finish | Baseline duration | Baseline 1 start | Baseline 1 finish | Total slack | Free slack | Constraint | Farol de Atraso | Farol Marcos | % Previsto Tempo | Índice de Desempenho Físico (IDF) | Farol IDF | % Previsto Ponderado | % Concluído Ponderado | Responsável | Código do Contrato | Farol de Início |
| --- | --- | --- | --- | --- | --- | --- | --- | --- | --- | --- | --- | --- | --- | --- | --- | --- | --- | --- | --- | --- | --- | --- | --- | --- | --- |
| 2273 | 2.3.29.1.3 | **Elaboração do Projeto** |  | 116d | 2019-09-18 | 2020-03-09 |  | 2019-09-18 | 2020-03-09 | 116d |  |  | 1475d |  |  | Verde | Verde | 0% | 0% | Verde | 0% | 0% |  |  |  |
| 2274 | 2.3.29.1.3.1 | Elaborar Projeto |  | 44d | 2019-09-18 | 2019-11-19 | 2272 | 2019-09-18 | 2019-11-19 | 44d | 2019-04-06 | 2019-07-05 | 1475d | 0d |  | Verde | Verde | 0% | 0% | Verde | 0% | 0% | 02 - Execução | PG 031 | Verde |
| 2275 | 2.3.29.1.3.2 | Projeto apresentado ao banco | milestone | 0d | 2019-11-19 | 2019-11-19 | 2274 | 2019-11-19 | 2019-11-19 | 0d |  |  | 1475d | 0d |  | Verde | Verde | 0% | 0% | Verde | 0% | 0% |  |  | Verde |
| 2276 | 2.3.29.1.3.3 | Analisar projeto |  | 22d | 2019-11-20 | 2019-12-20 | 2275 | 2019-11-20 | 2019-12-20 | 22d |  |  | 1475d | 0d |  | Verde | Verde | 0% | 0% | Verde | 0% | 0% |  |  | Verde |
| 2277 | 2.3.29.1.3.4 | Adequar/revisar projeto |  | 22d | 2019-12-23 | 2020-01-24 | 2276 | 2019-12-23 | 2020-01-24 | 22d |  |  | 1475d | 0d |  | Verde | Verde | 0% | 0% | Verde | 0% | 0% |  |  | Verde |
| 2278 | 2.3.29.1.3.5 | Analisar projeto - final |  | 23d | 2020-01-27 | 2020-03-02 | 2277 | 2020-01-27 | 2020-03-02 | 23d |  |  | 1475d | 0d |  | Verde | Verde | 0% | 0% | Verde | 0% | 0% |  |  | Verde |
| 2279 | 2.3.29.1.3.6 | Projeto concluído | milestone | 0d | 2020-03-02 | 2020-03-02 | 2278 | 2020-03-02 | 2020-03-02 | 0d |  |  | 1475d | 0d |  | Verde | Verde | 0% | 0% | Verde | 0% | 0% |  |  | Verde |
| 2280 | 2.3.29.1.3.7 | Recurso do projeto do pleito RICESPJ01 repassado | milestone | 0d | 2020-03-09 | 2020-03-09 | 2279FS+5d | 2020-03-09 | 2020-03-09 | 0d |  |  | 1475d | 0d |  | Verde | Verde | 0% | 0% | Verde | 0% | 0% |  |  | Verde |
| 2281 | 2.3.29.1.4 | Pleito de Rio Casca a definir concluído | milestone | 0d | 2020-03-09 | 2020-03-09 | 2280 | 2020-03-09 | 2020-03-09 | 0d |  |  | 1475d |  |  | Verde | Verde | 0% | 0% | Verde | 0% | 0% |  |  | Verde |
| 2282 | 2.3.29.2 | **Pleito de Rio Casca a definir - Obra da Sede** |  | 554d | 2019-11-29 | 2022-02-21 |  | 2019-11-29 | 2022-02-21 | 554d |  |  | 986d |  |  | Verde | Verde | 0% | 0% | Verde | 0% | 0% |  |  |  |
| 2283 | 2.3.29.2.1 | Pleito aprovado | milestone | 0d | 2019-11-29 | 2019-11-29 |  | 2019-11-29 | 2019-11-29 | 0d |  |  | 986d | 0d | start no earlier than 2019-11-29 | Verde | Verde | 0% | 0% | Verde | 0% | 0% |  |  | Verde |
| 2284 | 2.3.29.2.2 | **Licitação da Obra** |  | 78d | 2019-12-13 | 2020-04-09 |  | 2019-12-13 | 2020-04-09 | 78d |  |  | 986d |  |  | Verde | Verde | 0% | 0% | Verde | 0% | 0% |  |  |  |
| 2285 | 2.3.29.2.2.1 | Licitação da obra autorizada pelo banco | milestone | 0d | 2019-12-13 | 2019-12-13 | 2283FS+10d | 2019-12-13 | 2019-12-13 | 0d |  |  | 986d | 0d |  | Verde | Verde | 0% | 0% | Verde | 0% | 0% |  |  | Verde |
| 2286 | 2.3.29.2.2.2 | Licitar Obra |  | 64d | 2019-12-16 | 2020-03-20 | 2285 | 2019-12-16 | 2020-03-20 | 64d | 2019-07-05 | 2019-11-02 | 986d | 0d |  | Verde | Verde | 0% | 0% | Verde | 0% | 0% | 02 - Execução | PG 031 | Verde |
| 2287 | 2.3.29.2.2.3 | Analisar e emitir resultado da licitação da obra |  | 14d | 2020-03-23 | 2020-04-09 | 2286 | 2020-03-23 | 2020-04-09 | 14d |  |  | 986d | 0d |  | Verde | Verde | 0% | 0% | Verde | 0% | 0% |  |  | Verde |
| 2288 | 2.3.29.2.2.4 | Licitação da obra concluída | milestone | 0d | 2020-04-09 | 2020-04-09 | 2287 | 2020-04-09 | 2020-04-09 | 0d |  |  | 986d | 0d |  | Verde | Verde | 0% | 0% | Verde | 0% | 0% |  |  | Verde |
| 2289 | 2.3.29.2.3 | Executar obra |  | 313d | 2020-05-13 | 2021-08-11 | 2288FS+20d | 2020-05-13 | 2021-08-11 | 313d |  |  | 986d | 0d |  | Verde | Verde | 0% | 0% | Verde | 0% | 0% |  |  | Verde |
| 2290 | 2.3.29.2.4 | Realizar processo de pré-operação |  | 128d | 2021-08-12 | 2022-02-14 | 2289 | 2021-08-12 | 2022-02-14 | 128d |  |  | 986d | 0d |  | Verde | Verde | 0% | 0% | Verde | 0% | 0% |  |  | Verde |
| 2291 | 2.3.29.2.5 | Recurso da obra parcelado repassado | milestone | 0d | 2022-02-21 | 2022-02-21 | 2290FS+5d | 2022-02-21 | 2022-02-21 | 0d |  |  | 986d | 0d |  | Verde | Verde | 0% | 0% | Verde | 0% | 0% |  |  | Verde |
| 2292 | 2.3.29.2.6 | Pleito a definir concluído | milestone | 0d | 2022-02-21 | 2022-02-21 | 2291 | 2022-02-21 | 2022-02-21 | 0d |  |  | 986d |  |  | Verde | Verde | 0% | 0% | Verde | 0% | 0% |  |  | Verde |
| 2293 | 2.3.29.3 | **Pleito RICESOB01 - Complementação de recursos de contrapartida para TC/PAC 0352/14** |  | 311d | 2019-12-31 | 2021-04-01 |  | 2019-12-31 | 2021-04-01 | 311d |  |  | 970d |  |  | Verde | Verde | 0% | 0% | Verde | 0% | 0% |  |  |  |
| 2294 | 2.3.29.3.1 | Executar obra |  | 178d | 2019-12-31 | 2020-09-16 |  | 2019-12-31 | 2020-09-16 | 178d |  |  | 970d | 0d | start no earlier than 2019-12-31 | Verde | Verde | 0% | 0% | Verde | 0% | 0% |  |  | Verde |
| 2295 | 2.3.29.3.2 | Realizar processo de pré-operação |  | 128d | 2020-09-17 | 2021-03-25 | 2294 | 2020-09-17 | 2021-03-25 | 128d |  |  | 970d | 0d |  | Verde | Verde | 0% | 0% | Verde | 0% | 0% |  |  | Verde |
| 2296 | 2.3.29.3.3 | Recurso da obra parcelado repassado | milestone | 0d | 2021-04-01 | 2021-04-01 | 2295FS+5d | 2021-04-01 | 2021-04-01 | 0d |  |  | 970d | 0d |  | Verde | Verde | 0% | 0% | Verde | 0% | 0% |  |  | Verde |
| 2297 | 2.3.29.3.4 | Pleito RICESOB01 concluído | milestone | 0d | 2021-04-01 | 2021-04-01 | 2296 | 2021-04-01 | 2021-04-01 | 0d |  |  | 970d |  |  | Verde | Verde | 0% | 0% | Verde | 0% | 0% |  |  | Verde |

Notes:
- 2283: Em 25/05/2019: o pleito deve ser apresentado e aprovado em novembro de 2019, visto que novembro, dezembro, janeiro e fevereiro não são passíveis de apresentação de pleito, ou seja, o pleito só seria aprovado em final de maio (NT33).
- 2289: Em 25/04/2019: valor da obra R$ 5 milhões
- 2294: Em 25/04/2019: obra está em andamento e sendo paga com o recurso da Funasa. Foi considerado que a Renova iniciará o pagamento da obra em 02/01/2020, com base no cálculo da duração da obra da Funasa. Em fevereiro de 2019 a obra estava com avanço de 40% (planilha plano de aceleração). Considerando que o recurso da Funasa é de 10,5 milhões, o que representa 20 meses de acordo com as premissas utilizadas nesse cronograma, 60% seriam mais 12 meses de obra. Portanto, a parte da obra com recurso Funasa será concluída em fevereiro de 2020.

| ID | WBS | Task | Type | Duration | Start | Finish | Predecessors | Complete | Remaining | Baseline start | Baseline finish | Baseline duration | Total slack | Free slack | Constraint | Farol de Atraso | Farol Marcos | % Previsto Tempo | % Concluída Numérico | % Previsto Tempo Numérico | Índice de Desempenho Físico (IDF) | IDF Numérico | Farol IDF | % Previsto Ponderado | % Previsto Ponderado Numérico | % Concluído Ponderado | % Concluído Ponderado Numérico | Farol de Início |
| --- | --- | --- | --- | --- | --- | --- | --- | --- | --- | --- | --- | --- | --- | --- | --- | --- | --- | --- | --- | --- | --- | --- | --- | --- | --- | --- | --- | --- |
| 2298 | 2.3.29.4 | **Pleito RICESAO01 - Contratação de assessoria técnica para acompanhamento técnico de obras do TC/PAC 0352/14** |  | 379d | 2018-06-15 A | 2019-12-11 |  | 48% | 196.61d | 2018-06-15 | 2019-12-11 | 379d | 1291d |  |  | Verde | Verde | 58% | 48 | 58 | 90% | 90 | Vermelho | 49% | 49 | 44% | 44 |  |
| 2299 | 2.3.29.4.1 | **Licitação da empresa de assessoria técnica** |  | 69d | 2018-06-15 A | 2018-09-19 A |  | 100% |  | 2018-06-15 | 2018-09-19 | 69d |  |  |  | Verde | Verde | 100% | 100 | 100 | 100% | 100 | Verde | 100% | 100 | 100% | 100 |  |
| 2300 | 2.3.29.4.1.1 | Licitação da empresa de assessoria técnica autorizada pelo banco | milestone | 0d | 2018-06-15 A | 2018-06-15 A |  | 100% |  | 2018-06-15 | 2018-06-15 | 0d |  |  | must start on 2018-06-15 | Verde | Verde | 100% | 100 | 100 | 0% |  | Vermelho | 100% | 100 | 0% |  | Verde |
| 2301 | 2.3.29.4.1.2 | Licitar empresa de assessoria técnica |  | 58d | 2018-06-15 A | 2018-09-04 A | 2300 | 100% |  | 2018-06-15 | 2018-09-04 | 58d |  |  |  | Verde | Verde | 100% | 100 | 100 | 100% | 100 | Verde | 100% | 100 | 100% | 100 | Verde |
| 2302 | 2.3.29.4.1.3 | Documentação de licitação apresentada ao banco | milestone | 0d | 2018-09-11 A | 2018-09-11 A | 2301FS+5d | 100% |  | 2018-09-11 | 2018-09-11 | 0d |  |  |  | Verde | Verde | 100% | 100 | 100 | 0% |  | Vermelho | 100% | 100 | 0% |  | Verde |
| 2303 | 2.3.29.4.1.4 | Analisar e emitir resultado da licitação da empresa de assessoria técnica |  | 6d | 2018-09-12 A | 2018-09-19 A | 2302 | 100% |  | 2018-09-12 | 2018-09-19 | 6d |  |  |  | Verde | Verde | 100% | 100 | 100 | 100% | 100 | Verde | 100% | 100 | 100% | 100 | Verde |
| 2304 | 2.3.29.4.1.5 | Licitação da empresa de assessoria técnica concluída | milestone | 0d | 2018-09-19 A | 2018-09-19 A | 2303 | 100% |  | 2018-09-19 | 2018-09-19 | 0d |  |  |  | Verde | Verde | 100% | 100 | 100 | 0% |  | Vermelho | 100% | 100 | 0% |  | Verde |
| 2305 | 2.3.29.4.2 | Contratar e executar serviço de assessoria técnica |  | 229d | 2018-12-21 A | 2019-12-04 | 2304FS+67d | 34% | 152d | 2018-12-21 | 2019-12-04 | 229d | 1291d | 0d |  | Verde | Verde | 36% | 34 | 36 | 83% | 83 | Vermelho | 36% | 36 | 30% | 30 | Verde |
| 2306 | 2.3.29.4.3 | Recurso de assessoria técnica repassado | milestone | 0d | 2019-12-11 | 2019-12-11 | 2305FS+5d |  |  | 2019-12-11 | 2019-12-11 | 0d | 1291d | 0d |  | Verde | Verde | 0% |  |  | 0% |  | Verde | 0% |  | 0% |  | Verde |
| 2307 | 2.3.29.4.4 | Pleito RICESAO01 concluído | milestone | 0d | 2019-12-11 | 2019-12-11 | 2306 |  |  | 2019-12-11 | 2019-12-11 | 0d | 1291d |  |  | Verde | Verde | 0% |  |  | 0% |  | Verde | 0% |  | 0% |  | Verde |
| 2308 | 2.3.29.5 | **Pleito de Rio Casca de Resíduos Sólidos a definir** |  | 1096d | 2019-08-30 | 2024-01-29 |  |  |  | 2019-08-30 | 2024-01-29 | 1096d | 508d |  |  | Verde | Verde | 0% |  |  | 0% |  | Verde | 0% |  | 0% |  |  |
| 2309 | 2.3.29.5.1 | Pleito aprovado | milestone | 0d | 2019-08-30 | 2019-08-30 | 393 |  |  | 2019-08-30 | 2019-08-30 | 0d | 508d | 0d |  | Verde | Verde | 0% |  |  | 0% |  | Verde | 0% |  | 0% |  | Verde |
| 2310 | 2.3.29.5.2 | Iniciar pleito |  | 1d | 2019-08-30 | 2019-08-30 | 2309 |  |  | 2019-08-30 | 2019-08-30 | 1d | 508d | 0d |  | Verde | Verde | 0% |  |  | 0% |  | Verde | 0% |  | 0% |  | Verde |
| 2311 | 2.3.29.5.3 | Pleito de Rio Casca de Resíduos Sólidos a definir concluído | milestone | 0d | 2024-01-29 | 2024-01-29 | 2310FS+1095d |  |  | 2024-01-29 | 2024-01-29 | 0d | 508d |  |  | Verde | Verde | 0% |  |  | 0% |  | Verde | 0% |  | 0% |  | Verde |
| 2312 | 2.3.29.6 | **Pleito RICESPJ01 - Elaboração de Projeto do sistema de esgotamento sanitário do vilarejo de Jurumirim** |  | 1d | 2019-05-31 | 2019-05-31 |  |  |  | 2019-05-31 | 2019-05-31 | 1d | 1426d |  |  | Verde | Verde | 0% |  |  | 0% |  | Verde | 0% |  | 0% |  |  |
| 2313 | 2.3.29.6.1 | Avaliar pleito |  | 1d | 2019-05-31 | 2019-05-31 |  |  |  | 2019-05-31 | 2019-05-31 | 1d | 1426d | 0d | start no earlier than 2019-05-31 | Verde | Verde | 0% |  |  | 0% |  | Verde | 0% |  | 0% |  | Verde |
| 2314 | 2.3.29.6.2 | Pleito RICESPJ01 concluído | milestone | 0d | 2019-05-31 | 2019-05-31 | 2313 |  |  | 2019-05-31 | 2019-05-31 | 0d | 1426d |  |  | Verde | Verde | 0% |  |  | 0% |  | Verde | 0% |  | 0% |  | Verde |
| 2315 | 2.3.29.7 | **Pleito RICESOB02 - Implantação de sistema de esgotamento sanitário do povoado de Vista Alegre** |  | 1d | 2019-05-31 | 2019-05-31 |  |  |  | 2019-05-31 | 2019-05-31 | 1d | 1426d |  |  | Verde | Verde | 0% |  |  | 0% |  | Verde | 0% |  | 0% |  |  |
| 2316 | 2.3.29.7.1 | Avaliar pleito |  | 1d | 2019-05-31 | 2019-05-31 |  |  |  | 2019-05-31 | 2019-05-31 | 1d | 1426d | 0d | start no earlier than 2019-05-31 | Verde | Verde | 0% |  |  | 0% |  | Verde | 0% |  | 0% |  | Verde |
| 2317 | 2.3.29.7.2 | Pleito RICESOB02 concluído | milestone | 0d | 2019-05-31 | 2019-05-31 | 2316 |  |  | 2019-05-31 | 2019-05-31 | 0d | 1426d |  |  | Verde | Verde | 0% |  |  | 0% |  | Verde | 0% |  | 0% |  | Verde |
| 2318 | 2.3.29.8 | **Pleito RICESOB03 - Implantação de sistema de esgotamento sanitário do vilarejo de Jurumirim** |  | 1d | 2019-05-31 | 2019-05-31 |  |  |  | 2019-05-31 | 2019-05-31 | 1d | 1426d |  |  | Verde | Verde | 0% |  |  | 0% |  | Verde | 0% |  | 0% |  |  |
| 2319 | 2.3.29.8.1 | Avaliar pleito |  | 1d | 2019-05-31 | 2019-05-31 |  |  |  | 2019-05-31 | 2019-05-31 | 1d | 1426d | 0d | start no earlier than 2019-05-31 | Verde | Verde | 0% |  |  | 0% |  | Verde | 0% |  | 0% |  | Verde |
| 2320 | 2.3.29.8.2 | Pleito RICESOB03 concluído | milestone | 0d | 2019-05-31 | 2019-05-31 | 2319 |  |  | 2019-05-31 | 2019-05-31 | 0d | 1426d |  |  | Verde | Verde | 0% |  |  | 0% |  | Verde | 0% |  | 0% |  | Verde |
| 2321 | 2.3.29.9 | **Pleito RICESAO02 - Contratação de assessoria técnica para apoio na obtenção de licença ambiental das ETEs do distrito de vista Alegre e Jurumirim** |  | 1d | 2019-05-31 | 2019-05-31 |  |  |  | 2019-05-31 | 2019-05-31 | 1d | 1426d |  |  | Verde | Verde | 0% |  |  | 0% |  | Verde | 0% |  | 0% |  |  |
| 2322 | 2.3.29.9.1 | Avaliar pleito |  | 1d | 2019-05-31 | 2019-05-31 |  |  |  | 2019-05-31 | 2019-05-31 | 1d | 1426d | 0d | start no earlier than 2019-05-31 | Verde | Verde | 0% |  |  | 0% |  | Verde | 0% |  | 0% |  | Verde |
| 2323 | 2.3.29.9.2 | Pleito RICESAO02 concluído | milestone | 0d | 2019-05-31 | 2019-05-31 | 2322 |  |  | 2019-05-31 | 2019-05-31 | 0d | 1426d |  |  | Verde | Verde | 0% |  |  | 0% |  | Verde | 0% |  | 0% |  | Verde |
| 2324 | 2.3.29.10 | Recursos de Rio Casca repassados | milestone | 0d | 2018-12-21 A | 2018-12-21 A | 2314, 2323, 2297, 2307, 2317, 2320, 2281, 2292, 2311 | 100% |  | 2018-12-21 | 2018-12-21 | 0d |  |  |  | Verde | Verde | 100% | 100 | 100 | 0% |  | Vermelho | 100% | 100 | 0% |  | Verde |

Notes:
- 2300: Em 25/04/2019: banco autorizou a licitação da empresa no dia 15/06/2018 conforme planilha controle gerencial Renova
- 2302: Em 25/04/2019: conforme planilha controle gerencial Renova o município protocolou a licitação no dia 11/09/2018
- 2304: Em 25/04/2019: conforme planilha controle gerencial Renova o banco autorizou a contratação da empresa no dia 19/09/2018
- 2305: 18/12/2018 - Municipio está avaliando se manterá o pleito de Vista Alegre e alterou a data para 15/01/2019 / Em 29/04/2019: atualizado como agendado
- 2313: Em 25/04/2019: o pleito será substituido dos distritos para a sede na próxima CT/CIF de maio dia 31/05/2019. Ofício 199/2019 enviado dia 27/02/2019.
- 2316: Em 25/04/2019: o pleito será substituido dos distritos para a sede na próxima CT/CIF de maio dia 31/05/2019. Ofício 199/2019 enviado dia 27/02/2019.
- 2319: Em 25/04/2019: o pleito será substituido dos distritos para a sede na próxima CT/CIF de maio dia 31/05/2019. Ofício 199/2019 enviado dia 27/02/2019.
- 2322: Em 25/04/2019: o pleito será substituido dos distritos para a sede na próxima CT/CIF de maio dia 31/05/2019. Ofício 199/2019 enviado dia 27/02/2019.
- 2324: Valor de recurso destinado ao munícipio: R$7.878.321,79

| ID | WBS | Task | Type | Duration | Start | Finish | Predecessors | Complete | Remaining | Baseline start | Baseline finish | Baseline duration | Baseline 1 start | Baseline 1 finish | Total slack | Free slack | Constraint | Farol de Atraso | Farol Marcos | % Previsto Tempo | Índice de Desempenho Físico (IDF) | IDF Numérico | Farol IDF | % Previsto Ponderado | % Concluído Ponderado | % Concluída Numérico | % Previsto Tempo Numérico | % Previsto Ponderado Numérico | % Concluído Ponderado Numérico | Farol de Início | Responsável | Código do Contrato |
| --- | --- | --- | --- | --- | --- | --- | --- | --- | --- | --- | --- | --- | --- | --- | --- | --- | --- | --- | --- | --- | --- | --- | --- | --- | --- | --- | --- | --- | --- | --- | --- | --- |
| 2325 | 2.3.30 | **Rio Doce** |  | 1214d | 2019-03-12 A | 2024-01-29 |  | 6% | 1145.44d | 2019-03-12 | 2024-01-29 | 1214d | 2019-03-11 | 2020-07-03 | 268d |  |  | Verde | Verde | 2% | 50% | 50 | Vermelho | 2% | 1% |  |  |  |  |  |  |  |
| 2326 | 2.3.30.1 | **Pleito RIDESOB01 - Construção de SES para o distrito de Matadouro** |  | 428d | 2019-03-12 A | 2020-11-26 |  | 8% | 393.6d | 2019-03-12 | 2020-11-26 | 428d |  |  | 1054d |  |  | Verde | Verde | 7% | 100% | 100 | Verde | 2% | 2% |  |  |  |  |  |  |  |
| 2327 | 2.3.30.1.1 | **Aprovação do Projeto** |  | 86d | 2019-03-12 A | 2019-07-15 |  | 40% | 52d | 2019-03-12 | 2019-07-15 | 86d |  |  | 1054d |  |  | Verde | Verde | 39% | 88% | 88 | Vermelho | 25% | 22% | 40 | 39 | 25 | 22 |  |  |  |
| 2328 | 2.3.30.1.1.1 | Projeto apresentado ao banco | milestone | 0d | 2019-03-12 A | 2019-03-12 A |  | 100% |  | 2019-03-12 | 2019-03-12 | 0d |  |  |  |  | must start on 2019-03-12 | Verde | Verde | 100% | 0% |  | Vermelho | 100% | 0% | 100 | 100 | 100 |  | Verde |  |  |
| 2329 | 2.3.30.1.1.2 | Analisar projeto |  | 45d | 2019-03-12 A | 2019-05-16 | 2328 | 76% | 11d | 2019-03-12 | 2019-05-16 | 45d |  |  | 1054d | 0d |  | Verde | Verde | 75% | 89% | 89 | Vermelho | 75% | 67% | 76 | 75 | 75 | 67 | Verde |  |  |
| 2330 | 2.3.30.1.1.3 | Adequar/revisar projeto |  | 20d | 2019-05-17 | 2019-06-13 | 2329 |  |  | 2019-05-17 | 2019-06-13 | 20d |  |  | 1054d | 0d |  | Verde | Verde | 0% | 0% |  | Verde | 0% | 0% |  |  |  |  | Verde |  |  |
| 2331 | 2.3.30.1.1.4 | Analisar projeto - final |  | 21d | 2019-06-14 | 2019-07-15 | 2330 |  |  | 2019-06-14 | 2019-07-15 | 21d |  |  | 1054d | 0d |  | Verde | Verde | 0% | 0% |  | Verde | 0% | 0% |  |  |  |  | Verde |  |  |
| 2332 | 2.3.30.1.1.5 | Projeto aprovado | milestone | 0d | 2019-07-15 | 2019-07-15 | 2331 |  |  | 2019-07-15 | 2019-07-15 | 0d |  |  | 1054d | 0d |  | Verde | Verde | 0% | 0% |  | Verde | 0% | 0% |  |  |  |  | Verde |  |  |
| 2333 | 2.3.30.1.2 | **Licitação da Obra** |  | 80d | 2019-07-15 | 2019-11-05 |  |  |  | 2019-07-15 | 2019-11-05 | 80d |  |  | 1054d |  |  | Verde | Verde | 0% | 0% |  | Verde | 0% | 0% |  |  |  |  |  |  |  |
| 2334 | 2.3.30.1.2.1 | Licitação da obra autorizada pelo banco | milestone | 0d | 2019-07-15 | 2019-07-15 | 2332 |  |  | 2019-07-15 | 2019-07-15 | 0d |  |  | 1054d | 0d |  | Verde | Verde | 0% | 0% |  | Verde | 0% | 0% |  |  |  |  | Verde |  |  |
| 2335 | 2.3.30.1.2.2 | Licitar Obra |  | 66d | 2019-07-16 | 2019-10-16 | 2334 |  |  | 2019-07-16 | 2019-10-16 | 66d | 2019-03-11 | 2019-07-09 | 1054d | 0d |  | Verde | Verde | 0% | 0% |  | Verde | 0% | 0% |  |  |  |  | Verde | 02 - Execução | PG 031 |
| 2336 | 2.3.30.1.2.3 | Analisar e emitir resultado da licitação da obra |  | 14d | 2019-10-17 | 2019-11-05 | 2335 |  |  | 2019-10-17 | 2019-11-05 | 14d |  |  | 1054d | 0d |  | Verde | Verde | 0% | 0% |  | Verde | 0% | 0% |  |  |  |  | Verde |  |  |
| 2337 | 2.3.30.1.2.4 | Licitação da obra concluída | milestone | 0d | 2019-11-05 | 2019-11-05 | 2336 |  |  | 2019-11-05 | 2019-11-05 | 0d |  |  | 1054d | 0d |  | Verde | Verde | 0% | 0% |  | Verde | 0% | 0% |  |  |  |  | Verde |  |  |
| 2338 | 2.3.30.1.3 | Executar obra |  | 128d | 2019-11-06 | 2020-05-18 | 2337 |  |  | 2019-11-06 | 2020-05-18 | 128d |  |  | 1054d | 0d |  | Verde | Verde | 0% | 0% |  | Verde | 0% | 0% |  |  |  |  | Verde |  |  |
| 2339 | 2.3.30.1.4 | Realizar processo de pré-operação |  | 129d | 2020-05-19 | 2020-11-19 | 2338 |  |  | 2020-05-19 | 2020-11-19 | 129d | 2020-01-05 | 2020-07-03 | 1054d | 0d |  | Verde | Verde | 0% | 0% |  | Verde | 0% | 0% |  |  |  |  | Verde | 02 - Execução | PG 031 |
| 2340 | 2.3.30.1.5 | Recurso da obra parcelado repassado | milestone | 0d | 2020-11-26 | 2020-11-26 | 2339FS+5d |  |  | 2020-11-26 | 2020-11-26 | 0d |  |  | 1054d | 0d |  | Verde | Verde | 0% | 0% |  | Verde | 0% | 0% |  |  |  |  | Verde |  |  |
| 2341 | 2.3.30.1.6 | Pleito RIDESOB01 concluído | milestone | 0d | 2020-11-26 | 2020-11-26 | 2340 |  |  | 2020-11-26 | 2020-11-26 | 0d |  |  | 1054d | 786d |  | Verde | Verde | 0% | 0% |  | Verde | 0% | 0% |  |  |  |  | Verde |  |  |
| 2342 | 2.3.30.2 | **Pleito RIDESOB02 - Construção de SES para o distrito de Jorge** |  | 406d | 2019-03-12 A | 2020-10-26 |  | 9% | 369.67d | 2019-03-12 | 2020-10-26 | 406d |  |  | 1076d |  |  | Verde | Verde | 8% | 100% | 100 | Verde | 2% | 2% |  |  |  |  |  |  |  |
| 2343 | 2.3.30.2.1 | **Aprovação do Projeto** |  | 86d | 2019-03-12 A | 2019-07-15 |  | 40% | 52d | 2019-03-12 | 2019-07-15 | 86d |  |  | 1076d |  |  | Verde | Verde | 39% | 88% | 88 | Vermelho | 25% | 22% | 40 | 39 | 25 | 22 |  |  |  |
| 2344 | 2.3.30.2.1.1 | Projeto apresentado ao banco | milestone | 0d | 2019-03-12 A | 2019-03-12 A | 2328 | 100% |  | 2019-03-12 | 2019-03-12 | 0d |  |  |  |  |  | Verde | Verde | 100% | 0% |  | Vermelho | 100% | 0% | 100 | 100 | 100 |  | Verde |  |  |
| 2345 | 2.3.30.2.1.2 | Analisar projeto |  | 45d | 2019-03-12 A | 2019-05-16 | 2344 | 76% | 11d | 2019-03-12 | 2019-05-16 | 45d |  |  | 1076d | 0d |  | Verde | Verde | 75% | 89% | 89 | Vermelho | 75% | 67% | 76 | 75 | 75 | 67 | Verde |  |  |
| 2346 | 2.3.30.2.1.3 | Adequar/revisar projeto |  | 20d | 2019-05-17 | 2019-06-13 | 2345 |  |  | 2019-05-17 | 2019-06-13 | 20d |  |  | 1076d | 0d |  | Verde | Verde | 0% | 0% |  | Verde | 0% | 0% |  |  |  |  | Verde |  |  |
| 2347 | 2.3.30.2.1.4 | Analisar projeto - final |  | 21d | 2019-06-14 | 2019-07-15 | 2346 |  |  | 2019-06-14 | 2019-07-15 | 21d |  |  | 1076d | 0d |  | Verde | Verde | 0% | 0% |  | Verde | 0% | 0% |  |  |  |  | Verde |  |  |
| 2348 | 2.3.30.2.1.5 | Projeto aprovado | milestone | 0d | 2019-07-15 | 2019-07-15 | 2347 |  |  | 2019-07-15 | 2019-07-15 | 0d |  |  | 1076d | 0d |  | Verde | Verde | 0% | 0% |  | Verde | 0% | 0% |  |  |  |  | Verde |  |  |

Notes:
- 2325: Rio Doce pediu 82% (R$2.180.814,79) dos 90% de recursos destinado para Esgotamento Sanitário e teve todo o pleito aprovado, conforme Deliberação 75. / Não fez pleitos de resíduos sólidos. (10% do total do recurso destinado ao munícipio).
- 2328: Em 25/04/2019: o projeto foi protocolado no banco pelo município no dia 12/03/2019 conforme planilha controle gerencial Renova
- 2329: Em 25/04/2019: conforme planilha controle gerencial Renova o banco cobrou pendências do projeto no dia 02/04/2019. Considerado mais 1 mês e meio para resolução da análise ou solicitação de revisão. / Em 29/04/2019: atualizado como agendado
- 2338: Em 25/04/2019: valor da obra R$ 839 mil
- 2345: Em 29/04/2019: atualizado como agendado

| ID | WBS | Task | Type | Duration | Start | Finish | Predecessors | Baseline start | Baseline finish | Baseline duration | Total slack | Free slack | Constraint | Farol de Atraso | Farol Marcos | % Previsto Tempo | Índice de Desempenho Físico (IDF) | Farol IDF | % Previsto Ponderado | % Concluído Ponderado | Farol de Início |
| --- | --- | --- | --- | --- | --- | --- | --- | --- | --- | --- | --- | --- | --- | --- | --- | --- | --- | --- | --- | --- | --- |
| 2349 | 2.3.30.2.2 | **Licitação da Obra** |  | 37d | 2019-07-15 | 2019-09-05 |  | 2019-07-15 | 2019-09-05 | 37d | 1076d |  |  | Verde | Verde | 0% | 0% | Verde | 0% | 0% |  |
| 2350 | 2.3.30.2.2.1 | Licitação da obra autorizada pelo banco | milestone | 0d | 2019-07-15 | 2019-07-15 | 2348 | 2019-07-15 | 2019-07-15 | 0d | 1076d | 0d |  | Verde | Verde | 0% | 0% | Verde | 0% | 0% | Verde |
| 2351 | 2.3.30.2.2.2 | Licitar Obra |  | 23d | 2019-07-16 | 2019-08-16 | 2350 | 2019-07-16 | 2019-08-16 | 23d | 1076d | 0d |  | Verde | Verde | 0% | 0% | Verde | 0% | 0% | Verde |
| 2352 | 2.3.30.2.2.3 | Analisar e emitir resultado da licitação da obra |  | 14d | 2019-08-19 | 2019-09-05 | 2351 | 2019-08-19 | 2019-09-05 | 14d | 1076d | 0d |  | Verde | Verde | 0% | 0% | Verde | 0% | 0% | Verde |
| 2353 | 2.3.30.2.2.4 | Licitação da obra concluída | milestone | 0d | 2019-09-05 | 2019-09-05 | 2352 | 2019-09-05 | 2019-09-05 | 0d | 1076d | 0d |  | Verde | Verde | 0% | 0% | Verde | 0% | 0% | Verde |
| 2354 | 2.3.30.2.3 | Executar obra |  | 128d | 2019-10-07 | 2020-04-14 | 2353FS+21d | 2019-10-07 | 2020-04-14 | 128d | 1076d | 0d |  | Verde | Verde | 0% | 0% | Verde | 0% | 0% | Verde |
| 2355 | 2.3.30.2.4 | Realizar processo de pré-operação |  | 129d | 2020-04-15 | 2020-10-19 | 2354 | 2020-04-15 | 2020-10-19 | 129d | 1076d | 0d |  | Verde | Verde | 0% | 0% | Verde | 0% | 0% | Verde |
| 2356 | 2.3.30.2.5 | Recurso da obra parcelado repassado | milestone | 0d | 2020-10-26 | 2020-10-26 | 2355FS+5d | 2020-10-26 | 2020-10-26 | 0d | 1076d | 0d |  | Verde | Verde | 0% | 0% | Verde | 0% | 0% | Verde |
| 2357 | 2.3.30.2.6 | Pleito RIDESOB02 concluído | milestone | 0d | 2020-10-26 | 2020-10-26 | 2356 | 2020-10-26 | 2020-10-26 | 0d | 1076d | 808d |  | Verde | Verde | 0% | 0% | Verde | 0% | 0% | Verde |
| 2358 | 2.3.30.3 | **Pleito RIDESOB03 - Construção de SES para o distrito de São José de Entre Montes** |  | 427d | 2019-05-31 | 2021-02-18 |  | 2019-05-31 | 2021-02-18 | 427d | 1000d |  |  | Verde | Verde | 0% | 0% | Verde | 0% | 0% |  |
| 2359 | 2.3.30.3.1 | **Elaboração do Projeto** |  | 63d | 2019-05-31 | 2019-08-29 |  | 2019-05-31 | 2019-08-29 | 63d | 1000d |  |  | Verde | Verde | 0% | 0% | Verde | 0% | 0% |  |
| 2360 | 2.3.30.3.1.1 | Projeto apresentado ao banco | milestone | 0d | 2019-05-31 | 2019-05-31 |  | 2019-05-31 | 2019-05-31 | 0d | 1000d | 0d | start no earlier than 2019-05-31 | Verde | Verde | 0% | 0% | Verde | 0% | 0% | Verde |
| 2361 | 2.3.30.3.1.2 | Analisar projeto |  | 22d | 2019-05-31 | 2019-07-02 | 2360 | 2019-05-31 | 2019-07-02 | 22d | 1000d | 0d |  | Verde | Verde | 0% | 0% | Verde | 0% | 0% | Verde |
| 2362 | 2.3.30.3.1.3 | Adequar/revisar projeto |  | 20d | 2019-07-03 | 2019-07-30 | 2361 | 2019-07-03 | 2019-07-30 | 20d | 1000d | 0d |  | Verde | Verde | 0% | 0% | Verde | 0% | 0% | Verde |
| 2363 | 2.3.30.3.1.4 | Analisar projeto - final |  | 21d | 2019-07-31 | 2019-08-29 | 2362 | 2019-07-31 | 2019-08-29 | 21d | 1000d | 0d |  | Verde | Verde | 0% | 0% | Verde | 0% | 0% | Verde |
| 2364 | 2.3.30.3.1.5 | Projeto concluído | milestone | 0d | 2019-08-29 | 2019-08-29 | 2363 | 2019-08-29 | 2019-08-29 | 0d | 1000d | 0d |  | Verde | Verde | 0% | 0% | Verde | 0% | 0% | Verde |
| 2365 | 2.3.30.3.2 | **Licitação da Obra** |  | 80d | 2019-08-29 | 2019-12-23 |  | 2019-08-29 | 2019-12-23 | 80d | 1000d |  |  | Verde | Verde | 0% | 0% | Verde | 0% | 0% |  |
| 2366 | 2.3.30.3.2.1 | Licitação da obra autorizada pelo banco | milestone | 0d | 2019-08-29 | 2019-08-29 | 2364 | 2019-08-29 | 2019-08-29 | 0d | 1000d | 0d |  | Verde | Verde | 0% | 0% | Verde | 0% | 0% | Verde |
| 2367 | 2.3.30.3.2.2 | Licitar Obra |  | 66d | 2019-08-30 | 2019-12-02 | 2366 | 2019-08-30 | 2019-12-02 | 66d | 1000d | 0d |  | Verde | Verde | 0% | 0% | Verde | 0% | 0% | Verde |
| 2368 | 2.3.30.3.2.3 | Analisar e emitir resultado da licitação da obra |  | 14d | 2019-12-03 | 2019-12-23 | 2367 | 2019-12-03 | 2019-12-23 | 14d | 1000d | 0d |  | Verde | Verde | 0% | 0% | Verde | 0% | 0% | Verde |
| 2369 | 2.3.30.3.2.4 | Licitação da obra concluída | milestone | 0d | 2019-12-23 | 2019-12-23 | 2368 | 2019-12-23 | 2019-12-23 | 0d | 1000d | 0d |  | Verde | Verde | 0% | 0% | Verde | 0% | 0% | Verde |
| 2370 | 2.3.30.3.3 | Executar obra |  | 128d | 2020-01-28 | 2020-08-03 | 2369FS+22d | 2020-01-28 | 2020-08-03 | 128d | 1000d | 0d |  | Verde | Verde | 0% | 0% | Verde | 0% | 0% | Verde |
| 2371 | 2.3.30.3.4 | Realizar processo de pré-operação |  | 129d | 2020-08-04 | 2021-02-08 | 2370 | 2020-08-04 | 2021-02-08 | 129d | 1000d | 0d |  | Verde | Verde | 0% | 0% | Verde | 0% | 0% | Verde |
| 2372 | 2.3.30.3.5 | Recurso da obra parcelado repassado | milestone | 0d | 2021-02-18 | 2021-02-18 | 2371FS+5d | 2021-02-18 | 2021-02-18 | 0d | 1000d | 0d |  | Verde | Verde | 0% | 0% | Verde | 0% | 0% | Verde |
| 2373 | 2.3.30.3.6 | Pleito RIDESOB03 concluído | milestone | 0d | 2021-02-18 | 2021-02-18 | 2372 | 2021-02-18 | 2021-02-18 | 0d | 1000d | 732d |  | Verde | Verde | 0% | 0% | Verde | 0% | 0% | Verde |

Notes:
- 2360: Em 25/04/2019: o município não apresentou o projeto ao banco, foi considerado que o projeto será apresentado dia 31/05/2019.

| ID | WBS | Task | Type | Duration | Start | Finish | Predecessors | Baseline start | Baseline finish | Baseline duration | Baseline 1 start | Baseline 1 finish | Total slack | Free slack | Constraint | Farol de Atraso | Farol Marcos | % Previsto Tempo | Índice de Desempenho Físico (IDF) | Farol IDF | % Previsto Ponderado | % Concluído Ponderado | Farol de Início | Responsável | Código do Contrato |
| --- | --- | --- | --- | --- | --- | --- | --- | --- | --- | --- | --- | --- | --- | --- | --- | --- | --- | --- | --- | --- | --- | --- | --- | --- | --- |
| 2374 | 2.3.30.4 | **Pleito de Rio Doce de Resíduos Sólidos** |  | 1096d | 2019-08-30 | 2024-01-29 |  | 2019-08-30 | 2024-01-29 | 1096d |  |  | 268d |  |  | Verde | Verde | 0% | 0% | Verde | 0% | 0% |  |  |  |
| 2375 | 2.3.30.4.1 | Pleito aprovado | milestone | 0d | 2019-08-30 | 2019-08-30 | 393 | 2019-08-30 | 2019-08-30 | 0d |  |  | 268d | 0d |  | Verde | Verde | 0% | 0% | Verde | 0% | 0% | Verde |  |  |
| 2376 | 2.3.30.4.2 | Iniciar pleito |  | 1d | 2019-08-30 | 2019-08-30 | 2375 | 2019-08-30 | 2019-08-30 | 1d |  |  | 268d | 0d |  | Verde | Verde | 0% | 0% | Verde | 0% | 0% | Verde |  |  |
| 2377 | 2.3.30.4.3 | Pleito concluído | milestone | 0d | 2024-01-29 | 2024-01-29 | 2376FS+1095d | 2024-01-29 | 2024-01-29 | 0d |  |  | 268d | 0d |  | Verde | Verde | 0% | 0% | Verde | 0% | 0% | Verde |  |  |
| 2378 | 2.3.30.5 | Recursos de Rio Doce repassados | milestone | 0d | 2024-01-29 | 2024-01-29 | 2341, 2357, 2373, 2377 | 2024-01-29 | 2024-01-29 | 0d | 2019-08-08 | 2020-07-03 | 268d |  |  | Verde | Verde | 0% | 0% | Verde | 0% | 0% | Verde | 02 - Execução | PG 031 |
| 2379 | 2.3.31 | **Santa Cruz do Escalvado** |  | 1096d | 2019-08-30 | 2024-01-29 |  | 2019-08-30 | 2024-01-29 | 1096d | 2018-10-30 | 2021-06-25 | 0d |  |  | Verde | Verde | 0% | 0% | Verde | 0% | 0% |  |  |  |
| 2380 | 2.3.31.1 | **Pleito SCEESPJ01 - Elaboração de projetos de engenharia para a sede do município, distritos de Nova Soberbo e Zito Soares, povoados de São José da Vargem Alegre e Sagrado Coração de Jesus e outras 32 comunidades rurais** |  | 349d | 2019-08-30 | 2021-01-25 |  | 2019-08-30 | 2021-01-25 | 349d |  |  | 0d |  |  | Verde | Verde | 0% | 0% | Verde | 0% | 0% |  |  |  |
| 2381 | 2.3.31.1.1 | Alteração do pleito aprovada | milestone | 0d | 2019-08-30 | 2019-08-30 |  | 2019-08-30 | 2019-08-30 | 0d |  |  | 0d |  | must start on 2019-08-30 | Verde | Verde | 0% | 0% | Verde | 0% | 0% | Verde |  |  |
| 2382 | 2.3.31.1.2 | **Licitação do Projeto** |  | 61d | 2019-08-30 | 2019-11-25 |  | 2019-08-30 | 2019-11-25 | 61d |  |  | 544d |  |  | Verde | Verde | 0% | 0% | Verde | 0% | 0% |  |  |  |
| 2383 | 2.3.31.1.2.1 | Licitação do projeto autorizada pelo banco | milestone | 0d | 2019-08-30 | 2019-08-30 | 2381 | 2019-08-30 | 2019-08-30 | 0d |  |  | 544d | 0d |  | Verde | Verde | 0% | 0% | Verde | 0% | 0% | Verde |  |  |
| 2384 | 2.3.31.1.2.2 | Licitar projeto |  | 42d | 2019-08-30 | 2019-10-28 | 2383 | 2019-08-30 | 2019-10-28 | 42d | 2018-10-30 | 2019-02-27 | 544d | 0d |  | Verde | Verde | 0% | 0% | Verde | 0% | 0% | Verde | 02 - Execução | PG 031 |
| 2385 | 2.3.31.1.2.3 | Documentação de licitação apresentada ao banco | milestone | 0d | 2019-11-04 | 2019-11-04 | 2384FS+5d | 2019-11-04 | 2019-11-04 | 0d |  |  | 544d | 0d |  | Verde | Verde | 0% | 0% | Verde | 0% | 0% | Verde |  |  |
| 2386 | 2.3.31.1.2.4 | Analisar e emitir resultado da licitação do projeto |  | 14d | 2019-11-05 | 2019-11-25 | 2385 | 2019-11-05 | 2019-11-25 | 14d |  |  | 544d | 0d |  | Verde | Verde | 0% | 0% | Verde | 0% | 0% | Verde |  |  |
| 2387 | 2.3.31.1.2.5 | Licitação do projeto concluída | milestone | 0d | 2019-11-25 | 2019-11-25 | 2386 | 2019-11-25 | 2019-11-25 | 0d |  |  | 544d | 0d |  | Verde | Verde | 0% | 0% | Verde | 0% | 0% | Verde |  |  |
| 2388 | 2.3.31.1.3 | **Elaboração do Projeto Básico** |  | 136d | 2019-11-26 | 2020-06-17 |  | 2019-11-26 | 2020-06-17 | 136d |  |  | 544d |  |  | Verde | Verde | 0% | 0% | Verde | 0% | 0% |  |  |  |
| 2389 | 2.3.31.1.3.1 | Elaborar Projeto Básico |  | 64d | 2019-11-26 | 2020-03-03 | 2387 | 2019-11-26 | 2020-03-03 | 64d | 2019-02-27 | 2019-04-28 | 544d | 0d |  | Verde | Verde | 0% | 0% | Verde | 0% | 0% | Verde | 02 - Execução | PG 031 |
| 2390 | 2.3.31.1.3.2 | Projeto básico apresentado ao banco | milestone | 0d | 2020-03-03 | 2020-03-03 | 2389 | 2020-03-03 | 2020-03-03 | 0d |  |  | 544d | 0d |  | Verde | Verde | 0% | 0% | Verde | 0% | 0% | Verde |  |  |
| 2391 | 2.3.31.1.3.3 | Analisar projeto básico |  | 21d | 2020-03-04 | 2020-04-01 | 2390 | 2020-03-04 | 2020-04-01 | 21d |  |  | 544d | 0d |  | Verde | Verde | 0% | 0% | Verde | 0% | 0% | Verde |  |  |
| 2392 | 2.3.31.1.3.4 | Adequar/revisar projeto básico |  | 23d | 2020-04-02 | 2020-05-07 | 2391 | 2020-04-02 | 2020-05-07 | 23d |  |  | 544d | 0d |  | Verde | Verde | 0% | 0% | Verde | 0% | 0% | Verde |  |  |
| 2393 | 2.3.31.1.3.5 | Analisar projeto básico - final |  | 23d | 2020-05-08 | 2020-06-09 | 2392 | 2020-05-08 | 2020-06-09 | 23d |  |  | 544d | 0d |  | Verde | Verde | 0% | 0% | Verde | 0% | 0% | Verde |  |  |
| 2394 | 2.3.31.1.3.6 | Projeto básico concluído | milestone | 0d | 2020-06-09 | 2020-06-09 | 2393 | 2020-06-09 | 2020-06-09 | 0d |  |  | 544d | 0d |  | Verde | Verde | 0% | 0% | Verde | 0% | 0% | Verde |  |  |
| 2395 | 2.3.31.1.3.7 | Recurso do projeto básico do pleito SCEESPJ01 repassado | milestone | 0d | 2020-06-17 | 2020-06-17 | 2394FS+5d | 2020-06-17 | 2020-06-17 | 0d |  |  | 691d | 147d |  | Verde | Verde | 0% | 0% | Verde | 0% | 0% | Verde |  |  |
| 2396 | 2.3.31.1.4 | Realizar Licenciamento Ambiental |  | 147d | 2019-08-30 | 2020-04-02 | 2383 | 2019-08-30 | 2020-04-02 | 147d | 2019-04-28 | 2019-10-25 | 741d | 197d |  | Verde | Verde | 0% | 0% | Verde | 0% | 0% | Verde | 02 - Execução | PG 031 |
| 2397 | 2.3.31.1.5 | **Elaboração do Projeto Executivo** |  | 157d | 2020-06-10 | 2021-01-25 |  | 2020-06-10 | 2021-01-25 | 157d |  |  | 544d |  |  | Verde | Verde | 0% | 0% | Verde | 0% | 0% |  |  |  |
| 2398 | 2.3.31.1.5.1 | Elaborar Projeto Executivo |  | 87d | 2020-06-10 | 2020-10-13 | 2394 | 2020-06-10 | 2020-10-13 | 87d | 2019-04-28 | 2019-08-26 | 544d | 0d |  | Verde | Verde | 0% | 0% | Verde | 0% | 0% | Verde | 02 - Execução | PG 031 |
| 2399 | 2.3.31.1.5.2 | Projeto executivo apresentado ao banco | milestone | 0d | 2020-10-13 | 2020-10-13 | 2398 | 2020-10-13 | 2020-10-13 | 0d |  |  | 544d | 0d |  | Verde | Verde | 0% | 0% | Verde | 0% | 0% | Verde |  |  |
| 2400 | 2.3.31.1.5.3 | Analisar projeto executivo |  | 21d | 2020-10-14 | 2020-11-12 | 2399 | 2020-10-14 | 2020-11-12 | 21d |  |  | 544d | 0d |  | Verde | Verde | 0% | 0% | Verde | 0% | 0% | Verde |  |  |
| 2401 | 2.3.31.1.5.4 | Adequar/revisar projeto executivo |  | 22d | 2020-11-13 | 2020-12-14 | 2400 | 2020-11-13 | 2020-12-14 | 22d |  |  | 544d | 0d |  | Verde | Verde | 0% | 0% | Verde | 0% | 0% | Verde |  |  |
| 2402 | 2.3.31.1.5.5 | Analisar projeto executivo - final |  | 22d | 2020-12-15 | 2021-01-18 | 2401 | 2020-12-15 | 2021-01-18 | 22d |  |  | 544d | 0d |  | Verde | Verde | 0% | 0% | Verde | 0% | 0% | Verde |  |  |
| 2403 | 2.3.31.1.5.6 | Projeto executivo concluído | milestone | 0d | 2021-01-18 | 2021-01-18 | 2395, 2402, 2396 | 2021-01-18 | 2021-01-18 | 0d |  |  | 544d | 0d |  | Verde | Verde | 0% | 0% | Verde | 0% | 0% | Verde |  |  |
| 2404 | 2.3.31.1.5.7 | Recurso do projeto executivo do pleito SCEESPJ01 repassado | milestone | 0d | 2021-01-25 | 2021-01-25 | 2403FS+5d | 2021-01-25 | 2021-01-25 | 0d |  |  | 544d | 0d |  | Verde | Verde | 0% | 0% | Verde | 0% | 0% | Verde |  |  |
| 2405 | 2.3.31.1.6 | Pleito SCEESPJ01 concluído | milestone | 0d | 2021-01-25 | 2021-01-25 | 2404 | 2021-01-25 | 2021-01-25 | 0d |  |  | 544d | 0d |  | Verde | Verde | 0% | 0% | Verde | 0% | 0% | Verde |  |  |

Notes:
- 2378: Valor de recurso destinado ao munícipio: R$2.661.115,58
- 2379: Santa Cruz do Escalvado teve 100% dos pleitos de Esgotamento Sanitário aprovado (R$4.254.293,75), conforme Deliberação 75. / O município teve o pleito de resíduos sólidos negado (R$472.699,31, equivalente a 10% do total do recurso). / O município ainda possui dúvidas se irá atender a todas localidades listadas no pleito atualmente aprovado pelo CIF. Munícipio deverá estabelecer as áreas prioritarias de atendimento do programa e rever o pleito.
- 2381: Em 25/04/2019: o município não enviou ofício de alteração de pleito até o momento, por isso considerou-se que o pleito será enviado no mês que vem e só será analisado pela CT/CIF em agosto conforme NT 33

| ID | WBS | Task | Type | Duration | Start | Finish | Predecessors | Complete | Remaining | Baseline start | Baseline finish | Baseline duration | Baseline 1 start | Baseline 1 finish | Total slack | Free slack | Farol de Atraso | Farol Marcos | % Previsto Tempo | Índice de Desempenho Físico (IDF) | Farol IDF | % Previsto Ponderado | % Concluído Ponderado | Farol de Início | Responsável | Código do Contrato | % Concluída Numérico | % Previsto Tempo Numérico | IDF Numérico | % Previsto Ponderado Numérico |
| --- | --- | --- | --- | --- | --- | --- | --- | --- | --- | --- | --- | --- | --- | --- | --- | --- | --- | --- | --- | --- | --- | --- | --- | --- | --- | --- | --- | --- | --- | --- |
| 2406 | 2.3.31.2 | **Pleito SCEESOB01 - Execução da obra dos SES que serão projetados com os recursos destinados à prioridade 1** |  | 471d | 2021-01-25 | 2022-12-16 |  |  |  | 2021-01-25 | 2022-12-16 | 471d |  |  | 544d |  | Verde | Verde | 0% | 0% | Verde | 0% | 0% |  |  |  |  |  |  |  |
| 2407 | 2.3.31.2.1 | **Licitação da Obra** |  | 79d | 2021-01-25 | 2021-05-21 |  |  |  | 2021-01-25 | 2021-05-21 | 79d |  |  | 544d |  | Verde | Verde | 0% | 0% | Verde | 0% | 0% |  |  |  |  |  |  |  |
| 2408 | 2.3.31.2.1.1 | Licitação da obra autorizada pelo banco | milestone | 0d | 2021-01-25 | 2021-01-25 | 2405 |  |  | 2021-01-25 | 2021-01-25 | 0d |  |  | 544d | 0d | Verde | Verde | 0% | 0% | Verde | 0% | 0% | Verde |  |  |  |  |  |  |
| 2409 | 2.3.31.2.1.2 | Licitar Obra |  | 65d | 2021-01-26 | 2021-05-03 | 2408 |  |  | 2021-01-26 | 2021-05-03 | 65d | 2019-08-26 | 2019-12-24 | 544d | 0d | Verde | Verde | 0% | 0% | Verde | 0% | 0% | Verde | 02 - Execução | PG 031 |  |  |  |  |
| 2410 | 2.3.31.2.1.3 | Analisar e emitir resultado da licitação da obra |  | 14d | 2021-05-04 | 2021-05-21 | 2409 |  |  | 2021-05-04 | 2021-05-21 | 14d |  |  | 544d | 0d | Verde | Verde | 0% | 0% | Verde | 0% | 0% | Verde |  |  |  |  |  |  |
| 2411 | 2.3.31.2.1.4 | Licitação da obra concluída | milestone | 0d | 2021-05-21 | 2021-05-21 | 2410 |  |  | 2021-05-21 | 2021-05-21 | 0d |  |  | 544d | 0d | Verde | Verde | 0% | 0% | Verde | 0% | 0% | Verde |  |  |  |  |  |  |
| 2412 | 2.3.31.2.2 | Executar obra |  | 257d | 2021-05-24 | 2022-06-01 | 2411 |  |  | 2021-05-24 | 2022-06-01 | 257d |  |  | 544d | 0d | Verde | Verde | 0% | 0% | Verde | 0% | 0% | Verde |  |  |  |  |  |  |
| 2413 | 2.3.31.2.3 | Realizar processo de pré-operação |  | 130d | 2022-06-02 | 2022-12-08 | 2412 |  |  | 2022-06-02 | 2022-12-08 | 130d | 2020-12-27 | 2021-06-25 | 544d | 0d | Verde | Verde | 0% | 0% | Verde | 0% | 0% | Verde | 02 - Execução | PG 031 |  |  |  |  |
| 2414 | 2.3.31.2.4 | Recurso da obra parcelado repassado | milestone | 0d | 2022-12-16 | 2022-12-16 | 2413FS+5d |  |  | 2022-12-16 | 2022-12-16 | 0d |  |  | 544d | 0d | Verde | Verde | 0% | 0% | Verde | 0% | 0% | Verde |  |  |  |  |  |  |
| 2415 | 2.3.31.2.5 | Pleito SCEESOB01 concluído | milestone | 0d | 2022-12-16 | 2022-12-16 | 2414 |  |  | 2022-12-16 | 2022-12-16 | 0d |  |  | 544d | 276d | Verde | Verde | 0% | 0% | Verde | 0% | 0% | Verde |  |  |  |  |  |  |
| 2416 | 2.3.31.3 | **Pleito de Santa Cruz do Escalvado de Resíduos Sólidos a definir** |  | 1096d | 2019-08-30 | 2024-01-29 |  |  |  | 2019-08-30 | 2024-01-29 | 1096d |  |  | 268d |  | Verde | Verde | 0% | 0% | Verde | 0% | 0% |  |  |  |  |  |  |  |
| 2417 | 2.3.31.3.1 | Pleito aprovado | milestone | 0d | 2019-08-30 | 2019-08-30 | 393 |  |  | 2019-08-30 | 2019-08-30 | 0d |  |  | 268d | 0d | Verde | Verde | 0% | 0% | Verde | 0% | 0% | Verde |  |  |  |  |  |  |
| 2418 | 2.3.31.3.2 | Iniciar pleito |  | 1d | 2019-08-30 | 2019-08-30 | 2417 |  |  | 2019-08-30 | 2019-08-30 | 1d |  |  | 268d | 0d | Verde | Verde | 0% | 0% | Verde | 0% | 0% | Verde |  |  |  |  |  |  |
| 2419 | 2.3.31.3.3 | Pleito concluído | milestone | 0d | 2024-01-29 | 2024-01-29 | 2418FS+1095d |  |  | 2024-01-29 | 2024-01-29 | 0d |  |  | 268d | 0d | Verde | Verde | 0% | 0% | Verde | 0% | 0% | Verde |  |  |  |  |  |  |
| 2420 | 2.3.31.4 | Recursos de Santa Cruz do Escalvado repassados | milestone | 0d | 2024-01-29 | 2024-01-29 | 2405, 2415, 2419 |  |  | 2024-01-29 | 2024-01-29 | 0d | 2019-05-28 | 2021-06-25 | 268d |  | Verde | Verde | 0% | 0% | Verde | 0% | 0% | Verde | 02 - Execução | PG 031 |  |  |  |  |
| 2421 | 2.3.32 | **Santana do Paraíso** |  | 1261d | 2018-08-22 A | 2023-09-12 |  | 11% | 1124.22d | 2018-08-22 | 2023-09-12 | 1261d | 2019-02-01 | 2022-11-19 | 361d |  | Verde | Verde | 13% | 100% | Verde | 2% | 2% |  |  |  | 11 | 13 | 100 |  |
| 2422 | 2.3.32.1 | **Pleito SAPESPJ01 - Elaboração/adequação de projetos de engenharia para a prestação dos serviços de esgotamento sanitário nas localidades de Córrego Bom Sucesso, Córrego Batinga, Comunidade Boa Vista, Córrego Monjolo, Córrego do Achado, Córrego do Coruja,** |  | 419d | 2019-04-23 | 2020-12-28 |  |  |  | 2019-04-23 | 2020-12-28 | 419d |  |  | 361d |  | Verde | Verde | 1% | 0% | Vermelho | 0% | 0% |  |  |  |  |  |  |  |
| 2423 | 2.3.32.1.1 | Alteração do pleito aprovada | milestone | 0d | 2019-04-23 | 2019-04-23 | 206FS+88d |  |  | 2019-04-23 | 2019-04-23 | 0d |  |  | 361d | 0d | Verde | Verde | 100% | 0% | Vermelho | 100% | 0% | Verde |  |  |  | 100 |  | 100 |
| 2424 | 2.3.32.1.2 | **Licitação do Projeto** |  | 85d | 2019-05-08 | 2019-09-06 |  |  |  | 2019-05-08 | 2019-09-06 | 85d |  |  | 361d |  | Verde | Verde | 0% | 0% | Verde | 0% | 0% |  |  |  |  |  |  |  |
| 2425 | 2.3.32.1.2.1 | Licitação do projeto autorizada pelo banco | milestone | 0d | 2019-05-08 | 2019-05-08 | 2423FS+10d |  |  | 2019-05-08 | 2019-05-08 | 0d |  |  | 361d | 0d | Verde | Verde | 0% | 0% | Verde | 0% | 0% | Verde |  |  |  |  |  |  |
| 2426 | 2.3.32.1.2.2 | Licitar projeto |  | 66d | 2019-05-09 | 2019-08-09 | 2425 |  |  | 2019-05-09 | 2019-08-09 | 66d | 2019-02-01 | 2019-05-02 | 361d | 0d | Verde | Verde | 0% | 0% | Verde | 0% | 0% | Verde |  |  |  |  |  |  |
| 2427 | 2.3.32.1.2.3 | Documentação de licitação apresentada ao banco | milestone | 0d | 2019-08-19 | 2019-08-19 | 2426FS+5d |  |  | 2019-08-19 | 2019-08-19 | 0d |  |  | 361d | 0d | Verde | Verde | 0% | 0% | Verde | 0% | 0% | Verde |  |  |  |  |  |  |
| 2428 | 2.3.32.1.2.4 | Analisar e emitir resultado da licitação do projeto |  | 14d | 2019-08-20 | 2019-09-06 | 2427 |  |  | 2019-08-20 | 2019-09-06 | 14d |  |  | 361d | 0d | Verde | Verde | 0% | 0% | Verde | 0% | 0% | Verde |  |  |  |  |  |  |
| 2429 | 2.3.32.1.2.5 | Licitação do projeto concluída | milestone | 0d | 2019-09-06 | 2019-09-06 | 2428 |  |  | 2019-09-06 | 2019-09-06 | 0d |  |  | 361d | 0d | Verde | Verde | 0% | 0% | Verde | 0% | 0% | Verde |  |  |  |  |  |  |

Notes:
- 2420: Valor de recurso destinado ao munícipio: R$4.726.993,07
- 2421: Santana do Paraíso teve 100% dos pleitos de Esgotamento Sanitário Aprovado (R$11.338.753,82), conforme Deliberação 75. / O município teve 2,4%, dos 10% do valor teto destinado a Resíduos Sólidos aprovado (R$300.000,00). / Santana do Paraíso solicitou mudança de pleito, mas ainda não foi autorizado pelo CIF. / · Substituição da execução do Sistema de Esgotamento Sanitário na Bacia do Córrego do Garrafa para Sede.
- 2423: Em 25/04/2019: pleito aprovado na deliberação 276 no dia 23/04/2019

| ID | WBS | Task | Type | Duration | Start | Finish | Predecessors | Baseline start | Baseline finish | Baseline duration | Baseline 1 start | Baseline 1 finish | Total slack | Free slack | Farol de Atraso | Farol Marcos | % Previsto Tempo | Índice de Desempenho Físico (IDF) | Farol IDF | % Previsto Ponderado | % Concluído Ponderado | Responsável | Código do Contrato | Farol de Início |
| --- | --- | --- | --- | --- | --- | --- | --- | --- | --- | --- | --- | --- | --- | --- | --- | --- | --- | --- | --- | --- | --- | --- | --- | --- |
| 2430 | 2.3.32.1.3 | **Elaboração do Projeto Básico** |  | 171d | 2019-09-09 | 2020-05-19 |  | 2019-09-09 | 2020-05-19 | 171d |  |  | 361d |  | Verde | Verde | 0% | 0% | Verde | 0% | 0% |  |  |  |
| 2431 | 2.3.32.1.3.1 | Elaborar Projeto Básico |  | 105d | 2019-09-09 | 2020-02-07 | 2429 | 2019-09-09 | 2020-02-07 | 105d | 2019-05-02 | 2019-07-31 | 361d | 0d | Verde | Verde | 0% | 0% | Verde | 0% | 0% | 02 - Execução | PG 031 | Verde |
| 2432 | 2.3.32.1.3.2 | Projeto básico apresentado ao banco | milestone | 0d | 2020-02-07 | 2020-02-07 | 2431 | 2020-02-07 | 2020-02-07 | 0d |  |  | 361d | 0d | Verde | Verde | 0% | 0% | Verde | 0% | 0% |  |  | Verde |
| 2433 | 2.3.32.1.3.3 | Analisar projeto básico |  | 19d | 2020-02-10 | 2020-03-10 | 2432 | 2020-02-10 | 2020-03-10 | 19d |  |  | 361d | 0d | Verde | Verde | 0% | 0% | Verde | 0% | 0% |  |  | Verde |
| 2434 | 2.3.32.1.3.4 | Adequar/revisar projeto básico |  | 21d | 2020-03-11 | 2020-04-08 | 2433 | 2020-03-11 | 2020-04-08 | 21d |  |  | 361d | 0d | Verde | Verde | 0% | 0% | Verde | 0% | 0% |  |  | Verde |
| 2435 | 2.3.32.1.3.5 | Analisar projeto básico - final |  | 21d | 2020-04-09 | 2020-05-12 | 2434 | 2020-04-09 | 2020-05-12 | 21d |  |  | 361d | 0d | Verde | Verde | 0% | 0% | Verde | 0% | 0% |  |  | Verde |
| 2436 | 2.3.32.1.3.6 | Projeto básico concluído | milestone | 0d | 2020-05-12 | 2020-05-12 | 2435 | 2020-05-12 | 2020-05-12 | 0d |  |  | 361d | 0d | Verde | Verde | 0% | 0% | Verde | 0% | 0% |  |  | Verde |
| 2437 | 2.3.32.1.3.7 | Recurso do projeto básico do pleito repassado | milestone | 0d | 2020-05-19 | 2020-05-19 | 2436FS+5d | 2020-05-19 | 2020-05-19 | 0d |  |  | 509d | 148d | Verde | Verde | 0% | 0% | Verde | 0% | 0% |  |  | Verde |
| 2438 | 2.3.32.1.4 | Realizar Licenciamento Ambiental |  | 161d | 2020-02-10 | 2020-10-01 | 2432 | 2020-02-10 | 2020-10-01 | 161d | 2019-07-31 | 2020-01-27 | 414d | 53d | Verde | Verde | 0% | 0% | Verde | 0% | 0% | 02 - Execução | PG 031 | Verde |
| 2439 | 2.3.32.1.5 | **Elaboração do Projeto Executivo** |  | 158d | 2020-05-13 | 2020-12-28 |  | 2020-05-13 | 2020-12-28 | 158d |  |  | 361d |  | Verde | Verde | 0% | 0% | Verde | 0% | 0% |  |  |  |
| 2440 | 2.3.32.1.5.1 | Elaborar Projeto Executivo |  | 86d | 2020-05-13 | 2020-09-11 | 2436 | 2020-05-13 | 2020-09-11 | 86d | 2019-07-31 | 2020-01-27 | 361d | 0d | Verde | Verde | 0% | 0% | Verde | 0% | 0% | 02 - Execução | PG 031 | Verde |
| 2441 | 2.3.32.1.5.2 | Projeto executivo apresentado ao banco | milestone | 0d | 2020-09-11 | 2020-09-11 | 2440 | 2020-09-11 | 2020-09-11 | 0d |  |  | 361d | 0d | Verde | Verde | 0% | 0% | Verde | 0% | 0% |  |  | Verde |
| 2442 | 2.3.32.1.5.3 | Analisar projeto executivo |  | 22d | 2020-09-14 | 2020-10-14 | 2441 | 2020-09-14 | 2020-10-14 | 22d |  |  | 361d | 0d | Verde | Verde | 0% | 0% | Verde | 0% | 0% |  |  | Verde |
| 2443 | 2.3.32.1.5.4 | Adequar/revisar projeto executivo |  | 23d | 2020-10-15 | 2020-11-17 | 2442 | 2020-10-15 | 2020-11-17 | 23d |  |  | 361d | 0d | Verde | Verde | 0% | 0% | Verde | 0% | 0% |  |  | Verde |
| 2444 | 2.3.32.1.5.5 | Analisar projeto executivo - final |  | 22d | 2020-11-18 | 2020-12-17 | 2443 | 2020-11-18 | 2020-12-17 | 22d |  |  | 361d | 0d | Verde | Verde | 0% | 0% | Verde | 0% | 0% |  |  | Verde |
| 2445 | 2.3.32.1.5.6 | Projeto executivo concluído | milestone | 0d | 2020-12-17 | 2020-12-17 | 2444, 2450, 2438, 2437 | 2020-12-17 | 2020-12-17 | 0d |  |  | 361d | 0d | Verde | Verde | 0% | 0% | Verde | 0% | 0% |  |  | Verde |
| 2446 | 2.3.32.1.5.7 | Recurso do projeto executivo do pleito SAPESOB01 repassado | milestone | 0d | 2020-12-28 | 2020-12-28 | 2445FS+5d | 2020-12-28 | 2020-12-28 | 0d |  |  | 361d | 0d | Verde | Verde | 0% | 0% | Verde | 0% | 0% |  |  | Verde |
| 2447 | 2.3.32.1.6 | Pleito SAPESPJ01 concluído | milestone | 0d | 2020-12-28 | 2020-12-28 | 2446 | 2020-12-28 | 2020-12-28 | 0d |  |  | 361d | 0d | Verde | Verde | 0% | 0% | Verde | 0% | 0% |  |  | Verde |
| 2448 | 2.3.32.2 | **Pleito Santana do Paraíso a definir - Aquisição de Terreno** |  | 136d | 2020-05-29 | 2020-12-11 |  | 2020-05-29 | 2020-12-11 | 136d |  |  | 365d |  | Verde | Verde | 0% | 0% | Verde | 0% | 0% |  |  |  |
| 2449 | 2.3.32.2.1 | Pleito aprovado | milestone | 0d | 2020-05-29 | 2020-05-29 | 2433FS+55d | 2020-05-29 | 2020-05-29 | 0d |  |  | 365d | 0d | Verde | Verde | 0% | 0% | Verde | 0% | 0% |  |  | Verde |
| 2450 | 2.3.32.2.2 | **Aquisição de Imóvel** |  | 126d | 2020-06-16 | 2020-12-11 |  | 2020-06-16 | 2020-12-11 | 126d |  |  | 365d | 4d | Verde | Verde | 0% | 0% | Verde | 0% | 0% |  |  |  |
| 2451 | 2.3.32.2.2.1 | Regularizar terreno e apresentar escritura ao banco |  | 78d | 2020-06-16 | 2020-10-02 | 2449FS+10d | 2020-06-16 | 2020-10-02 | 78d |  |  | 365d | 0d | Verde | Verde | 0% | 0% | Verde | 0% | 0% |  |  | Verde |
| 2452 | 2.3.32.2.2.2 | Analisar documentação do terreno |  | 10d | 2020-10-05 | 2020-10-19 | 2451 | 2020-10-05 | 2020-10-19 | 10d |  |  | 403d | 0d | Verde | Verde | 0% | 0% | Verde | 0% | 0% |  |  | Verde |
| 2453 | 2.3.32.2.2.3 | 50% do valor do imóvel repassado (1) | milestone | 0d | 2020-10-19 | 2020-10-19 | 2452 | 2020-10-19 | 2020-10-19 | 0d |  |  | 403d | 38d | Verde | Verde | 0% | 0% | Verde | 0% | 0% |  |  | Verde |
| 2454 | 2.3.32.2.2.4 | Registrar imóvel e apresentar documentação ao banco |  | 38d | 2020-10-05 | 2020-11-27 | 2451 | 2020-10-05 | 2020-11-27 | 38d |  |  | 365d | 0d | Verde | Verde | 0% | 0% | Verde | 0% | 0% |  |  | Verde |
| 2455 | 2.3.32.2.2.5 | Analisar documentação do terreno |  | 10d | 2020-11-30 | 2020-12-11 | 2454 | 2020-11-30 | 2020-12-11 | 10d |  |  | 365d | 0d | Verde | Verde | 0% | 0% | Verde | 0% | 0% |  |  | Verde |
| 2456 | 2.3.32.2.2.6 | 50% do valor do imóvel repassado (2) | milestone | 0d | 2020-12-11 | 2020-12-11 | 2455 | 2020-12-11 | 2020-12-11 | 0d |  |  | 365d | 0d | Verde | Verde | 0% | 0% | Verde | 0% | 0% |  |  | Verde |
| 2457 | 2.3.32.2.2.7 | Aquisição de imóvel concluída | milestone | 0d | 2020-12-11 | 2020-12-11 | 2456, 2453 | 2020-12-11 | 2020-12-11 | 0d |  |  | 365d | 0d | Verde | Verde | 0% | 0% | Verde | 0% | 0% |  |  | Verde |
| 2458 | 2.3.32.2.3 | Pleito a definir concluído | milestone | 0d | 2020-12-11 | 2020-12-11 | 2457 | 2020-12-11 | 2020-12-11 | 0d |  |  | 1043d | 682d | Verde | Verde | 0% | 0% | Verde | 0% | 0% |  |  | Verde |

Notes:
- 2449: Em 25/04/2019: pleito aprovado no final de maio de 2020 conforme NT 33.

| ID | WBS | Task | Type | Duration | Start | Finish | Predecessors | Complete | Remaining | Baseline start | Baseline finish | Baseline duration | Baseline 1 start | Baseline 1 finish | Total slack | Free slack | Farol de Atraso | Farol Marcos | % Previsto Tempo | Índice de Desempenho Físico (IDF) | Farol IDF | % Previsto Ponderado | % Concluído Ponderado | Farol de Início | % Concluída Numérico | % Previsto Tempo Numérico | IDF Numérico | % Previsto Ponderado Numérico | % Concluído Ponderado Numérico | Responsável | Código do Contrato |
| --- | --- | --- | --- | --- | --- | --- | --- | --- | --- | --- | --- | --- | --- | --- | --- | --- | --- | --- | --- | --- | --- | --- | --- | --- | --- | --- | --- | --- | --- | --- | --- |
| 2459 | 2.3.32.3 | **Pleito de Santana do Paraíso a definir - Obra de SES para área rural** |  | 691d | 2020-11-30 | 2023-09-12 |  |  |  | 2020-11-30 | 2023-09-12 | 691d |  |  | 361d |  | Verde | Verde | 0% | 0% | Verde | 0% | 0% |  |  |  |  |  |  |  |  |
| 2460 | 2.3.32.3.1 | Pleito aprovado | milestone | 0d | 2020-11-30 | 2020-11-30 | 206FS+489d |  |  | 2020-11-30 | 2020-11-30 | 0d |  |  | 369d | 8d | Verde | Verde | 0% | 0% | Verde | 0% | 0% | Verde |  |  |  |  |  |  |  |
| 2461 | 2.3.32.3.2 | **Licitação da Obra** |  | 80d | 2020-12-28 | 2021-04-27 |  |  |  | 2020-12-28 | 2021-04-27 | 80d |  |  | 361d |  | Verde | Verde | 0% | 0% | Verde | 0% | 0% |  |  |  |  |  |  |  |  |
| 2462 | 2.3.32.3.2.1 | Licitação da obra autorizada pelo banco | milestone | 0d | 2020-12-28 | 2020-12-28 | 2460FS+10d, 2447 |  |  | 2020-12-28 | 2020-12-28 | 0d |  |  | 361d | 0d | Verde | Verde | 0% | 0% | Verde | 0% | 0% | Verde |  |  |  |  |  |  |  |
| 2463 | 2.3.32.3.2.2 | Licitar Obra |  | 66d | 2020-12-29 | 2021-04-06 | 2462 |  |  | 2020-12-29 | 2021-04-06 | 66d |  |  | 361d | 0d | Verde | Verde | 0% | 0% | Verde | 0% | 0% | Verde |  |  |  |  |  |  |  |
| 2464 | 2.3.32.3.2.3 | Analisar e emitir resultado da licitação da obra |  | 14d | 2021-04-07 | 2021-04-27 | 2463 |  |  | 2021-04-07 | 2021-04-27 | 14d |  |  | 361d | 0d | Verde | Verde | 0% | 0% | Verde | 0% | 0% | Verde |  |  |  |  |  |  |  |
| 2465 | 2.3.32.3.2.4 | Licitação da obra concluída | milestone | 0d | 2021-04-27 | 2021-04-27 | 2464 |  |  | 2021-04-27 | 2021-04-27 | 0d |  |  | 361d | 0d | Verde | Verde | 0% | 0% | Verde | 0% | 0% | Verde |  |  |  |  |  |  |  |
| 2466 | 2.3.32.3.3 | Executar obra |  | 440d | 2021-05-26 | 2023-03-01 | 2465FS+20d |  |  | 2021-05-26 | 2023-03-01 | 440d |  |  | 361d | 0d | Verde | Verde | 0% | 0% | Verde | 0% | 0% | Verde |  |  |  |  |  |  |  |
| 2467 | 2.3.32.3.4 | Realizar processo de pré-operação |  | 128d | 2023-03-02 | 2023-09-04 | 2466 |  |  | 2023-03-02 | 2023-09-04 | 128d |  |  | 361d | 0d | Verde | Verde | 0% | 0% | Verde | 0% | 0% | Verde |  |  |  |  |  |  |  |
| 2468 | 2.3.32.3.5 | Recurso da obra parcelado repassado | milestone | 0d | 2023-09-12 | 2023-09-12 | 2467FS+5d |  |  | 2023-09-12 | 2023-09-12 | 0d |  |  | 361d | 0d | Verde | Verde | 0% | 0% | Verde | 0% | 0% | Verde |  |  |  |  |  |  |  |
| 2469 | 2.3.32.3.6 | Pleito a definir concluído | milestone | 0d | 2023-09-12 | 2023-09-12 | 2468 |  |  | 2023-09-12 | 2023-09-12 | 0d |  |  | 361d | 0d | Verde | Verde | 0% | 0% | Verde | 0% | 0% | Verde |  |  |  |  |  |  |  |
| 2470 | 2.3.32.4 | **Pleito SAPRSPM01 - Revisão do PGIRS** |  | 224d | 2018-08-22 A | 2019-07-11 |  | 79% | 47.1d | 2018-08-22 | 2019-07-11 | 224d |  |  | 1398d |  | Verde | Verde | 77% | 98% | Vermelho | 81% | 79% |  | 79 | 77 | 98 | 81 | 79 |  |  |
| 2471 | 2.3.32.4.1 | **Licitação de Empresa para Elaboração de PGIRS** |  | 63d | 2018-08-22 A | 2018-11-16 A |  | 100% |  | 2018-08-22 | 2018-11-16 | 63d |  |  |  |  | Verde | Verde | 100% | 100% | Verde | 100% | 100% |  | 100 | 100 | 100 | 100 | 100 |  |  |
| 2472 | 2.3.32.4.1.1 | Licitação da empresa para elaboração de PGIRS autorizada pelo banco | milestone | 0d | 2018-08-22 A | 2018-08-22 A | 206FS-81d | 100% |  | 2018-08-22 | 2018-08-22 | 0d |  |  |  |  | Verde | Verde | 100% | 0% | Vermelho | 100% | 0% | Verde | 100 | 100 |  | 100 |  |  |  |
| 2473 | 2.3.32.4.1.2 | Licitar empresa de elaboração de PGIRS |  | 44d | 2018-08-22 A | 2018-10-22 A | 2472 | 100% |  | 2018-08-22 | 2018-10-22 | 44d |  |  |  |  | Verde | Verde | 100% | 100% | Verde | 100% | 100% | Verde | 100 | 100 | 100 | 100 | 100 |  |  |
| 2474 | 2.3.32.4.1.3 | Documentação de licitação apresentada ao banco | milestone | 0d | 2018-10-29 A | 2018-10-29 A | 2473FS+5d | 100% |  | 2018-10-29 | 2018-10-29 | 0d |  |  |  |  | Verde | Verde | 100% | 0% | Vermelho | 100% | 0% | Verde | 100 | 100 |  | 100 |  |  |  |
| 2475 | 2.3.32.4.1.4 | Analisar licitação da empresa para elaboração de PGIRS |  | 14d | 2018-10-30 A | 2018-11-16 A | 2474 | 100% |  | 2018-10-30 | 2018-11-16 | 14d |  |  |  |  | Verde | Verde | 100% | 100% | Verde | 100% | 100% | Verde | 100 | 100 | 100 | 100 | 100 |  |  |
| 2476 | 2.3.32.4.1.5 | Licitação da empresa para elaboração de PGIRS aprovada | milestone | 0d | 2018-11-16 A | 2018-11-16 A | 2475 | 100% |  | 2018-11-16 | 2018-11-16 | 0d |  |  |  |  | Verde | Verde | 100% | 0% | Vermelho | 100% | 0% | Verde | 100 | 100 |  | 100 |  |  |  |
| 2477 | 2.3.32.4.2 | **Elaboração do PGIRS** |  | 156d | 2018-11-19 A | 2019-07-04 |  | 71% | 45d | 2018-11-19 | 2019-07-04 | 156d |  |  | 1398d |  | Verde | Verde | 71% | 96% | Vermelho | 79% | 76% |  | 71 | 71 | 96 | 79 | 76 |  |  |
| 2478 | 2.3.32.4.2.1 | Elaborar PGIRS |  | 88d | 2018-11-19 A | 2019-03-26 A | 2476 | 100% |  | 2018-11-19 | 2019-03-26 | 88d |  |  |  |  | Verde | Verde | 100% | 100% | Verde | 100% | 100% | Verde | 100 | 100 | 100 | 100 | 100 |  |  |
| 2479 | 2.3.32.4.2.2 | PGIRS apresentado ao banco | milestone | 0d | 2019-03-26 A | 2019-03-26 A | 2478 | 100% |  | 2019-03-26 | 2019-03-26 | 0d |  |  |  |  | Verde | Verde | 100% | 0% | Vermelho | 100% | 0% | Verde | 100 | 100 |  | 100 |  |  |  |
| 2480 | 2.3.32.4.2.3 | Analisar PGIRS |  | 24d | 2019-03-27 A | 2019-05-02 | 2479 | 96% | 1d | 2019-03-27 | 2019-05-02 | 24d |  |  | 1398d | 0d | Verde | Verde | 95% | 71% | Vermelho | 95% | 67% | Verde | 96 | 95 | 71 | 95 | 67 |  |  |
| 2481 | 2.3.32.4.2.4 | Adequar/revisar PGIRS |  | 22d | 2019-05-03 | 2019-06-03 | 2480 |  |  | 2019-05-03 | 2019-06-03 | 22d |  |  | 1398d | 0d | Verde | Verde | 0% | 0% | Verde | 0% | 0% | Verde |  |  |  |  |  |  |  |
| 2482 | 2.3.32.4.2.5 | Analisar PGIRS - final |  | 22d | 2019-06-04 | 2019-07-04 | 2481 |  |  | 2019-06-04 | 2019-07-04 | 22d |  |  | 1398d | 0d | Verde | Verde | 0% | 0% | Verde | 0% | 0% | Verde |  |  |  |  |  |  |  |
| 2483 | 2.3.32.4.2.6 | PGIRS concluído | milestone | 0d | 2019-07-04 | 2019-07-04 | 2482 |  |  | 2019-07-04 | 2019-07-04 | 0d |  |  | 1398d | 0d | Verde | Verde | 0% | 0% | Verde | 0% | 0% | Verde |  |  |  |  |  |  |  |
| 2484 | 2.3.32.4.3 | Recurso do serviço parcelado repassado | milestone | 0d | 2019-07-11 | 2019-07-11 | 2483FS+5d |  |  | 2019-07-11 | 2019-07-11 | 0d |  |  | 1398d | 0d | Verde | Verde | 0% | 0% | Verde | 0% | 0% | Verde |  |  |  |  |  |  |  |
| 2485 | 2.3.32.4.4 | Pleito SAPRSPM01 concluído | milestone | 0d | 2019-07-11 | 2019-07-11 | 2484 |  |  | 2019-07-11 | 2019-07-11 | 0d |  |  | 1398d | 1037d | Verde | Verde | 0% | 0% | Verde | 0% | 0% | Verde |  |  |  |  |  |  |  |
| 2486 | 2.3.32.5 | Recursos de Santa do Paraíso repassados | milestone | 0d | 2023-09-12 | 2023-09-12 | 2447, 2485, 2458, 2469 |  |  | 2023-09-12 | 2023-09-12 | 0d | 2019-08-30 | 2022-11-19 | 361d |  | Verde | Verde | 0% | 0% | Verde | 0% | 0% | Verde |  |  |  |  |  | 02 - Execução | PG 031 |

Notes:
- 2460: Em 25/04/2019: o pleito deve ser enviado em setembro após conclusão do projeto executivo e será aprovado no próximo CT/CIF 30/11/2020 conforme NT 33
- 2466: Em 25/04/2019: valor da obra considerando teto menos projeto igual a R$ 10,7 milhões
- 2472: Em 24/04/2019: licitação de empresa para PGIRS autorizada pelo banco no dia 22/08/2018 conforme planilha controle gerencial renova.
- 2480: Em 29/04/2019: atualizado como agendado
- 2486: Valor de recurso destinado ao munícipio: R$12.605.314,86 / Em 19/03/19: por solicitação da A&M foi modificada a duração da atividade Santana do Paraíso de 1177 dias para 1171 dias para atendimento à demanda do MP e igualar as datas de término tendência às da definição do programa.

| ID | WBS | Task | Type | Duration | Start | Finish | Predecessors | Complete | Remaining | Baseline start | Baseline finish | Baseline duration | Baseline 1 start | Baseline 1 finish | Total slack | Free slack | Constraint | Farol de Atraso | Farol Marcos | % Previsto Tempo | % Concluída Numérico | % Previsto Tempo Numérico | Índice de Desempenho Físico (IDF) | IDF Numérico | Farol IDF | % Previsto Ponderado | % Concluído Ponderado | % Previsto Ponderado Numérico | % Concluído Ponderado Numérico | Farol de Início | Responsável | Código do Contrato |
| --- | --- | --- | --- | --- | --- | --- | --- | --- | --- | --- | --- | --- | --- | --- | --- | --- | --- | --- | --- | --- | --- | --- | --- | --- | --- | --- | --- | --- | --- | --- | --- | --- |
| 2487 | 2.3.33 | **São Domingos do Prata** |  | 765d | 2018-10-22 A | 2021-11-16 |  | 16% | 642.89d | 2018-10-22 | 2021-11-16 | 765d | 2019-03-13 | 2021-07-30 | 814d |  |  | Verde | Verde | 17% | 16 | 17 | 100% | 100 | Verde | 6% | 6% |  |  |  |  |  |
| 2488 | 2.3.33.1 | **Pleito SDPESOB05 - Construção do sistema de esgotamento sanitário da sede do município.** |  | 691d | 2019-02-04 A | 2021-11-16 |  | 12% | 611.11d | 2019-02-04 | 2021-11-16 | 691d |  |  | 814d |  |  | Verde | Verde | 8% | 12 |  | 100% | 100 | Verde | 5% | 5% |  |  |  |  |  |
| 2489 | 2.3.33.1.1 | **Aprovação do Projeto Executivo** |  | 87d | 2019-02-27 A | 2019-07-08 |  | 46% | 47d | 2019-02-27 | 2019-07-08 | 87d |  |  | 816d |  |  | Verde | Verde | 45% | 46 | 45 | 100% | 100 | Verde | 52% | 52% | 52 | 52 |  |  |  |
| 2490 | 2.3.33.1.1.1 | Projeto executivo apresentado ao banco | milestone | 0d | 2019-02-27 A | 2019-02-27 A |  | 100% |  | 2019-02-27 | 2019-02-27 | 0d |  |  |  |  | must start on 2019-02-27 | Verde | Verde | 100% | 100 | 100 | 0% |  | Vermelho | 100% | 0% | 100 |  | Verde |  |  |
| 2491 | 2.3.33.1.1.2 | Analisar projeto executivo |  | 11d | 2019-02-27 A | 2019-03-18 A | 2490 | 100% |  | 2019-02-27 | 2019-03-18 | 11d |  |  |  |  |  | Verde | Verde | 100% | 100 | 100 | 100% | 100 | Verde | 100% | 100% | 100 | 100 | Verde |  |  |
| 2492 | 2.3.33.1.1.3 | Adequar/revisar projeto executivo |  | 52d | 2019-03-19 A | 2019-06-03 | 2491 | 56% | 23d | 2019-03-19 | 2019-06-03 | 52d |  |  | 816d | 0d |  | Verde | Verde | 55% | 56 | 55 | 102% | 102 | Verde | 55% | 56% | 55 | 56 | Verde |  |  |
| 2493 | 2.3.33.1.1.4 | Analisar projeto executivo - final |  | 24d | 2019-06-04 | 2019-07-08 | 2492 |  |  | 2019-06-04 | 2019-07-08 | 24d |  |  | 816d | 0d |  | Verde | Verde | 0% |  |  | 0% |  | Verde | 0% | 0% |  |  | Verde |  |  |
| 2494 | 2.3.33.1.1.5 | Projeto concluído | milestone | 0d | 2019-07-08 | 2019-07-08 | 2493 |  |  | 2019-07-08 | 2019-07-08 | 0d |  |  | 816d | 0d |  | Verde | Verde | 0% |  |  | 0% |  | Verde | 0% | 0% |  |  | Verde |  |  |
| 2495 | 2.3.33.1.2 | Realizar Licenciamento Ambiental |  | 172d | 2019-02-04 A | 2019-10-11 | 199FS+142d | 33% | 115d | 2019-02-04 | 2019-10-11 | 172d |  |  | 814d | 0d |  | Verde | Verde | 33% | 33 | 33 | 88% | 88 | Vermelho | 33% | 29% | 33 | 29 | Verde |  |  |
| 2496 | 2.3.33.1.3 | **Licitação da Obra** |  | 66d | 2019-07-08 | 2019-10-09 |  |  |  | 2019-07-08 | 2019-10-09 | 66d |  |  | 816d |  |  | Verde | Verde | 0% |  |  | 0% |  | Verde | 0% | 0% |  |  |  |  |  |
| 2497 | 2.3.33.1.3.1 | Licitação da obra autorizada pelo banco | milestone | 0d | 2019-07-08 | 2019-07-08 | 2494 |  |  | 2019-07-08 | 2019-07-08 | 0d |  |  | 816d | 0d |  | Verde | Verde | 0% |  |  | 0% |  | Verde | 0% | 0% |  |  | Verde |  |  |
| 2498 | 2.3.33.1.3.2 | Licitar Obra |  | 43d | 2019-07-09 | 2019-09-06 | 2497 |  |  | 2019-07-09 | 2019-09-06 | 43d | 2019-04-12 | 2019-08-10 | 816d | 0d |  | Verde | Verde | 0% |  |  | 0% |  | Verde | 0% | 0% |  |  | Verde | 02 - Execução | PG 031 |
| 2499 | 2.3.33.1.3.3 | Analisar e emitir resultado da licitação da obra |  | 23d | 2019-09-09 | 2019-10-09 | 2498 |  |  | 2019-09-09 | 2019-10-09 | 23d |  |  | 816d | 0d |  | Verde | Verde | 0% |  |  | 0% |  | Verde | 0% | 0% |  |  | Verde |  |  |
| 2500 | 2.3.33.1.3.4 | Licitação da obra concluída | milestone | 0d | 2019-10-09 | 2019-10-09 | 2499 |  |  | 2019-10-09 | 2019-10-09 | 0d |  |  | 816d | 2d |  | Verde | Verde | 0% |  |  | 0% |  | Verde | 0% | 0% |  |  | Verde |  |  |
| 2501 | 2.3.33.1.4 | Executar obra |  | 386d | 2019-10-14 | 2021-05-06 | 2500, 2495 |  |  | 2019-10-14 | 2021-05-06 | 386d |  |  | 814d | 0d |  | Verde | Verde | 0% |  |  | 0% |  | Verde | 0% | 0% |  |  | Verde |  |  |
| 2502 | 2.3.33.1.5 | Realizar processo de pré-operação |  | 128d | 2021-05-07 | 2021-11-08 | 2501 |  |  | 2021-05-07 | 2021-11-08 | 128d | 2021-01-31 | 2021-07-30 | 814d | 0d |  | Verde | Verde | 0% |  |  | 0% |  | Verde | 0% | 0% |  |  | Verde | 02 - Execução | PG 031 |
| 2503 | 2.3.33.1.6 | Recurso da obra parcelado repassado | milestone | 0d | 2021-11-16 | 2021-11-16 | 2502FS+5d |  |  | 2021-11-16 | 2021-11-16 | 0d |  |  | 814d | 0d |  | Verde | Verde | 0% |  |  | 0% |  | Verde | 0% | 0% |  |  | Verde |  |  |
| 2504 | 2.3.33.1.7 | Pleito SDPESOB05 concluído | milestone | 0d | 2021-11-16 | 2021-11-16 | 2503 |  |  | 2021-11-16 | 2021-11-16 | 0d |  |  | 814d | 0d |  | Verde | Verde | 0% |  |  | 0% |  | Verde | 0% | 0% |  |  | Verde |  |  |
| 2505 | 2.3.33.2 | **Pleito SDPESCT02 - Aquisição de imóvel para a construção de estação de tratamento de esgotos e indenização da faixa de servidão.** |  | 147d | 2019-03-18 A | 2019-10-16 |  | 19% | 118.95d | 2019-03-18 | 2019-10-16 | 147d |  |  | 1330d |  |  | Verde | Verde | 19% | 19 | 19 | 100% | 100 | Verde | 16% | 16% | 16 | 16 |  |  |  |
| 2506 | 2.3.33.2.1 | Aquisição de imóvel autorizada pelo banco | milestone | 0d | 2019-03-18 A | 2019-03-18 A | 2491 | 100% |  | 2019-03-18 | 2019-03-18 | 0d |  |  |  |  |  | Verde | Verde | 100% | 100 | 100 | 0% |  | Vermelho | 100% | 0% | 100 |  | Verde |  |  |
| 2507 | 2.3.33.2.2 | **Aquisição de Imóvel** |  | 147d | 2019-03-19 A | 2019-10-16 |  | 19% | 118.95d | 2019-03-19 | 2019-10-16 | 147d |  |  | 1330d |  |  | Verde | Verde | 19% | 19 | 19 | 100% | 100 | Verde | 16% | 16% | 16 | 16 |  |  |  |
| 2508 | 2.3.33.2.2.1 | Regularizar terreno e apresentar escritura ao banco |  | 88d | 2019-03-19 A | 2019-07-24 | 2506 | 33% | 59d | 2019-03-19 | 2019-07-24 | 88d |  |  | 1330d | 0d |  | Verde | Verde | 32% | 33 | 32 | 97% | 97 | Vermelho | 32% | 31% | 32 | 31 | Verde |  |  |
| 2509 | 2.3.33.2.2.2 | Analisar documentação do terreno |  | 10d | 2019-07-25 | 2019-08-07 | 2508 |  |  | 2019-07-25 | 2019-08-07 | 10d |  |  | 1374d | 0d |  | Verde | Verde | 0% |  |  | 0% |  | Verde | 0% | 0% |  |  | Verde |  |  |
| 2510 | 2.3.33.2.2.3 | 50% do valor do imóvel repassado (1) | milestone | 0d | 2019-08-14 | 2019-08-14 | 2509FS+5d |  |  | 2019-08-14 | 2019-08-14 | 0d |  |  | 1374d | 44d |  | Verde | Verde | 0% |  |  | 0% |  | Verde | 0% | 0% |  |  | Verde |  |  |
| 2511 | 2.3.33.2.2.4 | Registrar imóvel e apresentar documentação ao banco |  | 44d | 2019-07-25 | 2019-09-25 | 2508 |  |  | 2019-07-25 | 2019-09-25 | 44d |  |  | 1330d | 0d |  | Verde | Verde | 0% |  |  | 0% |  | Verde | 0% | 0% |  |  | Verde |  |  |
| 2512 | 2.3.33.2.2.5 | Analisar documentação do terreno |  | 10d | 2019-09-26 | 2019-10-09 | 2511 |  |  | 2019-09-26 | 2019-10-09 | 10d |  |  | 1330d | 0d |  | Verde | Verde | 0% |  |  | 0% |  | Verde | 0% | 0% |  |  | Verde |  |  |
| 2513 | 2.3.33.2.2.6 | 50% do valor do imóvel repassado (2) | milestone | 0d | 2019-10-16 | 2019-10-16 | 2512FS+5d |  |  | 2019-10-16 | 2019-10-16 | 0d |  |  | 1330d | 0d |  | Verde | Verde | 0% |  |  | 0% |  | Verde | 0% | 0% |  |  | Verde |  |  |
| 2514 | 2.3.33.2.2.7 | Aquisição de imóvel concluída | milestone | 0d | 2019-10-16 | 2019-10-16 | 2510, 2513 |  |  | 2019-10-16 | 2019-10-16 | 0d |  |  | 1330d | 0d |  | Verde | Verde | 0% |  |  | 0% |  | Verde | 0% | 0% |  |  | Verde |  |  |
| 2515 | 2.3.33.2.3 | Pleito SDPESCT02 concluído | milestone | 0d | 2019-10-16 | 2019-10-16 | 2514 |  |  | 2019-10-16 | 2019-10-16 | 0d |  |  | 1330d | 516d |  | Verde | Verde | 0% |  |  | 0% |  | Verde | 0% | 0% |  |  | Verde |  |  |

Notes:
- 2487: São Domingos do Prata teve 100% dos pleitos de Esgotamento Sanitário aprovado (R$8.508.587,53), conforme Deliberação 75. / O município teve 1,6% dos 10% do valor teto destinado a Resíduos Sólidos aprovado (R$155.746,00). / Foi solicitado alteração de pleito, cancelamento de todos os pleitos anteriores para SES e pleito de execução do SES da sede (R$ 7.858.587,00), aquisição de imóvel para implantação da ETE e indenização da faixa de servidão (R$ 650.000,00).
- 2490: Em 25/04/2019: conforme planilha controle gerencial Renova o município protocolou o projeto no banco no dia 27/02/2019.
- 2491: Em 25/04/2019: município recolheu o projeto do banco no dia 18/03 para revisão conforme planilha controle gerencial Renova
- 2492: Em 25/04/2019: município não terminou de revisar o projeto, considerado prazo até 03/05/2019 / Em 29/04/2019: atualizado como agendado
- 2495: Em 29/04/2019: atualizado como agendado
- 2508: Em 29/04/2019: atualizado como agendado

| ID | WBS | Task | Type | Duration | Start | Finish | Predecessors | Complete | Remaining | Baseline start | Baseline finish | Baseline duration | Total slack | Free slack | Constraint | Farol de Atraso | Farol Marcos | % Previsto Tempo | % Concluída Numérico | % Previsto Tempo Numérico | Índice de Desempenho Físico (IDF) | IDF Numérico | Farol IDF | % Previsto Ponderado | % Previsto Ponderado Numérico | % Concluído Ponderado | % Concluído Ponderado Numérico | Farol de Início |
| --- | --- | --- | --- | --- | --- | --- | --- | --- | --- | --- | --- | --- | --- | --- | --- | --- | --- | --- | --- | --- | --- | --- | --- | --- | --- | --- | --- | --- |
| 2516 | 2.3.33.3 | **Pleito SDPRSPM01 - Elaboração do Plano Municipal de Gestão Integrada de Resíduos Sólidos (PGIRS)** |  | 185d | 2018-10-22 A | 2019-07-17 |  | 61% | 71.94d | 2018-10-22 | 2019-07-17 | 185d | 1394d |  |  | Verde | Verde | 70% | 61 | 70 | 91% | 91 | Vermelho | 80% | 80 | 73% | 73 |  |
| 2517 | 2.3.33.3.1 | **Licitação de Empresa para Elaboração de PGIRS** |  | 54d | 2018-10-22 A | 2019-01-04 A |  | 100% |  | 2018-10-22 | 2019-01-04 | 54d |  |  |  | Verde | Verde | 100% | 100 | 100 | 0% |  | Vermelho | 0% |  | 0% |  |  |
| 2518 | 2.3.33.3.1.1 | Documentação de licitação apresentada ao banco | milestone | 0d | 2018-10-22 A | 2018-10-22 A |  | 100% |  | 2018-10-22 | 2018-10-22 | 0d |  |  | must start on 2018-10-22 | Verde | Verde | 100% | 100 | 100 | 0% |  | Vermelho | 100% | 100 | 0% |  | Verde |
| 2519 | 2.3.33.3.1.2 | Licitação da empresa para elaboração de PGIRS aprovada | milestone | 0d | 2019-01-04 A | 2019-01-04 A | 2518FS+54d | 100% |  | 2019-01-04 | 2019-01-04 | 0d |  |  |  | Verde | Verde | 100% | 100 | 100 | 0% |  | Vermelho | 100% | 100 | 0% |  | Verde |
| 2520 | 2.3.33.3.2 | **Elaboração do PGIRS** |  | 126d | 2019-01-07 A | 2019-07-10 |  | 61% | 49d | 2019-01-07 | 2019-07-10 | 126d | 1394d |  |  | Verde | Verde | 61% | 61 | 61 | 91% | 91 | Vermelho | 80% | 80 | 73% | 73 |  |
| 2521 | 2.3.33.3.2.1 | Elaborar PGIRS |  | 60d | 2019-01-07 A | 2019-04-03 A | 2519 | 100% |  | 2019-01-07 | 2019-04-03 | 60d |  |  |  | Verde | Verde | 100% | 100 | 100 | 100% | 100 | Verde | 100% | 100 | 100% | 100 | Verde |
| 2522 | 2.3.33.3.2.2 | PGIRS apresentado ao banco | milestone | 0d | 2019-04-03 A | 2019-04-03 A | 2521 | 100% |  | 2019-04-03 | 2019-04-03 | 0d |  |  |  | Verde | Verde | 100% | 100 | 100 | 0% |  | Vermelho | 100% | 100 | 0% |  | Verde |
| 2523 | 2.3.33.3.2.3 | Analisar PGIRS |  | 22d | 2019-04-04 A | 2019-05-08 | 2522 | 77% | 5d | 2019-04-04 | 2019-05-08 | 22d | 1394d | 0d |  | Verde | Verde | 77% | 77 | 77 | 0% |  | Vermelho | 77% | 77 | 0% |  | Verde |
| 2524 | 2.3.33.3.2.4 | Adequar/revisar PGIRS |  | 22d | 2019-05-09 | 2019-06-07 | 2523 |  |  | 2019-05-09 | 2019-06-07 | 22d | 1394d | 0d |  | Verde | Verde | 0% |  |  | 0% |  | Verde | 0% |  | 0% |  | Verde |
| 2525 | 2.3.33.3.2.5 | Analisar PGIRS - final |  | 22d | 2019-06-10 | 2019-07-10 | 2524 |  |  | 2019-06-10 | 2019-07-10 | 22d | 1394d | 0d |  | Verde | Verde | 0% |  |  | 0% |  | Verde | 0% |  | 0% |  | Verde |
| 2526 | 2.3.33.3.2.6 | PGIRS concluído | milestone | 0d | 2019-07-10 | 2019-07-10 | 2525 |  |  | 2019-07-10 | 2019-07-10 | 0d | 1394d | 0d |  | Verde | Verde | 0% |  |  | 0% |  | Verde | 0% |  | 0% |  | Verde |
| 2527 | 2.3.33.3.3 | Recurso do serviço parcelado repassado | milestone | 0d | 2019-07-17 | 2019-07-17 | 2526FS+5d |  |  | 2019-07-17 | 2019-07-17 | 0d | 1394d | 0d |  | Verde | Verde | 0% |  |  | 0% |  | Verde | 0% |  | 0% |  | Verde |
| 2528 | 2.3.33.3.4 | Pleito SDPRSPM01 concluído | milestone | 0d | 2019-07-17 | 2019-07-17 | 2527 |  |  | 2019-07-17 | 2019-07-17 | 0d | 1394d | 580d |  | Verde | Verde | 0% |  |  | 0% |  | Verde | 0% |  | 0% |  | Verde |
| 2529 | 2.3.33.4 | **Pleito SDPRSOB02 - Implantação do Centro de Tratamento e Reciclagem de Resíduos Orgânicos e Recicláveis, cujo projeto encontra-se elaborado.** |  | 495d | 2019-01-16 A | 2021-01-13 |  | 15% | 421.59d | 2019-01-16 | 2021-01-13 | 495d | 1023d |  |  | Verde | Verde | 14% | 15 | 14 | 0% |  | Vermelho | 2% |  | 0% |  |  |
| 2530 | 2.3.33.4.1 | **Aprovação do Projeto Executivo** |  | 140d | 2019-01-16 A | 2019-08-08 |  | 50% | 70d | 2019-01-16 | 2019-08-08 | 140d | 1023d |  |  | Verde | Verde | 50% | 50 | 50 | 0% |  | Vermelho | 24% | 24 | 0% |  |  |
| 2531 | 2.3.33.4.1.1 | Projeto apresentado ao banco | milestone | 0d | 2019-01-16 A | 2019-01-16 A |  | 100% |  | 2019-01-16 | 2019-01-16 | 0d |  |  | must start on 2019-01-16 | Verde | Verde | 100% | 100 | 100 | 0% |  | Vermelho | 100% | 100 | 0% |  | Verde |
| 2532 | 2.3.33.4.1.2 | Analisar projeto |  | 96d | 2019-01-16 A | 2019-06-06 | 2531 | 73% | 26d | 2019-01-16 | 2019-06-06 | 96d | 1023d | 0d |  | Verde | Verde | 72% | 73 | 72 | 0% |  | Vermelho | 72% | 72 | 0% |  | Verde |
| 2533 | 2.3.33.4.1.3 | Adequar/revisar projeto |  | 22d | 2019-06-07 | 2019-07-09 | 2532 |  |  | 2019-06-07 | 2019-07-09 | 22d | 1023d | 0d |  | Verde | Verde | 0% |  |  | 0% |  | Verde | 0% |  | 0% |  | Verde |
| 2534 | 2.3.33.4.1.4 | Analisar projeto - final |  | 22d | 2019-07-10 | 2019-08-08 | 2533 |  |  | 2019-07-10 | 2019-08-08 | 22d | 1023d | 0d |  | Verde | Verde | 0% |  |  | 0% |  | Verde | 0% |  | 0% |  | Verde |
| 2535 | 2.3.33.4.1.5 | Projeto concluído | milestone | 0d | 2019-08-08 | 2019-08-08 | 2534 |  |  | 2019-08-08 | 2019-08-08 | 0d | 1023d | 0d |  | Verde | Verde | 0% |  |  | 0% |  | Verde | 0% |  | 0% |  | Verde |
| 2536 | 2.3.33.4.2 | **Licitação da obra** |  | 80d | 2019-08-08 | 2019-12-02 |  |  |  | 2019-08-08 | 2019-12-02 | 80d | 1023d |  |  | Verde | Verde | 0% |  |  | 0% |  | Verde | 0% |  | 0% |  |  |
| 2537 | 2.3.33.4.2.1 | Licitação da obra autorizada pelo banco | milestone | 0d | 2019-08-08 | 2019-08-08 | 2535 |  |  | 2019-08-08 | 2019-08-08 | 0d | 1023d | 0d |  | Verde | Verde | 0% |  |  | 0% |  | Verde | 0% |  | 0% |  | Verde |
| 2538 | 2.3.33.4.2.2 | Licitar obra |  | 66d | 2019-08-09 | 2019-11-11 | 2537 |  |  | 2019-08-09 | 2019-11-11 | 66d | 1023d | 0d |  | Verde | Verde | 0% |  |  | 0% |  | Verde | 0% |  | 0% |  | Verde |
| 2539 | 2.3.33.4.2.3 | Analisar e emitir resultado da licitação da obra |  | 14d | 2019-11-12 | 2019-12-02 | 2538 |  |  | 2019-11-12 | 2019-12-02 | 14d | 1023d | 0d |  | Verde | Verde | 0% |  |  | 0% |  | Verde | 0% |  | 0% |  | Verde |
| 2540 | 2.3.33.4.2.4 | Licitação da obra concluída | milestone | 0d | 2019-12-02 | 2019-12-02 | 2539 |  |  | 2019-12-02 | 2019-12-02 | 0d | 1023d | 0d |  | Verde | Verde | 0% |  |  | 0% |  | Verde | 0% |  | 0% |  | Verde |
| 2541 | 2.3.33.4.3 | Executar obra |  | 124d | 2020-01-02 | 2020-07-02 | 2540FS+18d |  |  | 2020-01-02 | 2020-07-02 | 124d | 1023d | 0d |  | Verde | Verde | 0% |  |  | 0% |  | Verde | 0% |  | 0% |  | Verde |
| 2542 | 2.3.33.4.4 | Realizar processo de pré-operação |  | 128d | 2020-07-03 | 2021-01-06 | 2541 |  |  | 2020-07-03 | 2021-01-06 | 128d | 1023d | 0d |  | Verde | Verde | 0% |  |  | 0% |  | Verde | 0% |  | 0% |  | Verde |
| 2543 | 2.3.33.4.5 | Recurso da obra parcelado repassado | milestone | 0d | 2021-01-13 | 2021-01-13 | 2542FS+5d |  |  | 2021-01-13 | 2021-01-13 | 0d | 1023d | 0d |  | Verde | Verde | 0% |  |  | 0% |  | Verde | 0% |  | 0% |  | Verde |
| 2544 | 2.3.33.4.6 | Pleito SDPRSOB02 concluído | milestone | 0d | 2021-01-13 | 2021-01-13 | 2543 |  |  | 2021-01-13 | 2021-01-13 | 0d | 1023d | 209d |  | Verde | Verde | 0% |  |  | 0% |  | Verde | 0% |  | 0% |  | Verde |

Notes:
- 2518: Em 24/04/2019: conforme planilha Controle Gerencial Renova o município protocolou licitação no dia 22/10/2018
- 2523: Em 29/04/2019: atualizado como agendado
- 2532: Em 24/09/2019: foi utilizada a premissa de que o início do processo de análise do projeto da UTC a partir do último contato do banco com o município (orientado por Cynthia) / Em 29/04/2019: atualizado como agendado
- 2541: Em 24/04/2019: valor da obra R$ 299 mil

| ID | WBS | Task | Type | Duration | Start | Finish | Predecessors | Complete | Remaining | Baseline start | Baseline finish | Baseline duration | Baseline 1 start | Baseline 1 finish | Total slack | Free slack | Constraint | Farol de Atraso | Farol Marcos | % Previsto Tempo | Índice de Desempenho Físico (IDF) | Farol IDF | % Previsto Ponderado | % Concluído Ponderado | % Concluída Numérico | % Previsto Tempo Numérico | % Previsto Ponderado Numérico | Farol de Início | Responsável | Código do Contrato | IDF Numérico | % Concluído Ponderado Numérico |
| --- | --- | --- | --- | --- | --- | --- | --- | --- | --- | --- | --- | --- | --- | --- | --- | --- | --- | --- | --- | --- | --- | --- | --- | --- | --- | --- | --- | --- | --- | --- | --- | --- |
| 2545 | 2.3.33.5 | **Pleito SDPRSPM04 - Elaboração do Plano de Recuperação de Área Degradada (PRAD) por lixão/aterro controlado apenas para o município de São Domingos do Prata.** |  | 222d | 2019-03-28 A | 2020-02-14 |  | 7% | 207.13d | 2019-03-28 | 2020-02-14 | 222d |  |  | 1248d |  |  | Verde | Verde | 9% | 0% | Vermelho | 3% | 0% |  |  |  |  |  |  |  |  |
| 2546 | 2.3.33.5.1 | Pleito aprovado | milestone | 0d | 2019-03-28 A | 2019-03-28 A |  | 100% |  | 2019-03-28 | 2019-03-28 | 0d |  |  |  |  | must start on 2019-03-28 | Verde | Verde | 100% | 0% | Vermelho | 100% | 0% | 100 | 100 | 100 | Verde |  |  |  |  |
| 2547 | 2.3.33.5.2 | **Licitação do Plano de Recuperação de Área Degradada** |  | 58d | 2019-04-08 A | 2019-07-03 |  | 24% | 44d | 2019-04-08 | 2019-07-03 | 58d |  |  | 1248d |  |  | Verde | Verde | 24% | 0% | Vermelho | 16% | 0% | 24 | 24 | 16 |  |  |  |  |  |
| 2548 | 2.3.33.5.2.1 | Licitação do PRAD autorizada pelo banco | milestone | 0d | 2019-04-08 A | 2019-04-08 A | 2546FS+8d | 100% |  | 2019-04-08 | 2019-04-08 | 0d |  |  |  |  |  | Verde | Verde | 100% | 0% | Vermelho | 100% | 0% | 100 | 100 | 100 | Verde |  |  |  |  |
| 2549 | 2.3.33.5.2.2 | Licitar PRAD |  | 44d | 2019-04-09 A | 2019-06-12 | 2548 | 32% | 30d | 2019-04-09 | 2019-06-12 | 44d |  |  | 1248d | 0d |  | Verde | Verde | 31% | 0% | Vermelho | 31% | 0% | 32 | 31 | 31 | Verde |  |  |  |  |
| 2550 | 2.3.33.5.2.3 | Documentação de licitação apresentada ao banco | milestone | 0d | 2019-06-12 | 2019-06-12 | 2549 |  |  | 2019-06-12 | 2019-06-12 | 0d |  |  | 1248d | 0d |  | Verde | Verde | 0% | 0% | Verde | 0% | 0% |  |  |  | Verde |  |  |  |  |
| 2551 | 2.3.33.5.2.4 | Analisar e emitir resultado da licitação do PRAD |  | 14d | 2019-06-13 | 2019-07-03 | 2550 |  |  | 2019-06-13 | 2019-07-03 | 14d |  |  | 1248d | 0d |  | Verde | Verde | 0% | 0% | Verde | 0% | 0% |  |  |  | Verde |  |  |  |  |
| 2552 | 2.3.33.5.2.5 | Licitação do PRAD concluída | milestone | 0d | 2019-07-03 | 2019-07-03 | 2551 |  |  | 2019-07-03 | 2019-07-03 | 0d |  |  | 1248d | 0d |  | Verde | Verde | 0% | 0% | Verde | 0% | 0% |  |  |  | Verde |  |  |  |  |
| 2553 | 2.3.33.5.3 | **Elaboração do Plano de Recuperação de Área Degradada** |  | 156d | 2019-07-04 | 2020-02-14 |  |  |  | 2019-07-04 | 2020-02-14 | 156d |  |  | 1248d |  |  | Verde | Verde | 0% | 0% | Verde | 0% | 0% |  |  |  |  |  |  |  |  |
| 2554 | 2.3.33.5.3.1 | Elaborar PRAD |  | 87d | 2019-07-04 | 2019-11-04 | 2552 |  |  | 2019-07-04 | 2019-11-04 | 87d |  |  | 1248d | 0d |  | Verde | Verde | 0% | 0% | Verde | 0% | 0% |  |  |  | Verde |  |  |  |  |
| 2555 | 2.3.33.5.3.2 | PRAD apresentado ao banco | milestone | 0d | 2019-11-04 | 2019-11-04 | 2554 |  |  | 2019-11-04 | 2019-11-04 | 0d |  |  | 1248d | 0d |  | Verde | Verde | 0% | 0% | Verde | 0% | 0% |  |  |  | Verde |  |  |  |  |
| 2556 | 2.3.33.5.3.3 | Analisar PRAD |  | 22d | 2019-11-05 | 2019-12-05 | 2555 |  |  | 2019-11-05 | 2019-12-05 | 22d |  |  | 1248d | 0d |  | Verde | Verde | 0% | 0% | Verde | 0% | 0% |  |  |  | Verde |  |  |  |  |
| 2557 | 2.3.33.5.3.4 | Adequar/revisar PRAD |  | 18d | 2019-12-06 | 2020-01-06 | 2556 |  |  | 2019-12-06 | 2020-01-06 | 18d |  |  | 1248d | 0d |  | Verde | Verde | 0% | 0% | Verde | 0% | 0% |  |  |  | Verde |  |  |  |  |
| 2558 | 2.3.33.5.3.5 | Analisar PRAD - final |  | 24d | 2020-01-07 | 2020-02-07 | 2557 |  |  | 2020-01-07 | 2020-02-07 | 24d |  |  | 1248d | 0d |  | Verde | Verde | 0% | 0% | Verde | 0% | 0% |  |  |  | Verde |  |  |  |  |
| 2559 | 2.3.33.5.3.6 | PRAD concluído | milestone | 0d | 2020-02-07 | 2020-02-07 | 2558 |  |  | 2020-02-07 | 2020-02-07 | 0d |  |  | 1248d | 0d |  | Verde | Verde | 0% | 0% | Verde | 0% | 0% |  |  |  | Verde |  |  |  |  |
| 2560 | 2.3.33.5.3.7 | Recurso do PRAD do pleito repassado | milestone | 0d | 2020-02-14 | 2020-02-14 | 2559FS+5d |  |  | 2020-02-14 | 2020-02-14 | 0d |  |  | 1248d | 0d |  | Verde | Verde | 0% | 0% | Verde | 0% | 0% |  |  |  | Verde |  |  |  |  |
| 2561 | 2.3.33.5.4 | Pleito SDPRSPM04 concluído | milestone | 0d | 2020-02-14 | 2020-02-14 | 2560 |  |  | 2020-02-14 | 2020-02-14 | 0d |  |  | 1248d | 434d |  | Verde | Verde | 0% | 0% | Verde | 0% | 0% |  |  |  | Verde |  |  |  |  |
| 2562 | 2.3.33.6 | Recursos de São Domingos do Prata repassados | milestone | 0d | 2021-11-16 | 2021-11-16 | 2504, 2515, 2528, 2544, 2561 |  |  | 2021-11-16 | 2021-11-16 | 0d | 2019-03-13 | 2021-07-30 | 814d |  |  | Verde | Verde | 0% | 0% | Verde | 0% | 0% |  |  |  | Verde | 02 - Execução | PG 031 |  |  |
| 2563 | 2.3.34 | **São José do Goiabal** |  | 1385d | 2018-07-10 A | 2024-01-29 |  | 22% | 1084.34d | 2018-07-10 | 2024-01-29 | 1385d | 2018-08-28 | 2020-08-05 | 508d |  |  | Verde | Verde | 14% | 100% | Verde | 9% | 9% | 22 | 14 |  |  |  |  | 100 |  |
| 2564 | 2.3.34.1 | **Pleito SJGESPJ02 - Adequação do projeto de SES da sede do municipio. Ajuste necessário à liberação dos recursos do TC/PAC 534/14 firmado com a Funasa.** |  | 119d | 2018-07-10 A | 2018-12-21 A |  | 100% |  | 2018-07-10 | 2018-12-21 | 119d |  |  |  |  |  | Verde | Verde | 100% | 100% | Verde | 100% | 100% | 100 | 100 | 100 |  |  |  | 100 | 100 |
| 2565 | 2.3.34.1.1 | Licitação do projeto autorizada pelo banco | milestone | 0d | 2018-07-10 A | 2018-07-10 A |  | 100% |  | 2018-07-10 | 2018-07-10 | 0d |  |  |  |  | must start on 2018-07-10 | Verde | Verde | 100% | 0% | Vermelho | 100% | 0% | 100 | 100 | 100 | Verde |  |  |  |  |
| 2566 | 2.3.34.1.2 | Documentação de licitação apresentada ao banco | milestone | 0d | 2018-12-18 A | 2018-12-18 A | 2565FS+116d | 100% |  | 2018-12-18 | 2018-12-18 | 0d |  |  |  |  |  | Verde | Verde | 100% | 0% | Vermelho | 100% | 0% | 100 | 100 | 100 | Verde |  |  |  |  |
| 2567 | 2.3.34.1.3 | Licitação do projeto aprovada pelo banco | milestone | 0d | 2018-12-20 A | 2018-12-20 A | 2566FS+2d | 100% |  | 2018-12-20 | 2018-12-20 | 0d |  |  |  |  |  | Verde | Verde | 100% | 0% | Vermelho | 100% | 0% | 100 | 100 | 100 | Verde |  |  |  |  |
| 2568 | 2.3.34.1.4 | Adequar projeto de SES |  | 1d | 2018-12-21 A | 2018-12-21 A | 2567 | 100% |  | 2018-12-21 | 2018-12-21 | 1d |  |  |  |  |  | Verde | Verde | 100% | 100% | Verde | 100% | 100% | 100 | 100 | 100 | Verde |  |  | 100 | 100 |
| 2569 | 2.3.34.1.5 | Recurso do projeto do pleito SJGESPJ02 repassado | milestone | 0d | 2018-12-21 A | 2018-12-21 A | 2568 | 100% |  | 2018-12-21 | 2018-12-21 | 0d |  |  |  |  |  | Verde | Verde | 100% | 0% | Vermelho | 100% | 0% | 100 | 100 | 100 | Verde |  |  |  |  |
| 2570 | 2.3.34.1.6 | Pleito SJGESPJ02 concluído | milestone | 0d | 2018-12-21 A | 2018-12-21 A | 2569 | 100% |  | 2018-12-21 | 2018-12-21 | 0d |  |  |  |  |  | Verde | Verde | 100% | 0% | Vermelho | 100% | 0% | 100 | 100 | 100 | Verde |  |  |  |  |

Notes:
- 2546: Em 24/04/2019: pleito aprovado dia 28/03 pelo CIF na deliberação 269 conforme planilha de Gestão de Pleitos
- 2549: Em 29/04/2019: atualizado como agendado
- 2562: Valor de recurso destinado ao munícipio: R$9.453.986,14
- 2563: São José do Goiabal teve 100% dos pleitos de Esgotamento Sanitário aprovado (R$4.254.000,00), conforme Deliberação 75. / O município teve o pleito de resíduos sólidos negado (R$472.699,31, equivalente a 10% do total do recurso) / São José do Goiabal solicitou mudança de pleito, e foi autorizado pelo CIF. / · Reembolso do projeto, já executado, para a sede/ ·100% dos recursos de SES para a Sede/ ·Retirada de São João do pleito de destinação de R$189.100,00 para projetos, pois o mesmo já foi contemplado no projeto da sede. / O pleito de projeto não está vinculado a nenhuma obra (o recurso para execução não será da Renova).
- 2565: Em 25/04/2019: conforme planilha controle gerencial Renova

| ID | WBS | Task | Type | Duration | Start | Finish | Predecessors | Complete | Remaining | Baseline start | Baseline finish | Baseline duration | Baseline 1 start | Baseline 1 finish | Total slack | Free slack | Constraint | Farol de Atraso | Farol Marcos | % Previsto Tempo | % Concluída Numérico | % Previsto Tempo Numérico | Índice de Desempenho Físico (IDF) | IDF Numérico | Farol IDF | % Previsto Ponderado | % Previsto Ponderado Numérico | % Concluído Ponderado | % Concluído Ponderado Numérico | Responsável | Código do Contrato | Farol de Início |
| --- | --- | --- | --- | --- | --- | --- | --- | --- | --- | --- | --- | --- | --- | --- | --- | --- | --- | --- | --- | --- | --- | --- | --- | --- | --- | --- | --- | --- | --- | --- | --- | --- |
| 2571 | 2.3.34.2 | **Pleito SJGESPJ03 - Elaboração de projetos de engenharia de sistemas de esgotamento sanitário para as localidades de Biboca, Patrimônio, Lagoa das Palmeiras, Messias Gomes e Isidório** |  | 254d | 2018-08-28 A | 2019-08-30 |  | 56% | 111.65d | 2018-08-28 | 2019-08-30 | 254d |  |  | 1363d |  |  | Verde | Verde | 66% | 56 | 66 | 100% | 100 | Verde | 50% | 50 | 50% | 50 |  |  |  |
| 2572 | 2.3.34.2.1 | Licitar Projetos |  | 64d | 2018-08-28 A | 2018-12-03 A | 200FS+12d | 100% |  | 2018-08-28 | 2018-12-03 | 64d | 2018-08-28 | 2018-11-26 |  |  |  | Verde | Verde | 100% | 100 | 100 | 100% | 100 | Verde | 100% | 100 | 100% | 100 | 02 - Execução | PG 031 | Verde |
| 2573 | 2.3.34.2.2 | **Elaboração do Projeto** |  | 123d | 2019-02-28 A | 2019-08-30 |  | 32% | 83.39d | 2019-02-28 | 2019-08-30 | 123d |  |  | 1363d |  |  | Verde | Verde | 30% | 32 | 30 | 98% | 98 | Vermelho | 45% | 45 | 44% | 44 |  |  |  |
| 2574 | 2.3.34.2.2.1 | Elaborar Projeto |  | 56d | 2019-02-28 A | 2019-05-27 | 2572FS+62d | 68% | 18d | 2019-02-28 | 2019-05-27 | 56d | 2018-11-26 | 2019-02-24 | 1363d | 0d |  | Verde | Verde | 67% | 68 | 67 | 100% | 100 | Verde | 67% | 67 | 67% | 67 | 02 - Execução | PG 031 | Verde |
| 2575 | 2.3.34.2.2.2 | Projeto apresentado ao banco | milestone | 0d | 2019-05-27 | 2019-05-27 | 2574 |  |  | 2019-05-27 | 2019-05-27 | 0d |  |  | 1363d | 0d |  | Verde | Verde | 0% |  |  | 0% |  | Verde | 0% |  | 0% |  |  |  | Verde |
| 2576 | 2.3.34.2.2.3 | Analisar projeto |  | 21d | 2019-05-28 | 2019-06-26 | 2575 |  |  | 2019-05-28 | 2019-06-26 | 21d |  |  | 1363d | 0d |  | Verde | Verde | 0% |  |  | 0% |  | Verde | 0% |  | 0% |  |  |  | Verde |
| 2577 | 2.3.34.2.2.4 | Adequar/revisar projeto |  | 21d | 2019-06-27 | 2019-07-25 | 2576 |  |  | 2019-06-27 | 2019-07-25 | 21d |  |  | 1363d | 0d |  | Verde | Verde | 0% |  |  | 0% |  | Verde | 0% |  | 0% |  |  |  | Verde |
| 2578 | 2.3.34.2.2.5 | Analisar projeto - final |  | 20d | 2019-07-26 | 2019-08-23 | 2577 |  |  | 2019-07-26 | 2019-08-23 | 20d |  |  | 1363d | 0d |  | Verde | Verde | 0% |  |  | 0% |  | Verde | 0% |  | 0% |  |  |  | Verde |
| 2579 | 2.3.34.2.2.6 | Projeto concluído | milestone | 0d | 2019-08-23 | 2019-08-23 | 2578 |  |  | 2019-08-23 | 2019-08-23 | 0d |  |  | 1363d | 0d |  | Verde | Verde | 0% |  |  | 0% |  | Verde | 0% |  | 0% |  |  |  | Verde |
| 2580 | 2.3.34.2.2.7 | Recurso do projeto do pleito SJGESPJ03 repassado | milestone | 0d | 2019-08-30 | 2019-08-30 | 2579FS+5d |  |  | 2019-08-30 | 2019-08-30 | 0d |  |  | 1363d | 0d |  | Verde | Verde | 0% |  |  | 0% |  | Verde | 0% |  | 0% |  |  |  | Verde |
| 2581 | 2.3.34.2.3 | Pleito SJGESPJ03 concluído | milestone | 0d | 2019-08-30 | 2019-08-30 | 2580 |  |  | 2019-08-30 | 2019-08-30 | 0d |  |  | 1363d | 682d |  | Verde | Verde | 0% |  |  | 0% |  | Verde | 0% |  | 0% |  |  |  | Verde |
| 2582 | 2.3.34.3 | **Pleito SJGESOB02 - Ampliação e adequação do sistema de esgotamento sanitário da sede do município** |  | 383d | 2019-04-02 A | 2020-10-14 |  | 5% | 363.75d | 2019-04-02 | 2020-10-14 | 383d |  |  | 1324d |  |  | Verde | Verde | 4% |  |  | 117% | 117 | Verde | 6% |  | 7% |  |  |  |  |
| 2583 | 2.3.34.3.1 | Executar obra |  | 250d | 2019-04-02 A | 2020-04-02 |  | 8% | 231d | 2019-04-02 | 2020-04-02 | 250d |  |  | 1324d | 0d | start no earlier than 2019-04-02 | Verde | Verde | 7% |  |  | 114% | 114 | Verde | 7% |  | 8% |  |  |  | Verde |
| 2584 | 2.3.34.3.2 | Realizar processo de pré-operação |  | 128d | 2020-04-03 | 2020-10-06 | 2583 |  |  | 2020-04-03 | 2020-10-06 | 128d |  |  | 1324d | 0d |  | Verde | Verde | 0% |  |  | 0% |  | Verde | 0% |  | 0% |  |  |  | Verde |
| 2585 | 2.3.34.3.3 | Recurso da obra parcelado repassado | milestone | 0d | 2020-10-14 | 2020-10-14 | 2584FS+5d |  |  | 2020-10-14 | 2020-10-14 | 0d |  |  | 1324d | 0d |  | Verde | Verde | 0% |  |  | 0% |  | Verde | 0% |  | 0% |  |  |  | Verde |
| 2586 | 2.3.34.3.4 | Pleito SJGESOB02 concluído | milestone | 0d | 2020-10-14 | 2020-10-14 | 2585 |  |  | 2020-10-14 | 2020-10-14 | 0d |  |  | 1324d |  |  | Verde | Verde | 0% |  |  | 0% |  | Verde | 0% |  | 0% |  |  |  | Verde |
| 2587 | 2.3.34.4 | **Pleito de São José do Goiabal de Resíduos Sólidos a definir** |  | 1096d | 2019-08-30 | 2024-01-29 |  |  |  | 2019-08-30 | 2024-01-29 | 1096d |  |  | 508d |  |  | Verde | Verde | 0% |  |  | 0% |  | Verde | 0% |  | 0% |  |  |  |  |
| 2588 | 2.3.34.4.1 | Pleito aprovado | milestone | 0d | 2019-08-30 | 2019-08-30 | 393 |  |  | 2019-08-30 | 2019-08-30 | 0d |  |  | 508d | 0d |  | Verde | Verde | 0% |  |  | 0% |  | Verde | 0% |  | 0% |  |  |  | Verde |
| 2589 | 2.3.34.4.2 | Iniciar pleito |  | 1d | 2019-08-30 | 2019-08-30 | 2588 |  |  | 2019-08-30 | 2019-08-30 | 1d |  |  | 508d | 0d |  | Verde | Verde | 0% |  |  | 0% |  | Verde | 0% |  | 0% |  |  |  | Verde |
| 2590 | 2.3.34.4.3 | Pleito de São José do Goiabal de Resíduos Sólidos a definir concluído | milestone | 0d | 2024-01-29 | 2024-01-29 | 2589FS+1095d |  |  | 2024-01-29 | 2024-01-29 | 0d |  |  | 508d |  |  | Verde | Verde | 0% |  |  | 0% |  | Verde | 0% |  | 0% |  |  |  | Verde |
| 2591 | 2.3.34.5 | Recursos de São José do Goiabal repassados | milestone | 0d | 2018-12-19 A | 2018-12-19 A | 2581, 2570, 2586, 2590 | 100% |  | 2018-12-19 | 2018-12-19 | 0d |  |  |  |  |  | Verde | Verde | 100% | 100 | 100 | 0% |  | Vermelho | 100% | 100 | 0% |  |  |  | Verde |
| 2592 | 2.3.35 | **São Pedro dos Ferros** |  | 1303d | 2018-11-01 A | 2024-01-29 |  | 9% | 1183.13d | 2018-11-01 | 2024-01-29 | 1303d | 2018-09-02 | 2021-01-24 | 268d |  |  | Verde | Verde | 9% |  |  | 0% |  | Vermelho | 0% |  | 0% |  |  |  |  |
| 2593 | 2.3.35.1 | **Pleito SPFESPJ01 - Elaboração de projeto de engenharia para a sede do município e distrito de Águas Férreas** |  | 433d | 2018-11-01 A | 2020-07-28 |  | 20% | 346.82d | 2018-11-01 | 2020-07-28 | 433d |  |  | 754d |  |  | Verde | Verde | 28% | 20 | 28 | 0% |  | Vermelho | 4% |  | 0% |  |  |  |  |
| 2594 | 2.3.35.1.1 | **Licitação do Projeto** |  | 150d | 2018-11-01 A | 2019-06-07 |  | 85% | 22.76d | 2018-11-01 | 2019-06-07 | 150d |  |  | 754d |  |  | Verde | Verde | 82% | 85 | 82 | 0% |  | Vermelho | 46% | 46 | 0% |  |  |  |  |
| 2595 | 2.3.35.1.1.1 | Licitar projeto |  | 131d | 2018-11-01 A | 2019-05-13 |  | 94% | 8d | 2018-11-01 | 2019-05-13 | 131d |  |  | 754d | 0d | start no earlier than 2018-11-01 | Verde | Verde | 93% | 94 | 93 | 0% |  | Vermelho | 93% | 93 | 0% |  |  |  | Verde |
| 2596 | 2.3.35.1.1.2 | Documentação de licitação apresentada ao banco | milestone | 0d | 2019-05-20 | 2019-05-20 | 2595FS+5d |  |  | 2019-05-20 | 2019-05-20 | 0d |  |  | 754d | 0d |  | Verde | Verde | 0% |  |  | 0% |  | Verde | 0% |  | 0% |  |  |  | Verde |
| 2597 | 2.3.35.1.1.3 | Analisar e emitir resultado da licitação do projeto |  | 14d | 2019-05-21 | 2019-06-07 | 2596 |  |  | 2019-05-21 | 2019-06-07 | 14d |  |  | 754d | 0d |  | Verde | Verde | 0% |  |  | 0% |  | Verde | 0% |  | 0% |  |  |  | Verde |
| 2598 | 2.3.35.1.1.4 | Licitação do projeto concluída | milestone | 0d | 2019-06-07 | 2019-06-07 | 2597 |  |  | 2019-06-07 | 2019-06-07 | 0d |  |  | 754d | 0d |  | Verde | Verde | 0% |  |  | 0% |  | Verde | 0% |  | 0% |  |  |  | Verde |

Notes:
- 2572: 25/01/19 - A licitação foi concluída e está aguardando aprovação do banco
- 2574: Em 29/04/2019: atualizado como agendado
- 2583: Em 25/04/2019: o início da obra (uso de recurso da Renova) foi autorizado pelo banco 02/04/2019. / Em 29/04/2019: atualizado como agendado
- 2591: Valor de recurso destinado ao munícipio: R$4.726.993,07
- 2592: São Pedro dos Ferros teve 88,9% (R$4.200.000,00) dos recursos destinado para Esgotamento Sanitário aprovado, conforme Deliberação 75. / O município teve o pleito de resíduos sólidos negado (R$472.699,31, equivalente a 10% do total do recurso,).
- 2595: 22/01/19 - Ainda não licitou pois está aguardando formalização da CT quato a necessidade de 3 orçamentos / Em 29/04/2019: atualizado como agendado

| ID | WBS | Task | Type | Duration | Start | Finish | Predecessors | Baseline start | Baseline finish | Baseline duration | Baseline 1 start | Baseline 1 finish | Total slack | Free slack | Farol de Atraso | Farol Marcos | % Previsto Tempo | Índice de Desempenho Físico (IDF) | Farol IDF | % Previsto Ponderado | % Concluído Ponderado | Responsável | Código do Contrato | Farol de Início |
| --- | --- | --- | --- | --- | --- | --- | --- | --- | --- | --- | --- | --- | --- | --- | --- | --- | --- | --- | --- | --- | --- | --- | --- | --- |
| 2599 | 2.3.35.1.2 | **Elaboração do Projeto Básico** |  | 152d | 2019-06-10 | 2020-01-16 |  | 2019-06-10 | 2020-01-16 | 152d |  |  | 754d |  | Verde | Verde | 0% | 0% | Verde | 0% | 0% |  |  |  |
| 2600 | 2.3.35.1.2.1 | Elaborar Projeto Básico |  | 83d | 2019-06-10 | 2019-10-04 | 2598 | 2019-06-10 | 2019-10-04 | 83d | 2019-03-31 | 2019-09-27 | 754d | 0d | Verde | Verde | 0% | 0% | Verde | 0% | 0% | 02 - Execução | PG 031 | Verde |
| 2601 | 2.3.35.1.2.2 | Projeto básico apresentado ao banco | milestone | 0d | 2019-10-04 | 2019-10-04 | 2600 | 2019-10-04 | 2019-10-04 | 0d |  |  | 754d | 0d | Verde | Verde | 0% | 0% | Verde | 0% | 0% |  |  | Verde |
| 2602 | 2.3.35.1.2.3 | Analisar projeto básico |  | 22d | 2019-10-07 | 2019-11-05 | 2601 | 2019-10-07 | 2019-11-05 | 22d |  |  | 754d | 0d | Verde | Verde | 0% | 0% | Verde | 0% | 0% |  |  | Verde |
| 2603 | 2.3.35.1.2.4 | Adequar/revisar projeto básico |  | 22d | 2019-11-06 | 2019-12-06 | 2602 | 2019-11-06 | 2019-12-06 | 22d |  |  | 754d | 0d | Verde | Verde | 0% | 0% | Verde | 0% | 0% |  |  | Verde |
| 2604 | 2.3.35.1.2.5 | Analisar projeto básico - final |  | 20d | 2019-12-09 | 2020-01-09 | 2603 | 2019-12-09 | 2020-01-09 | 20d |  |  | 754d | 0d | Verde | Verde | 0% | 0% | Verde | 0% | 0% |  |  | Verde |
| 2605 | 2.3.35.1.2.6 | Projeto básico concluído | milestone | 0d | 2020-01-09 | 2020-01-09 | 2604 | 2020-01-09 | 2020-01-09 | 0d |  |  | 754d | 0d | Verde | Verde | 0% | 0% | Verde | 0% | 0% |  |  | Verde |
| 2606 | 2.3.35.1.2.7 | Recurso do projeto básico do pleito SPFESPJ01 repassado | milestone | 0d | 2020-01-16 | 2020-01-16 | 2605FS+5d | 2020-01-16 | 2020-01-16 | 0d |  |  | 880d | 126d | Verde | Verde | 0% | 0% | Verde | 0% | 0% |  |  | Verde |
| 2607 | 2.3.35.1.3 | Realizar Licenciamento Ambiental |  | 195d | 2019-10-07 | 2020-07-21 | 2601 | 2019-10-07 | 2020-07-21 | 195d |  |  | 754d | 0d | Verde | Verde | 0% | 0% | Verde | 0% | 0% |  |  | Verde |
| 2608 | 2.3.35.1.4 | **Elaboração do Projeto Executivo** |  | 136d | 2020-01-10 | 2020-07-28 |  | 2020-01-10 | 2020-07-28 | 136d |  |  | 754d |  | Verde | Verde | 0% | 0% | Verde | 0% | 0% |  |  |  |
| 2609 | 2.3.35.1.4.1 | Elaborar Projeto Executivo |  | 65d | 2020-01-10 | 2020-04-15 | 2605 | 2020-01-10 | 2020-04-15 | 65d | 2019-03-31 | 2019-07-29 | 754d | 0d | Verde | Verde | 0% | 0% | Verde | 0% | 0% | 02 - Execução | PG 031 | Verde |
| 2610 | 2.3.35.1.4.2 | Projeto executivo apresentado ao banco | milestone | 0d | 2020-04-15 | 2020-04-15 | 2609 | 2020-04-15 | 2020-04-15 | 0d |  |  | 754d | 0d | Verde | Verde | 0% | 0% | Verde | 0% | 0% |  |  | Verde |
| 2611 | 2.3.35.1.4.3 | Analisar projeto executivo |  | 23d | 2020-04-16 | 2020-05-20 | 2610 | 2020-04-16 | 2020-05-20 | 23d |  |  | 754d | 0d | Verde | Verde | 0% | 0% | Verde | 0% | 0% |  |  | Verde |
| 2612 | 2.3.35.1.4.4 | Adequar/revisar projeto executivo |  | 21d | 2020-05-21 | 2020-06-19 | 2611 | 2020-05-21 | 2020-06-19 | 21d |  |  | 754d | 0d | Verde | Verde | 0% | 0% | Verde | 0% | 0% |  |  | Verde |
| 2613 | 2.3.35.1.4.5 | Aprovar projeto executivo - final |  | 22d | 2020-06-22 | 2020-07-21 | 2612 | 2020-06-22 | 2020-07-21 | 22d |  |  | 754d | 0d | Verde | Verde | 0% | 0% | Verde | 0% | 0% |  |  | Verde |
| 2614 | 2.3.35.1.4.6 | Projeto Executivo concluído | milestone | 0d | 2020-07-21 | 2020-07-21 | 2613, 2606, 2607 | 2020-07-21 | 2020-07-21 | 0d |  |  | 754d | 0d | Verde | Verde | 0% | 0% | Verde | 0% | 0% |  |  | Verde |
| 2615 | 2.3.35.1.4.7 | Recurso do projeto executivo do pleito SPFESPJ01 repassado | milestone | 0d | 2020-07-28 | 2020-07-28 | 2614FS+5d | 2020-07-28 | 2020-07-28 | 0d |  |  | 754d | 0d | Verde | Verde | 0% | 0% | Verde | 0% | 0% |  |  | Verde |
| 2616 | 2.3.35.1.5 | Pleito SPFESPJ01 concluído | milestone | 0d | 2020-07-28 | 2020-07-28 | 2615 | 2020-07-28 | 2020-07-28 | 0d |  |  | 754d | 0d | Verde | Verde | 0% | 0% | Verde | 0% | 0% |  |  | Verde |
| 2617 | 2.3.35.2 | **Pleito SPFESOB01 - Execução de obras para coleta e tratamento de esgoto para a sede do município** |  | 384d | 2020-07-28 | 2022-02-09 |  | 2020-07-28 | 2022-02-09 | 384d |  |  | 754d |  | Verde | Verde | 0% | 0% | Verde | 0% | 0% |  |  |  |
| 2618 | 2.3.35.2.1 | **Licitação da Obra** |  | 59d | 2020-07-28 | 2020-10-21 |  | 2020-07-28 | 2020-10-21 | 59d |  |  | 754d |  | Verde | Verde | 0% | 0% | Verde | 0% | 0% |  |  |  |
| 2619 | 2.3.35.2.1.1 | Licitação da obra autorizada pelo banco | milestone | 0d | 2020-07-28 | 2020-07-28 | 2616 | 2020-07-28 | 2020-07-28 | 0d |  |  | 754d | 0d | Verde | Verde | 0% | 0% | Verde | 0% | 0% |  |  | Verde |
| 2620 | 2.3.35.2.1.2 | Licitar Obra |  | 44d | 2020-07-29 | 2020-09-29 | 2619 | 2020-07-29 | 2020-09-29 | 44d | 2019-07-29 | 2019-11-26 | 754d | 0d | Verde | Verde | 0% | 0% | Verde | 0% | 0% | 02 - Execução | PG 031 | Verde |
| 2621 | 2.3.35.2.1.3 | Analisar e emitir resultado da licitação da obra |  | 15d | 2020-09-30 | 2020-10-21 | 2620 | 2020-09-30 | 2020-10-21 | 15d |  |  | 754d | 0d | Verde | Verde | 0% | 0% | Verde | 0% | 0% |  |  | Verde |
| 2622 | 2.3.35.2.1.4 | Licitação da obra concluída | milestone | 0d | 2020-10-21 | 2020-10-21 | 2621 | 2020-10-21 | 2020-10-21 | 0d |  |  | 754d | 0d | Verde | Verde | 0% | 0% | Verde | 0% | 0% |  |  | Verde |
| 2623 | 2.3.35.2.2 | Executar obra |  | 172d | 2020-11-20 | 2021-07-30 | 2622FS+20d | 2020-11-20 | 2021-07-30 | 172d |  |  | 754d | 0d | Verde | Verde | 0% | 0% | Verde | 0% | 0% |  |  | Verde |
| 2624 | 2.3.35.2.3 | Realizar processo de pré-operação |  | 128d | 2021-08-02 | 2022-02-02 | 2623 | 2021-08-02 | 2022-02-02 | 128d | 2020-07-28 | 2021-01-24 | 754d | 0d | Verde | Verde | 0% | 0% | Verde | 0% | 0% | 02 - Execução | PG 031 | Verde |
| 2625 | 2.3.35.2.4 | Recurso da obra parcelado repassado | milestone | 0d | 2022-02-09 | 2022-02-09 | 2624FS+5d | 2022-02-09 | 2022-02-09 | 0d |  |  | 754d | 0d | Verde | Verde | 0% | 0% | Verde | 0% | 0% |  |  | Verde |
| 2626 | 2.3.35.2.5 | Pleito SPFESOB01 concluído | milestone | 0d | 2022-02-09 | 2022-02-09 | 2625 | 2022-02-09 | 2022-02-09 | 0d |  |  | 754d | 486d | Verde | Verde | 0% | 0% | Verde | 0% | 0% |  |  | Verde |

| ID | WBS | Task | Type | Duration | Start | Finish | Predecessors | Complete | Remaining | Baseline start | Baseline finish | Baseline duration | Baseline 1 start | Baseline 1 finish | Total slack | Free slack | Constraint | Farol de Atraso | Farol Marcos | % Previsto Tempo | Índice de Desempenho Físico (IDF) | Farol IDF | % Previsto Ponderado | % Concluído Ponderado | Farol de Início | Responsável | Código do Contrato | % Concluída Numérico | % Previsto Tempo Numérico | % Previsto Ponderado Numérico |
| --- | --- | --- | --- | --- | --- | --- | --- | --- | --- | --- | --- | --- | --- | --- | --- | --- | --- | --- | --- | --- | --- | --- | --- | --- | --- | --- | --- | --- | --- | --- |
| 2627 | 2.3.35.3 | **Pleito SPFESOB02 - Execução de obras para coleta e tratamento de esgoto para distrito de Águas Férreas** |  | 384d | 2020-07-28 | 2022-02-09 |  |  |  | 2020-07-28 | 2022-02-09 | 384d |  |  | 754d |  |  | Verde | Verde | 0% | 0% | Verde | 0% | 0% |  |  |  |  |  |  |
| 2628 | 2.3.35.3.1 | **Licitação da Obra** |  | 59d | 2020-07-28 | 2020-10-21 |  |  |  | 2020-07-28 | 2020-10-21 | 59d |  |  | 754d |  |  | Verde | Verde | 0% | 0% | Verde | 0% | 0% |  |  |  |  |  |  |
| 2629 | 2.3.35.3.1.1 | Licitação da obra autorizada pelo banco | milestone | 0d | 2020-07-28 | 2020-07-28 | 2616 |  |  | 2020-07-28 | 2020-07-28 | 0d |  |  | 754d | 0d |  | Verde | Verde | 0% | 0% | Verde | 0% | 0% | Verde |  |  |  |  |  |
| 2630 | 2.3.35.3.1.2 | Licitar Obra |  | 44d | 2020-07-29 | 2020-09-29 | 2629 |  |  | 2020-07-29 | 2020-09-29 | 44d |  |  | 754d | 0d |  | Verde | Verde | 0% | 0% | Verde | 0% | 0% | Verde |  |  |  |  |  |
| 2631 | 2.3.35.3.1.3 | Analisar e emitir resultado da licitação da obra |  | 15d | 2020-09-30 | 2020-10-21 | 2630 |  |  | 2020-09-30 | 2020-10-21 | 15d |  |  | 754d | 0d |  | Verde | Verde | 0% | 0% | Verde | 0% | 0% | Verde |  |  |  |  |  |
| 2632 | 2.3.35.3.1.4 | Licitação da obra concluída | milestone | 0d | 2020-10-21 | 2020-10-21 | 2631 |  |  | 2020-10-21 | 2020-10-21 | 0d |  |  | 754d | 0d |  | Verde | Verde | 0% | 0% | Verde | 0% | 0% | Verde |  |  |  |  |  |
| 2633 | 2.3.35.3.2 | Executar obra |  | 172d | 2020-11-20 | 2021-07-30 | 2632FS+20d |  |  | 2020-11-20 | 2021-07-30 | 172d |  |  | 754d | 0d |  | Verde | Verde | 0% | 0% | Verde | 0% | 0% | Verde |  |  |  |  |  |
| 2634 | 2.3.35.3.3 | Realizar processo de pré-operação |  | 128d | 2021-08-02 | 2022-02-02 | 2633 |  |  | 2021-08-02 | 2022-02-02 | 128d |  |  | 754d | 0d |  | Verde | Verde | 0% | 0% | Verde | 0% | 0% | Verde |  |  |  |  |  |
| 2635 | 2.3.35.3.4 | Recurso da obra parcelado repassado | milestone | 0d | 2022-02-09 | 2022-02-09 | 2634FS+5d |  |  | 2022-02-09 | 2022-02-09 | 0d |  |  | 754d | 0d |  | Verde | Verde | 0% | 0% | Verde | 0% | 0% | Verde |  |  |  |  |  |
| 2636 | 2.3.35.3.5 | Pleito SPFESOB02 concluído | milestone | 0d | 2022-02-09 | 2022-02-09 | 2635 |  |  | 2022-02-09 | 2022-02-09 | 0d |  |  | 754d | 486d |  | Verde | Verde | 0% | 0% | Verde | 0% | 0% | Verde |  |  |  |  |  |
| 2637 | 2.3.35.4 | **Pleito de São Pedro dos Ferros de Resíduos Sólidos a definir** |  | 1096d | 2019-08-30 | 2024-01-29 |  |  |  | 2019-08-30 | 2024-01-29 | 1096d |  |  | 268d |  |  | Verde | Verde | 0% | 0% | Verde | 0% | 0% |  |  |  |  |  |  |
| 2638 | 2.3.35.4.1 | Pleito aprovado | milestone | 0d | 2019-08-30 | 2019-08-30 | 393 |  |  | 2019-08-30 | 2019-08-30 | 0d |  |  | 268d | 0d |  | Verde | Verde | 0% | 0% | Verde | 0% | 0% | Verde |  |  |  |  |  |
| 2639 | 2.3.35.4.2 | Iniciar pleito |  | 1d | 2019-08-30 | 2019-08-30 | 2638 |  |  | 2019-08-30 | 2019-08-30 | 1d |  |  | 268d | 0d |  | Verde | Verde | 0% | 0% | Verde | 0% | 0% | Verde |  |  |  |  |  |
| 2640 | 2.3.35.4.3 | Pleito de São Pedro dos Ferros de Resíduos Sólidos a definir concluído | milestone | 0d | 2024-01-29 | 2024-01-29 | 2639FS+1095d |  |  | 2024-01-29 | 2024-01-29 | 0d |  |  | 268d | 0d |  | Verde | Verde | 0% | 0% | Verde | 0% | 0% | Verde |  |  |  |  |  |
| 2641 | 2.3.35.5 | Recursos de São Pedro dos Ferros repassados | milestone | 0d | 2024-01-29 | 2024-01-29 | 2616, 2626, 2636, 2640 |  |  | 2024-01-29 | 2024-01-29 | 0d | 2019-04-30 | 2021-01-24 | 268d |  |  | Verde | Verde | 0% | 0% | Verde | 0% | 0% | Verde | 02 - Execução | PG 031 |  |  |  |
| 2642 | 2.3.36 | **Sem-Peixe** |  | 1237d | 2019-02-04 A | 2024-01-29 |  | 7% | 1153.16d | 2019-02-04 | 2024-01-29 | 1237d | 2018-10-02 | 2020-07-23 | 268d |  |  | Verde | Verde | 4% | 0% | Vermelho | 0% | 0% |  |  |  |  |  |  |
| 2643 | 2.3.36.1 | **Pleito SEPESPJ01 - Elaboração de projeto de engenharia do distrito de São Bartolomeu** |  | 341d | 2019-02-04 A | 2020-06-22 |  | 16% | 286.4d | 2019-02-04 | 2020-06-22 | 341d |  |  | 1164d |  |  | Verde | Verde | 16% | 0% | Vermelho | 10% | 0% |  |  |  | 16 | 16 | 10 |
| 2644 | 2.3.36.1.1 | **Licitação do Projeto** |  | 127d | 2019-05-02 | 2019-10-29 |  |  |  | 2019-05-02 | 2019-10-29 | 127d |  |  | 807d |  |  | Verde | Verde | 0% | 0% | Verde | 0% | 0% |  |  |  |  |  |  |
| 2645 | 2.3.36.1.1.1 | Licitar projeto |  | 108d | 2019-05-02 | 2019-10-02 |  |  |  | 2019-05-02 | 2019-10-02 | 108d |  |  | 807d | 0d | start no earlier than 2019-05-02 | Verde | Verde | 0% | 0% | Verde | 0% | 0% | Verde |  |  |  |  |  |
| 2646 | 2.3.36.1.1.2 | Documentação de licitação apresentada ao banco | milestone | 0d | 2019-10-09 | 2019-10-09 | 2645FS+5d |  |  | 2019-10-09 | 2019-10-09 | 0d |  |  | 807d | 0d |  | Verde | Verde | 0% | 0% | Verde | 0% | 0% | Verde |  |  |  |  |  |
| 2647 | 2.3.36.1.1.3 | Analisar e emitir resultado da licitação do projeto |  | 14d | 2019-10-10 | 2019-10-29 | 2646 |  |  | 2019-10-10 | 2019-10-29 | 14d |  |  | 807d | 0d |  | Verde | Verde | 0% | 0% | Verde | 0% | 0% | Verde |  |  |  |  |  |
| 2648 | 2.3.36.1.1.4 | Licitação do projeto concluída | milestone | 0d | 2019-10-29 | 2019-10-29 | 2647 |  |  | 2019-10-29 | 2019-10-29 | 0d |  |  | 807d | 0d |  | Verde | Verde | 0% | 0% | Verde | 0% | 0% | Verde |  |  |  |  |  |
| 2649 | 2.3.36.1.2 | **Elaboração do Projeto** |  | 157d | 2019-10-30 | 2020-06-22 |  |  |  | 2019-10-30 | 2020-06-22 | 157d |  |  | 807d |  |  | Verde | Verde | 0% | 0% | Verde | 0% | 0% |  |  |  |  |  |  |
| 2650 | 2.3.36.1.2.1 | Elaborar Projeto Básico/Executivo |  | 88d | 2019-10-30 | 2020-03-11 | 2648 |  |  | 2019-10-30 | 2020-03-11 | 88d |  |  | 807d | 0d |  | Verde | Verde | 0% | 0% | Verde | 0% | 0% | Verde |  |  |  |  |  |
| 2651 | 2.3.36.1.2.2 | Projeto apresentado ao banco | milestone | 0d | 2020-03-11 | 2020-03-11 | 2650 |  |  | 2020-03-11 | 2020-03-11 | 0d |  |  | 807d | 0d |  | Verde | Verde | 0% | 0% | Verde | 0% | 0% | Verde |  |  |  |  |  |
| 2652 | 2.3.36.1.2.3 | Analisar projeto |  | 23d | 2020-03-12 | 2020-04-14 | 2651 |  |  | 2020-03-12 | 2020-04-14 | 23d |  |  | 807d | 0d |  | Verde | Verde | 0% | 0% | Verde | 0% | 0% | Verde |  |  |  |  |  |
| 2653 | 2.3.36.1.2.4 | Adequar/revisar projeto |  | 20d | 2020-04-15 | 2020-05-14 | 2652 |  |  | 2020-04-15 | 2020-05-14 | 20d |  |  | 807d | 0d |  | Verde | Verde | 0% | 0% | Verde | 0% | 0% | Verde |  |  |  |  |  |
| 2654 | 2.3.36.1.2.5 | Analisar projeto - final |  | 21d | 2020-05-15 | 2020-06-15 | 2653 |  |  | 2020-05-15 | 2020-06-15 | 21d |  |  | 807d | 0d |  | Verde | Verde | 0% | 0% | Verde | 0% | 0% | Verde |  |  |  |  |  |
| 2655 | 2.3.36.1.2.6 | Projeto concluído | milestone | 0d | 2020-06-15 | 2020-06-15 | 2654, 2657 |  |  | 2020-06-15 | 2020-06-15 | 0d |  |  | 807d | 0d |  | Verde | Verde | 0% | 0% | Verde | 0% | 0% | Verde |  |  |  |  |  |
| 2656 | 2.3.36.1.2.7 | Recurso do projeto do pleito SEPESPJ01 repassado | milestone | 0d | 2020-06-22 | 2020-06-22 | 2655FS+5d |  |  | 2020-06-22 | 2020-06-22 | 0d |  |  | 1164d | 0d |  | Verde | Verde | 0% | 0% | Verde | 0% | 0% | Verde |  |  |  |  |  |
| 2657 | 2.3.36.1.3 | Realizar Licenciamento Ambiental |  | 82d | 2019-02-04 A | 2019-06-05 | 202FS+120d | 70% | 25d | 2019-02-04 | 2019-06-05 | 82d |  |  | 1061d | 254d |  | Verde | Verde | 69% | 0% | Vermelho | 69% | 0% | Verde |  |  | 70 | 69 | 69 |
| 2658 | 2.3.36.1.4 | Pleito SEPESPJ01 concluído | milestone | 0d | 2020-06-22 | 2020-06-22 | 2656 |  |  | 2020-06-22 | 2020-06-22 | 0d |  |  | 1164d | 896d |  | Verde | Verde | 0% | 0% | Verde | 0% | 0% | Verde |  |  |  |  |  |

Notes:
- 2641: Valor de recurso destinado ao munícipio: R$4.726.993,07
- 2642: Sem Peixe teve 100% dos pleitos de Esgotamento Sanitário Aprovado (R$4.254.293,76), conforme Deliberação 75. / O município teve o pleito de resíduos sólidos negado (R$472.699,31, equivalente a 10% do total do recurso). / Aderiu à ata de registro de preço.
- 2645: Em 25/04/2019: o município está verificando a possibilidade fazer uma licitação própria e cancelar a adesão a ATA de registro de preço (report de apoio técnico de abril 2019). Foi premissado que o município de irá licitar o projeto em 5 meses visto necessidade de iniciar pela elaboração do TR. Início previsto para 02/05.
- 2657: Em 29/04/2019: atualizado como agendado

| ID | WBS | Task | Type | Duration | Start | Finish | Predecessors | Complete | Remaining | Baseline start | Baseline finish | Baseline duration | Baseline 1 start | Baseline 1 finish | Total slack | Free slack | Constraint | Farol de Atraso | Farol Marcos | % Previsto Tempo | % Concluída Numérico | % Previsto Tempo Numérico | Índice de Desempenho Físico (IDF) | Farol IDF | % Previsto Ponderado | % Concluído Ponderado | Farol de Início | % Previsto Ponderado Numérico | Responsável | Código do Contrato |
| --- | --- | --- | --- | --- | --- | --- | --- | --- | --- | --- | --- | --- | --- | --- | --- | --- | --- | --- | --- | --- | --- | --- | --- | --- | --- | --- | --- | --- | --- | --- |
| 2659 | 2.3.36.2 | **Pleito SEPESPJ02 - Elaboração de projeto de engenharia do vilarejo de São Paulino e toda a zona rural** |  | 341d | 2019-02-04 A | 2020-06-22 |  | 16% | 286.4d | 2019-02-04 | 2020-06-22 | 341d |  |  | 1164d |  |  | Verde | Verde | 16% | 16 | 16 | 0% | Vermelho | 6% | 0% |  |  |  |  |
| 2660 | 2.3.36.2.1 | **Licitação do Projeto** |  | 127d | 2019-05-02 | 2019-10-29 |  |  |  | 2019-05-02 | 2019-10-29 | 127d |  |  | 808d |  |  | Verde | Verde | 0% |  |  | 0% | Verde | 0% | 0% |  |  |  |  |
| 2661 | 2.3.36.2.1.1 | Licitar projeto |  | 108d | 2019-05-02 | 2019-10-02 | 2645SS |  |  | 2019-05-02 | 2019-10-02 | 108d |  |  | 808d | 0d |  | Verde | Verde | 0% |  |  | 0% | Verde | 0% | 0% | Verde |  |  |  |
| 2662 | 2.3.36.2.1.2 | Documentação de licitação apresentada ao banco | milestone | 0d | 2019-10-09 | 2019-10-09 | 2661FS+5d |  |  | 2019-10-09 | 2019-10-09 | 0d |  |  | 808d | 0d |  | Verde | Verde | 0% |  |  | 0% | Verde | 0% | 0% | Verde |  |  |  |
| 2663 | 2.3.36.2.1.3 | Analisar e emitir resultado da licitação do projeto |  | 14d | 2019-10-10 | 2019-10-29 | 2662 |  |  | 2019-10-10 | 2019-10-29 | 14d |  |  | 808d | 0d |  | Verde | Verde | 0% |  |  | 0% | Verde | 0% | 0% | Verde |  |  |  |
| 2664 | 2.3.36.2.1.4 | Licitação do projeto concluída | milestone | 0d | 2019-10-29 | 2019-10-29 | 2663 |  |  | 2019-10-29 | 2019-10-29 | 0d |  |  | 808d | 0d |  | Verde | Verde | 0% |  |  | 0% | Verde | 0% | 0% | Verde |  |  |  |
| 2665 | 2.3.36.2.2 | **Elaboração do Projeto** |  | 157d | 2019-10-30 | 2020-06-22 |  |  |  | 2019-10-30 | 2020-06-22 | 157d |  |  | 808d |  |  | Verde | Verde | 0% |  |  | 0% | Verde | 0% | 0% |  |  |  |  |
| 2666 | 2.3.36.2.2.1 | Elaborar Projeto Básico/Executivo |  | 88d | 2019-10-30 | 2020-03-11 | 2664 |  |  | 2019-10-30 | 2020-03-11 | 88d |  |  | 808d | 0d |  | Verde | Verde | 0% |  |  | 0% | Verde | 0% | 0% | Verde |  |  |  |
| 2667 | 2.3.36.2.2.2 | Projeto apresentado ao banco | milestone | 0d | 2020-03-11 | 2020-03-11 | 2666 |  |  | 2020-03-11 | 2020-03-11 | 0d |  |  | 808d | 0d |  | Verde | Verde | 0% |  |  | 0% | Verde | 0% | 0% | Verde |  |  |  |
| 2668 | 2.3.36.2.2.3 | Analisar projeto |  | 23d | 2020-03-12 | 2020-04-14 | 2667 |  |  | 2020-03-12 | 2020-04-14 | 23d |  |  | 808d | 0d |  | Verde | Verde | 0% |  |  | 0% | Verde | 0% | 0% | Verde |  |  |  |
| 2669 | 2.3.36.2.2.4 | Adequar/revisar projeto |  | 20d | 2020-04-15 | 2020-05-14 | 2668 |  |  | 2020-04-15 | 2020-05-14 | 20d |  |  | 808d | 0d |  | Verde | Verde | 0% |  |  | 0% | Verde | 0% | 0% | Verde |  |  |  |
| 2670 | 2.3.36.2.2.5 | Analisar projeto - final |  | 21d | 2020-05-15 | 2020-06-15 | 2669 |  |  | 2020-05-15 | 2020-06-15 | 21d |  |  | 808d | 0d |  | Verde | Verde | 0% |  |  | 0% | Verde | 0% | 0% | Verde |  |  |  |
| 2671 | 2.3.36.2.2.6 | Projeto concluído | milestone | 0d | 2020-06-15 | 2020-06-15 | 2670, 2673 |  |  | 2020-06-15 | 2020-06-15 | 0d |  |  | 808d | 0d |  | Verde | Verde | 0% |  |  | 0% | Verde | 0% | 0% | Verde |  |  |  |
| 2672 | 2.3.36.2.2.7 | Recurso do projeto do pleito SEPESPJ02 repassado | milestone | 0d | 2020-06-22 | 2020-06-22 | 2671FS+5d |  |  | 2020-06-22 | 2020-06-22 | 0d |  |  | 1164d | 0d |  | Verde | Verde | 0% |  |  | 0% | Verde | 0% | 0% | Verde |  |  |  |
| 2673 | 2.3.36.2.3 | Realizar Licenciamento Ambiental |  | 82d | 2019-02-04 A | 2019-06-05 | 2661SS-57d | 70% | 25d | 2019-02-04 | 2019-06-05 | 82d |  |  | 1062d | 254d |  | Verde | Verde | 69% | 70 | 69 | 0% | Vermelho | 69% | 0% | Verde | 69 |  |  |
| 2674 | 2.3.36.2.4 | Pleito SEPESPJ02 concluído | milestone | 0d | 2020-06-22 | 2020-06-22 | 2672 |  |  | 2020-06-22 | 2020-06-22 | 0d |  |  | 1164d | 896d |  | Verde | Verde | 0% |  |  | 0% | Verde | 0% | 0% | Verde |  |  |  |
| 2675 | 2.3.36.3 | **Pleito SEPESOB01 - Complementação de recursos de contrapartida para o TC/PAC 0366/14** |  | 302d | 2019-06-03 | 2020-08-17 |  |  |  | 2019-06-03 | 2020-08-17 | 302d |  |  | 1124d |  |  | Verde | Verde | 0% |  |  | 0% | Verde | 0% | 0% |  |  |  |  |
| 2676 | 2.3.36.3.1 | Executar obra |  | 169d | 2019-06-03 | 2020-02-03 |  |  |  | 2019-06-03 | 2020-02-03 | 169d |  |  | 1124d | 0d | start no earlier than 2019-06-03 | Verde | Verde | 0% |  |  | 0% | Verde | 0% | 0% | Verde |  |  |  |
| 2677 | 2.3.36.3.2 | Realizar processo de pré-operação |  | 128d | 2020-02-04 | 2020-08-10 | 2676 |  |  | 2020-02-04 | 2020-08-10 | 128d |  |  | 1124d | 0d |  | Verde | Verde | 0% |  |  | 0% | Verde | 0% | 0% | Verde |  |  |  |
| 2678 | 2.3.36.3.3 | Recurso da obra parcelado repassado | milestone | 0d | 2020-08-17 | 2020-08-17 | 2677FS+5d |  |  | 2020-08-17 | 2020-08-17 | 0d |  |  | 1124d | 0d |  | Verde | Verde | 0% |  |  | 0% | Verde | 0% | 0% | Verde |  |  |  |
| 2679 | 2.3.36.3.4 | Pleito SEPESOB01 concluído | milestone | 0d | 2020-08-17 | 2020-08-17 | 2678 |  |  | 2020-08-17 | 2020-08-17 | 0d |  |  | 1124d | 856d |  | Verde | Verde | 0% |  |  | 0% | Verde | 0% | 0% | Verde |  |  |  |
| 2680 | 2.3.36.4 | **Pleito SEPESOB02 - Implantação tratamento de esgotos do Distrito de São Bartolomeu** |  | 362d | 2020-06-15 | 2021-11-25 |  |  |  | 2020-06-15 | 2021-11-25 | 362d |  |  | 807d |  |  | Verde | Verde | 0% |  |  | 0% | Verde | 0% | 0% |  |  |  |  |
| 2681 | 2.3.36.4.1 | **Licitação da Obra** |  | 80d | 2020-06-15 | 2020-10-06 |  |  |  | 2020-06-15 | 2020-10-06 | 80d |  |  | 807d |  |  | Verde | Verde | 0% |  |  | 0% | Verde | 0% | 0% |  |  |  |  |
| 2682 | 2.3.36.4.1.1 | Licitação da obra autorizada pelo banco | milestone | 0d | 2020-06-15 | 2020-06-15 | 2655 |  |  | 2020-06-15 | 2020-06-15 | 0d |  |  | 807d | 0d |  | Verde | Verde | 0% |  |  | 0% | Verde | 0% | 0% | Verde |  |  |  |
| 2683 | 2.3.36.4.1.2 | Licitar Obra |  | 66d | 2020-06-16 | 2020-09-16 | 2682 |  |  | 2020-06-16 | 2020-09-16 | 66d | 2019-03-01 | 2019-05-30 | 807d | 0d |  | Verde | Verde | 0% |  |  | 0% | Verde | 0% | 0% | Verde |  | 02 - Execução | PG 031 |
| 2684 | 2.3.36.4.1.3 | Analisar e emitir resultado da licitação da obra |  | 14d | 2020-09-17 | 2020-10-06 | 2683 |  |  | 2020-09-17 | 2020-10-06 | 14d |  |  | 807d | 0d |  | Verde | Verde | 0% |  |  | 0% | Verde | 0% | 0% | Verde |  |  |  |
| 2685 | 2.3.36.4.1.4 | Licitação da obra concluída | milestone | 0d | 2020-10-06 | 2020-10-06 | 2684 |  |  | 2020-10-06 | 2020-10-06 | 0d |  |  | 807d | 0d |  | Verde | Verde | 0% |  |  | 0% | Verde | 0% | 0% | Verde |  |  |  |
| 2686 | 2.3.36.4.2 | Executar obra |  | 128d | 2020-11-09 | 2021-05-17 | 2685FS+21d |  |  | 2020-11-09 | 2021-05-17 | 128d |  |  | 807d | 0d |  | Verde | Verde | 0% |  |  | 0% | Verde | 0% | 0% | Verde |  |  |  |
| 2687 | 2.3.36.4.3 | Realizar processo de pré-operação |  | 128d | 2021-05-18 | 2021-11-18 | 2686 |  |  | 2021-05-18 | 2021-11-18 | 128d |  |  | 807d | 0d |  | Verde | Verde | 0% |  |  | 0% | Verde | 0% | 0% | Verde |  |  |  |
| 2688 | 2.3.36.4.4 | Recurso da obra parcelado repassado | milestone | 0d | 2021-11-25 | 2021-11-25 | 2687FS+5d |  |  | 2021-11-25 | 2021-11-25 | 0d |  |  | 807d | 0d |  | Verde | Verde | 0% |  |  | 0% | Verde | 0% | 0% | Verde |  |  |  |
| 2689 | 2.3.36.4.5 | Pleito SEPESOB02 concluído | milestone | 0d | 2021-11-25 | 2021-11-25 | 2688 |  |  | 2021-11-25 | 2021-11-25 | 0d |  |  | 807d | 539d |  | Verde | Verde | 0% |  |  | 0% | Verde | 0% | 0% | Verde |  |  |  |

Notes:
- 2673: Em 29/04/2019: atualizado como agendado
- 2676: Em 25/04/2019: obra está em andamento e sendo paga com o recurso da Funasa. Foi considerado que a Renova iniciará o pagamento da obra em 01/06/2019, com base no cálculo da duração da obra da Funasa. Em fevereiro de 2019 a obra estava com avanço de 85% (planilha cronograma). Considerando que o recurso da Funasa é de 3,4 milhões, o que representa 12 meses de acordo com as premissas utilizadas nesse cronograma, 15% seriam mais 5 meses de obra. Portanto, a parte da obra com recurso Funasa será concluída em julho de 2019.
- 2686: Em 25/04/2019: o valor da obra é R$ 1 milhão

| ID | WBS | Task | Type | Duration | Start | Finish | Predecessors | Complete | Remaining | Baseline start | Baseline finish | Baseline duration | Baseline 1 start | Baseline 1 finish | Total slack | Free slack | Farol de Atraso | Farol Marcos | % Previsto Tempo | Índice de Desempenho Físico (IDF) | Farol IDF | % Previsto Ponderado | % Concluído Ponderado | Farol de Início | Responsável | Código do Contrato | % Concluída Numérico | % Previsto Tempo Numérico | IDF Numérico | % Previsto Ponderado Numérico |
| --- | --- | --- | --- | --- | --- | --- | --- | --- | --- | --- | --- | --- | --- | --- | --- | --- | --- | --- | --- | --- | --- | --- | --- | --- | --- | --- | --- | --- | --- | --- |
| 2690 | 2.3.36.5 | **Pleito SEPESOB03 - Construção de fossas e sumiduros em todo o vilarejo de São Paulino e toda a zona rural** |  | 361d | 2020-06-15 | 2021-11-24 |  |  |  | 2020-06-15 | 2021-11-24 | 361d |  |  | 808d |  | Verde | Verde | 0% | 0% | Verde | 0% | 0% |  |  |  |  |  |  |  |
| 2691 | 2.3.36.5.1 | **Licitação da Obra** |  | 80d | 2020-06-15 | 2020-10-06 |  |  |  | 2020-06-15 | 2020-10-06 | 80d |  |  | 808d |  | Verde | Verde | 0% | 0% | Verde | 0% | 0% |  |  |  |  |  |  |  |
| 2692 | 2.3.36.5.1.1 | Licitação da obra autorizada pelo banco | milestone | 0d | 2020-06-15 | 2020-06-15 | 2671 |  |  | 2020-06-15 | 2020-06-15 | 0d |  |  | 808d | 0d | Verde | Verde | 0% | 0% | Verde | 0% | 0% | Verde |  |  |  |  |  |  |
| 2693 | 2.3.36.5.1.2 | Licitar Obra |  | 66d | 2020-06-16 | 2020-09-16 | 2692 |  |  | 2020-06-16 | 2020-09-16 | 66d |  |  | 808d | 0d | Verde | Verde | 0% | 0% | Verde | 0% | 0% | Verde |  |  |  |  |  |  |
| 2694 | 2.3.36.5.1.3 | Analisar e emitir resultado da licitação da obra |  | 14d | 2020-09-17 | 2020-10-06 | 2693 |  |  | 2020-09-17 | 2020-10-06 | 14d |  |  | 808d | 0d | Verde | Verde | 0% | 0% | Verde | 0% | 0% | Verde |  |  |  |  |  |  |
| 2695 | 2.3.36.5.1.4 | Licitação da obra concluída | milestone | 0d | 2020-10-06 | 2020-10-06 | 2694 |  |  | 2020-10-06 | 2020-10-06 | 0d |  |  | 808d | 0d | Verde | Verde | 0% | 0% | Verde | 0% | 0% | Verde |  |  |  |  |  |  |
| 2696 | 2.3.36.5.2 | Executar obra |  | 128d | 2020-11-06 | 2021-05-14 | 2695FS+20d |  |  | 2020-11-06 | 2021-05-14 | 128d |  |  | 808d | 0d | Verde | Verde | 0% | 0% | Verde | 0% | 0% | Verde |  |  |  |  |  |  |
| 2697 | 2.3.36.5.3 | Realizar processo de pré-operação |  | 128d | 2021-05-17 | 2021-11-17 | 2696 |  |  | 2021-05-17 | 2021-11-17 | 128d |  |  | 808d | 0d | Verde | Verde | 0% | 0% | Verde | 0% | 0% | Verde |  |  |  |  |  |  |
| 2698 | 2.3.36.5.4 | Recurso da obra parcelado repassado | milestone | 0d | 2021-11-24 | 2021-11-24 | 2697FS+5d |  |  | 2021-11-24 | 2021-11-24 | 0d |  |  | 808d | 0d | Verde | Verde | 0% | 0% | Verde | 0% | 0% | Verde |  |  |  |  |  |  |
| 2699 | 2.3.36.5.5 | Pleito SEPESOB03 concluído | milestone | 0d | 2021-11-24 | 2021-11-24 | 2698 |  |  | 2021-11-24 | 2021-11-24 | 0d |  |  | 808d | 540d | Verde | Verde | 0% | 0% | Verde | 0% | 0% | Verde |  |  |  |  |  |  |
| 2700 | 2.3.36.6 | **Pleito de Sem Peixe de Resíduos Sólidos a definir** |  | 1096d | 2019-08-30 | 2024-01-29 |  |  |  | 2019-08-30 | 2024-01-29 | 1096d |  |  | 268d |  | Verde | Verde | 0% | 0% | Verde | 0% | 0% |  |  |  |  |  |  |  |
| 2701 | 2.3.36.6.1 | Pleito aprovado | milestone | 0d | 2019-08-30 | 2019-08-30 | 393 |  |  | 2019-08-30 | 2019-08-30 | 0d |  |  | 268d | 0d | Verde | Verde | 0% | 0% | Verde | 0% | 0% | Verde |  |  |  |  |  |  |
| 2702 | 2.3.36.6.2 | Iniciar pleito |  | 1d | 2019-08-30 | 2019-08-30 | 2701 |  |  | 2019-08-30 | 2019-08-30 | 1d |  |  | 268d | 0d | Verde | Verde | 0% | 0% | Verde | 0% | 0% | Verde |  |  |  |  |  |  |
| 2703 | 2.3.36.6.3 | Pleito de Sem-Peixe de Resíduos Sólidos concluído | milestone | 0d | 2024-01-29 | 2024-01-29 | 2702FS+1095d |  |  | 2024-01-29 | 2024-01-29 | 0d |  |  | 268d | 0d | Verde | Verde | 0% | 0% | Verde | 0% | 0% | Verde |  |  |  |  |  |  |
| 2704 | 2.3.36.7 | Recursos de Sem Peixe repassados | milestone | 0d | 2024-01-29 | 2024-01-29 | 2658, 2674, 2679, 2689, 2699, 2703 |  |  | 2024-01-29 | 2024-01-29 | 0d | 2019-04-03 | 2020-07-19 | 268d |  | Verde | Verde | 0% | 0% | Verde | 0% | 0% | Verde | 02 - Execução | PG 031 |  |  |  |  |
| 2705 | 2.3.37 | **Sobrália** |  | 940d | 2018-06-15 A | 2022-03-18 |  | 19% | 765.97d | 2018-06-15 | 2022-03-18 | 940d | 2018-11-05 | 2021-01-23 | 730d |  | Verde | Verde | 23% | 100% | Verde | 2% | 2% |  |  |  | 19 | 23 | 100 |  |
| 2706 | 2.3.37.1 | **Pleito SOBESPJ01 - Elaboração de projetos de sistema de esgotamento sanitário da sede do município e distrito de Plautino Soares.** |  | 265d | 2019-03-15 A | 2020-04-07 |  | 5% | 250.47d | 2019-03-15 | 2020-04-07 | 265d |  |  | 1214d |  | Verde | Verde | 11% | 0% | Vermelho | 6% | 0% |  |  |  |  | 11 |  |  |
| 2707 | 2.3.37.1.1 | **Licitação do Projeto** |  | 65d | 2019-03-15 | 2019-06-18 |  |  |  | 2019-03-15 | 2019-06-18 | 65d |  |  | 30d |  | Verde | Verde | 47% | 0% | Vermelho | 34% | 0% |  |  |  |  | 47 |  | 34 |
| 2708 | 2.3.37.1.1.1 | Licitar projeto |  | 46d | 2019-03-15 | 2019-05-22 | 206FS+62d |  |  | 2019-03-15 | 2019-05-22 | 46d |  |  | 30d | 0d | Verde | Verde | 67% | 0% | Vermelho | 67% | 0% | Verde |  |  |  | 67 |  | 67 |
| 2709 | 2.3.37.1.1.2 | Documentação de licitação apresentada ao banco | milestone | 0d | 2019-05-29 | 2019-05-29 | 2708FS+5d |  |  | 2019-05-29 | 2019-05-29 | 0d |  |  | 730d | 0d | Verde | Verde | 0% | 0% | Verde | 0% | 0% | Verde |  |  |  |  |  |  |
| 2710 | 2.3.37.1.1.3 | Analisar e emitir resultado da licitação do projeto |  | 14d | 2019-05-30 | 2019-06-18 | 2709 |  |  | 2019-05-30 | 2019-06-18 | 14d |  |  | 730d | 0d | Verde | Verde | 0% | 0% | Verde | 0% | 0% | Verde |  |  |  |  |  |  |
| 2711 | 2.3.37.1.1.4 | Licitação do projeto concluída | milestone | 0d | 2019-06-18 | 2019-06-18 | 2710 |  |  | 2019-06-18 | 2019-06-18 | 0d |  |  | 730d | 0d | Verde | Verde | 0% | 0% | Verde | 0% | 0% | Verde |  |  |  |  |  |  |
| 2712 | 2.3.37.1.2 | **Elaboração do Projeto Básico** |  | 132d | 2019-06-19 | 2019-12-27 |  |  |  | 2019-06-19 | 2019-12-27 | 132d |  |  | 730d |  | Verde | Verde | 0% | 0% | Verde | 0% | 0% |  |  |  |  |  |  |  |
| 2713 | 2.3.37.1.2.1 | Elaborar Projeto Básico |  | 64d | 2019-06-19 | 2019-09-18 | 2711 |  |  | 2019-06-19 | 2019-09-18 | 64d |  |  | 730d | 0d | Verde | Verde | 0% | 0% | Verde | 0% | 0% | Verde |  |  |  |  |  |  |
| 2714 | 2.3.37.1.2.2 | Projeto básico apresentado ao banco | milestone | 0d | 2019-09-18 | 2019-09-18 | 2713 |  |  | 2019-09-18 | 2019-09-18 | 0d |  |  | 730d | 0d | Verde | Verde | 0% | 0% | Verde | 0% | 0% | Verde |  |  |  |  |  |  |
| 2715 | 2.3.37.1.2.3 | Analisar projeto básico |  | 20d | 2019-09-19 | 2019-10-16 | 2714 |  |  | 2019-09-19 | 2019-10-16 | 20d |  |  | 793d | 0d | Verde | Verde | 0% | 0% | Verde | 0% | 0% | Verde |  |  |  |  |  |  |
| 2716 | 2.3.37.1.2.4 | Adequar/revisar projeto básico |  | 21d | 2019-10-17 | 2019-11-14 | 2715 |  |  | 2019-10-17 | 2019-11-14 | 21d |  |  | 793d | 0d | Verde | Verde | 0% | 0% | Verde | 0% | 0% | Verde |  |  |  |  |  |  |
| 2717 | 2.3.37.1.2.5 | Analisar projeto básico - final |  | 22d | 2019-11-18 | 2019-12-18 | 2716 |  |  | 2019-11-18 | 2019-12-18 | 22d |  |  | 793d | 0d | Verde | Verde | 0% | 0% | Verde | 0% | 0% | Verde |  |  |  |  |  |  |
| 2718 | 2.3.37.1.2.6 | Projeto básico concluído | milestone | 0d | 2019-12-18 | 2019-12-18 | 2717 |  |  | 2019-12-18 | 2019-12-18 | 0d |  |  | 793d | 0d | Verde | Verde | 0% | 0% | Verde | 0% | 0% | Verde |  |  |  |  |  |  |
| 2719 | 2.3.37.1.2.7 | Recurso do projeto básico do pleito SOBESPJ01 repassado | milestone | 0d | 2019-12-27 | 2019-12-27 | 2718FS+5d |  |  | 2019-12-27 | 2019-12-27 | 0d |  |  | 793d | 63d | Verde | Verde | 0% | 0% | Verde | 0% | 0% | Verde |  |  |  |  |  |  |
| 2720 | 2.3.37.1.3 | Realizar Licenciamento Ambiental |  | 229d | 2019-03-18 A | 2020-02-13 | 2708SS+1d | 13% | 199d | 2019-03-18 | 2020-02-13 | 229d | 2019-01-04 | 2019-07-03 | 760d | 30d | Verde | Verde | 13% | 0% | Vermelho | 13% | 0% | Verde | 02 - Execução | PG 031 | 13 | 13 |  | 13 |

Notes:
- 2696: Em 25/04/2019: valor da obra R$ 1 milhão
- 2704: Valor de recurso destinado ao munícipio: R$4.726.993,07
- 2705: Sobrália teve 100% dos pleitos de Esgotamento Sanitário Aprovado (R$4.254.193,76), conforme Deliberação 75. / O município teve 0,8%, dos 10% do valor teto destinado a Resíduos Sólidos aprovado (R$37.131,34). / Aderiu à ata de registro de preço.
- 2708: Em 25/04/2019: dia 15/03/2019 o município informou ao banco que foi cancelado o processo licitatório anterior. Considerado o início do novo processo em seguida. / Em 29/04/2019: atualizado como agendado
- 2720: 25/01/19 - Não foram iniciados / Em 29/04/2019: atualizado como agendado

| ID | WBS | Task | Type | Duration | Start | Finish | Predecessors | Complete | Remaining | Baseline start | Baseline finish | Baseline duration | Baseline 1 start | Baseline 1 finish | Total slack | Free slack | Farol de Atraso | Farol Marcos | % Previsto Tempo | Índice de Desempenho Físico (IDF) | Farol IDF | % Previsto Ponderado | % Concluído Ponderado | Farol de Início | % Concluída Numérico | % Previsto Tempo Numérico | IDF Numérico | % Previsto Ponderado Numérico | % Concluído Ponderado Numérico | Responsável | Código do Contrato |
| --- | --- | --- | --- | --- | --- | --- | --- | --- | --- | --- | --- | --- | --- | --- | --- | --- | --- | --- | --- | --- | --- | --- | --- | --- | --- | --- | --- | --- | --- | --- | --- |
| 2721 | 2.3.37.1.4 | **Elaboração do Projeto Executivo** |  | 136d | 2019-09-19 | 2020-04-07 |  |  |  | 2019-09-19 | 2020-04-07 | 136d |  |  | 730d |  | Verde | Verde | 0% | 0% | Verde | 0% | 0% |  |  |  |  |  |  |  |  |
| 2722 | 2.3.37.1.4.1 | Elaborar Projeto Executivo |  | 64d | 2019-09-19 | 2019-12-19 | 2714 |  |  | 2019-09-19 | 2019-12-19 | 64d |  |  | 730d | 0d | Verde | Verde | 0% | 0% | Verde | 0% | 0% | Verde |  |  |  |  |  |  |  |
| 2723 | 2.3.37.1.4.2 | Analisar projeto executivo |  | 21d | 2019-12-20 | 2020-01-22 | 2722 |  |  | 2019-12-20 | 2020-01-22 | 21d |  |  | 730d | 0d | Verde | Verde | 0% | 0% | Verde | 0% | 0% | Verde |  |  |  |  |  |  |  |
| 2724 | 2.3.37.1.4.3 | Adequar/revisar projeto executivo |  | 23d | 2020-01-23 | 2020-02-27 | 2723 |  |  | 2020-01-23 | 2020-02-27 | 23d |  |  | 730d | 0d | Verde | Verde | 0% | 0% | Verde | 0% | 0% | Verde |  |  |  |  |  |  |  |
| 2725 | 2.3.37.1.4.4 | Analisar projeto executivo |  | 23d | 2020-02-28 | 2020-03-31 | 2724 |  |  | 2020-02-28 | 2020-03-31 | 23d |  |  | 730d | 0d | Verde | Verde | 0% | 0% | Verde | 0% | 0% | Verde |  |  |  |  |  |  |  |
| 2726 | 2.3.37.1.4.5 | Projeto executivo concluído | milestone | 0d | 2020-03-31 | 2020-03-31 | 2725, 2719, 2720 |  |  | 2020-03-31 | 2020-03-31 | 0d |  |  | 730d | 0d | Verde | Verde | 0% | 0% | Verde | 0% | 0% | Verde |  |  |  |  |  |  |  |
| 2727 | 2.3.37.1.4.6 | Recurso do projeto executivo do pleito SOBESPJ01 repassado | milestone | 0d | 2020-04-07 | 2020-04-07 | 2726FS+5d |  |  | 2020-04-07 | 2020-04-07 | 0d |  |  | 1214d | 0d | Verde | Verde | 0% | 0% | Verde | 0% | 0% | Verde |  |  |  |  |  |  |  |
| 2728 | 2.3.37.1.5 | Pleito SOBESPJ01 concluído | milestone | 0d | 2020-04-07 | 2020-04-07 | 2727 |  |  | 2020-04-07 | 2020-04-07 | 0d |  |  | 1214d | 484d | Verde | Verde | 0% | 0% | Verde | 0% | 0% | Verde |  |  |  |  |  |  |  |
| 2729 | 2.3.37.2 | **Pleito de Sobrália a definir - Aquisição de Imóvel** |  | 157d | 2018-11-29 A | 2019-07-17 |  | 58% | 66.11d | 2018-11-29 | 2019-07-17 | 157d |  |  | 1394d |  | Verde | Verde | 65% | 90% | Vermelho | 67% | 60% |  | 58 | 65 | 90 | 67 | 60 |  |  |
| 2730 | 2.3.37.2.1 | Pleito aprovado | milestone | 0d | 2018-11-29 A | 2018-11-29 A | 206FS-10d | 100% |  | 2018-11-29 | 2018-11-29 | 0d |  |  |  |  | Verde | Verde | 100% | 0% | Vermelho | 100% | 0% | Verde | 100 | 100 |  | 100 |  |  |  |
| 2731 | 2.3.37.2.2 | **Aquisição de Imóvel** |  | 147d | 2018-12-13 A | 2019-07-17 |  | 58% | 61.89d | 2018-12-13 | 2019-07-17 | 147d |  |  | 1394d |  | Verde | Verde | 63% | 90% | Vermelho | 67% | 60% |  | 58 | 63 | 90 | 67 | 60 |  |  |
| 2732 | 2.3.37.2.2.1 | Regularizar terreno e apresentar escritura ao banco |  | 88d | 2018-12-13 A | 2019-04-23 A | 2730FS+10d | 100% |  | 2018-12-13 | 2019-04-23 | 88d |  |  |  |  | Verde | Verde | 100% | 100% | Verde | 100% | 100% | Verde | 100 | 100 | 100 | 100 | 100 |  |  |
| 2733 | 2.3.37.2.2.2 | Analisar documentação do terreno |  | 10d | 2019-04-24 | 2019-05-08 | 2732 |  |  | 2019-04-24 | 2019-05-08 | 10d |  |  | 1438d | 0d | Verde | Verde | 50% | 0% | Vermelho | 50% | 0% | Verde |  | 50 |  | 50 |  |  |  |
| 2734 | 2.3.37.2.2.3 | 50% do valor do imóvel repassado (1) | milestone | 0d | 2019-05-15 | 2019-05-15 | 2733FS+5d |  |  | 2019-05-15 | 2019-05-15 | 0d |  |  | 1438d | 44d | Verde | Verde | 0% | 0% | Verde | 0% | 0% | Verde |  |  |  |  |  |  |  |
| 2735 | 2.3.37.2.2.4 | Registrar imóvel e apresentar documentação ao banco |  | 44d | 2019-04-24 | 2019-06-26 | 2732 |  |  | 2019-04-24 | 2019-06-26 | 44d |  |  | 1394d | 0d | Verde | Verde | 11% | 0% | Vermelho | 11% | 0% | Verde |  | 11 |  | 11 |  |  |  |
| 2736 | 2.3.37.2.2.5 | Analisar documentação do terreno |  | 10d | 2019-06-27 | 2019-07-10 | 2735 |  |  | 2019-06-27 | 2019-07-10 | 10d |  |  | 1394d | 0d | Verde | Verde | 0% | 0% | Verde | 0% | 0% | Verde |  |  |  |  |  |  |  |
| 2737 | 2.3.37.2.2.6 | 50% do valor do imóvel repassado (2) | milestone | 0d | 2019-07-17 | 2019-07-17 | 2736FS+5d |  |  | 2019-07-17 | 2019-07-17 | 0d |  |  | 1394d | 0d | Verde | Verde | 0% | 0% | Verde | 0% | 0% | Verde |  |  |  |  |  |  |  |
| 2738 | 2.3.37.2.2.7 | Aquisição do imóvel concluída | milestone | 0d | 2019-07-17 | 2019-07-17 | 2734, 2737 |  |  | 2019-07-17 | 2019-07-17 | 0d |  |  | 1394d | 0d | Verde | Verde | 0% | 0% | Verde | 0% | 0% | Verde |  |  |  |  |  |  |  |
| 2739 | 2.3.37.2.3 | Pleito de Sobrália a definir concluído | milestone | 0d | 2019-07-17 | 2019-07-17 | 2738 |  |  | 2019-07-17 | 2019-07-17 | 0d |  |  | 1394d | 664d | Verde | Verde | 0% | 0% | Verde | 0% | 0% | Verde |  |  |  |  |  |  |  |
| 2740 | 2.3.37.3 | **Pleito SOBESOB01 - Implantação de sistema de esgotamento sanitário da sede do município e distrito de Plautino Soares.** |  | 489d | 2020-03-31 | 2022-03-18 |  |  |  | 2020-03-31 | 2022-03-18 | 489d |  |  | 730d |  | Verde | Verde | 0% | 0% | Verde | 0% | 0% |  |  |  |  |  |  |  |  |
| 2741 | 2.3.37.3.1 | **Licitação da Obra** |  | 77d | 2020-03-31 | 2020-07-22 |  |  |  | 2020-03-31 | 2020-07-22 | 77d |  |  | 730d |  | Verde | Verde | 0% | 0% | Verde | 0% | 0% |  |  |  |  |  |  |  |  |
| 2742 | 2.3.37.3.1.1 | Licitação da obra autorizada pelo banco | milestone | 0d | 2020-03-31 | 2020-03-31 | 2726 |  |  | 2020-03-31 | 2020-03-31 | 0d |  |  | 730d | 0d | Verde | Verde | 0% | 0% | Verde | 0% | 0% | Verde |  |  |  |  |  |  |  |
| 2743 | 2.3.37.3.1.2 | Licitar Obra |  | 62d | 2020-04-01 | 2020-07-01 | 2742 |  |  | 2020-04-01 | 2020-07-01 | 62d | 2019-04-04 | 2019-08-02 | 730d | 0d | Verde | Verde | 0% | 0% | Verde | 0% | 0% | Verde |  |  |  |  |  | 02 - Execução | PG 031 |
| 2744 | 2.3.37.3.1.3 | Analisar e emitir resultado da licitação da obra |  | 15d | 2020-07-02 | 2020-07-22 | 2743 |  |  | 2020-07-02 | 2020-07-22 | 15d |  |  | 730d | 0d | Verde | Verde | 0% | 0% | Verde | 0% | 0% | Verde |  |  |  |  |  |  |  |
| 2745 | 2.3.37.3.1.4 | Licitação da obra concluída | milestone | 0d | 2020-07-22 | 2020-07-22 | 2744 |  |  | 2020-07-22 | 2020-07-22 | 0d |  |  | 730d | 0d | Verde | Verde | 0% | 0% | Verde | 0% | 0% | Verde |  |  |  |  |  |  |  |
| 2746 | 2.3.37.3.2 | Executar obra |  | 257d | 2020-08-20 | 2021-08-31 | 2745FS+20d |  |  | 2020-08-20 | 2021-08-31 | 257d |  |  | 730d | 0d | Verde | Verde | 0% | 0% | Verde | 0% | 0% | Verde |  |  |  |  |  |  |  |
| 2747 | 2.3.37.3.3 | Realizar processo de pré-operação |  | 130d | 2021-09-01 | 2022-03-11 | 2746 |  |  | 2021-09-01 | 2022-03-11 | 130d | 2020-07-27 | 2021-01-23 | 730d | 0d | Verde | Verde | 0% | 0% | Verde | 0% | 0% | Verde |  |  |  |  |  | 02 - Execução | PG 031 |
| 2748 | 2.3.37.3.4 | Recurso da obra parcelado repassado | milestone | 0d | 2022-03-18 | 2022-03-18 | 2747FS+5d |  |  | 2022-03-18 | 2022-03-18 | 0d |  |  | 730d | 0d | Verde | Verde | 0% | 0% | Verde | 0% | 0% | Verde |  |  |  |  |  |  |  |
| 2749 | 2.3.37.3.5 | Pleito SOBESOB01 concluído | milestone | 0d | 2022-03-18 | 2022-03-18 | 2748 |  |  | 2022-03-18 | 2022-03-18 | 0d |  |  | 730d | 0d | Verde | Verde | 0% | 0% | Verde | 0% | 0% | Verde |  |  |  |  |  |  |  |

Notes:
- 2730: Em 25/04/2019: o pleito será apresentado dia 20/09/2019 e será aprovado na CT/CIF final de novembro (NT33)

| ID | WBS | Task | Type | Duration | Start | Finish | Predecessors | Complete | Remaining | Baseline start | Baseline finish | Baseline duration | Baseline 1 start | Baseline 1 finish | Total slack | Free slack | Farol de Atraso | Farol Marcos | % Previsto Tempo | % Concluída Numérico | % Previsto Tempo Numérico | Índice de Desempenho Físico (IDF) | IDF Numérico | Farol IDF | % Previsto Ponderado | % Concluído Ponderado | % Previsto Ponderado Numérico | % Concluído Ponderado Numérico | Farol de Início | Responsável | Código do Contrato |
| --- | --- | --- | --- | --- | --- | --- | --- | --- | --- | --- | --- | --- | --- | --- | --- | --- | --- | --- | --- | --- | --- | --- | --- | --- | --- | --- | --- | --- | --- | --- | --- |
| 2750 | 2.3.37.4 | **Pleito SOBRSPM01 - Elaboração de estudos de viabilidade para concepção dos serviços de infraestrutura de sistemas integrados de destinação final de resíduos sólidos urbanos, assim como educação ambiental e programa de coleta seletiva no valor** |  | 437d | 2018-06-15 A | 2020-03-11 |  | 45% | 241.47d | 2018-06-15 | 2020-03-11 | 437d |  |  | 1233d |  | Verde | Verde | 50% | 45 | 50 | 100% | 100 | Verde | 6% | 6% |  |  |  |  |  |
| 2751 | 2.3.37.4.1 | **Licitação de Empresa para Estudo de Viabilidade** |  | 283d | 2018-06-15 A | 2019-07-26 |  | 75% | 71.39d | 2018-06-15 | 2019-07-26 | 283d |  |  | 1233d |  | Verde | Verde | 78% | 75 | 78 | 95% | 95 | Vermelho | 63% | 60% | 63 | 60 |  |  |  |
| 2752 | 2.3.37.4.1.1 | Licitação da empresa para Estudo de Viabilidade autorizada pelo banco | milestone | 0d | 2018-06-15 A | 2018-06-15 A | 313 | 100% |  | 2018-06-15 | 2018-06-15 | 0d |  |  |  |  | Verde | Verde | 100% | 100 | 100 | 0% |  | Vermelho | 100% | 0% | 100 |  | Verde |  |  |
| 2753 | 2.3.37.4.1.2 | Licitar empresa para Estudo de Viabilidade |  | 208d | 2018-09-03 A | 2019-07-01 | 2752FS+56d | 80% | 42d | 2018-09-03 | 2019-07-01 | 208d |  |  | 1233d | 0d | Verde | Verde | 79% | 80 | 79 | 95% | 95 | Vermelho | 79% | 75% | 79 | 75 | Verde |  |  |
| 2754 | 2.3.37.4.1.3 | Documentação de licitação apresentada ao banco | milestone | 0d | 2019-07-08 | 2019-07-08 | 2753FS+5d |  |  | 2019-07-08 | 2019-07-08 | 0d |  |  | 1233d | 0d | Verde | Verde | 0% |  |  | 0% |  | Verde | 0% | 0% |  |  | Verde |  |  |
| 2755 | 2.3.37.4.1.4 | Analisar e emitir resultado da licitação da empresa para Estudo de Viabilidade |  | 14d | 2019-07-09 | 2019-07-26 | 2754 |  |  | 2019-07-09 | 2019-07-26 | 14d |  |  | 1233d | 0d | Verde | Verde | 0% |  |  | 0% |  | Verde | 0% | 0% |  |  | Verde |  |  |
| 2756 | 2.3.37.4.1.5 | Licitação da empresa para Estudo de Viabilidade concluída | milestone | 0d | 2019-07-26 | 2019-07-26 | 2755 |  |  | 2019-07-26 | 2019-07-26 | 0d |  |  | 1233d | 0d | Verde | Verde | 0% |  |  | 0% |  | Verde | 0% | 0% |  |  | Verde |  |  |
| 2757 | 2.3.37.4.2 | **Elaboração do estudo de viabilidade** |  | 149d | 2019-07-29 | 2020-03-04 |  |  |  | 2019-07-29 | 2020-03-04 | 149d |  |  | 1233d |  | Verde | Verde | 0% |  |  | 0% |  | Verde | 0% | 0% |  |  |  |  |  |
| 2758 | 2.3.37.4.2.1 | Elaborar estudo de viabilidade |  | 88d | 2019-07-29 | 2019-11-29 | 2756 |  |  | 2019-07-29 | 2019-11-29 | 88d |  |  | 1233d | 0d | Verde | Verde | 0% |  |  | 0% |  | Verde | 0% | 0% |  |  | Verde |  |  |
| 2759 | 2.3.37.4.2.2 | Analisar estudo |  | 20d | 2019-12-02 | 2020-01-02 | 2758 |  |  | 2019-12-02 | 2020-01-02 | 20d |  |  | 1233d | 0d | Verde | Verde | 0% |  |  | 0% |  | Verde | 0% | 0% |  |  | Verde |  |  |
| 2760 | 2.3.37.4.2.3 | Adequar/revisar estudo |  | 22d | 2020-01-03 | 2020-02-03 | 2759 |  |  | 2020-01-03 | 2020-02-03 | 22d |  |  | 1233d | 0d | Verde | Verde | 0% |  |  | 0% |  | Verde | 0% | 0% |  |  | Verde |  |  |
| 2761 | 2.3.37.4.2.4 | Analisar estudo - final |  | 19d | 2020-02-04 | 2020-03-04 | 2760 |  |  | 2020-02-04 | 2020-03-04 | 19d |  |  | 1233d | 0d | Verde | Verde | 0% |  |  | 0% |  | Verde | 0% | 0% |  |  | Verde |  |  |
| 2762 | 2.3.37.4.2.5 | Estudo concluído | milestone | 0d | 2020-03-04 | 2020-03-04 | 2761 |  |  | 2020-03-04 | 2020-03-04 | 0d |  |  | 1233d | 0d | Verde | Verde | 0% |  |  | 0% |  | Verde | 0% | 0% |  |  | Verde |  |  |
| 2763 | 2.3.37.4.3 | Recurso do serviço repassado | milestone | 0d | 2020-03-11 | 2020-03-11 | 2762FS+5d |  |  | 2020-03-11 | 2020-03-11 | 0d |  |  | 1233d | 0d | Verde | Verde | 0% |  |  | 0% |  | Verde | 0% | 0% |  |  | Verde |  |  |
| 2764 | 2.3.37.4.4 | Pleito SOBRSPM01 concluído | milestone | 0d | 2020-03-11 | 2020-03-11 | 2763 |  |  | 2020-03-11 | 2020-03-11 | 0d |  |  | 1233d | 503d | Verde | Verde | 0% |  |  | 0% |  | Verde | 0% | 0% |  |  | Verde |  |  |
| 2765 | 2.3.37.5 | Recursos de Sobrália repassados | milestone | 0d | 2022-03-18 | 2022-03-18 | 2728, 2739, 2749, 2764 |  |  | 2022-03-18 | 2022-03-18 | 0d | 2019-05-04 | 2021-01-23 | 730d |  | Verde | Verde | 0% |  |  | 0% |  | Verde | 0% | 0% |  |  | Verde | 02 - Execução | PG 031 |
| 2766 | 2.3.38 | **Timóteo** |  | 765d | 2019-05-03 | 2022-05-30 |  |  |  | 2019-05-03 | 2022-05-30 | 765d | 2019-01-08 | 2021-10-24 | 681d |  | Verde | Verde | 0% |  |  | 0% |  | Verde | 0% | 0% |  |  |  |  |  |
| 2767 | 2.3.38.1 | **Pleito TIMRSPM01 - Estudos de viabilidade para a implantação de aterro sanitário regional** |  | 217d | 2019-05-03 | 2020-03-17 |  |  |  | 2019-05-03 | 2020-03-17 | 217d |  |  | 1229d |  | Verde | Verde | 0% |  |  | 0% |  | Verde | 0% | 0% |  |  |  |  |  |
| 2768 | 2.3.38.1.1 | **Licitação de Empresa para Estudo de Viabilidade** |  | 63d | 2019-05-03 | 2019-08-01 |  |  |  | 2019-05-03 | 2019-08-01 | 63d |  |  | 1229d |  | Verde | Verde | 0% |  |  | 0% |  | Verde | 0% | 0% |  |  |  |  |  |
| 2769 | 2.3.38.1.1.1 | Licitação da empresa para Estudo de Viabilidade autorizada pelo banco | milestone | 0d | 2019-05-03 | 2019-05-03 | 1133 |  |  | 2019-05-03 | 2019-05-03 | 0d |  |  | 1229d | 0d | Verde | Verde | 0% |  |  | 0% |  | Verde | 0% | 0% |  |  | Verde |  |  |
| 2770 | 2.3.38.1.1.2 | Licitar empresa para Estudo de Viabilidade |  | 44d | 2019-05-06 | 2019-07-05 | 2769 |  |  | 2019-05-06 | 2019-07-05 | 44d |  |  | 1229d | 0d | Verde | Verde | 0% |  |  | 0% |  | Verde | 0% | 0% |  |  | Verde |  |  |
| 2771 | 2.3.38.1.1.3 | Documentação de licitação apresentada ao banco | milestone | 0d | 2019-07-12 | 2019-07-12 | 2770FS+5d |  |  | 2019-07-12 | 2019-07-12 | 0d |  |  | 1229d | 0d | Verde | Verde | 0% |  |  | 0% |  | Verde | 0% | 0% |  |  | Verde |  |  |
| 2772 | 2.3.38.1.1.4 | Analisar e emitir resultado da licitação da empresa para Estudo de Viabilidade |  | 14d | 2019-07-15 | 2019-08-01 | 2771 |  |  | 2019-07-15 | 2019-08-01 | 14d |  |  | 1229d | 0d | Verde | Verde | 0% |  |  | 0% |  | Verde | 0% | 0% |  |  | Verde |  |  |
| 2773 | 2.3.38.1.1.5 | Licitação da empresa para Estudo de Viabilidade concluída | milestone | 0d | 2019-08-01 | 2019-08-01 | 2772 |  |  | 2019-08-01 | 2019-08-01 | 0d |  |  | 1229d | 0d | Verde | Verde | 0% |  |  | 0% |  | Verde | 0% | 0% |  |  | Verde |  |  |

Notes:
- 2753: Em 29/04/2019: atualizado como agendado
- 2765: Valor de recurso destinado ao munícipio: R$4.726.993,07
- 2766: Timóteo solicitou mudança de pleito e foi autorizado pelo CIF na NT21. / ·Alteração de pleito e da proporção 90% para Esgotamento Sanitário e 10% para Resíduos Sólidos./ ·Com o novo pleito aprovado Timóteo terá 18% (R$3.970.674,18) para Esgotamento Sanitário e 82% para Resíduos Sólidos. / Já foi autorizado 18% (R$3.970.674,18) para Esgotamento Sanitário e 21,7%(R$4.783.065,71) para Resíduos Sólidos.

| ID | WBS | Task | Type | Duration | Start | Finish | Predecessors | Baseline start | Baseline finish | Baseline duration | Total slack | Free slack | Farol de Atraso | Farol Marcos | % Previsto Tempo | Índice de Desempenho Físico (IDF) | Farol IDF | % Previsto Ponderado | % Concluído Ponderado | Farol de Início |
| --- | --- | --- | --- | --- | --- | --- | --- | --- | --- | --- | --- | --- | --- | --- | --- | --- | --- | --- | --- | --- |
| 2774 | 2.3.38.1.2 | **Elaboração do estudo de viabilidade** |  | 149d | 2019-08-02 | 2020-03-10 |  | 2019-08-02 | 2020-03-10 | 149d | 1229d |  | Verde | Verde | 0% | 0% | Verde | 0% | 0% |  |
| 2775 | 2.3.38.1.2.1 | Elaborar estudo de viabilidade |  | 88d | 2019-08-02 | 2019-12-05 | 2773 | 2019-08-02 | 2019-12-05 | 88d | 1229d | 0d | Verde | Verde | 0% | 0% | Verde | 0% | 0% | Verde |
| 2776 | 2.3.38.1.2.2 | Analisar estudo |  | 20d | 2019-12-06 | 2020-01-08 | 2775 | 2019-12-06 | 2020-01-08 | 20d | 1229d | 0d | Verde | Verde | 0% | 0% | Verde | 0% | 0% | Verde |
| 2777 | 2.3.38.1.2.3 | Adequar/revisar estudo |  | 22d | 2020-01-09 | 2020-02-07 | 2776 | 2020-01-09 | 2020-02-07 | 22d | 1229d | 0d | Verde | Verde | 0% | 0% | Verde | 0% | 0% | Verde |
| 2778 | 2.3.38.1.2.4 | Analisar estudo - final |  | 19d | 2020-02-10 | 2020-03-10 | 2777 | 2020-02-10 | 2020-03-10 | 19d | 1229d | 0d | Verde | Verde | 0% | 0% | Verde | 0% | 0% | Verde |
| 2779 | 2.3.38.1.2.5 | Estudo concluído | milestone | 0d | 2020-03-10 | 2020-03-10 | 2778 | 2020-03-10 | 2020-03-10 | 0d | 1229d | 0d | Verde | Verde | 0% | 0% | Verde | 0% | 0% | Verde |
| 2780 | 2.3.38.1.3 | Recurso do serviço repassado | milestone | 0d | 2020-03-17 | 2020-03-17 | 2779FS+5d | 2020-03-17 | 2020-03-17 | 0d | 1229d | 0d | Verde | Verde | 0% | 0% | Verde | 0% | 0% | Verde |
| 2781 | 2.3.38.1.4 | Pleito TIMRSPM01 concluído | milestone | 0d | 2020-03-17 | 2020-03-17 | 2780 | 2020-03-17 | 2020-03-17 | 0d | 1229d | 548d | Verde | Verde | 0% | 0% | Verde | 0% | 0% | Verde |
| 2782 | 2.3.38.2 | **Pleito TIMRSPJ01 - Erradicação do lixão** |  | 672d | 2019-06-28 | 2022-03-10 |  | 2019-06-28 | 2022-03-10 | 672d | 736d |  | Verde | Verde | 0% | 0% | Verde | 0% | 0% |  |
| 2783 | 2.3.38.2.1 | Iniciar pleito |  | 1d | 2019-06-28 | 2019-06-28 | 206FS+133d | 2019-06-28 | 2019-06-28 | 1d | 736d | 0d | Verde | Verde | 0% | 0% | Verde | 0% | 0% | Verde |
| 2784 | 2.3.38.2.2 | Pleito TIMRSPJ01 concluído | milestone | 0d | 2022-03-10 | 2022-03-10 | 2783FS+671d | 2022-03-10 | 2022-03-10 | 0d | 736d | 55d | Verde | Verde | 0% | 0% | Verde | 0% | 0% | Verde |
| 2785 | 2.3.38.3 | **Pleito a definir - Projeto** |  | 206d | 2019-08-30 | 2020-07-01 |  | 2019-08-30 | 2020-07-01 | 206d | 681d |  | Verde | Verde | 0% | 0% | Verde | 0% | 0% |  |
| 2786 | 2.3.38.3.1 | Pleito aprovado | milestone | 0d | 2019-08-30 | 2019-08-30 | 206FS+178d | 2019-08-30 | 2019-08-30 | 0d | 681d | 0d | Verde | Verde | 0% | 0% | Verde | 0% | 0% | Verde |
| 2787 | 2.3.38.3.2 | **Licitação do Projeto** |  | 60d | 2019-09-13 | 2019-12-09 |  | 2019-09-13 | 2019-12-09 | 60d | 681d |  | Verde | Verde | 0% | 0% | Verde | 0% | 0% |  |
| 2788 | 2.3.38.3.2.1 | Licitação do projeto autorizada pelo banco | milestone | 0d | 2019-09-13 | 2019-09-13 | 2786FS+10d | 2019-09-13 | 2019-09-13 | 0d | 681d | 0d | Verde | Verde | 0% | 0% | Verde | 0% | 0% | Verde |
| 2789 | 2.3.38.3.2.2 | Licitar projeto |  | 41d | 2019-09-16 | 2019-11-11 | 2788 | 2019-09-16 | 2019-11-11 | 41d | 681d | 0d | Verde | Verde | 0% | 0% | Verde | 0% | 0% | Verde |
| 2790 | 2.3.38.3.2.3 | Documentação de licitação apresentada ao banco | milestone | 0d | 2019-11-19 | 2019-11-19 | 2789FS+5d | 2019-11-19 | 2019-11-19 | 0d | 681d | 0d | Verde | Verde | 0% | 0% | Verde | 0% | 0% | Verde |
| 2791 | 2.3.38.3.2.4 | Analisar e emitir resultado da licitação do projeto |  | 14d | 2019-11-20 | 2019-12-09 | 2790 | 2019-11-20 | 2019-12-09 | 14d | 681d | 0d | Verde | Verde | 0% | 0% | Verde | 0% | 0% | Verde |
| 2792 | 2.3.38.3.2.5 | Licitação do projeto concluída | milestone | 0d | 2019-12-09 | 2019-12-09 | 2791 | 2019-12-09 | 2019-12-09 | 0d | 681d | 0d | Verde | Verde | 0% | 0% | Verde | 0% | 0% | Verde |
| 2793 | 2.3.38.3.3 | Realizar licenciamento ambiental |  | 48d | 2019-09-02 | 2019-11-06 | 2814SS | 2019-09-02 | 2019-11-06 | 48d | 834d | 153d | Verde | Verde | 0% | 0% | Verde | 0% | 0% | Verde |
| 2794 | 2.3.38.3.4 | **Elaboração de Projeto Executivo** |  | 136d | 2019-12-10 | 2020-07-01 |  | 2019-12-10 | 2020-07-01 | 136d | 681d |  | Verde | Verde | 0% | 0% | Verde | 0% | 0% |  |
| 2795 | 2.3.38.3.4.1 | Elaborar Projeto Executivo |  | 66d | 2019-12-10 | 2020-03-19 | 2792 | 2019-12-10 | 2020-03-19 | 66d | 681d | 0d | Verde | Verde | 0% | 0% | Verde | 0% | 0% | Verde |
| 2796 | 2.3.38.3.4.2 | Projeto executivo apresentado ao banco | milestone | 0d | 2020-03-19 | 2020-03-19 | 2795 | 2020-03-19 | 2020-03-19 | 0d | 681d | 0d | Verde | Verde | 0% | 0% | Verde | 0% | 0% | Verde |
| 2797 | 2.3.38.3.4.3 | Analisar projeto executivo |  | 20d | 2020-03-20 | 2020-04-17 | 2796 | 2020-03-20 | 2020-04-17 | 20d | 681d | 0d | Verde | Verde | 0% | 0% | Verde | 0% | 0% | Verde |
| 2798 | 2.3.38.3.4.4 | Adequar/revisar projeto executivo |  | 23d | 2020-04-20 | 2020-05-22 | 2797 | 2020-04-20 | 2020-05-22 | 23d | 681d | 0d | Verde | Verde | 0% | 0% | Verde | 0% | 0% | Verde |
| 2799 | 2.3.38.3.4.5 | Analisar projeto executivo - final |  | 22d | 2020-05-25 | 2020-06-24 | 2798 | 2020-05-25 | 2020-06-24 | 22d | 681d | 0d | Verde | Verde | 0% | 0% | Verde | 0% | 0% | Verde |
| 2800 | 2.3.38.3.4.6 | Projeto executivo concluído | milestone | 0d | 2020-06-24 | 2020-06-24 | 2799, 2793 | 2020-06-24 | 2020-06-24 | 0d | 681d | 0d | Verde | Verde | 0% | 0% | Verde | 0% | 0% | Verde |
| 2801 | 2.3.38.3.4.7 | Recurso do projeto executivo do pleito repassado | milestone | 0d | 2020-07-01 | 2020-07-01 | 2800FS+5d | 2020-07-01 | 2020-07-01 | 0d | 1157d | 0d | Verde | Verde | 0% | 0% | Verde | 0% | 0% | Verde |
| 2802 | 2.3.38.3.5 | Pleito concluído | milestone | 0d | 2020-07-01 | 2020-07-01 | 2801 | 2020-07-01 | 2020-07-01 | 0d | 1157d | 476d | Verde | Verde | 0% | 0% | Verde | 0% | 0% | Verde |

Notes:
- 2783: Em 24/04/2019: foi considerado o início do pleito 30/06/2019 em virtude da dependência da contrapartida financeira de Coronel Fabriciano, ainda pendente de negociação.
- 2784: Em 24/09/2019: Foram considerados os prazos de aprovação de projeto, licenciamento e obra (conforme valor do pleito)
- 2786: Em 25/04/2019: considerado que o pleito será aprovado na próxima CIF no dia 30/08/2019 conforme NT33

| ID | WBS | Task | Type | Duration | Start | Finish | Predecessors | Baseline start | Baseline finish | Baseline duration | Baseline 1 start | Baseline 1 finish | Total slack | Free slack | Farol de Atraso | Farol Marcos | % Previsto Tempo | Índice de Desempenho Físico (IDF) | Farol IDF | % Previsto Ponderado | % Concluído Ponderado | Farol de Início | Responsável | Código do Contrato |
| --- | --- | --- | --- | --- | --- | --- | --- | --- | --- | --- | --- | --- | --- | --- | --- | --- | --- | --- | --- | --- | --- | --- | --- | --- |
| 2803 | 2.3.38.4 | **Pleito TIMESOB02 - Implantação de interceptores em Caichoeira do Vale (ME) e Piracicaba (MD) além de EEB-2 e respectiva LR-2** |  | 481d | 2020-06-24 | 2022-05-30 |  | 2020-06-24 | 2022-05-30 | 481d |  |  | 681d |  | Verde | Verde | 0% | 0% | Verde | 0% | 0% |  |  |  |
| 2804 | 2.3.38.4.1 | **Licitação da Obra** |  | 78d | 2020-06-24 | 2020-10-14 |  | 2020-06-24 | 2020-10-14 | 78d |  |  | 681d |  | Verde | Verde | 0% | 0% | Verde | 0% | 0% |  |  |  |
| 2805 | 2.3.38.4.1.1 | Licitação da obra autorizada pelo banco | milestone | 0d | 2020-06-24 | 2020-06-24 | 2800 | 2020-06-24 | 2020-06-24 | 0d |  |  | 681d | 0d | Verde | Verde | 0% | 0% | Verde | 0% | 0% | Verde |  |  |
| 2806 | 2.3.38.4.1.2 | Licitar Obra |  | 63d | 2020-06-25 | 2020-09-22 | 2805 | 2020-06-25 | 2020-09-22 | 63d |  |  | 681d | 0d | Verde | Verde | 0% | 0% | Verde | 0% | 0% | Verde |  |  |
| 2807 | 2.3.38.4.1.3 | Analisar e emitir resultado da licitação da obra |  | 15d | 2020-09-23 | 2020-10-14 | 2806 | 2020-09-23 | 2020-10-14 | 15d |  |  | 681d | 0d | Verde | Verde | 0% | 0% | Verde | 0% | 0% | Verde |  |  |
| 2808 | 2.3.38.4.1.4 | Licitação da obra concluída | milestone | 0d | 2020-10-14 | 2020-10-14 | 2807 | 2020-10-14 | 2020-10-14 | 0d |  |  | 681d | 0d | Verde | Verde | 0% | 0% | Verde | 0% | 0% | Verde |  |  |
| 2809 | 2.3.38.4.2 | Executar obra |  | 250d | 2020-11-13 | 2021-11-16 | 2808FS+20d | 2020-11-13 | 2021-11-16 | 250d |  |  | 681d | 0d | Verde | Verde | 0% | 0% | Verde | 0% | 0% | Verde |  |  |
| 2810 | 2.3.38.4.3 | Realizar processo de pré-operação |  | 128d | 2021-11-17 | 2022-05-23 | 2809 | 2021-11-17 | 2022-05-23 | 128d | 2021-04-27 | 2021-10-24 | 681d | 0d | Verde | Verde | 0% | 0% | Verde | 0% | 0% | Verde | 02 - Execução | PG 031 |
| 2811 | 2.3.38.4.4 | Recurso da obra parcelado repassado | milestone | 0d | 2022-05-30 | 2022-05-30 | 2810FS+5d | 2022-05-30 | 2022-05-30 | 0d |  |  | 681d | 0d | Verde | Verde | 0% | 0% | Verde | 0% | 0% | Verde |  |  |
| 2812 | 2.3.38.4.5 | Pleito TIMESOB02 concluído | milestone | 0d | 2022-05-30 | 2022-05-30 | 2811 | 2022-05-30 | 2022-05-30 | 0d |  |  | 681d | 0d | Verde | Verde | 0% | 0% | Verde | 0% | 0% | Verde |  |  |
| 2813 | 2.3.38.5 | **Pleito de Timóteo a definir - Gerenciadora de obra** |  | 554d | 2019-08-30 | 2021-11-23 |  | 2019-08-30 | 2021-11-23 | 554d |  |  | 809d |  | Verde | Verde | 0% | 0% | Verde | 0% | 0% |  |  |  |
| 2814 | 2.3.38.5.1 | Pleito aprovado | milestone | 0d | 2019-08-30 | 2019-08-30 | 206FS+178d | 2019-08-30 | 2019-08-30 | 0d |  |  | 834d | 0d | Verde | Verde | 0% | 0% | Verde | 0% | 0% | Verde |  |  |
| 2815 | 2.3.38.5.2 | **Licitação da Empresa Gerenciadora** |  | 55d | 2020-06-24 | 2020-09-10 |  | 2020-06-24 | 2020-09-10 | 55d |  |  | 852d |  | Verde | Verde | 0% | 0% | Verde | 0% | 0% |  |  |  |
| 2816 | 2.3.38.5.2.1 | Licitação da gerenciadora autorizada pelo banco | milestone | 0d | 2020-06-24 | 2020-06-24 | 2805 | 2020-06-24 | 2020-06-24 | 0d |  |  | 852d | 0d | Verde | Verde | 0% | 0% | Verde | 0% | 0% | Verde |  |  |
| 2817 | 2.3.38.5.2.2 | Licitar gerenciadora |  | 41d | 2020-06-25 | 2020-08-20 | 2816 | 2020-06-25 | 2020-08-20 | 41d |  |  | 852d | 0d | Verde | Verde | 0% | 0% | Verde | 0% | 0% | Verde |  |  |
| 2818 | 2.3.38.5.2.3 | Analisar e emitir resultado da licitação da gerenciadora |  | 14d | 2020-08-21 | 2020-09-10 | 2817 | 2020-08-21 | 2020-09-10 | 14d |  |  | 852d | 0d | Verde | Verde | 0% | 0% | Verde | 0% | 0% | Verde |  |  |
| 2819 | 2.3.38.5.2.4 | Licitação da gerenciadora concluída | milestone | 0d | 2020-09-10 | 2020-09-10 | 2818 | 2020-09-10 | 2020-09-10 | 0d |  |  | 852d | 43d | Verde | Verde | 0% | 0% | Verde | 0% | 0% | Verde |  |  |
| 2820 | 2.3.38.5.3 | Executar serviço |  | 250d | 2020-11-13 | 2021-11-16 | 2819, 2809SS | 2020-11-13 | 2021-11-16 | 250d |  |  | 809d | 0d | Verde | Verde | 0% | 0% | Verde | 0% | 0% | Verde |  |  |
| 2821 | 2.3.38.5.4 | Recurso da gerenciadora repassado | milestone | 0d | 2021-11-23 | 2021-11-23 | 2820FS+5d | 2021-11-23 | 2021-11-23 | 0d |  |  | 809d | 0d | Verde | Verde | 0% | 0% | Verde | 0% | 0% | Verde |  |  |
| 2822 | 2.3.38.5.5 | Pleito de Timóteo a definir concluído | milestone | 0d | 2021-11-23 | 2021-11-23 | 2821 | 2021-11-23 | 2021-11-23 | 0d |  |  | 809d | 128d | Verde | Verde | 0% | 0% | Verde | 0% | 0% | Verde |  |  |
| 2823 | 2.3.38.6 | Recursos de Timóteo repassados | milestone | 0d | 2022-05-30 | 2022-05-30 | 2781, 2784, 2802, 2812, 2822 | 2022-05-30 | 2022-05-30 | 0d | 2019-06-07 | 2021-10-24 | 681d |  | Verde | Verde | 0% | 0% | Verde | 0% | 0% | Verde | 02 - Execução | PG 031 |
| 2824 | 2.3.39 | **Tumiritinga** |  | 923d | 2019-05-03 | 2023-01-13 |  | 2019-05-03 | 2023-01-13 | 923d | 2018-10-02 | 2020-10-01 | 524d |  | Verde | Verde | 0% | 0% | Verde | 0% | 0% |  |  |  |
| 2825 | 2.3.39.1 | **Pleito TUMESPJ01 - Elaboração de projetos de sistema de esgotamento sanitário da sede do município e distrito de São Geraldo do Tumiritinga** |  | 261d | 2019-05-03 | 2020-05-20 |  | 2019-05-03 | 2020-05-20 | 261d |  |  | 805d |  | Verde | Verde | 0% | 0% | Verde | 0% | 0% |  |  |  |
| 2826 | 2.3.39.1.1 | **Licitação do Projeto** |  | 61d | 2019-05-03 | 2019-07-29 |  | 2019-05-03 | 2019-07-29 | 61d |  |  | 805d |  | Verde | Verde | 0% | 0% | Verde | 0% | 0% |  |  |  |
| 2827 | 2.3.39.1.1.1 | Licitar projeto |  | 43d | 2019-05-03 | 2019-07-03 | 206FS+94d | 2019-05-03 | 2019-07-03 | 43d |  |  | 805d | 0d | Verde | Verde | 0% | 0% | Verde | 0% | 0% | Verde |  |  |
| 2828 | 2.3.39.1.1.2 | Documentação de licitação apresentada ao banco | milestone | 0d | 2019-07-09 | 2019-07-09 | 2827FS+4d | 2019-07-09 | 2019-07-09 | 0d |  |  | 805d | 0d | Verde | Verde | 0% | 0% | Verde | 0% | 0% | Verde |  |  |
| 2829 | 2.3.39.1.1.3 | Analisar e emitir resultado da licitação do projeto |  | 14d | 2019-07-10 | 2019-07-29 | 2828 | 2019-07-10 | 2019-07-29 | 14d |  |  | 805d | 0d | Verde | Verde | 0% | 0% | Verde | 0% | 0% | Verde |  |  |
| 2830 | 2.3.39.1.1.4 | Licitação do projeto concluída | milestone | 0d | 2019-07-29 | 2019-07-29 | 2829 | 2019-07-29 | 2019-07-29 | 0d |  |  | 805d | 0d | Verde | Verde | 0% | 0% | Verde | 0% | 0% | Verde |  |  |

Notes:
- 2805: 22/01/19 - Ainda não licitando. Fase de elaboração de TR para: / - Licitação de obra SES (Copasa) / - PRAD / - Contratação de estudo de viabilidade de implantação de aterro sanitário (CONDIM)
- 2814: Em 25/04/2019: considerado que o pleito será aprovado na próxima CIF no dia 30/08/2019 conforme NT33
- 2823: Valor de recurso destinado ao munícipio: R$22.059.301,00
- 2824: Tumiritinga solicitou 60,3% (R$2.850.000,00) dos 90% de recursos destinado para Esgotamento Sanitário e teve todo o pleito aprovado, conforme Deliberação 75. / O município teve o pleito de resíduos sólidos negado (R$472.699,31), equivalente a 10% do total do recurso). / Tumiritinga aderiu a ata de registro de preços

| ID | WBS | Task | Type | Duration | Start | Finish | Predecessors | Baseline start | Baseline finish | Baseline duration | Baseline 1 start | Baseline 1 finish | Total slack | Free slack | Farol de Atraso | Farol Marcos | % Previsto Tempo | Índice de Desempenho Físico (IDF) | Farol IDF | % Previsto Ponderado | % Concluído Ponderado | Farol de Início | Responsável | Código do Contrato |
| --- | --- | --- | --- | --- | --- | --- | --- | --- | --- | --- | --- | --- | --- | --- | --- | --- | --- | --- | --- | --- | --- | --- | --- | --- |
| 2831 | 2.3.39.1.2 | **Elaboração do Projeto Básico** |  | 134d | 2019-07-30 | 2020-02-10 |  | 2019-07-30 | 2020-02-10 | 134d |  |  | 805d |  | Verde | Verde | 0% | 0% | Verde | 0% | 0% |  |  |  |
| 2832 | 2.3.39.1.2.1 | Elaborar Projeto Básico |  | 64d | 2019-07-30 | 2019-10-28 | 2830 | 2019-07-30 | 2019-10-28 | 64d |  |  | 805d | 0d | Verde | Verde | 0% | 0% | Verde | 0% | 0% | Verde |  |  |
| 2833 | 2.3.39.1.2.2 | Projeto básico apresentado ao banco | milestone | 0d | 2019-10-28 | 2019-10-28 | 2832 | 2019-10-28 | 2019-10-28 | 0d |  |  | 805d | 0d | Verde | Verde | 0% | 0% | Verde | 0% | 0% | Verde |  |  |
| 2834 | 2.3.39.1.2.3 | Analisar projeto básico |  | 21d | 2019-10-29 | 2019-11-27 | 2833 | 2019-10-29 | 2019-11-27 | 21d |  |  | 866d | 0d | Verde | Verde | 0% | 0% | Verde | 0% | 0% | Verde |  |  |
| 2835 | 2.3.39.1.2.4 | Adequar/revisar projeto básico |  | 22d | 2019-11-28 | 2020-01-02 | 2834 | 2019-11-28 | 2020-01-02 | 22d |  |  | 866d | 0d | Verde | Verde | 0% | 0% | Verde | 0% | 0% | Verde |  |  |
| 2836 | 2.3.39.1.2.5 | Analisar projeto básico - final |  | 22d | 2020-01-03 | 2020-02-03 | 2835 | 2020-01-03 | 2020-02-03 | 22d |  |  | 866d | 0d | Verde | Verde | 0% | 0% | Verde | 0% | 0% | Verde |  |  |
| 2837 | 2.3.39.1.2.6 | Projeto básico concluído | milestone | 0d | 2020-02-03 | 2020-02-03 | 2836 | 2020-02-03 | 2020-02-03 | 0d |  |  | 866d | 0d | Verde | Verde | 0% | 0% | Verde | 0% | 0% | Verde |  |  |
| 2838 | 2.3.39.1.2.7 | Recurso do projeto básico do pleito TUMESPJ01 repassado | milestone | 0d | 2020-02-10 | 2020-02-10 | 2837FS+5d | 2020-02-10 | 2020-02-10 | 0d |  |  | 866d | 61d | Verde | Verde | 0% | 0% | Verde | 0% | 0% | Verde |  |  |
| 2839 | 2.3.39.1.3 | Realizar Licenciamento Ambiental |  | 131d | 2019-10-29 | 2020-05-13 | 2832 | 2019-10-29 | 2020-05-13 | 131d |  |  | 805d | 0d | Verde | Verde | 0% | 0% | Verde | 0% | 0% | Verde |  |  |
| 2840 | 2.3.39.1.4 | **Elaboração do Projeto Executivo** |  | 136d | 2019-10-29 | 2020-05-20 |  | 2019-10-29 | 2020-05-20 | 136d |  |  | 805d |  | Verde | Verde | 0% | 0% | Verde | 0% | 0% |  |  |  |
| 2841 | 2.3.39.1.4.1 | Elaborar Projeto Executivo |  | 65d | 2019-10-29 | 2020-02-03 | 2833 | 2019-10-29 | 2020-02-03 | 65d |  |  | 805d | 0d | Verde | Verde | 0% | 0% | Verde | 0% | 0% | Verde |  |  |
| 2842 | 2.3.39.1.4.2 | Projeto executivo apresentado ao banco | milestone | 0d | 2020-02-03 | 2020-02-03 | 2841 | 2020-02-03 | 2020-02-03 | 0d |  |  | 805d | 0d | Verde | Verde | 0% | 0% | Verde | 0% | 0% | Verde |  |  |
| 2843 | 2.3.39.1.4.3 | Analisar projeto executivo |  | 21d | 2020-02-04 | 2020-03-06 | 2842 | 2020-02-04 | 2020-03-06 | 21d |  |  | 805d | 0d | Verde | Verde | 0% | 0% | Verde | 0% | 0% | Verde |  |  |
| 2844 | 2.3.39.1.4.4 | Adequar/revisar projeto executivo |  | 22d | 2020-03-09 | 2020-04-07 | 2843 | 2020-03-09 | 2020-04-07 | 22d |  |  | 805d | 0d | Verde | Verde | 0% | 0% | Verde | 0% | 0% | Verde |  |  |
| 2845 | 2.3.39.1.4.5 | Analisar projeto executivo - final |  | 23d | 2020-04-08 | 2020-05-13 | 2844 | 2020-04-08 | 2020-05-13 | 23d |  |  | 805d | 0d | Verde | Verde | 0% | 0% | Verde | 0% | 0% | Verde |  |  |
| 2846 | 2.3.39.1.4.6 | Projeto executivo concluído | milestone | 0d | 2020-05-13 | 2020-05-13 | 2845, 2838, 2839 | 2020-05-13 | 2020-05-13 | 0d |  |  | 805d | 0d | Verde | Verde | 0% | 0% | Verde | 0% | 0% | Verde |  |  |
| 2847 | 2.3.39.1.4.7 | Recurso do projeto executivo do pleito TUMESPJ01 repassado | milestone | 0d | 2020-05-20 | 2020-05-20 | 2846FS+5d | 2020-05-20 | 2020-05-20 | 0d |  |  | 805d | 0d | Verde | Verde | 0% | 0% | Verde | 0% | 0% | Verde |  |  |
| 2848 | 2.3.39.1.5 | Pleito TUMESPJ01 concluído | milestone | 0d | 2020-05-20 | 2020-05-20 | 2847 | 2020-05-20 | 2020-05-20 | 0d |  |  | 805d | 0d | Verde | Verde | 0% | 0% | Verde | 0% | 0% | Verde |  |  |
| 2849 | 2.3.39.2 | **Pleito TUMESOB01 - Execução de obras de rede de esgotamento sanitário e ampliação de estação de ETE da Sede** |  | 381d | 2020-05-20 | 2021-11-29 |  | 2020-05-20 | 2021-11-29 | 381d |  |  | 805d |  | Verde | Verde | 0% | 0% | Verde | 0% | 0% |  |  |  |
| 2850 | 2.3.39.2.1 | **Licitação da Obra** |  | 76d | 2020-05-20 | 2020-09-04 |  | 2020-05-20 | 2020-09-04 | 76d |  |  | 805d |  | Verde | Verde | 0% | 0% | Verde | 0% | 0% |  |  |  |
| 2851 | 2.3.39.2.1.1 | Licitação da obra autorizada pelo banco | milestone | 0d | 2020-05-20 | 2020-05-20 | 2848 | 2020-05-20 | 2020-05-20 | 0d |  |  | 805d | 0d | Verde | Verde | 0% | 0% | Verde | 0% | 0% | Verde |  |  |
| 2852 | 2.3.39.2.1.2 | Licitar Obra |  | 63d | 2020-05-21 | 2020-08-18 | 2851 | 2020-05-21 | 2020-08-18 | 63d | 2019-03-31 | 2019-07-29 | 805d | 0d | Verde | Verde | 0% | 0% | Verde | 0% | 0% | Verde | 02 - Execução | PG 031 |
| 2853 | 2.3.39.2.1.3 | Analisar e emitir resultado da licitação da obra |  | 13d | 2020-08-19 | 2020-09-04 | 2852 | 2020-08-19 | 2020-09-04 | 13d |  |  | 805d | 0d | Verde | Verde | 0% | 0% | Verde | 0% | 0% | Verde |  |  |
| 2854 | 2.3.39.2.1.4 | Licitação da obra concluída | milestone | 0d | 2020-09-04 | 2020-09-04 | 2853 | 2020-09-04 | 2020-09-04 | 0d |  |  | 805d | 0d | Verde | Verde | 0% | 0% | Verde | 0% | 0% | Verde |  |  |
| 2855 | 2.3.39.2.2 | Executar obra |  | 172d | 2020-09-08 | 2021-05-19 | 2854 | 2020-09-08 | 2021-05-19 | 172d |  |  | 805d | 0d | Verde | Verde | 0% | 0% | Verde | 0% | 0% | Verde |  |  |
| 2856 | 2.3.39.2.3 | Realizar processo de pré-operação |  | 128d | 2021-05-20 | 2021-11-22 | 2855 | 2021-05-20 | 2021-11-22 | 128d | 2020-02-04 | 2020-10-01 | 805d | 0d | Verde | Verde | 0% | 0% | Verde | 0% | 0% | Verde | 02 - Execução | PG 031 |
| 2857 | 2.3.39.2.4 | Recurso da obra parcelado repassado | milestone | 0d | 2021-11-29 | 2021-11-29 | 2856FS+5d | 2021-11-29 | 2021-11-29 | 0d |  |  | 805d | 0d | Verde | Verde | 0% | 0% | Verde | 0% | 0% | Verde |  |  |
| 2858 | 2.3.39.2.5 | Pleito TUMESOB01 concluído | milestone | 0d | 2021-11-29 | 2021-11-29 | 2857 | 2021-11-29 | 2021-11-29 | 0d |  |  | 805d | 281d | Verde | Verde | 0% | 0% | Verde | 0% | 0% | Verde |  |  |

Notes:
- 2855: Em 24/04/2019: valor da obra R$ 1,7 milhões

| ID | WBS | Task | Type | Duration | Start | Finish | Predecessors | Baseline start | Baseline finish | Baseline duration | Baseline 1 start | Baseline 1 finish | Total slack | Free slack | Constraint | Farol de Atraso | Farol Marcos | % Previsto Tempo | Índice de Desempenho Físico (IDF) | Farol IDF | % Previsto Ponderado | % Concluído Ponderado | Farol de Início | Responsável | Código do Contrato |
| --- | --- | --- | --- | --- | --- | --- | --- | --- | --- | --- | --- | --- | --- | --- | --- | --- | --- | --- | --- | --- | --- | --- | --- | --- | --- |
| 2859 | 2.3.39.3 | **Pleito TUMESOB02 - Execução de obras de rede de esgotamento sanitário e implantação de estação de ETE de São Geraldo do Tumiritinga** |  | 381d | 2020-05-20 | 2021-11-29 |  | 2020-05-20 | 2021-11-29 | 381d |  |  | 805d |  |  | Verde | Verde | 0% | 0% | Verde | 0% | 0% |  |  |  |
| 2860 | 2.3.39.3.1 | **Licitação da Obra** |  | 76d | 2020-05-20 | 2020-09-04 |  | 2020-05-20 | 2020-09-04 | 76d |  |  | 805d |  |  | Verde | Verde | 0% | 0% | Verde | 0% | 0% |  |  |  |
| 2861 | 2.3.39.3.1.1 | Licitação da obra autorizada pelo banco | milestone | 0d | 2020-05-20 | 2020-05-20 | 2848 | 2020-05-20 | 2020-05-20 | 0d |  |  | 805d | 0d |  | Verde | Verde | 0% | 0% | Verde | 0% | 0% | Verde |  |  |
| 2862 | 2.3.39.3.1.2 | Licitar Obra |  | 63d | 2020-05-21 | 2020-08-18 | 2861 | 2020-05-21 | 2020-08-18 | 63d |  |  | 805d | 0d |  | Verde | Verde | 0% | 0% | Verde | 0% | 0% | Verde |  |  |
| 2863 | 2.3.39.3.1.3 | Analisar e emitir resultado da licitação da obra |  | 13d | 2020-08-19 | 2020-09-04 | 2862 | 2020-08-19 | 2020-09-04 | 13d |  |  | 805d | 0d |  | Verde | Verde | 0% | 0% | Verde | 0% | 0% | Verde |  |  |
| 2864 | 2.3.39.3.1.4 | Licitação da obra concluída | milestone | 0d | 2020-09-04 | 2020-09-04 | 2863 | 2020-09-04 | 2020-09-04 | 0d |  |  | 805d | 0d |  | Verde | Verde | 0% | 0% | Verde | 0% | 0% | Verde |  |  |
| 2865 | 2.3.39.3.2 | Executar obra |  | 172d | 2020-09-08 | 2021-05-19 | 2864 | 2020-09-08 | 2021-05-19 | 172d |  |  | 805d | 0d |  | Verde | Verde | 0% | 0% | Verde | 0% | 0% | Verde |  |  |
| 2866 | 2.3.39.3.3 | Realizar processo de pré-operação |  | 128d | 2021-05-20 | 2021-11-22 | 2865 | 2021-05-20 | 2021-11-22 | 128d |  |  | 805d | 0d |  | Verde | Verde | 0% | 0% | Verde | 0% | 0% | Verde |  |  |
| 2867 | 2.3.39.3.4 | Recurso da obra parcelado repassado | milestone | 0d | 2021-11-29 | 2021-11-29 | 2866FS+5d | 2021-11-29 | 2021-11-29 | 0d |  |  | 805d | 0d |  | Verde | Verde | 0% | 0% | Verde | 0% | 0% | Verde |  |  |
| 2868 | 2.3.39.3.5 | Pleito TUMESOB02 concluído | milestone | 0d | 2021-11-29 | 2021-11-29 | 2867 | 2021-11-29 | 2021-11-29 | 0d |  |  | 805d | 281d |  | Verde | Verde | 0% | 0% | Verde | 0% | 0% | Verde |  |  |
| 2869 | 2.3.39.4 | **Pleito de Tumiritinga de Resíduos Sólidos a definir** |  | 839d | 2019-08-30 | 2023-01-13 |  | 2019-08-30 | 2023-01-13 | 839d |  |  | 524d |  |  | Verde | Verde | 0% | 0% | Verde | 0% | 0% |  |  |  |
| 2870 | 2.3.39.4.1 | Pleito aprovado | milestone | 0d | 2019-08-30 | 2019-08-30 | 206FS+178d | 2019-08-30 | 2019-08-30 | 0d |  |  | 524d | 0d |  | Verde | Verde | 0% | 0% | Verde | 0% | 0% | Verde |  |  |
| 2871 | 2.3.39.4.2 | Iniciar pleito |  | 1d | 2019-09-02 | 2019-09-02 | 2870 | 2019-09-02 | 2019-09-02 | 1d |  |  | 524d | 0d |  | Verde | Verde | 0% | 0% | Verde | 0% | 0% | Verde |  |  |
| 2872 | 2.3.39.4.3 | Pleito de Tumiritinga de Resíduos Sólidos a definir concluído | milestone | 0d | 2023-01-13 | 2023-01-13 | 2871FS+838d | 2023-01-13 | 2023-01-13 | 0d |  |  | 524d | 0d |  | Verde | Verde | 0% | 0% | Verde | 0% | 0% | Verde |  |  |
| 2873 | 2.3.39.5 | Recursos de Tumiritinga repassados | milestone | 0d | 2023-01-13 | 2023-01-13 | 2848, 2858, 2868, 2872 | 2023-01-13 | 2023-01-13 | 0d | 2019-04-30 | 2020-10-01 | 524d |  |  | Verde | Verde | 0% | 0% | Verde | 0% | 0% | Verde | 02 - Execução | PG 031 |
| 2874 | 2.3.40 | **CONDOESTE** |  | 1142d | 2019-08-30 | 2024-04-08 |  | 2019-08-30 | 2024-04-08 | 1142d |  |  | 0d |  |  | Verde | Verde | 0% | 0% | Verde | 0% | 0% |  |  |  |
| 2875 | 2.3.40.1 | **Pleito CDTRSOB01 - Construção das 05 Estações de Transbordo, projetadas para serem construídas nos municípios de Alto Rio Novo, Itarana, Laranja da Terra, São Domingos do Norte e Colatina.** |  | 1142d | 2019-08-30 | 2024-04-08 |  | 2019-08-30 | 2024-04-08 | 1142d |  |  | 0d |  |  | Verde | Verde | 0% | 0% | Verde | 0% | 0% |  |  |  |
| 2876 | 2.3.40.1.1 | Revisão do pleito aprovada | milestone | 0d | 2019-08-30 | 2019-08-30 |  | 2019-08-30 | 2019-08-30 | 0d |  |  | 0d |  | must start on 2019-08-30 | Verde | Verde | 0% | 0% | Verde | 0% | 0% | Verde |  |  |
| 2877 | 2.3.40.1.2 | **Licitação do Projeto** |  | 63d | 2019-09-12 | 2019-12-11 |  | 2019-09-12 | 2019-12-11 | 63d |  |  | 222d |  |  | Verde | Verde | 0% | 0% | Verde | 0% | 0% |  |  |  |
| 2878 | 2.3.40.1.2.1 | Licitação do projeto autorizada pelo banco | milestone | 0d | 2019-09-12 | 2019-09-12 | 2876FS+10d | 2019-09-12 | 2019-09-12 | 0d |  |  | 222d | 0d |  | Verde | Verde | 0% | 0% | Verde | 0% | 0% | Verde |  |  |
| 2879 | 2.3.40.1.2.2 | Licitar projeto |  | 44d | 2019-09-13 | 2019-11-13 | 2878 | 2019-09-13 | 2019-11-13 | 44d |  |  | 222d | 0d |  | Verde | Verde | 0% | 0% | Verde | 0% | 0% | Verde |  |  |
| 2880 | 2.3.40.1.2.3 | Documentação de licitação apresentada ao banco | milestone | 0d | 2019-11-21 | 2019-11-21 | 2879FS+5d | 2019-11-21 | 2019-11-21 | 0d |  |  | 222d | 0d |  | Verde | Verde | 0% | 0% | Verde | 0% | 0% | Verde |  |  |
| 2881 | 2.3.40.1.2.4 | Analisar e emitir resultado da licitação do projeto |  | 14d | 2019-11-22 | 2019-12-11 | 2880 | 2019-11-22 | 2019-12-11 | 14d |  |  | 222d | 0d |  | Verde | Verde | 0% | 0% | Verde | 0% | 0% | Verde |  |  |
| 2882 | 2.3.40.1.2.5 | Licitação do projeto concluída | milestone | 0d | 2019-12-11 | 2019-12-11 | 2881 | 2019-12-11 | 2019-12-11 | 0d |  |  | 222d | 0d |  | Verde | Verde | 0% | 0% | Verde | 0% | 0% | Verde |  |  |

Notes:
- 2870: Em 24/04/2019: considerado que o pleito será elaborado até julho de 2019 e aprovado no CT/CIF de agosto
- 2873: Valor de recurso destinado ao munícipio: R$4.726.993,07
- 2876: Em 24/09/2019: na reunião do 25/03/2019, CONDOESTE manifestou intenção de revisar o pleito dos 17 milhões. A definição da revisão do pleito está prevista para 23 de junho de 2019. O pleito será aprovado na reunião do CIF de agosto segundo NT 33.

| ID | WBS | Task | Type | Duration | Start | Finish | Predecessors | Baseline start | Baseline finish | Baseline duration | Total slack | Free slack | Farol de Atraso | Farol Marcos | % Previsto Tempo | Índice de Desempenho Físico (IDF) | Farol IDF | % Previsto Ponderado | % Concluído Ponderado | Farol de Início |
| --- | --- | --- | --- | --- | --- | --- | --- | --- | --- | --- | --- | --- | --- | --- | --- | --- | --- | --- | --- | --- |
| 2883 | 2.3.40.1.3 | **Elaboração do Projeto Básico** |  | 115d | 2019-12-13 | 2020-06-03 |  | 2019-12-13 | 2020-06-03 | 115d | 222d |  | Verde | Verde | 0% | 0% | Verde | 0% | 0% |  |
| 2884 | 2.3.40.1.3.1 | Elaborar Projeto Básico |  | 44d | 2019-12-13 | 2020-02-17 | 2882 | 2019-12-13 | 2020-02-17 | 44d | 222d | 0d | Verde | Verde | 0% | 0% | Verde | 0% | 0% | Verde |
| 2885 | 2.3.40.1.3.2 | Projeto básico apresentado ao banco | milestone | 0d | 2020-02-17 | 2020-02-17 | 2884 | 2020-02-17 | 2020-02-17 | 0d | 283d | 0d | Verde | Verde | 0% | 0% | Verde | 0% | 0% | Verde |
| 2886 | 2.3.40.1.3.3 | Analisar projeto básico |  | 22d | 2020-02-18 | 2020-03-23 | 2885 | 2020-02-18 | 2020-03-23 | 22d | 283d | 0d | Verde | Verde | 0% | 0% | Verde | 0% | 0% | Verde |
| 2887 | 2.3.40.1.3.4 | Adequar/revisar projeto básico |  | 22d | 2020-03-24 | 2020-04-24 | 2886 | 2020-03-24 | 2020-04-24 | 22d | 283d | 0d | Verde | Verde | 0% | 0% | Verde | 0% | 0% | Verde |
| 2888 | 2.3.40.1.3.5 | Analisar projeto básico - final |  | 22d | 2020-04-27 | 2020-05-27 | 2887 | 2020-04-27 | 2020-05-27 | 22d | 283d | 0d | Verde | Verde | 0% | 0% | Verde | 0% | 0% | Verde |
| 2889 | 2.3.40.1.3.6 | Projeto básico concluído | milestone | 0d | 2020-05-27 | 2020-05-27 | 2888 | 2020-05-27 | 2020-05-27 | 0d | 283d | 0d | Verde | Verde | 0% | 0% | Verde | 0% | 0% | Verde |
| 2890 | 2.3.40.1.3.7 | Recurso do projeto básico do pleito repassado | milestone | 0d | 2020-06-03 | 2020-06-03 | 2889FS+5d | 2020-06-03 | 2020-06-03 | 0d | 283d | 61d | Verde | Verde | 0% | 0% | Verde | 0% | 0% | Verde |
| 2891 | 2.3.40.1.4 | Realizar Licenciamento Ambiental |  | 60d | 2020-02-18 | 2020-05-19 | 2884 | 2020-02-18 | 2020-05-19 | 60d | 294d | 72d | Verde | Verde | 0% | 0% | Verde | 0% | 0% | Verde |
| 2892 | 2.3.40.1.5 | **Elaboração do Projeto Executivo** |  | 137d | 2020-02-18 | 2020-09-04 |  | 2020-02-18 | 2020-09-04 | 137d | 222d |  | Verde | Verde | 0% | 0% | Verde | 0% | 0% |  |
| 2893 | 2.3.40.1.5.1 | Elaborar Projeto Executivo |  | 66d | 2020-02-18 | 2020-05-27 | 2884 | 2020-02-18 | 2020-05-27 | 66d | 222d | 0d | Verde | Verde | 0% | 0% | Verde | 0% | 0% | Verde |
| 2894 | 2.3.40.1.5.2 | Projeto executivo apresentado ao banco | milestone | 0d | 2020-05-27 | 2020-05-27 | 2893 | 2020-05-27 | 2020-05-27 | 0d | 222d | 0d | Verde | Verde | 0% | 0% | Verde | 0% | 0% | Verde |
| 2895 | 2.3.40.1.5.3 | Analisar projeto executivo |  | 22d | 2020-05-28 | 2020-06-29 | 2894 | 2020-05-28 | 2020-06-29 | 22d | 222d | 0d | Verde | Verde | 0% | 0% | Verde | 0% | 0% | Verde |
| 2896 | 2.3.40.1.5.4 | Adequar/revisar projeto executivo |  | 22d | 2020-06-30 | 2020-07-29 | 2895 | 2020-06-30 | 2020-07-29 | 22d | 222d | 0d | Verde | Verde | 0% | 0% | Verde | 0% | 0% | Verde |
| 2897 | 2.3.40.1.5.5 | Analisar projeto executivo - final |  | 22d | 2020-07-30 | 2020-08-28 | 2896 | 2020-07-30 | 2020-08-28 | 22d | 222d | 0d | Verde | Verde | 0% | 0% | Verde | 0% | 0% | Verde |
| 2898 | 2.3.40.1.5.6 | Projeto executivo concluído | milestone | 0d | 2020-08-28 | 2020-08-28 | 2897, 2891, 2890 | 2020-08-28 | 2020-08-28 | 0d | 222d | 0d | Verde | Verde | 0% | 0% | Verde | 0% | 0% | Verde |
| 2899 | 2.3.40.1.5.7 | Recurso do projeto executivo do pleito repassado | milestone | 0d | 2020-09-04 | 2020-09-04 | 2898FS+5d | 2020-09-04 | 2020-09-04 | 0d | 1110d | 888d | Verde | Verde | 0% | 0% | Verde | 0% | 0% | Verde |
| 2900 | 2.3.40.1.6 | **Licitação da obra** |  | 80d | 2020-08-28 | 2020-12-23 |  | 2020-08-28 | 2020-12-23 | 80d | 222d |  | Verde | Verde | 0% | 0% | Verde | 0% | 0% |  |
| 2901 | 2.3.40.1.6.1 | Licitação da obra autorizada pelo banco | milestone | 0d | 2020-08-28 | 2020-08-28 | 2898 | 2020-08-28 | 2020-08-28 | 0d | 222d | 0d | Verde | Verde | 0% | 0% | Verde | 0% | 0% | Verde |
| 2902 | 2.3.40.1.6.2 | Licitar obra |  | 66d | 2020-08-31 | 2020-12-03 | 2901 | 2020-08-31 | 2020-12-03 | 66d | 222d | 0d | Verde | Verde | 0% | 0% | Verde | 0% | 0% | Verde |
| 2903 | 2.3.40.1.6.3 | Analisar e emitir resultado da licitação da obra |  | 14d | 2020-12-04 | 2020-12-23 | 2902 | 2020-12-04 | 2020-12-23 | 14d | 222d | 0d | Verde | Verde | 0% | 0% | Verde | 0% | 0% | Verde |
| 2904 | 2.3.40.1.6.4 | Licitação da obra concluída | milestone | 0d | 2020-12-23 | 2020-12-23 | 2903 | 2020-12-23 | 2020-12-23 | 0d | 222d | 0d | Verde | Verde | 0% | 0% | Verde | 0% | 0% | Verde |
| 2905 | 2.3.40.1.7 | Executar obra |  | 660d | 2021-01-26 | 2023-09-20 | 2904FS+20d | 2021-01-26 | 2023-09-20 | 660d | 222d | 0d | Verde | Verde | 0% | 0% | Verde | 0% | 0% | Verde |
| 2906 | 2.3.40.1.8 | Realizar processo de pré-operação |  | 128d | 2023-09-21 | 2024-04-01 | 2905 | 2023-09-21 | 2024-04-01 | 128d | 222d | 0d | Verde | Verde | 0% | 0% | Verde | 0% | 0% | Verde |
| 2907 | 2.3.40.1.9 | Recurso da obra parcelado repassado | milestone | 0d | 2024-04-08 | 2024-04-08 | 2906FS+5d | 2024-04-08 | 2024-04-08 | 0d | 222d | 0d | Verde | Verde | 0% | 0% | Verde | 0% | 0% | Verde |
| 2908 | 2.3.40.1.10 | Pleito CDTRSOB01 concluído | milestone | 0d | 2024-04-08 | 2024-04-08 | 2907, 2899 | 2024-04-08 | 2024-04-08 | 0d | 222d | 0d | Verde | Verde | 0% | 0% | Verde | 0% | 0% | Verde |
| 2909 | 2.3.40.2 | Recursos de CONDOESTE repassados | milestone | 0d | 2024-04-08 | 2024-04-08 | 2908 | 2024-04-08 | 2024-04-08 | 0d | 222d | 0d | Verde | Verde | 0% | 0% | Verde | 0% | 0% | Verde |
| 2910 | 2.3.41 | PF 8136-3: Processo de Repasse de Recursos aos Municípios concluído | milestone | 0d | 2025-02-24 | 2025-02-24 | 263, 326, 366, 396, 443, 507, 568, 611, 1066, 1099, 1119, 1168, 1272, 1336, 1428, 1485, 1547, 1601, 1683, 1778, 1914, 1956, 2007, 2056, 2107, 2159, 2194, 2263, 2324, 2378, 2420, 2486, 2562, 2591, 2641, 2704, 2765, 2823, 2873 | 2025-02-24 | 2025-02-24 | 0d | 0d |  | Verde | Verde | 0% | 0% | Verde | 0% | 0% | Verde |

| ID | WBS | Task | Type | Duration | Start | Finish | Predecessors | Complete | Remaining | Baseline start | Baseline finish | Baseline duration | Baseline 1 start | Baseline 1 finish | Total slack | Free slack | Constraint | Farol de Atraso | Farol Marcos | % Previsto Tempo | % Concluída Numérico | % Previsto Tempo Numérico | Índice de Desempenho Físico (IDF) | IDF Numérico | Farol IDF | % Previsto Ponderado | % Previsto Ponderado Numérico | % Concluído Ponderado | % Concluído Ponderado Numérico | Responsável | Código do Contrato | Farol de Início | Áreas de Suporte |
| --- | --- | --- | --- | --- | --- | --- | --- | --- | --- | --- | --- | --- | --- | --- | --- | --- | --- | --- | --- | --- | --- | --- | --- | --- | --- | --- | --- | --- | --- | --- | --- | --- | --- |
| 2911 | 2.4 | **Atividade Interna Renova** |  | 573d | 2017-11-10 A | 2020-02-10 |  | 85% | 86.33d | 2017-11-10 | 2020-02-10 | 573d | 2017-11-10 | 2020-10-07 | 1252d |  |  | Verde | Verde | 65% | 85 | 65 | 100% | 100 | Verde | 45% | 45 | 45% | 45 |  |  |  |  |
| 2912 | 2.4.1 | **Atividade Interna Renova** |  | 421d | 2017-11-10 A | 2019-07-03 |  | 88% | 50.88d | 2017-11-10 | 2019-07-03 | 421d | 2017-11-10 | 2019-04-01 | 1252d |  |  | Verde | Verde | 89% | 88 | 89 | 92% | 92 | Vermelho | 53% | 53 | 49% | 49 |  |  |  |  |
| 2913 | 2.4.1.1 | Atividade Interna Renova |  | 54d | 2017-11-10 A | 2018-01-24 A | 63FS+14ed | 100% |  | 2017-11-10 | 2018-01-24 | 54d | 2017-11-10 | 2018-01-24 |  |  |  | Verde | Verde | 100% | 100 | 100 | 100% | 100 | Verde | 100% | 100 | 100% | 100 | 02 - Execução | PG031 | Verde |  |
| 2914 | 2.4.1.2 | **Atividade Interna Renova** |  | 368d | 2018-01-24 A | 2019-07-03 |  | 86% | 51.98d | 2018-01-24 | 2019-07-03 | 368d | 2018-01-24 | 2018-09-12 | 1252d |  |  | Verde | Verde | 88% | 86 | 88 | 88% | 88 | Vermelho | 41% | 41 | 36% | 36 |  |  |  |  |
| 2915 | 2.4.1.2.1 | Atividade Interna Renova |  | 93d | 2018-01-24 A | 2018-06-01 A | 2913 | 100% |  | 2018-01-24 | 2018-06-01 | 93d | 2018-01-24 | 2018-06-03 |  |  |  | Verde | Verde | 100% | 100 | 100 | 0% |  | Vermelho | 0% |  | 0% |  | 02 - Execução | PG031 | Verde | ܁3 |
| 2916 | 2.4.1.2.2 | Atividade Interna Renova |  | 5d | 2018-06-03 A | 2018-06-08 A | 2915 | 100% |  | 2018-06-03 | 2018-06-08 | 5d | 2018-06-03 | 2018-06-08 |  |  |  | Verde | Verde | 100% | 100 | 100 | 0% |  | Vermelho | 0% |  | 0% |  | 02 - Execução | PG031 | Verde | ܁3 |
| 2917 | 2.4.1.2.3 | Atividade Interna Renova |  | 1d | 2018-06-07 A | 2018-06-07 A | 2916 | 100% |  | 2018-06-07 | 2018-06-07 | 1d | 2018-06-07 | 2018-06-07 |  |  |  | Verde | Verde | 100% | 100 | 100 | 0% |  | Vermelho | 0% |  | 0% |  | 02 - Execução | PG031 | Verde | ܁3 |
| 2918 | 2.4.1.2.4 | Atividade Interna Renova |  | 34d | 2018-06-11 A | 2018-07-30 A | 2916FS+2d | 100% |  | 2018-06-11 | 2018-07-30 | 34d | 2018-06-11 | 2018-07-27 |  |  |  | Verde | Verde | 100% | 100 | 100 | 0% |  | Vermelho | 0% |  | 0% |  | 02 - Execução | PG031 | Verde | ܁3 |
| 2919 | 2.4.1.2.5 | Atividade Interna Renova |  | 5d | 2018-06-18 A | 2018-06-22 A | 2917, 2918SS+5ed | 100% |  | 2018-06-18 | 2018-06-22 | 5d | 2018-06-18 | 2018-06-22 |  |  |  | Verde | Verde | 100% | 100 | 100 | 0% |  | Vermelho | 0% |  | 0% |  | 02 - Execução | PG031 | Verde | ܁3 |
| 2920 | 2.4.1.2.6 | Atividade Interna Renova |  | 5d | 2018-06-22 A | 2018-06-29 A | 2919 | 100% |  | 2018-06-22 | 2018-06-29 | 5d | 2018-06-22 | 2018-06-29 |  |  |  | Verde | Verde | 100% | 100 | 100 | 0% |  | Vermelho | 0% |  | 0% |  | 02 - Execução | PG031 | Verde | ܁3 |
| 2921 | 2.4.1.2.7 | Atividade Interna Renova |  | 5d | 2018-07-30 A | 2018-08-03 A | 2918 | 100% |  | 2018-07-30 | 2018-08-03 | 5d | 2018-07-30 | 2018-08-03 |  |  |  | Verde | Verde | 100% | 100 | 100 | 0% |  | Vermelho | 0% |  | 0% |  |  |  | Verde | ܁3 |
| 2922 | 2.4.1.2.8 | Atividade Interna Renova |  | 11d | 2018-07-02 A | 2018-07-18 A | 2920FS+1d | 100% |  | 2018-07-02 | 2018-07-18 | 11d | 2018-07-02 | 2018-07-17 |  |  |  | Verde | Verde | 100% | 100 | 100 | 0% |  | Vermelho | 0% |  | 0% |  | 02 - Execução | PG031 | Verde | ܁3 |
| 2923 | 2.4.1.2.9 | Atividade Interna Renova |  | 19d | 2018-08-02 A | 2018-08-28 A | 2921, 2922 | 100% |  | 2018-08-02 | 2018-08-28 | 19d | 2018-08-02 | 2018-08-28 |  |  | finish no earlier than 2018-08-28 | Verde | Verde | 100% | 100 | 100 | 0% |  | Vermelho | 0% |  | 0% |  | 02 - Execução | PG031 | Verde | ܁3 |
| 2924 | 2.4.1.2.10 | Atividade Interna Renova |  | 1d | 2018-09-12 A | 2018-09-12 A | 2923FS+14ed | 100% |  | 2018-09-12 | 2018-09-12 | 1d | 2018-09-12 | 2018-09-12 |  |  |  | Verde | Verde | 100% | 100 | 100 | 0% |  | Vermelho | 0% |  | 0% |  |  |  | Verde | ܁3 |
| 2925 | 2.4.1.2.11 | Atividade Interna Renova | milestone | 0d | 2018-10-01 A | 2018-10-01 A | 2924FS+13d | 100% |  | 2018-10-01 | 2018-10-01 | 0d |  |  |  |  |  | Verde | Verde | 100% | 100 | 100 | 0% |  | Vermelho | 100% | 100 | 0% |  |  |  | Verde | ܁3 |
| 2926 | 2.4.1.2.12 | **Atividade Interna Renova** |  | 202d | 2018-09-12 A | 2019-07-03 |  | 68% | 64.75d | 2018-09-12 | 2019-07-03 | 202d | 2018-09-12 | 2019-04-01 | 1252d |  |  | Verde | Verde | 78% | 68 | 78 | 88% | 88 | Vermelho | 41% | 41 | 36% | 36 |  |  |  | ܁3 |
| 2927 | 2.4.1.2.12.1 | Atividade Interna Renova |  | 36d | 2018-09-12 A | 2018-11-02 A | 2924 | 100% |  | 2018-09-12 | 2018-11-02 | 36d | 2018-09-12 | 2018-11-05 |  |  |  | Verde | Verde | 100% | 100 | 100 | 100% | 100 | Verde | 100% | 100 | 100% | 100 |  |  | Verde | ܁3 |
| 2928 | 2.4.1.2.12.2 | Atividade Interna Renova |  | 49d | 2018-11-05 A | 2019-01-29 A | 2927 | 100% |  | 2018-11-05 | 2019-01-29 | 49d | 2018-11-05 | 2019-01-29 |  |  |  | Verde | Verde | 100% | 100 | 100 | 100% | 100 | Verde | 100% | 100 | 100% | 100 |  |  | Verde | ܁3 |
| 2929 | 2.4.1.2.12.3 | Atividade Interna Renova |  | 4d | 2019-01-29 A | 2019-02-04 A | 2928 | 100% |  | 2019-01-29 | 2019-02-04 | 4d | 2019-01-29 | 2019-02-03 |  |  |  | Verde | Verde | 100% | 100 | 100 | 100% | 100 | Verde | 100% | 100 | 100% | 100 |  |  | Verde | ܁3 |
| 2930 | 2.4.1.2.12.4 | Atividade Interna Renova |  | 34d | 2019-03-28 A | 2019-05-17 | 2929FS+34d | 20% | 27.2d | 2019-03-28 | 2019-05-17 | 34d |  |  | 1252d | 0d |  | Verde | Verde | 64% | 20 | 64 | 31% | 31 | Vermelho | 64% | 64 | 20% | 20 |  |  | Verde | ܁3 |
| 2931 | 2.4.1.2.12.5 | Atividade Interna Renova |  | 5d | 2019-05-20 | 2019-05-24 | 2930 |  |  | 2019-05-20 | 2019-05-24 | 5d | 2019-02-04 | 2019-02-12 | 1252d | 0d |  | Verde | Verde | 0% |  |  | 0% |  | Verde | 0% |  | 0% |  |  |  | Verde | ܁3 |
| 2932 | 2.4.1.2.12.6 | Atividade Interna Renova |  | 1d | 2019-05-27 | 2019-05-27 | 2931 |  |  | 2019-05-27 | 2019-05-27 | 1d |  |  | 1252d | 0d |  | Verde | Verde | 0% |  |  | 0% |  | Verde | 0% |  | 0% |  |  |  | Verde | ܁3 |
| 2933 | 2.4.1.2.12.7 | Atividade Interna Renova |  | 1d | 2019-06-13 | 2019-06-13 | 2932FS+12d |  |  | 2019-06-13 | 2019-06-13 | 1d |  |  | 1252d | 0d |  | Verde | Verde | 0% |  |  | 0% |  | Verde | 0% |  | 0% |  |  |  | Verde | ܁3 |
| 2934 | 2.4.1.2.12.8 | Atividade Interna Renova |  | 1d | 2019-06-18 | 2019-06-18 | 2933FS+2d |  |  | 2019-06-18 | 2019-06-18 | 1d | 2019-02-25 | 2019-03-01 | 1252d | 0d | start no earlier than 2019-05-23 | Verde | Verde | 0% |  |  | 0% |  | Verde | 0% |  | 0% |  |  |  | Verde | ܁3 |
| 2935 | 2.4.1.2.12.9 | Atividade Interna Renova |  | 10d | 2019-06-19 | 2019-07-03 | 2934 |  |  | 2019-06-19 | 2019-07-03 | 10d | 2019-03-11 | 2019-04-01 | 1252d | 0d |  | Verde | Verde | 0% |  |  | 0% |  | Verde | 0% |  | 0% |  | 02 - Execução | PG031 | Verde | ܁3 |
| 2936 | 2.4.1.2.12.10 | Atividade Interna Renova | milestone | 0d | 2019-07-03 | 2019-07-03 | 2935 |  |  | 2019-07-03 | 2019-07-03 | 0d | 2019-04-01 | 2019-04-01 | 1252d | 0d |  | Verde | Verde | 0% |  |  | 0% |  | Verde | 0% |  | 0% |  | 02 - Execução | PG031 | Verde | ܁3 |

Notes:
- 2923: A reunião do conselho para aprovação de APRO que estava agendada para o dia 17/07,foi adiada para o dia 01/08. / Com este adiamento as atividades subsequentes à esta aprovação ficaram todas atrasadas.
- 2930: Em 25/04/2019: houve atraso em suprimentos e foi considerado mais uma semana para a entrega da análise da APRO. Considerado 20% de conclusão por estar na primeira parte de analises.

| ID | WBS | Task | Type | Duration | Start | Finish | Predecessors | Complete | Baseline start | Baseline finish | Baseline duration | Baseline 1 start | Baseline 1 finish | Total slack | Free slack | Constraint | Farol de Atraso | Farol Marcos | % Previsto Tempo | Índice de Desempenho Físico (IDF) | Farol IDF | % Previsto Ponderado | % Concluído Ponderado | Farol de Início | Responsável | Código do Contrato | % Concluída Numérico | % Previsto Tempo Numérico | IDF Numérico | % Previsto Ponderado Numérico | % Concluído Ponderado Numérico | Áreas de Suporte |
| --- | --- | --- | --- | --- | --- | --- | --- | --- | --- | --- | --- | --- | --- | --- | --- | --- | --- | --- | --- | --- | --- | --- | --- | --- | --- | --- | --- | --- | --- | --- | --- | --- |
| 2937 | 2.4.2 | **Atividade Interna Renova** |  | 144d | 2019-07-16 | 2020-02-10 |  |  | 2019-07-16 | 2020-02-10 | 144d | 2019-04-16 | 2020-10-07 | 1252d |  |  | Verde | Verde | 0% | 0% | Verde | 0% | 0% |  |  |  |  |  |  |  |  |  |
| 2938 | 2.4.2.1 | Atividade Interna Renova |  | 1d | 2019-07-16 | 2019-07-16 | 2936FS+8d |  | 2019-07-16 | 2019-07-16 | 1d |  |  | 1252d | 0d |  | Verde | Verde | 0% | 0% | Verde | 0% | 0% | Verde |  |  |  |  |  |  |  |  |
| 2939 | 2.4.2.2 | Atividade Interna Renova |  | 35d | 2019-07-17 | 2019-09-04 | 2938 |  | 2019-07-17 | 2019-09-04 | 35d | 2019-04-16 | 2019-06-05 | 1252d | 0d |  | Verde | Verde | 0% | 0% | Verde | 0% | 0% | Verde | 02 - Execução | PG 031 |  |  |  |  |  |  |
| 2940 | 2.4.2.3 | Atividade Interna Renova |  | 21d | 2019-07-29 | 2019-08-27 | 2939SS+10ed |  | 2019-07-29 | 2019-08-27 | 21d | 2019-04-26 | 2019-05-26 | 1365d | 6d |  | Verde | Verde | 0% | 0% | Verde | 0% | 0% | Verde |  |  |  |  |  |  |  |  |
| 2941 | 2.4.2.4 | Atividade Interna Renova |  | 11d | 2019-08-16 | 2019-08-30 | 2939SS+30ed |  | 2019-08-16 | 2019-08-30 | 11d | 2019-05-17 | 2019-06-03 | 1362d | 3d |  | Verde | Verde | 0% | 0% | Verde | 0% | 0% | Verde | 02 - Execução | PG 031 |  |  |  |  |  |  |
| 2942 | 2.4.2.5 | Atividade Interna Renova |  | 1d | 2019-09-05 | 2019-09-05 | 2941, 2940, 2939 |  | 2019-09-05 | 2019-09-05 | 1d |  |  | 1359d | 107d |  | Verde | Verde | 0% | 0% | Verde | 0% | 0% | Verde |  |  |  |  |  |  |  |  |
| 2943 | 2.4.2.6 | Atividade Interna Renova | milestone | 0ed | 2020-02-10 | 2020-02-10 | 2939FS+108d, 2940, 2941, 2942 |  | 2020-02-10 | 2020-02-10 | 0ed | 2020-10-07 | 2020-10-07 | 5524.88d | 0d |  | Verde | Verde | 0% | 0% | Verde | 0% | 0% | Verde | 02 - Execução | PG 031 |  |  |  |  |  |  |
| 2944 | 2.4.3 | **Atividade Interna Renova** |  | 108d | 2018-10-25 A | 2019-03-29 A |  | 100% | 2018-10-25 | 2019-03-29 | 108d | 2018-10-25 | 2019-04-21 |  |  |  | Verde | Verde | 100% | 100% | Verde | 100% | 100% |  |  |  | 100 | 100 | 100 | 100 | 100 |  |
| 2945 | 2.4.3.1 | Atividade Interna Renova |  | 1d | 2018-10-25 A | 2018-10-25 A | 2925 | 100% | 2018-10-25 | 2018-10-25 | 1d | 2018-10-25 | 2018-10-25 |  |  | start no earlier than 2018-10-25 | Verde | Verde | 100% | 100% | Verde | 100% | 100% | Verde |  |  | 100 | 100 | 100 | 100 | 100 |  |
| 2946 | 2.4.3.2 | Atividade Interna Renova |  | 33d | 2018-10-29 A | 2018-12-18 A | 2945FS+4ed | 100% | 2018-10-29 | 2018-12-18 | 33d | 2018-10-29 | 2019-03-29 |  |  |  | Verde | Verde | 100% | 100% | Verde | 100% | 100% | Verde |  |  | 100 | 100 | 100 | 100 | 100 |  |
| 2947 | 2.4.3.3 | Atividade Interna Renova |  | 62d | 2018-12-12 A | 2019-03-27 A | 2945FS+48ed | 100% | 2018-12-12 | 2019-03-27 | 62d | 2018-12-12 | 2019-04-21 |  |  |  | Verde | Verde | 100% | 100% | Verde | 100% | 100% | Verde |  |  | 100 | 100 | 100 | 100 | 100 |  |
| 2948 | 2.4.3.4 | Atividade Interna Renova |  | 55d | 2019-01-08 A | 2019-03-29 A | 2945FS+75ed | 100% | 2019-01-08 | 2019-03-29 | 55d | 2018-12-12 | 2019-03-12 |  |  |  | Verde | Verde | 100% | 100% | Verde | 100% | 100% | Verde |  |  | 100 | 100 | 100 | 100 | 100 |  |
| 2949 | 2.4.3.5 | Atividade Interna Renova | milestone | 0d | 2019-03-29 A | 2019-03-29 A | 2946, 2947, 2948 | 100% | 2019-03-29 | 2019-03-29 | 0d |  |  |  |  |  | Verde | Verde | 100% | 0% | Vermelho | 100% | 0% | Verde |  |  | 100 | 100 |  | 100 |  |  |
| 2950 | 2.4.4 | **Atividade Interna Renova** |  | 173d | 2018-05-13 A | 2019-01-10 A |  | 100% | 2018-05-13 | 2019-01-10 | 173d | 2018-05-13 | 2019-01-10 |  |  |  | Verde | Verde | 100% | 100% | Verde | 100% | 100% |  |  |  | 100 | 100 | 100 | 100 | 100 | ܁3 |
| 2951 | 2.4.4.1 | Atividade Interna Renova |  | 33d | 2018-05-13 A | 2018-06-27 A | 2915FS-21ed | 100% | 2018-05-13 | 2018-06-27 | 33d | 2018-05-13 | 2018-06-27 |  |  |  | Verde | Verde | 100% | 100% | Verde | 100% | 100% | Verde | 02 - Execução | PG 031 | 100 | 100 | 100 | 100 | 100 | ܁3 |
| 2952 | 2.4.4.2 | Atividade Interna Renova |  | 1d | 2018-06-28 A | 2018-06-28 A | 2951FS+1d | 100% | 2018-06-28 | 2018-06-28 | 1d | 2018-06-28 | 2018-06-28 |  |  |  | Verde | Verde | 100% | 100% | Verde | 100% | 100% | Verde | 02 - Execução | PG 031 | 100 | 100 | 100 | 100 | 100 | ܁3 |
| 2953 | 2.4.4.3 | Atividade Interna Renova |  | 17d | 2018-06-28 A | 2018-07-24 A | 2952 | 100% | 2018-06-28 | 2018-07-24 | 17d | 2018-06-28 | 2018-07-23 |  |  |  | Verde | Verde | 100% | 100% | Verde | 100% | 100% | Verde | 02 - Execução | PG 031 | 100 | 100 | 100 | 100 | 100 | ܁3 |
| 2954 | 2.4.4.4 | Atividade Interna Renova |  | 70d | 2018-07-23 A | 2018-10-31 A | 2953 | 100% | 2018-07-23 | 2018-10-31 | 70d | 2018-07-23 | 2018-10-31 |  |  |  | Verde | Verde | 100% | 100% | Verde | 100% | 100% | Verde | 02 - Execução | PG 031 | 100 | 100 | 100 | 100 | 100 | ܁3 |
| 2955 | 2.4.4.5 | Atividade Interna Renova |  | 10d | 2018-11-26 A | 2018-12-10 A | 2954FS+26ed | 100% | 2018-11-26 | 2018-12-10 | 10d | 2018-11-26 | 2018-12-10 |  |  |  | Verde | Verde | 100% | 100% | Verde | 100% | 100% | Verde | 02 - Execução | PG 031 | 100 | 100 | 100 | 100 | 100 | ܁3 |
| 2956 | 2.4.4.6 | Atividade Interna Renova |  | 9d | 2018-12-11 A | 2018-12-21 A | 2955 | 100% | 2018-12-11 | 2018-12-21 | 9d | 2018-12-11 | 2018-12-21 |  |  |  | Verde | Verde | 100% | 100% | Verde | 100% | 100% | Verde | 02 - Execução | PG 031 | 100 | 100 | 100 | 100 | 100 | ܁3 |
| 2957 | 2.4.4.7 | Atividade Interna Renova |  | 2d | 2018-10-26 A | 2018-11-01 A | 2954 | 100% | 2018-10-26 | 2018-11-01 | 2d | 2018-10-26 | 2018-11-01 |  |  |  | Verde | Verde | 100% | 100% | Verde | 100% | 100% | Verde | 02 - Execução | PG 031 | 100 | 100 | 100 | 100 | 100 | ܁3 |
| 2958 | 2.4.4.8 | Atividade Interna Renova |  | 6d | 2018-11-02 A | 2018-11-12 A | 2957 | 100% | 2018-11-02 | 2018-11-12 | 6d | 2018-11-02 | 2018-11-12 |  |  |  | Verde | Verde | 100% | 100% | Verde | 100% | 100% | Verde | 02 - Execução | PG 031 | 100 | 100 | 100 | 100 | 100 | ܁3 |
| 2959 | 2.4.4.9 | Atividade Interna Renova |  | 6d | 2018-11-13 A | 2018-11-22 A | 2958 | 100% | 2018-11-13 | 2018-11-22 | 6d | 2018-11-13 | 2018-11-22 |  |  |  | Verde | Verde | 100% | 100% | Verde | 100% | 100% | Verde | 02 - Execução | PG 031 | 100 | 100 | 100 | 100 | 100 | ܁3 |
| 2960 | 2.4.4.10 | Atividade Interna Renova |  | 2d | 2018-11-22 A | 2018-11-26 A | 2959 | 100% | 2018-11-22 | 2018-11-26 | 2d | 2018-11-22 | 2018-11-26 |  |  |  | Verde | Verde | 100% | 100% | Verde | 100% | 100% | Verde | 02 - Execução | PG 031 | 100 | 100 | 100 | 100 | 100 | ܁3 |
| 2961 | 2.4.4.11 | Atividade Interna Renova |  | 4d | 2018-11-27 A | 2018-11-30 A | 2960 | 100% | 2018-11-27 | 2018-11-30 | 4d | 2018-11-27 | 2018-11-30 |  |  |  | Verde | Verde | 100% | 100% | Verde | 100% | 100% | Verde |  |  | 100 | 100 | 100 | 100 | 100 | ܁3 |
| 2962 | 2.4.4.12 | Atividade Interna Renova |  | 4d | 2018-12-21 A | 2019-01-10 A | 2956, 2961 | 100% | 2018-12-21 | 2019-01-10 | 4d | 2018-12-21 | 2019-01-10 |  |  |  | Verde | Verde | 100% | 100% | Verde | 100% | 100% | Verde | 02 - Execução | PG 031 | 100 | 100 | 100 | 100 | 100 | ܁3 |
| 2963 | 2.4.4.13 | Atividade Interna Renova | milestone | 0d | 2019-01-10 A | 2019-01-10 A | 2962 | 100% | 2019-01-10 | 2019-01-10 | 0d | 2019-01-10 | 2019-01-10 |  |  |  | Verde | Verde | 100% | 0% | Vermelho | 100% | 0% | Verde | 02 - Execução | PG 031 | 100 | 100 |  | 100 |  | ܁3 |
| 2964 | 2.4.5 | Atividade Interna Renova | milestone | 0d | 2020-02-10 | 2020-02-10 | 2936, 2949, 2963, 2943 |  | 2020-02-10 | 2020-02-10 | 0d |  |  | 1252d |  |  | Verde | Verde | 0% | 0% | Verde | 0% | 0% | Verde |  |  |  |  |  |  |  |  |
| 2965 | 2.5 | Execução concluída | milestone | 0d | 2025-02-24 | 2025-02-24 | 83, 208, 2910, 2964 |  | 2025-02-24 | 2025-02-24 | 0d |  |  | 0d |  |  | Verde | Verde | 0% | 0% | Verde | 0% | 0% | Verde |  |  |  |  |  |  |  |  |

Notes:
- 2937: Esta implementação deverá ser detalhada após a contratação concorrencial da empresa para dar a capacitação.
- 2944: Esta capacitação teve como data de início o Workshop de Licenciamento e Outorga em Colatina - ES.

| ID | WBS | Task | Type | Duration | Start | Finish | Predecessors | Baseline start | Baseline finish | Baseline duration | Baseline 1 start | Baseline 1 finish | Total slack | Farol de Atraso | Farol Marcos | % Previsto Tempo | Índice de Desempenho Físico (IDF) | Farol IDF | % Previsto Ponderado | % Concluído Ponderado | Farol de Início |
| --- | --- | --- | --- | --- | --- | --- | --- | --- | --- | --- | --- | --- | --- | --- | --- | --- | --- | --- | --- | --- | --- |
| 2966 | 3 | **Encerramento** |  | 240d | 2025-02-25 | 2026-02-11 |  | 2025-02-25 | 2026-02-11 | 240d | 2019-12-30 | 2023-01-20 | 0d | Verde | Verde | 0% | 0% | Verde | 0% | 0% |  |
| 2967 | 3.1 | Atividade Interna Renova |  | 240d | 2025-02-25 | 2026-02-11 | 13, 69, 14, 15, 16, 17, 18, 19, 20, 21, 3, 10, 22, 11 | 2025-02-25 | 2026-02-11 | 240d |  |  | 0d | Verde | Verde | 0% | 0% | Verde | 0% | 0% | Verde |
| 2968 | 3.2 | Atividade Interna Renova | milestone | 0d | 2026-02-11 | 2026-02-11 | 2967 | 2026-02-11 | 2026-02-11 | 0d |  |  | 0d | Verde | Verde | 0% | 0% | Verde | 0% | 0% | Verde |
| 2969 | 4 | Programa finalizado | milestone | 0d | 2026-02-11 | 2026-02-11 | 2968 | 2026-02-11 | 2026-02-11 | 0d |  |  | 0d | Verde | Verde | 0% | 0% | Verde | 0% | 0% | Verde |

Notes:
- 2968: Em 19/03/19: por solicitação da A&M foi modificada a duração e as predecessoras da atividade Encerramento Interno de 6 meses para 8 meses e de 6TT; 5TT; 4TT; 61 para 6TI; 4TI; 5TI para atendimento à demanda do MP e igualar as datas de término tendência às da definição do programa.
